# 3GPP_Release-2000

Schedule from MS Project, 1999-01-01 to 2012-07-30, A marks actual dates.

## Calendars

- Standard: Mon-Fri 08:00-12:00, 13:00-17:00; Sat-Sun off. Exceptions (off unless hours are given): 2000-01-15 08:00-12:00, 13:00-17:00, 2009-05-30 08:00-12:00, 13:00-17:00.

## Resources

| Resource |
| --- |
| NP |
| N1 |
| N2 |
| N3 |
| N4 |
| N5 |
| TP |
| T1 |
| T2 |
| T3 |
| RP |
| R1 |
| R2 |
| R3 |
| R4 |
| SP |
| S1 |
| S2 |
| S3 |
| S4 |
| S5 |
| PCG |
| GP |
| No |
| CN4 |
| ? |
| WG G2 |
| G2 |
| G1 |
| G4 |
| G3 |
| All |
| Generic |
| MLST |
| G5 |
| S3, G2 |
| WG T2 |
| GP,G1 |
| G4,G5 |
| OMA |
| GP-G2 |
| Yes |
| GP, |
| N4, |
| GP, N1 |
| CT5 |
| C5 |
| C1 |
| C4 |
| C3 |
| C6 |
| G1, |
| 4 |
| ct |
| c,s,r |
| CT,RAN,SA |
| G2, |
| G1, G3 |
| CT6 |
| CT1 |
| CT1, CT3, CT4 |
| C1, C3, C4 |
| CP |
| R5 |
| C |
| Rel-8 |
| GP, G2 |
| R1,R4 |
| S5,C1 |
| CT,RAN,SA,GERAN |
| S3,C1,C4 |
| 5 |
| S1,C1,C3,C4,S5 |
| S1,C1,C3,C5 |
| S1,C1,C3,C4 |
| S1,S5 |
| S2,S3 |
| RAN,SA |
| RP,S5 |
| S2,CT |
| S1,CT |
| S1,CT,GERAN |
| S1,C5 |
| S3,CT |
| S4,CT |
| C1,SA |
| S1,S2 |
| S1,S4 |
| S2,S2,S3,CT |
| S2,S3,CT |
| S1,CT,GX |
| S1,S4,CT |
| S2,S2,S3,S5,CT |
| S1,S2,CT |
| S1,S2,S3,CT |
| S1,S2,S3,S5CT |
| S1,S2,S3,S5,CT |
| S2,S5,CT |
| S4,S3 |
| S1,C1 |
| CP,C1 |
| C1,C3 |
| C1,C3,C4 |
| S1,S5,CT |
| C4,C3 |
| CP,RAN,SA,GERAN |
| S1,S2,S3,S5,CP |
| S2,S3,CP |
| S2,CP |
| S1,CP,GX |
| S1,CP |
| S1,S4,CP |
| S1,S2,CP |
| S1,S2,S3,CP |
| S2,S5,CP |
| S3,CP |
| S1,S5,CP |
| RAN,SA,GERAN |
| S1,S2,S3,S5,C1,C3,C4,C6 |
| S2,S3,C1,C3,C4 |
| S2,C4 |
| S2,C1,C3,C4 |
| S2,C1,C4 |
| S2,S3,C1,C4 |
| S1,C1,C4,G2 |
| C1,C4 |
| S1,C1,C3 |
| S1,S4,C1,C3,C4 |
| S1,S2,S3,C1,C3,C4 |
| S2,S5,C3 |
| S1,S2,C1,C4 |
| S2,C1 |
| S2,C1,C3 |
| S3,C1,C3,C4 |
| S1,S5,C1,C3,C4 |
| S2,C3,C4 |
| C3,C1 |
| R2,R4 |
| R2,R5 |
| RP,R5 |
| RP,S5,R5 |
| R1,R5 |
| S1,C1,R5 |
| S1,C1,S4,R5 |
| GERAN |
| G3new |
| G1, G3new |
| C4,C1,C3 |
| R1.R4 |
| R1, R4 |
| R2,R3 |
| C3,C4 |
| S4,C3 |
| S4,C3,C1,C4 |
| S1,S2,C1 |
| S1,S2<C1,C3,C4 |
| S1,S2,C1,C3,C4 |
| S5,C1,C3,C4 |
| GP,C4 |
| C4,C1 |
| S2,S1 |
| RP,SP,GP |
| RP,SP,CP,GP |
| CP,GP,RP,SP |
| GP,C4,S4 |
| S1,C1,C4 |
| S1,S2,C3,C1 |
| R2,R4,R3 |
| CP,GP, RP,SP |
| S2,S1,C1,S5 |
| S2,S1,C1 |
| S1,C1,S4 |
| S1,S2,GP,C4,R2 |
| S1,GP,R2 |
| S1,C6 |
| S1,S2,C1,S4 |
| S2,S3,S5,C1,C3,C4 |
| S2,S5,C1 |
| S2,S3,S5 |
| CP,GP, RP,SP,TP |
| S2,C4,C1 |
| S1,C1,C4,S3 |
| S2,S5 |
| S3,C1 |
| S3,C4 |
| S1,C4 |
| S2,S5,C3,C1 |
| S2,S1,S5,C1,C4 |
| S1,R1,C3 |
| S1,C1,R2 |
| S2,S1,C1,C4 |
| S1,C1,C6 |
| GP,S4,C4,C1,C3 |
| C3,C1,C4 |
| S1,C4,C1 |
| S1,S3 |
| S1,S2,S5,C3,C4 |
| R4,G1 |
| G1,R4 |
| RP,GP |
| R4,GP |
| R3,R2 |
| C6,RP,SP |
| R5,C6 |
| CP,RP,SP |
| RP,SP,CP |
| R3,S5 |
| S1,S2,RP |
| S1,S2,S5,RP |
| S2,S1,RP |
| Rel-9 |
| S3,C6 |
| S1,S2,S3,S5,RP |
| S2,S1,S3 |
| S1,S2,S3 |
| S1,S2,S3,S5 |
| C6,R5 |
| S1,S2,RP,GP |
| S1,S2,S4,S5,RP,GP |
| GP,G2 |
| GP,GP, N1 |
| GP,S2,G1,G2 |
| GP,R2,R3,S2,G1,G2 |
| GP,S2,S5,R2,R3,G2,G1 |
| GP,R3 |
| N4,S2 |
| GP,RP |
| GP,S2,RP |
| G5,G4 |
| G4,R3 |
| S2,R2,R4 |
| S1,S2,R2,R4 |
| GP,S5 |
| S1,S2,S5 |
| R4,R5 |
| R4,R2,R3,R5 |
| S2,S5,N4,RP |
| S1,S2,S3,S5,NP |
| S2,S4,S5 |
| T2,S1,S4,S5 |
| SP,RP |
| S2,RP |
| S1,S2,CP,G2 |
| CP,SP |
| S1,G2 |
| SP,CP |
| S1,S2,S5,C3 |
| S1,C1,S3 |
| G1,G3new |
| C4, C3, C1C4 |
| C4,C3,C1 |
| S1,S2,S3,S5,R2,R3,R4 |
| S1,S2,S3,R2 |
| S2,S3,S5,C4,R2 |
| S1,S5,C1 |
| S1,S2,S3,C1,C3,C4,R2 |
| Ggp |
| S3,S2,C1,C4,G2 G3new |
| R1,R2,R3,R4 |
| R4,R1,R2,R3 |
| R4,R2,R3 |
| S1,C1,C4,R2 |
| R4,R2 |
| S2,C4,R2,R4 |
| S2,C4,R2 |
| S2,S3,S5,C3,C4,R2 |
| S1,S2,S4,T2 |
| S1,S2,S4 |
| S1,S2,S4,R5 |
| S3,S2,C1,C4,G2,G3new |
| GP,C1 |
| S1,S5,C4 |
| S1,S2,S3,S5,R2,R3,R4,GP |
| GP,C4,C3,C1 |
| SMG9 |
| SMG1 |
| SMG2 |
| N3,R5 |
| N1, N2, N4, G1, G2, R3, S1, SMG2 |
| S1,SMG1 |
| SMG1,N4 |
| N1,C1,N4,S1,T2,G2,SMG1,SMG2,SMG3,SMG7,SMG9 |
| SMG1,N2 |
| S1,S2,N2,N4 |
| N4,N2 |
| G1,G2 |
| G1,G2,C1 |
| G1,G2,N1 |
| SMG2, SMG1, SMG3, SMG4, SMG7, SMG9, SMG10, G1, G2, G3, N1, N3, T2 |
| SMG2,G1 |
| S1,G1,G2 |
| SMG1,N1,G1,G2 |
| G2,G1 |
| G1,G2,G3,S1,S2,SMG1,SMG2,SMG7,N1,N2,N3,N4,T2 |
| 23.003, 23.008, 29.060 |
| S1, S2, SMG1, SMG2, SMG12, G2, N1, N2, N4 |
| S1,S2,SMG1,SMG2,SMG12,G2,N1,N2,N4 |
| S1,SMG2,N1,N2,N4 |
| SMG1,T2 |
| S1,N1,N2,N4 |
| S1,S2,N5 |
| SMG2,SMG7,G2,T2 |
| S3,N1,N2,N3 |
| S3,N1,N2,N4 |
| SMG9,T3 |
| SMG2,SMG3,SMG7,G2,N2 |
| SMG2,N1,G1,G2 |
| S1,N2 |
| N1,N3 |
| S2,N1 |
| N1,N2,N4 |
| N2,N1,N4 |
| N2,N4 |
| S1,T3 |
| T2,N3 |
| S3,N2 |
| T2,S1 |
| S1,N4 |
| SMG1,SMG2,SMG7 |
| N1,S1,T1 |
| SMG1,SMG3 |
| N4,S2,N1 |
| S1,S2,SMG1,SMG2,SMG7,G1,G2,G3,N1,N2,N3,N4,T2 |
| SMG1,N3 |
| S1,N3 |
| CP,SP,SMG |
| CP,SP,TP,GP,SMG |
| NP,SP,TP,GP,SMG |
| NP,GP, RP,SP,TP |
| SMG2,SMG1,SMG3,SMG4,SMG7,SMG9,SMG10,G1,G2,G3,N1,N3,T2 |
| S1,N2,N4 |
| S1,S2,S3,C1,C3,C4,R2,R3 |
| R2,R3,R1,R4 |
| R2,R3,R4 |
| R2,R1,R3,R4 |
| S2,C4,R2,R3,R4 |
| S2,C4,R2,R1,R3,R4 |
| S2,S3,S5,C3,C4,R2,R3,R4 |
| R1,R2,R4 |
| R3,R1,R4 |
| S2, |
| S2,G2, |
| S1,S2,G2, |
| S1,S2,G2,R2,R3, |
| S1,S2,C4,G2,R2,R3 |
| S1,S2,N4,G2,R2,R3 |
| S1,S2,SMG1,SMG2,SMG12,G2,N1,N2,N4,R2,R3 |
| S1,SMG1,T2 |
| S1,SMG1,S2 |
| S1,N4,N2 |
| T2,N1,N3 |
| S3,N2,N4 |
| SMG1,SMG2,SMG3,SMG7,SMG9,N1,C1,N4,S1,T2,G2 |
| SMG1,N2,N4 |
| S2,T2,N1,N2,N4 |
| S1,T2 |
| S1,S2,C4 |
| S1,S2,N4,RP |
| S2,N4 |
| S1,S2,N3,N4,RP |
| S1,S2,SMG1,SMG2,SMG12,T2,G2,N1,N2,N4,R2,R3 |
| S1,T2,N1,N3 |
| S1,S2,SMG1,SMG2,SMG12,T2,G2,N1,N2,N3,N4,R2,R3 |
| S1,S2,S3,SMG1,SMG2,SMG12,G2,N1,N2,N4,R2,R3 |
| S1,S2,SMG,G1,G2,G3,N1,N2,N3,N4,T2 |
| S1,S2,SMG,T2,G2,N1,N2,N3,N4,R2,R3 |
| S1,S3,SMG,G1,G2,G3,N1,N2,N3,N4,T2 |
| S1,S3,T2,N2,N4 |
| S1,S2,SMG,T2,G1,G2,G3,N1,N2,N3,N4 |
| G2,S2 |
| T1,R5 |
| R5,T1 |
| S1,S2,S4,T1,R5 |
| S1,S2,S4,S5,T1,RP,GP |
| S1,S2,S3,S5,R2,R3,R4,GP,C1 |
| S1,S2,S3,SMG1,SMG2,SMG12,N1,N2,N4,R2,R3 |
| S1,S2,SMG,T2,N1,N2,N3,N4,R2,R3 |
| NP,SP,TP,SMG |
| S1,S2,SMG,T2,N1,N2,N3,N4 |
| SMG,N1 |
| SMG |
| S1,S2,SMG1,SMG2,SMG7,N1,N2,N3,N4,T2 |
| SMG2,SMG1,SMG3,SMG4,SMG7,SMG9,SMG10,N1,N3,T2 |
| S1,SMG |
| SMG2,SMG7,T2 |
| SMG2,S2 |
| N1,N2,N4,R3,S1,SMG |
| SMG2,SMG3,SMG7,N2 |
| SMG1,SMG2,SMG3,SMG7,SMG9,N1,C1,N4,S1,T2 |
| S1,S2,SMG,N3,N4,RP |
| S1,S2,S4,SMG,N3,N4,RP |
| S2,C1,C4,R2,R1,R3,R4 |
| R2,S2,S4 |
| G3new,R5 |
| GP,R4 |
| S2,S4,R2 |
| SP,GP |
| RP,SP |
| S2,S1,S3,S5 |
| S3,S1 |
| N4,N1,N2,S2 |
| S2,G1,G2,R2,R3 |
| S2,G1,G2 |
| G1,G2,R2,R3 |
| N4,T3 |
| S3,S2,N1,N4,T3,OMA |
| T2,S1,S4,S5,OMA |
| S2,N3 |
| S4,S1 |
| N4,N3,S1 |
| R5,G3new |
| R4,R2,R1 |
| S2,R2 |
| C3, C4,C1 |
| S3,C1,C4,C3 |
| C1,C4,C3 |
| S2,C1,C4,C3 |
| R3,R5 |
| S1,S2,C3 |
| R1,R2 |
| S3,C1,C4,G2,G3new |
| R1,R3 |
| GP,N1 |
| R1,R2,R3 |
| R3,R2,R4 |
| R4,R3 |
| S1,S2,R2,R3 |
| S1,S2,S3,C1,C3,C4,R2,R3,R5 |
| S2,S1,S5 |
| C4, C1 |
| C3, C1, C4 |
| S2,S1,S3,S5,C4,C1 |
| S2,C3,C1,C4 |
| S2,S1,S5,C3 |
| GP,S2,C1 |
| GP,S2,C1,G2 |
| G2,S2,C1 |
| v |
| G3new,G1,G2 |
| G1,G2,C1,G3new |
| S2,S1,S5,C1,C3 |
| C1,C3,C4,R5 |
| R2,R1 |
| S1<S2,N1,R2,R5 |
| S1,S2,N1,R2,R5 |
| S2,R5 |
| S1,S2,S5,R5 |
| S2,C1,C4,R2,R1,R3,R4,R5 |
| S1,S2,S3,S5,NP,R5 |
| S1,S2,S4,S5,RP,R5,GP |
| S1,S2,S3,S5,C1,C6,R2,R3,R4 |
| S1,S2,S3,S5,C1,C6,R2,R3,R4,GP |
| S4,R2 |
| S1,S2,C1,C4,G2 |
| S4,C3,C4 |
| S5,C1,C4 |
| S2,C4,C3,C1 |
| C4, C3, C1 |
| S2,S4,R2,C4,C3,C1 |
| GP1,GP2 |
| GP,GP1,GP2 |
| GP,G1,G2 |
| G2,R3 |
| S1,S2,S3,C1,C3,C4,G2 |
| GP,G1,C1 |
| S1,S2,C4,C3,C1 |
| - |
| GP,G1,G2,G3new |
| S1,S2,S3,C1,C3,C4,G2,R2,R3 |
| S1,S2,C1,C3,C4,G2,R2,R3 |

## Schedule

| ID | WBS | Task | Type | Duration | Start | Finish | Complete | Remaining | Baseline start | Baseline finish | Baseline duration | Total slack | Constraint | Resources | Work | Actual work | Text6 | Text8 | Text1 | Text2 | Text4 | Text5 | Text7 | Text3 |
| --- | --- | --- | --- | --- | --- | --- | --- | --- | --- | --- | --- | --- | --- | --- | --- | --- | --- | --- | --- | --- | --- | --- | --- | --- |
| 1 | 1 | Version 2010 Oct 01 | milestone | 0d? | 2000-01-03 A | 2000-01-03 A | 100% |  | 2000-01-03 | 2000-01-03 | 0d? |  |  | - |  |  |  |  |  |  |  |  |  |  |
| 2 | 2 | Rel-9 Two GERAN exceptions to 11/2010 (VAMOS, AGNSSPTP) | milestone | 0d? | 2000-01-03 A | 2000-01-03 A | 100% |  | 2000-01-03 | 2000-01-03 | 0d? |  | finish no earlier than 1998-12-07 | - |  |  |  |  |  |  |  |  |  |  |
| 3 | 3 | Rel-10 Stage 2 freeze 03/2011 | milestone | 0d | 2000-01-03 A | 2000-01-03 A | 100% |  | 2000-01-03 | 2000-01-03 | 0d |  | finish no earlier than 1998-12-07 | - |  |  |  |  |  |  |  |  |  |  |
| 4 | 4 | Rel-11 Stage 1 freeze 09/2011 | milestone | 0d | 2000-01-03 A | 2000-01-03 A | 100% |  | 2000-01-03 | 2000-01-03 | 0d |  | finish no earlier than 1998-12-07 | - |  |  |  |  |  |  |  |  |  |  |
| 5 | 5 | Gantt: dark blue=done; light blue=to be done; grey: previous values; black=summary | milestone | 0d? | 2000-01-03 A | 2000-01-03 A | 100% |  | 2000-01-03 | 2000-01-03 | 0d? |  | finish no earlier than 1998-12-07 | - |  |  |  |  |  |  |  |  |  |  |
| 6 | 6 | Release 11 Features |  | 457d? | 2010-03-25 | 2011-12-23 |  |  | 2010-03-25 | 2011-12-23 | 457d? | 155.8d | finish no earlier than 2011-12-23 | SP | 3656h |  | Rel-11 | All |  |  |  |  |  |  |
| 7 | 7 | **Support BroadBand forum Accesses Interworking** |  | 402d? | 2009-12-10 A | 2011-06-24 | 26% | 299.31d? | 2009-12-10 | 2011-06-24 | 402d? | 285.8d |  | S2,S1 | 13736h | 3508.9h | Rel-11 | Alain | BBAI | PCG-24 | Ericsson | peter.bleckert@ericsson.com | SP-46 |  |
| 8 | 7.1 | TR on Stage 2 for BroadBand forum Accesses Interworking |  | 326d? | 2010-03-26 A | 2011-06-24 | 12% | 286.88d? | 2010-03-26 | 2011-06-24 | 326d? | 285.8d | finish no earlier than 2011-06-24 | S2 | 2608h | 312.97h | Rel-11 | Maurice | BBAI | PCG-24 | Ericsson, Huawei | stefan.rommer@ericsson.com, marco.spini@huawei.com | SP-47 | new TR 23.839 |
| 9 | 7.2 | Stage 1 Building Block I for BroadBand forum Accesses Interworking |  | 76d? | 2009-12-10 A | 2010-03-25 A | 100% |  | 2009-12-10 | 2010-03-25 | 76d? |  | start no earlier than 2009-12-10 | S1 | 608h | 608h | Rel-11 | Alain | BBAI | PCG-24 | Ericsson | peter.bleckert@ericsson.com | SP-46 | 22.278 CR#0058 |
| 10 | 7.3 | Stage 2 Building Block I for BroadBand forum Accesses Interworking |  | 259d? | 2010-03-26 A | 2011-03-23 | 20% | 207.2d? | 2010-03-26 | 2011-03-23 | 259d? | 352.8d | finish no earlier than 2011-03-23 | S2 | 2072h | 414.4h | Rel-11 | Maurice | BBAI | PCG-24 | Ericsson, Huawei | stefan.rommer@ericsson.com | SP-47 | 23.203, 23.401, 23.402 |
| 11 | 7.4 | Stage 1 Building Block II for BroadBand forum Accesses Interworking |  | 130d? | 2010-09-23 A | 2011-03-23 | 70% | 39d? | 2010-09-23 | 2011-03-23 | 130d? | 352.8d | finish no earlier than 2011-03-23 | S1 | 1040h | 728h | Rel-11 | Alain | BBAI | PCG-25 | Ericsson, Huawei | peter.bleckert@ericsson.com | SP-49 | 22.278 |
| 12 | 7.5 | Stage 2 Building Block II for BroadBand forum Accesses Interworking |  | 197d? | 2010-09-23 | 2011-06-24 |  |  | 2010-09-23 | 2011-06-24 | 197d? | 285.8d | finish no earlier than 2011-06-24 | S2 | 1576h |  | Rel-11 | Maurice | BBAI | PCG-24 | Ericsson | stefan.rommer@ericsson.com | SP-47 | 23.203, 23.401, 23.402 |
| 13 | 7.6 | Stage 1 Building Block III for BroadBand forum Accesses Interworking |  | 130d? | 2010-09-23 A | 2011-03-23 | 60% | 52d? | 2010-09-23 | 2011-03-23 | 130d? | 352.8d | finish no earlier than 2011-03-23 | S1 | 1040h | 624h | Rel-11 | Alain | BBAI | PCG-25 | Huawei | Amar Deol (adeol@huawei.com) | SP-49 | 22.278 |
| 14 | 7.7 | Stage 2 Building Block III for BroadBand forum Accesses Interworking |  | 197d? | 2010-09-23 | 2011-06-24 |  |  | 2010-09-23 | 2011-06-24 | 197d? | 285.8d | finish no earlier than 2011-06-24 | S2 | 1576h |  | Rel-11 | Maurice | BBAI | PCG-24 | Huawei | marco.spini@huawei.com | SP-47 | 23.203, 23.401, 23.402 |
| 15 | 8 | **Advanced IP Interconnection of Services** |  | 187d | 2010-03-25 A | 2010-12-10 | 25% | 140.25d | 2010-03-25 | 2010-12-10 | 187d | 425.8d |  | S1 | 2992h | 748h | Rel-11 | Alain | IPXS | PCG-24 | Telefónica | chris.friel@O2.com | SP-47 |  |
| 16 | 8.1 | Stage 1 for IPXS |  | 187d | 2010-03-25 A | 2010-12-10 | 25% | 140.25d | 2010-03-25 | 2010-12-10 | 187d | 425.8d | finish no earlier than 2010-12-10 | S1 | 1496h | 374h | Rel-11 | Alain | IPXS | PCG-24 | Telefónica | chris.friel@O2.com | SP-47 | 22.101, 22.228 |
| 17 | 9 | **System Improvements to Machine-Type Communications** |  | 396d? | 2010-06-10 | 2011-12-15 |  |  | 2010-06-10 | 2011-12-15 | 396d? | 161.8d |  | S1,S2,S3 | 15816h |  | Rel-11 | Alain | SIMTC | PCG-25 | KPN | Toon Norp (toon.norp@tno.nl) | SP-48 |  |
| 18 | 9.1 | Stage 1 for System Improvements to Machine-Type Communications |  | 132d? | 2010-06-10 | 2010-12-10 |  |  | 2010-06-10 | 2010-12-10 | 132d? | 425.8d | finish no earlier than 2010-12-10 | S1 | 1056h |  | Rel-11 | Alain | SIMTC | PCG-25 | KPN | Toon Norp (toon.norp@tno.nl) | SP-48 | 22.368 |
| 19 | 9.2 | TR on Stage 2 for System Improvements to Machine-Type Communications |  | 336d? | 2010-06-10 | 2011-09-22 |  |  | 2010-06-10 | 2011-09-22 | 336d? | 221.8d | finish no earlier than 2011-09-22 | S2 | 2688h |  | Rel-11 | Maurice | SIMTC | PCG-25 | Samsung | erik.guttman@partner.samsung.com | SP-48 | new TR 23.8xx |
| 20 | 9.3 | TR on Security aspects of System Improvements to Machine-Type Communications |  | 321d? | 2010-09-23 | 2011-12-15 |  |  | 2010-09-23 | 2011-12-15 | 321d? | 161.8d | finish no earlier than 2011-12-15 | S3 | 2568h |  | Rel-11 | Dionisio | SIMTC | PCG-25 | Samsung | Rajavelsamy R (rajvel@samsung.com) | SP-49 | new TR 33.8xy |
| 21 | 9.4 | Stage 2 on SA2 part for System Improvements to Machine-Type Communications |  | 396d? | 2010-06-10 | 2011-12-15 |  |  | 2010-06-10 | 2011-12-15 | 396d? | 161.8d | finish no earlier than 2011-12-15 | S2 | 3168h |  | Rel-11 | Maurice | SIMTC | PCG-25 | Samsung | erik.guttman@partner.samsung.com | SP-48 | Depends on the outcome of the Stage 2 TR |
| 22 | 9.5 | Stage 2 on Security part for System Improvements to Machine-Type Communications |  | 396d? | 2010-06-10 | 2011-12-15 |  |  | 2010-06-10 | 2011-12-15 | 396d? | 161.8d | finish no earlier than 2011-12-15 | S3 | 3168h |  | Rel-11 | Dionisio | SIMTC | PCG-25 | Samsung | Rajavelsamy R (rajvel@samsung.com) | SP-48 | Depends on the outcome of the Stage 2 Security TR |
| 23 | 10 | **Unstructured Supplementary Service Data (USSD) simulation service in IMS** |  | 0d? | 2010-06-10 A | 2010-06-10 A | 100% |  | 2010-06-10 | 2010-06-10 | 0d? |  |  | S1 |  |  | Rel-11 | Alain | USSI | PCG-25 | Deutsche Telekom | kurt.bischinger@t-mobile.at | SP-48 |  |
| 24 | 10.1 | Stage 1 for USSD simulation service in IMS | milestone | 0d? | 2010-06-10 A | 2010-06-10 A | 100% |  | 2010-06-10 | 2010-06-10 | 0d? |  | finish no earlier than 2010-06-10 | S1 |  |  | Rel-11 | Alain | USSI | PCG-25 | Deutsche Telekom | kurt.bischinger@t-mobile.at | SP-48 | 22.173 |
| 25 | 11 | SRVCC aspect of enhancements for Multimedia Priority Service |  | 205d? | 2010-06-10 | 2011-03-23 |  |  | 2010-06-10 | 2011-03-23 | 205d? | 352.8d | finish no earlier than 2011-03-23 | S2 | 1640h |  | Rel-11 | Maurice | eMPS_SRVCC | PCG-25 | Telcordia, NTT DoCoMo | Katsutoshi Nishida | SP-48 | 23.216 |

Notes:
- 1: -
- 2: -
- 3: -
- 4: -
- 5: -
- 6: -
- 7: SP#49 moved to Rel-11. Updated WID SP-100222=>SP-100630. Triggered by BBF WT 203. Interworking between the 3GPP EPS and the fixed broadband accesses as defined by BBF
- 8: SP#48 completion 03/10=>06/11. TR structure to follow the structure of the Building Blocks. Once a BB is completed, TR to be sent for SA Information. When all the BBs are completed, TR to be sent for SA approval.
- 9: SP#47 completed. Provide service requirements for supporting interworking between 3GPP EPS and the fixed broadband accesses defined by BBF
- 10: SP#49 moved to Rel-11. Completion 12/10=>03/11
- 11: 22.278 CRs for clarification to complete the support of H(e)NB and WLAN (Building Block II)
- 12: SP#48 completion 03/10=>06/11
- 13: 22.278 CRs for clarification to introduce use cases/ requirements for the convergence scenario (Building Block III)
- 14: SP#48 completion 03/10=>06/11
- 15: Triggered by Rel-10 TR 22.893 UID_380083 Study on advanced requirements for IP interconnect (FS_IPXS)
- 16: -
- 17: SP#49 updated WID SP-100447=>SP-100637 (added security TR). Enhancements to Rel-10 Feature UID_410031 (Network Improvements for Machine Type Communications) based on Rel-11 Study on enhancements to MTC
- 18: -
- 19: SP#49 updated WID SP-100447=>SP-100637 (added security TR).
- 20: SP#49 updated WID SP-100447=>SP-100637 (added security TR).
- 21: -
- 22: -
- 23: SP#48 approved WID & Stage 1 completed. Specify a "CS domain USSD" like service over IMS (see GSM Mobile User Initiated USSD)
- 24: SP#48 completed
- 25: SP#49 moved to Rel-11. Completion 09/10=>03/11. Analyze and if needed specify mechanisms for the priority handling of SRVCC with regard to LTE/EPC

| ID | WBS | Task | Duration | Start | Finish | Complete | Remaining | Baseline start | Baseline finish | Baseline duration | Total slack | Constraint | Resources | Work | Actual work | Text1 | Text2 | Text4 | Text5 | Text6 | Text7 | Text8 |
| --- | --- | --- | --- | --- | --- | --- | --- | --- | --- | --- | --- | --- | --- | --- | --- | --- | --- | --- | --- | --- | --- | --- |
| 26 | 12 | **Network Provided Location Information for IMS** | 271d? | 2010-06-10 A | 2011-06-23 | 12% | 239.07d? | 2010-06-10 | 2011-06-23 | 271d? | 286.8d |  | S2,S1,S5 | 7016h | 826.75h | NWK-PL2IMS | PCG-25 | T-Mobile | michele.zarri@t-mobile.co.uk | Rel-11 | SP-48 | Maurice |
| 27 | 12.1 | TR on Study on network provided location information to the IMS | 205d? | 2010-06-10 A | 2011-03-23 | 18% | 168.82d? | 2010-06-10 | 2011-03-23 | 205d? | 352.8d | finish no earlier than 2011-03-23 | S2 | 1640h | 289.44h | NWK-PL2IMS | PCG-25 | T-Mobile | michele.zarri@t-mobile.co.uk | Rel-11 | SP-48 | Maurice |
| 28 | 12.2 | Stage 2 for Network Provided Location Information for IMS | 271d? | 2010-06-10 A | 2011-06-23 | 13% | 235.77d? | 2010-06-10 | 2011-06-23 | 271d? | 286.8d | finish no earlier than 2011-06-23 | S2 | 2168h | 281.84h | NWK-PL2IMS | PCG-25 | T-Mobile | michele.zarri@t-mobile.co.uk | Rel-11 | SP-48 | Maurice |
| 29 | 12.3 | Charging for Network Provided Location Information for IMS | 130d? | 2010-09-23 | 2011-03-23 |  |  | 2010-09-23 | 2011-03-23 | 130d? | 352.8d | start no earlier than 2010-09-23 | S5 | 1040h |  | NWK-PL2IMS_CH | PCG-25 | Nokia Siemens Networks | Nokia Siemens Networks | Rel-11 | SP-49 | Gerald.Goermer@nsn.com |
| 30 | 13 | **SIPTO Service Continuity of IP Data Session** | 61d? | 2010-09-23 A | 2010-12-16 | 80% | 12.2d? | 2010-09-23 | 2010-12-16 | 61d? | 421.8d |  | S1 | 976h | 780.8h | SIPTO_SC | PCG-25 | Vodafone | mona.mustapha@vodafone.com | Rel-11 | SP-49 | Alain |
| 31 | 13.1 | Stage 1 for SIPTO Service Continuity of IP Data Session | 61d? | 2010-09-23 A | 2010-12-16 | 80% | 12.2d? | 2010-09-23 | 2010-12-16 | 61d? | 421.8d | finish no earlier than 2010-12-16 | S1 | 488h | 390.4h | SIPTO_SC | PCG-25 | Vodafone | mona.mustapha@vodafone.com | Rel-11 | SP-49 | Alain |
| 32 | 14 | **QoS Control Based on Subscriber Spending Limits** | 61d? | 2010-09-23 A | 2010-12-16 | 95% | 3.05d? | 2010-09-23 | 2010-12-16 | 61d? | 421.8d |  | S1 | 976h | 927.2h | QoS_SSL | PCG-25 | Vodafone | mona.mustapha@vodafone.com | Rel-11 | SP-49 | Alain |
| 33 | 14.1 | Stage 1 for QoS Control Based on Subscriber Spending Limits | 61d? | 2010-09-23 A | 2010-12-16 | 95% | 3.05d? | 2010-09-23 | 2010-12-16 | 61d? | 421.8d | finish no earlier than 2010-12-16 | S1 | 488h | 463.6h | QoS_SSL | PCG-25 | Vodafone | mona.mustapha@vodafone.com | Rel-11 | SP-49 | Alain |
| 34 | 15 | **Optimized Service Charging and Allocation of Resources in IMS whilst Roaming** | 321d? | 2010-09-23 A | 2011-12-15 | 5% | 305.65d? | 2010-09-23 | 2011-12-15 | 321d? | 161.8d |  | S1,S2 | 7672h | 366.76h | OSCAR | PCG-25 | Vodafone | mona.mustapha@vodafone.com | Rel-11 | SP-49 | Alain |
| 35 | 15.1 | Study on Stage 2 for Optimized Service Charging and Allocation of Resources in IMS whilst Roaming | 256d? | 2010-09-23 | 2011-09-15 |  |  | 2010-09-23 | 2011-09-15 | 256d? | 226.8d | finish no earlier than 2011-09-15 | S2 | 2048h |  | OSCAR | PCG-25 | Vodafone | nick.russell@vodafone.com | Rel-11 | SP-49 | Maurice |
| 36 | 15.2 | Stage 1 for Optimized Service Charging and Allocation of Resources in IMS whilst Roaming | 61d? | 2010-09-23 A | 2010-12-16 | 50% | 30.5d? | 2010-09-23 | 2010-12-16 | 61d? | 421.8d | finish no earlier than 2010-12-16 | S1 | 488h | 244h | OSCAR | PCG-25 | Vodafone | mona.mustapha@vodafone.com | Rel-11 | SP-49 | Alain |
| 37 | 15.3 | Stage 2 for Optimized Service Charging and Allocation of Resources in IMS whilst Roaming | 321d? | 2010-09-23 | 2011-12-15 |  |  | 2010-09-23 | 2011-12-15 | 321d? | 161.8d | finish no earlier than 2011-12-15 | S2 | 2568h |  | OSCAR | PCG-25 | Vodafone | nick.russell@vodafone.com | Rel-11 | SP-49 | Maurice |
| 38 | 16 | EEA3 and EIA3 (new Encryption & Integrity EPS security Algorithms) | 661d? | 2009-06-04 A | 2011-12-15 | 40% | 396.6d? | 2009-06-04 | 2011-12-15 | 661d? | 161.8d | finish no earlier than 2011-12-15 | S3 | 5288h | 2115.2h | EEA3_EIA3 | PCG-23 | CATR | Yuan Qi, yuanqi@mail.ritt.com.cn | Rel-11 | SP-44 | Dionisio |
| 39 | 17 | Specification of Protection against Unsolicited Communication for IMS | 266d? | 2010-06-10 A | 2011-06-16 | 10% | 239.4d? | 2010-06-10 | 2011-06-16 | 266d? | 291.8d | finish no earlier than 2011-06-16 | S3 | 2128h | 212.8h | SPUCI | PCG-25 | NEC | Anand R. Prasad (anand@bq.jp.nec.com) | Rel-11 | SP-48 | Dionisio |
| 40 | 18 | **Codec for Enhanced Voice Services** | 510d? | 2010-03-25 A | 2012-03-07 | 20% | 407.2d? | 2010-03-25 | 2012-03-07 | 510d? | 102.8d |  | S4,S1 | 8168h | 1646.38h | EVS_codec | PCG-24 | Huawei | anisse.taleb@huawei.com | Rel-11 | SP-47 | Paolo |
| 41 | 18.1 | Stage 1 for EVS_codec | 1d? | 2010-03-25 A | 2010-03-25 A | 100% |  | 2010-03-25 | 2010-03-25 | 1d? |  | start no earlier than 2010-03-25 | S1 | 8h | 8h | EVS_codec | PCG-24 | Huawei | anisse.taleb@huawei.com | Rel-11 | SP-47 | Paolo |
| 42 | 18.2 | Codec for Enhanced Voice Services | 510d? | 2010-03-25 A | 2012-03-07 | 20% | 408d? | 2010-03-25 | 2012-03-07 | 510d? | 102.8d | finish no earlier than 2012-03-07 | S4 | 4080h | 816h | EVS_codec | PCG-24 | Huawei | anisse.taleb@huawei.com | Rel-11 | SP-47 | Paolo |
| 43 | 19 | (Small) Technical Enhancements and Improvements for Rel-11 | 402d? | 2010-06-10 | 2011-12-23 |  |  | 2010-06-10 | 2011-12-23 | 402d? | 155.8d | finish no earlier than 2011-12-23 | All | 3216h |  | TEI11 | PCG-25 |  |  | Rel-11 | SP-48 | All |
| 44 | 20 | Release 11 Studies | 335d? | 2009-12-10 A | 2011-03-23 |  | 335d? | 2009-12-10 | 2011-03-23 | 335d? | 352.8d | finish no earlier than 2011-03-23 | SP,GP | 1086.4h |  |  |  |  |  | Rel-11 |  | All |
| 45 | 21 | Study on IMS based Peer-to-Peer Content Distribution Services | 284d? | 2009-05-12 A | 2010-06-10 A | 100% |  | 2009-05-12 | 2010-06-10 | 284d? |  | finish no earlier than 2010-06-10 | S1,S2 | 2272h | 2272h | FS_IMS_P2P | PCG-23 | China Mobile | Li Gang (ligangyf@chinamobile.com) | Rel-11 | SP-45 | Alain |
| 46 | 22 | Study on IMS based Peer-to-Peer Content Distribution Services (Stage 2) | 321d? | 2010-09-23 | 2011-12-15 |  |  | 2010-09-23 | 2011-12-15 | 321d? | 161.8d | finish no earlier than 2011-12-15 | S2,S1 | 2568h |  | FS_IMS_P2P_CDS | PCG-25 | China Mobile | Yu Qing (yuqing@chinamobile.com) | Rel-11 | SP-49 | Maurice |
| 47 | 23 | Study on Non Voice Emergency Services | 266d? | 2009-12-10 A | 2010-12-16 | 70% | 79.8d? | 2009-12-10 | 2010-12-16 | 266d? | 421.8d | finish no earlier than 2010-12-16 | S1 | 2128h | 1489.6h | FS_NOVES | PCG-24 | Qualcomm | dwilliams@qualcomm.com | Rel-11 | SP-46 | Alain |
| 48 | 24 | Study on UICC/USIM enhancements | 335d? | 2009-12-10 A | 2011-03-23 | 45% | 184.25d? | 2009-12-10 | 2011-03-23 | 335d? | 352.8d | finish no earlier than 2011-03-23 | S1 | 2680h | 1206h | FS_U2e | PCG-24 | Giesecke & Devrient | Ilario ilario.macchi@gi-de.com | Rel-11 | SP-46 | Alain |
| 49 | 25 | Study on Alternatives to E.164 for Machine-Type Communications | 191d? | 2010-03-25 A | 2010-12-16 | 15% | 162.35d? | 2010-03-25 | 2010-12-16 | 191d? | 421.8d | finish no earlier than 2010-12-16 | S1 | 1528h | 229.2h | FS_AMTC | PCG-24 | T-Mobile USA | gary.jones@T-Mobile.com | Rel-11 | SP-47 | Alain |
| 50 | 26 | Study on enhancements for Machine-Type Communications (MTC) | 266d? | 2010-06-10 A | 2011-06-16 | 10% | 239.4d? | 2010-06-10 | 2011-06-16 | 266d? | 291.8d | finish no earlier than 2011-06-16 | S1 | 2128h | 212.8h | FS_MTCe | PCG-25 | Huawei | laurence.meriau@huawei.com | Rel-11 | SP-48 | Alain |
| 51 | 27 | Study on Support for 3GPP Voice Interworking with Enterprise IP-PBX | 205d? | 2010-09-23 A | 2011-07-06 | 40% | 123d? | 2010-09-23 | 2011-07-06 | 205d? | 277.8d | finish no earlier than 2011-03-23 | S1,S2 | 1640h | 656h | FS_VINE | PCG-25 | Tatara Systems | Phillip Brown (pbrown@tatarasystems.com) | Rel-11 | SP-48 | Alain |
| 52 | 28 | Study on IMS Network-Independent Public User Identities | 131d? | 2010-09-23 | 2011-03-24 |  |  | 2010-09-23 | 2011-03-24 | 131d? | 351.8d | finish no earlier than 2011-03-24 | S1 | 1048h |  | FS_INIPUI | PCG-25 | Vodafone | mona.mustapha@vodafone.com | Rel-11 | SP-49 | Alain |
| 53 | 29 | Study on Integration of Single Sign-On (SSO) frameworks with 3GPP networks | 191d? | 2010-09-23 | 2011-06-16 |  |  | 2010-09-23 | 2011-06-16 | 191d? | 291.8d | finish no earlier than 2011-06-16 | S1 | 1528h |  | FS_SSO_Int | PCG-25 | InterDigital | christopher.wallace@interdigital.com | Rel-11 | SP-49 | Alain |
| 54 | 30 | Study on Core Network Overload solutions | 321d? | 2010-09-23 | 2011-12-15 |  |  | 2010-09-23 | 2011-12-15 | 321d? | 161.8d | finish no earlier than 2011-12-15 | S2 | 2568h |  | FS_CNO | PCG-25 | Huawei | David Xiang (dxiang@huawei.com) | Rel-11 | SP-49 | Maurice |
| 55 | 31 | Study on Solutions for GSM/EDGE BTS Energy Saving | 261d? | 2010-09-03 | 2011-09-02 |  |  | 2010-09-03 | 2011-09-02 | 261d? | 235.8d | finish no earlier than 2011-09-02 | G1,G2 | 2088h |  | FS_Energy_BTS | PCG-25 | Nokia Siemens Networks, Vodafone | juergen.hofmann@nsn.com, leo.patanapongpibul@vodafone.com | Rel-11 | GP-47 | Paolo |
| 56 | 32 | Release 10 Features | 593d? | 2008-12-11 A | 2012-07-30 |  | 593d? | 2008-12-11 | 2012-07-30 | 593d? | 0d |  | CP,GP,RP,SP | 4744h |  |  |  |  |  | Rel-10 |  |  |

Notes:
- 26: Architecture solutions making Cell/PLMN ID (the UE is camped on) available to IMS nodes when the mobile operator needs to record this information either to fulfil legal obligations or for charging purposes.
- 27: - / Text3: new TR 23.8bc
- 28: - / Text3: 23.060, 23.203, 23.228, 23.401
- 29: Stage 2/3. Stage 1 in SA1 TS 22.115 / Text3: 32.240 (Stage 2), 32.260, 32.298, 32.299
- 30: Linked to Rel-10 Local IP Access and Selected Internet IP Traffic Offload (LIPA_SIPTO)
- 31: - / Text3: 22.101, 22.220
- 32: Stage 1/2/3 ?
- 33: Use cases & service requirements to allow: 1) modification of QoS based on subscribers spending limits 2) enforcing of spending limits for roaming subscribers without having dedicated support in the visited network / Text3: 22.115
- 34: Triggered by S1-102236 / GSMA RILTE 10_007r1 (IREG LS_038 to 3GPP on Optimal Media Routing drawbacks)
- 35: - / Text3: new TR 23.849
- 36: - / Text3: 22.115, 22.173
- 37: - / Text3: TBD
- 38: SP#49 moved to Rel-11. Develop new EPS algorithms acceptable to regions such as China / Text3: 35.xxx (EEA3 & EIA3 Algorithm Specification, Implementers’ test data, Design and evaluation report, Final project report), 33.401 (SAE Security Architecture)
- 39: SP#49 moved to Rel-11. Continuation of Rel-9 UID_410027/410029. Builds on TR 33.937 Study of Mechanisms for PUCI / Text3: new TR 33.8xy, TS 33.abc
- 40: SP#49 SA4 completion =>03/12. Moved to Rel-11. SP#47 Stage 1 completed. Develop EVS codec for EPS based on TR 22.813 recommendations. Triggered by UID_370045 Study on enhanced voice service requirements for EPS (TR 22.813)
- 41: SP#47 completed / Text3: 22.173
- 42: SP#49 completion 12/11=>03/12 / Text3: 26.xyz, 26.xyz, 26.xyz, 26.xyz, 26.xyz, 26.xyz, 26.xyz, 26.xyz, 26.xyz, 26.xyz, 26.9yz, 26.xyz
- 43: -
- 44: -
- 45: SP#48 completed / Text3: 22.906
- 46: Triggered by TR 22.906 SA1 Study on IMS based Peer-to-Peer Content Distribution Services UID_450047 / Text3: 23.844
- 47: SP#49 completion 09/10=>12/10? / Text3: 22.871
- 48: SP#49 completion 09/10=>03/11? Triggered by GSMA Smart SIM and 3GNBK projects, and to evolve from traditional USAT to multimedia USIM toolkit support, particularly to Smart Card Web Server / Text3: 22.817
- 49: Determine an alternative to E.164 for identifying individual devices and route messages between those devices / Text3: 22.988
- 50: Study Network improvements for MTC Device to MTC Device communications via one or more PLMNs (direct-mode communication between devices is out of scope), etc. Align also with ETSI TC M2M work. / Text3: 22.888
- 51: Support Interworking between 3GPP networks and Enterprise environments to provide enterprise voice services via 3GPP mobile devices / Text3: 22.809
- 52: - / Text3: 22.894
- 53: Linked to SA3 Study on Single Sign On (SSO) Application Security for IMS - based on SIP Digest (UID_480048), SA3 TR 33.924 Extended Identity Management (GBA-IdM) and SA3 TR 33.980 Liberty Alliance and 3GPP Security Interworking (LibSec) / Text3: 22.895
- 54: Linked to CT4 UID_490014 Study on EPC Nodes Restoration. Support from CT4 and RAN WGs is anticipated. / Text3: 23.843
- 55: GP#47 approved SID / Text3: TR 45.8xy Potential solutions for energy-saving for GSM/EDGE radio access BTS
- 56: -

| ID | WBS | Task | Duration | Start | Finish | Complete | Remaining | Baseline start | Baseline finish | Baseline duration | Total slack | Constraint | Resources | Work | Actual work | Text1 | Text2 | Text4 | Text5 | Text6 | Text7 | Text8 | Text9 | Text12 |
| --- | --- | --- | --- | --- | --- | --- | --- | --- | --- | --- | --- | --- | --- | --- | --- | --- | --- | --- | --- | --- | --- | --- | --- | --- |
| 57 | 33 | **Enhancements for Multimedia Priority Service** | 1311d? | 2006-03-13 A | 2011-03-18 | 74% | 335.1d? | 2006-03-13 | 2011-03-18 | 1311d? | 355.8d |  | S1,S2,C4,C3,C1 | 28592h | 17789.6h | eMPS | PCG-21 | Telcordia | jgarraha@telcordia.com | Rel-10 | SP-39 | Alain |  |  |
| 58 | 33.1 | Stage 1 on enhancements for Multimedia Priority Service | 584d? | 2006-03-13 A | 2008-06-05 A | 100% |  | 2006-03-13 | 2008-06-05 | 584d? |  | start no earlier than 2006-03-12 | S1 | 4672h | 4672h | ePRIOR | PCG-21 | Telcordia | jgarraha@telcordia.com | Rel-10 | SP-39 | Alain |  |  |
| 59 | 33.2 | **Stage 2 on enhancements for Multimedia Priority Service** | 206d? | 2009-12-10 A | 2010-09-23 A | 100% |  | 2009-12-10 | 2010-09-23 | 206d? |  |  | S2 | 6592h | 6592h | eMPS | PCG-24 | Telcordia, NTT DoCoMo | Vijay Varma, Katsutoshi Nishida | Rel-10 | SP-46 | Maurice |  |  |
| 60 | 33.2.1 | Stage 2 on eMPS for CSFB | 206d? | 2009-12-10 A | 2010-09-23 A | 100% |  | 2009-12-10 | 2010-09-23 | 206d? |  | finish no earlier than 2010-09-24 | S2 | 1648h | 1648h | eMPS | PCG-24 | Telcordia, NTT DoCoMo | Vijay Varma, Katsutoshi Nishida | Rel-10 | SP-46 | Maurice |  |  |
| 61 | 33.2.2 | Stage 2 on eMPS for EPS Bearer Service | 206d? | 2009-12-10 A | 2010-09-23 A | 100% |  | 2009-12-10 | 2010-09-23 | 206d? |  | finish no earlier than 2010-12-09 | S2 | 1648h | 1648h | eMPS | PCG-24 | Telcordia, NTT DoCoMo | Vijay Varma, Katsutoshi Nishida | Rel-10 | SP-46 | Maurice |  |  |
| 62 | 33.2.3 | Stage 2 on eMPS for IMS Aspects | 206d? | 2009-12-10 A | 2010-09-23 A | 100% |  | 2009-12-10 | 2010-09-23 | 206d? |  | finish no earlier than 2010-12-09 | S2 | 1648h | 1648h | eMPS | PCG-24 | Telcordia, NTT DoCoMo | Vijay Varma, Katsutoshi Nishida | Rel-10 | SP-46 | Maurice |  |  |
| 63 | 33.3 | TR on Stage 2 on enhancements for Multimedia Priority Service | 331d? | 2009-12-10 A | 2011-03-17 | 70% | 99.3d? | 2009-12-10 | 2011-03-17 | 331d? | 356.8d | finish no earlier than 2011-03-17 | S2 | 2648h | 1853.6h | eMPS | PCG-24 | Telcordia, NTT DoCoMo | Vijay Varma, Katsutoshi Nishida | Rel-10 | SP-46 | Maurice |  |  |
| 64 | 33.4 | **Stage 3 on enhancements for Multimedia Priority Service** | 131d? | 2010-09-17 | 2011-03-18 |  |  | 2010-09-17 | 2011-03-18 | 131d? | 355.8d |  | C4,C3,C1 | 4192h |  | eMPS-CN | PCG-25 | Ericsson | Philip.hodges@ericsson.com | Rel-10 | CP-49 | Kimmo |  |  |
| 65 | 33.4.1 | CT4 part on Stage 3 on enhancements for Multimedia Priority Service | 131d? | 2010-09-17 | 2011-03-18 |  |  | 2010-09-17 | 2011-03-18 | 131d? | 355.8d | start no earlier than 2010-09-17 | C4 | 1048h |  | eMPS-CN | PCG-25 | Ericsson | Philip.hodges@ericsson.com | Rel-10 | CP-49 | Kimmo |  |  |
| 66 | 33.4.2 | CT3 part on Stage 3 on enhancements for Multimedia Priority Service | 131d? | 2010-09-17 | 2011-03-18 |  |  | 2010-09-17 | 2011-03-18 | 131d? | 355.8d | start no earlier than 2010-09-17 | C3 | 1048h |  | eMPS-CN | PCG-25 | Ericsson | Philip.hodges@ericsson.com | Rel-10 | CP-49 | Gwiho |  |  |
| 67 | 33.4.3 | CT1 part on Stage 3 on enhancements for Multimedia Priority Service | 131d? | 2010-09-17 | 2011-03-18 |  |  | 2010-09-17 | 2011-03-18 | 131d? | 355.8d | start no earlier than 2010-09-17 | C1 | 1048h |  | eMPS-CN | PCG-25 | Ericsson | Philip.hodges@ericsson.com | Rel-10 | CP-49 | Frederic |  |  |
| 68 | 34 | **Network Improvements for Machine-Type Communications** | 656d? | 2008-09-18 A | 2011-03-23 | 51% | 320.7d? | 2008-09-18 | 2011-03-23 | 656d? | 352.8d |  | S1,S2,C1,C3,C4,G2,R2,R3 | 21929.2h | 10393.8h | NIMTC | PCG-21 | KPN | Toon Norp (toon.norp@tno.nl) | Rel-10 | SP-41 | Alain |  |  |
| 69 | 34.1 | Stage 1 for Network Improvements for Machine-Type Communications | 397d? | 2008-09-18 A | 2010-03-25 A | 100% |  | 2008-09-18 | 2010-03-25 | 397d? |  | finish no earlier than 2009-12-10 | S1 | 3176h | 3176h | NIMTC | PCG-21 | KPN | Toon Norp (toon.norp@tno.nl) | Rel-10 | SP-41 | Alain |  |  |
| 70 | 34.2 | TR on Stage 2 for Network Improvements for Machine-Type Communications | 390d? | 2009-09-24 A | 2011-03-23 | 87% | 48.96d? | 2009-09-24 | 2011-03-23 | 390d? | 352.8d | finish no earlier than 2011-03-23 | S2 | 3120h | 2728.32h | NIMTC | PCG-23 | Samsung | erik.guttman@partner.samsung.com | Rel-10 | SP-45 | Maurice |  |  |
| 71 | 34.3 | Stage 2 for Network Improvements for Machine-Type Communications | 19d? | 2010-08-30 A | 2010-09-23 A | 100% |  | 2010-08-30 | 2010-09-23 | 19d? |  | finish no earlier than 2010-09-17 | S2 | 152h | 152h | NIMTC | PCG-23 | Samsung | erik.guttman@partner.samsung.com | Rel-10 | SP-45 | Maurice |  |  |
| 72 | 34.4 | Deleted - Security for Network Improvements for Machine-Type Communications | 193.15d? | 2009-12-10 A | 2010-09-23 A | 100% |  | 2009-12-10 | 2010-09-23 | 193.15d? |  | finish no earlier than 2010-09-23 | S3 | 1545.2h | 1545.2h | NIMTC | PCG-24 | Samsung | Rajavelsamy R (rajvel@samsung.com) | Rel-10 | SP-46 | Dionisio | PCG-25 | SP-49 |
| 73 | 34.5 | **CN part of Stage 3 for Network Improvements for Machine-Type Communications** | 206d? | 2010-06-04 A | 2011-03-18 | 2% | 202.57d? | 2010-06-04 | 2011-03-18 | 206d? | 355.8d |  | C1,C3,C4 | 6592h | 109.87h | NIMTC | PCG-25 | Ericsson | mikael.wass@ericsson.com | Rel-10 | CP-48 | Frederic |  |  |
| 74 | 34.5.1 | CT1 part of Stage 3 for Network Improvements for Machine-Type Communications | 206d? | 2010-06-04 A | 2011-03-18 | 5% | 195.7d? | 2010-06-04 | 2011-03-18 | 206d? | 355.8d | finish no earlier than 2011-03-18 | C1 | 1648h | 82.4h | NIMTC | PCG-25 | Ericsson | mikael.wass@ericsson.com | Rel-10 | CP-48 | Frederic |  |  |
| 75 | 34.5.2 | CT3 part of Stage 3 for Network Improvements for Machine-Type Communications | 206d? | 2010-06-04 | 2011-03-18 |  |  | 2010-06-04 | 2011-03-18 | 206d? | 355.8d | finish no earlier than 2011-03-18 | C3 | 1648h |  | NIMTC | PCG-25 | Ericsson | mikael.wass@ericsson.com | Rel-10 | CP-48 | Gwiho |  |  |
| 76 | 34.5.3 | CT4 part of Stage 3 for Network Improvements for Machine-Type Communications | 206d? | 2010-06-04 | 2011-03-18 |  |  | 2010-06-04 | 2011-03-18 | 206d? | 355.8d | finish no earlier than 2011-03-18 | C4 | 1648h |  | NIMTC | PCG-25 | Ericsson | mikael.wass@ericsson.com | Rel-10 | CP-48 | Kimmo |  |  |
| 77 | 34.6 | GERAN part of Network Improvements for Machine-Type Communications (Stage 3) | 131d? | 2010-09-03 | 2011-03-04 |  |  | 2010-09-03 | 2011-03-04 | 131d? | 365.8d | finish no earlier than 2011-03-04 | G2 | 1048h |  | NIMTC | PCG-25 | Vodafone, Ericsson | leo.patanapongpibul@vodafone.com, john.diachina@ericsson.com | Rel-10 | GP-47 | Gert |  |  |
| 78 | 34.7 | RAN mechanisms to avoid CN overload due to Machine-Type Communications | 131d? | 2010-09-17 | 2011-03-18 |  |  | 2010-09-17 | 2011-03-18 | 131d? | 355.8d | finish no earlier than 2011-03-18 | R2,R3 | 1048h |  | NIMTC-RAN_overload | PCG-25 | Huawei | Jeff Gao (gaoyq@huawei.com) | Rel-10 | RP-49 | Joern |  |  |
| 79 | 35 | Multi Access PDN Connectivity | 401d? | 2009-03-13 A | 2010-09-23 A | 100% |  | 2009-03-13 | 2010-09-23 | 401d? |  | finish no earlier than 2010-09-23 | S2 | 3208h | 3208h | MAPCON | PCG-22 | Telecom Italia | ivano.guardini@telecomitalia.it | Rel-10 | SP-43 | Maurice |  |  |
| 80 | 36 | **IMS Service Continuity – Inter Device Transfer enhancements** | 467d? | 2009-06-04 A | 2011-03-18 | 68% | 149.66d? | 2009-06-04 | 2011-03-18 | 467d? | 355.8d |  | S1,S2,C1 | 9600h | 5672.8h | IMS_SC_eIDT | PCG-23 | Huawei | Amar Deol (adeol@huawei.com) | Rel-10 | SP-44 | Alain |  |  |
| 81 | 36.1 | Stage 1 - IMS Service Continuity – Inter Device Transfer enhancements | 211d? | 2009-06-04 A | 2010-03-25 A | 100% |  | 2009-06-04 | 2010-03-25 | 211d? |  | finish no earlier than 2010-03-25 | S1 | 1688h | 1688h | IMS_SC_eIDT | PCG-23 | Huawei | Amar Deol (adeol@huawei.com) | Rel-10 | SP-44 | Alain |  |  |
| 82 | 36.2 | Stage 2 - IMS Inter-UE Transfer enhancements | 261d? | 2009-09-24 A | 2010-09-23 A | 100% |  | 2009-09-24 | 2010-09-23 | 261d? |  | finish no earlier than 2010-09-23 | S2 | 2088h | 2088h | IMS_SC_eIDT | PCG-23 | Huawei | Lee Valerius (lvalerius@huawei.com) | Rel-10 | SP-45 | Maurice |  |  |
| 83 | 36.3 | Stage 3 - IMS Inter-UE Transfer enhancements | 261d? | 2010-03-19 A | 2011-03-18 | 10% | 234.9d? | 2010-03-19 | 2011-03-18 | 261d? | 355.8d | start no earlier than 2010-03-19 | C1 | 2088h | 208.8h | IMS_SC_eIDT | PCG-24 | Huawei | georg.mayer@huawei.com | Rel-10 | CP-47 | Frederic |  |  |

Notes:
- 57: SP#49 moved Stage 1 from Rel-9 & Completed Stage 2. SP#40 Stage 1 completed. Continuation of Rel-8 Feature PRIOR (UID_340044)
- 58: SP#49 moved from Rel-9. SP#40 completed / Text3: 22.153, 22.278
- 59: SP#49 completed. Updated WID SP-100166=>SP-100647
- 60: SP#49 completed / Text3: 23.002, 23.203, 23.221, 23.228, 23.272, 23.401
- 61: SP#49 completed / Text3: 23.002, 23.203, 23.221, 23.228, 23.272, 23.401
- 62: SP#49 completed / Text3: 23.002, 23.203, 23.221, 23.228, 23.272, 23.401
- 63: SP#49 TR 23.854v100 for Information (target completion 12/10=>03/11). Updated WID SP-100166=>SP-100647 / Text3: new 23.854
- 64: Stage 3
- 65: - / Text3: 23.008, 29.002, 29.228, 29.229, 29.272, 29.274, 29.277, 29.328, 29.329
- 66: - / Text3: 29.212, 29.213, 29.214
- 67: - / Text3: 24.229, 24.301
- 68: SP#49 Security stopped. SP#47 Stage 1 completed. Triggered by Rel-8 UID_7027 Study on Facilitating Machine to Machine Communication in GSM and UMTS (FS_M2M) TR 22.868
- 69: SA#47 completed / Text3: new 22.368
- 70: SP#49 TR 23.888v100 for Information / Text3: new TR 23.888
- 71: SP#49 completed / Text3: 23.060, 23.236, 23.401
- 72: SP#49 stopped (activity moved to Rel-11 under UID_490028 TR on Security aspects of System Improvements to Machine-Type Communications (SIMTC) / Text3: new 33.868
- 73: -
- 74: - / Text3: 24.008, 24.301
- 75: - / Text3: 29.061, 29.007
- 76: - / Text3: 23.003, 23.008, 29.002, 29.272, 29.274, 29.275, 29.060
- 77: GP#47 approved WID / Text3: 44.018, 44.060
- 78: UTRA, LTE Stage 3 / Text3: 25.331, 25.413, 36.331, 36.413
- 79: SP#49 completed. Triggered by TR 23.861 UID_410043 FS_MAPIM. Stage 1 in Rel-9 22.278 (6.2 - IP session control) / Text3: 23.237, 23.401, 23.402
- 80: SP#47 Stage 1 completed. Rel-9 set Inter-Device Transfer requirements UID_410033 (IMS_SCC-IDT). Adding additional scenarios and requirements for IDT.
- 81: SA#47 completed / Text3: 22.228
- 82: SP#49 completed. TR 23.831v200 for Approval / Text3: 23.237, 23.292, new 23.831
- 83: CP#48 revised WID CP-100100=>CP-100334 (added new TR) / Text3: 24.216, 24.229, 24.237, new 24.837

| ID | WBS | Task | Duration | Start | Finish | Complete | Remaining | Baseline start | Baseline finish | Baseline duration | Total slack | Constraint | Resources | Work | Actual work | Text1 | Text2 | Text4 | Text6 | Text7 | Text8 |
| --- | --- | --- | --- | --- | --- | --- | --- | --- | --- | --- | --- | --- | --- | --- | --- | --- | --- | --- | --- | --- | --- |
| 84 | 37 | **IP-Short-Message-Gateway enhancements for CPM-SMS Interworking** | 257d? | 2009-09-24 A | 2010-09-17 A | 100% |  | 2009-09-24 | 2010-09-17 | 257d? |  |  | S1,S2,C3 | 5792.8h | 5792.8h | CPM-SMS | PCG-23 | China Mobile | Rel-10 | SP-45 | Alain |
| 85 | 37.1 | Stage 1 for CPM-SMS | 131d? | 2009-09-24 A | 2010-03-25 A | 100% |  | 2009-09-24 | 2010-03-25 | 131d? |  | finish no earlier than 2010-03-25 | S1 | 1048h | 1048h | CPM-SMS | PCG-23 | China Mobile | Rel-10 | SP-45 | Alain |
| 86 | 37.2 | Stage 2 for CPM-SMS | 130.1d? | 2009-09-24 A | 2010-03-25 A | 100% |  | 2009-09-24 | 2010-03-25 | 130.1d? |  | finish no earlier than 2010-03-25 | S2 | 1040.8h | 1040.8h | CPM-SMS | PCG-23 | Orange | Rel-10 | SP-45 | Maurice |
| 87 | 37.3 | Stage 3 for IP-Short-Message-Gateway enhancements for CPM-SMS Interworking | 206d? | 2009-12-04 A | 2010-09-17 A | 100% |  | 2009-12-04 | 2010-09-17 | 206d? |  | finish no earlier than 2010-09-17 | C3 | 1648h | 1648h | CPM-SMS | PCG-24 | Ericsson | Rel-10 | CP-46 | Gwiho |
| 88 | 38 | **Completion of Communications on Not Logged-in** | 317d? | 2009-09-24 A | 2010-12-10 | 86% | 45.18d? | 2009-09-24 | 2010-12-10 | 317d? | 425.8d |  | S1,C1,C3 | 4680h | 1846.4h | CCNL | PCG-23 | Deutsche Telekom | Rel-10 | SP-45 | Alain |
| 89 | 38.1 | Stage 1 for Completion of Communications on Not Logged-in | 1d? | 2009-09-24 A | 2009-09-24 A | 100% |  | 2009-09-24 | 2009-09-24 | 1d? |  | start no earlier than 2009-09-24 | S1 | 8h | 8h | CCNL | PCG-23 | Deutsche Telekom | Rel-10 | SP-45 | Alain |
| 90 | 38.2 | CT1 part of Stage 3 for Completion of Communications on Not Logged-in | 191d? | 2010-03-19 A | 2010-12-10 | 80% | 38.2d? | 2010-03-19 | 2010-12-10 | 191d? | 425.8d | finish no earlier than 2010-12-10 | C1 | 1528h | 1222.4h | CCNL | PCG-24 | Deutsche Telekom | Rel-10 | CP-47 | Frederic |
| 91 | 38.3 | CT3 part of Stage 3 for Completion of Communications on Not Logged-in | 76d? | 2010-06-04 A | 2010-09-17 A | 100% |  | 2010-06-04 | 2010-09-17 | 76d? |  | finish no earlier than 2010-09-17 | C3 | 608h | 608h | CCNL | PCG-25 | Deutsche Telekom | Rel-10 | CP-48 | Gwiho |
| 92 | 39 | **Local IP Access and Selected Internet IP Traffic Offload** | 387d? | 2009-09-24 A | 2011-03-18 | 61% | 150.52d? | 2009-09-24 | 2011-03-18 | 387d? | 355.8d |  | S2,S1,S3,S5,C4,C1 | 27304h | 14014.4h | LIPA_SIPTO | PCG-23 | Huawei, China Mobile | Rel-10 | SP-45 | Maurice |
| 93 | 39.1 | Stage 1 for Local IP Access and Selected Internet IP Traffic Offload | 131d? | 2009-09-24 A | 2010-03-25 A | 100% |  | 2009-09-24 | 2010-03-25 | 131d? |  | finish no earlier than 2010-03-25 | S1 | 1048h | 1048h | LIPA_SIPTO | PCG-23 | Huawei, China Mobile | Rel-10 | SP-45 | Alain |
| 94 | 39.2 | TR on Local IP Access and Selected Internet IP Traffic Offload | 321d? | 2009-09-24 A | 2010-12-16 | 80% | 64.2d? | 2009-09-24 | 2010-12-16 | 321d? | 421.8d | finish no earlier than 2010-12-16 | S2 | 2568h | 2054.4h | LIPA_SIPTO | PCG-23 | Huawei, China Mobile | Rel-10 | SP-45 | Maurice |
| 95 | 39.3 | Security for Local IP Access and Selected Internet IP Traffic Offload | 261d? | 2009-09-24 A | 2010-09-23 A | 100% |  | 2009-09-24 | 2010-09-23 | 261d? |  | finish no earlier than 2010-09-23 | S3 | 2088h | 2088h | LIPA_SIPTO | PCG-23 | Huawei, Qualcomm | Rel-10 | SP-45 | Dionisio |
| 96 | 39.4 | OAM&P for Local IP Access and Selected Internet IP Traffic Offload | 321d? | 2009-09-24 A | 2010-12-16 | 30% | 224.7d? | 2009-09-24 | 2010-12-16 | 321d? | 421.8d | finish no earlier than 2010-12-16 | S5 | 2568h | 770.4h | LIPA_SIPTO | PCG-23 | Huawei, China Mobile | Rel-10 | SP-45 | Dionisio |
| 97 | 39.5 | Charging for Local IP Access and Selected Internet IP Traffic Offload | 266d? | 2009-12-10 A | 2010-12-16 | 20% | 212.8d? | 2009-12-10 | 2010-12-16 | 266d? | 421.8d | finish no earlier than 2010-12-16 | S5 | 2128h | 425.6h | LIPA_SIPTO | PCG-24 | Huawei, China Mobile | Rel-10 | SP-46 | Dionisio |
| 98 | 39.6 | Stage 2 for Local IP Access | 229d? | 2009-09-24 A | 2010-08-10 A | 100% |  | 2009-09-24 | 2010-08-10 | 229d? |  | finish no earlier than 2010-08-10 | S2 | 1832h | 1832h | LIPA | PCG-23 | Huawei, China Mobile | Rel-10 | SP-45 | Maurice |
| 99 | 39.7 | **Stage 3 for Local IP Access** | 206d? | 2010-06-04 A | 2011-03-18 | 3% | 200.85d? | 2010-06-04 | 2011-03-18 | 206d? | 355.8d |  | C4,C1 | 4944h | 123.6h | LIPA | PCG-25 | China Mobile | Rel-10 | CP-48 | Kimmo |
| 100 | 39.7.1 | CT4 part of Stage 3 for Local IP Access | 206d? | 2010-06-04 A | 2011-03-18 | 5% | 195.7d? | 2010-06-04 | 2011-03-18 | 206d? | 355.8d | finish no earlier than 2011-03-18 | C4 | 1648h | 82.4h | LIPA | PCG-25 | China Mobile | Rel-10 | CP-48 | Kimmo |
| 101 | 39.7.2 | CT1 part of Stage 3 for Local IP Access | 206d? | 2010-06-04 | 2011-03-18 |  |  | 2010-06-04 | 2011-03-18 | 206d? | 355.8d | finish no earlier than 2011-03-18 | C1 | 1648h |  | LIPA | PCG-25 | China Mobile | Rel-10 | CP-48 | Frederic |
| 102 | 39.8 | Stage 2 for SIPTO for macro networks | 261d? | 2009-09-24 A | 2010-09-23 A | 100% |  | 2009-09-24 | 2010-09-23 | 261d? |  | finish no earlier than 2010-09-23 | S2 | 2088h | 2088h | SIPTO | PCG-23 | Huawei, China Mobile | Rel-10 | SP-45 | Maurice |
| 103 | 39.9 | **Stage 3 for SIPTO for macro networks** | 206d? | 2010-06-04 A | 2011-03-18 | 73% | 56.65d? | 2010-06-04 | 2011-03-18 | 206d? | 355.8d |  | C4,C1 | 4944h | 3584.4h | SIPTO | PCG-25 | Huawei | Rel-10 | CP-48 | Kimmo |
| 104 | 39.9.1 | CT4 part of Stage 3 for SIPTO for macro networks | 206d? | 2010-06-04 A | 2011-03-18 | 55% | 92.7d? | 2010-06-04 | 2011-03-18 | 206d? | 355.8d | finish no earlier than 2011-03-18 | C4 | 1648h | 906.4h | SIPTO | PCG-25 | Huawei | Rel-10 | CP-48 | Kimmo |
| 105 | 39.9.2 | CT1 part of Stage 3 for SIPTO for macro networks | 206d? | 2010-06-04 A | 2011-03-18 | 90% | 20.6d? | 2010-06-04 | 2011-03-18 | 206d? | 355.8d | finish no earlier than 2011-03-18 | C1 | 1648h | 1483.2h | SIPTO | PCG-25 | Huawei | Rel-10 | CP-48 | Frederic |
| 106 | 40 | **IP Flow Mobility and seamless WLAN offload** | 387d? | 2009-09-24 A | 2011-03-18 | 44% | 215.97d? | 2009-09-24 | 2011-03-18 | 387d? | 355.8d |  | S2,S1,S5,C1,C3 | 12624h | 4301.2h | IFOM | PCG-23 | Qualcomm | Rel-10 | SP-45 | Maurice |
| 107 | 40.1 | Stage 1 for IP Flow Mobility and seamless WLAN offload | 56d? | 2009-09-24 A | 2009-12-10 A | 100% |  | 2009-09-24 | 2009-12-10 | 56d? |  | finish no earlier than 2009-12-10 | S1 | 448h | 448h | IFOM | PCG-23 | Qualcomm | Rel-10 | SP-45 | Alain |
| 108 | 40.2 | Stage 2 for IP Flow Mobility and seamless WLAN offload | 261d? | 2009-09-24 A | 2010-09-23 A | 100% |  | 2009-09-24 | 2010-09-23 | 261d? |  | finish no earlier than 2010-09-23 | S2 | 2088h | 2088h | IFOM | PCG-23 | Qualcomm | Rel-10 | SP-45 | Maurice |
| 109 | 40.3 | Charging for IP Flow Mobility and seamless WLAN offload | 256d? | 2010-03-25 A | 2011-03-17 | 10% | 230.4d? | 2010-03-25 | 2011-03-17 | 256d? | 356.8d | finish no earlier than 2011-03-17 | S5 | 2048h | 204.8h | IFOM | PCG-24 | Alcatel-Lucent | Rel-10 | SP-47 | Dionisio |

Notes:
- 84: SP#47 Stage 1 completed. IP-SM-GW enhancements for interworking with OMA CPM / Text5: Qing Huang
- 85: SA#47 completed. External requirements (Stage 1 in OMA-RD-CPM-V1_0-20090310-C) / Text3: 22.340 / Text5: Qing Huang
- 86: SP#47 completed / Text3: 23.204, new TR 23.824 / Text5: Antoine Mouquet
- 87: CP#49 completed. Linked to Rel-8 UID_340031 Service-Level Interworking for Messaging Services (MESSIW) 23.204 / Text3: 29.311 / Text5: Jan Holm
- 88: SP#45 Stage 1 completed / Text5: Kurt Bischinger
- 89: SP#45 completed / Text3: 22.173 CR#0056r1 / Text5: Kurt Bischinger
- 90: CP#49 completion 09/10=>12/10 / Text3: 24.173, 24.642 / Text5: martin.huelsemann@telekom.de
- 91: CP#49 completed / Text3: 29.165 / Text5: martin.huelsemann@telekom.de
- 92: SP#49 Stage 2 & Security completed. UID_400035 Enhanced Home NodeB/eNodeB (EHNB) formerly covered Local IP Access to Internet and Local access to Home Network from the Home NodeB/eNodeB Features now covered by this WI / Text5: patrice.hede@huawei.com, Tao Sun (suntao@chinamobile.com)
- 93: SP#47 completed / Text3: 22.101, 22.220 / Text5: Amar Deol (adeolf@huawei.com), Gang Li (ligangyf@chinamobile.com)
- 94: SP#49 for Information 2nd time TR 23.829v130 / Text3: new 23.829 / Text5: patrice.hede@huawei.com, Tao Sun (suntao@chinamobile.com)
- 95: SP#49 completed / Text3: 33.102, 33.107, 33.108, 33.320, 33.401 / Text5: Marcus Wong (mwong@huawei.com), Brian Rosenberg (bmr@qualcomm.com)
- 96: - / Text3: 32.101, 32.102, 32.405, 32.425, 32.452, 32.453, 32.581, 32.582, 32.583, 32.584, 32.591, 32.592, 32.593, 32.594, 32.64x, 32.76x / Text5: Zou Lan (zlan@huawei.com), Chen Gang (chengang@chinamobile.com)
- 97: SP#49 SA5 considered SA2 TR 23.829. SA5 findings: No normative impact on Charging for SIPTO. LIPA Charging will not change the Charging Architecture. / Text3: 32.240, 32.251, 32.298, 32.299 / Text5: shan.mingjun@huawei.com, Ai Chen (chenai@chinamobile.com)
- 98: SP#49 completed (has impacts to RAN) / Text3: 23.060, 23.203, 23.401 / Text5: patrice.hede@huawei.com, Tao Sun (suntao@chinamobile.com)
- 99: - / Text5: Zhang Hao (zhanghao@chinamobile.com)
- 100: - / Text3: 23.008, 29.002, 29.060, 29.272, 29.274, 29.281, 29.303 / Text5: Zhang Hao (zhanghao@chinamobile.com)
- 101: - / Text3: 24.008, 24.301 / Text5: Zhang Hao (zhanghao@chinamobile.com)
- 102: SP#49 completed / Text3: 23.060, 23.203, 23.401 / Text5: patrice.hede@huawei.com, Tao Sun (suntao@chinamobile.com)
- 103: - / Text5: Caixia Qi (qcxmay@huawei.com)
- 104: - / Text3: 23.003, 23.008, 29.002, 29.272, 29.303 / Text5: Caixia Qi (qcxmay@huawei.com)
- 105: - / Text3: 24.008, 24.301 / Text5: Caixia Qi (qcxmay@huawei.com)
- 106: Triggered by Rel-10 TR 23.861 (UID_410043 Study on Multi Access PDN connectivity and IP flow mobility - MAPIM) / Text5: Gerardo Giaretta (gerardo@qualcomm.com)
- 107: SP#46completed / Text3: 22.278 / Text5: David Williams (dwilliam@qualcomm.com)
- 108: SP#49 completed / Text3: 23.203, 23.402, new 23.261 / Text5: Gerardo Giaretta (gerardo@qualcomm.com)
- 109: - / Text3: 32.240, 32.251, 32.252, 32.298, 32.299 / Text5: maryse.gardella@alcatel-lucent.com

| ID | WBS | Task | Type | Duration | Start | Finish | Complete | Remaining | Baseline start | Baseline finish | Baseline duration | Total slack | Constraint | Resources | Work | Actual work | Text1 | Text2 | Text4 | Text5 | Text6 | Text7 | Text8 | Text3 |
| --- | --- | --- | --- | --- | --- | --- | --- | --- | --- | --- | --- | --- | --- | --- | --- | --- | --- | --- | --- | --- | --- | --- | --- | --- |
| 110 | 40.4 | **Stage 3 for IP Flow Mobility and seamless WLAN offload** |  | 206d? | 2010-06-04 A | 2011-03-18 | 23% | 159.65d? | 2010-06-04 | 2011-03-18 | 206d? | 355.8d |  | C1,C3 | 4944h | 1112.4h | IFOM-CT | PCG-25 | Qualcomm | Patrick Stupar (pstupar@qualcomm.com) | Rel-10 | CP-48 | Frederic |  |
| 111 | 40.4.1 | CT1 part of Stage 3 for IP Flow Mobility and seamless WLAN offload |  | 206d? | 2010-06-04 A | 2011-03-18 | 25% | 154.5d? | 2010-06-04 | 2011-03-18 | 206d? | 355.8d | finish no earlier than 2011-03-18 | C1 | 1648h | 412h | IFOM-CT | PCG-25 | Qualcomm | Patrick Stupar (pstupar@qualcomm.com) | Rel-10 | CP-48 | Frederic | 24.302, 24.303, 24.312, 24.327 |
| 112 | 40.4.2 | CT3 part of Stage 3 for IP Flow Mobility and seamless WLAN offload |  | 206d? | 2010-06-04 A | 2011-03-18 | 20% | 164.8d? | 2010-06-04 | 2011-03-18 | 206d? | 355.8d | finish no earlier than 2011-03-18 | C3 | 1648h | 329.6h | IFOM-CT | PCG-25 | Qualcomm | Patrick Stupar (pstupar@qualcomm.com) | Rel-10 | CP-48 | Gwiho | 29.212, 29.213, 29.214, 29.215 |
| 113 | 41 | **Enabling Coder Selection and Rate Adaptation for UTRAN and E-UTRAN for Load Adaptive Applications** |  | 387d? | 2009-09-24 A | 2011-03-18 | 47% | 204.77d? | 2009-09-24 | 2011-03-18 | 387d? | 355.8d |  | S2,S4,R2,C4,C3,C1 | 13920h | 4603.2h | ECSRA_LAA | PCG-23 | Qualcomm | AC Mahendran (ac@qualcomm.com) | Rel-10 | SP-45 | Maurice | UTRA, LTE |
| 114 | 41.1 | TR on Enabling Coder Selection and Rate Adaptation for UTRAN and E-UTRAN for Load Adaptive Applications |  | 186d? | 2009-09-24 A | 2010-06-10 A | 100% |  | 2009-09-24 | 2010-06-10 | 186d? |  | finish no earlier than 2010-09-23 | S2,S4,R2 | 1488h | 1488h | ECSRA_LAA | PCG-23 | Qualcomm | AC Mahendran (ac@qualcomm.com) | Rel-10 | SP-45 | Maurice | new 23.860 |
| 115 | 41.2 | SA4 review of TR on Enabling Coder Selection and Rate Adaptation for UTRAN and E-UTRAN for Load Adaptive Applications |  | 321d? | 2009-09-24 A | 2010-12-16 | 40% | 192.6d? | 2009-09-24 | 2010-12-16 | 321d? | 421.8d | finish no earlier than 2010-09-23 | S4,R2 | 2568h | 1027.2h | ECSRA_LAA | PCG-23 | Qualcomm | AC Mahendran (ac@qualcomm.com) | Rel-10 | SP-45 | Paolo | new 23.860 |
| 116 | 41.3 | Stage 2 for Enabling Coder Selection and Rate Adaptation for UTRAN and E-UTRAN for Load Adaptive Applications |  | 261d? | 2009-09-24 A | 2010-09-23 A | 100% |  | 2009-09-24 | 2010-09-23 | 261d? |  | finish no earlier than 2010-09-23 | S2 | 2088h | 2088h | ECSRA_LAA | PCG-23 | Qualcomm | AC Mahendran (ac@qualcomm.com) | Rel-10 | SP-45 | Maurice | 23.060, 23.203, 23.228, 23.401 |
| 117 | 41.4 | SA4 aspects of Enabling Coder Selection and Rate Adaptation for UTRAN and E-UTRAN for Load Adaptive Applications |  | 61d? | 2010-09-23 | 2010-12-16 |  |  | 2010-09-23 | 2010-12-16 | 61d? | 421.8d | finish no earlier than 2010-12-16 | S4 | 488h |  | ECSRA_LAA | PCG-25 | Qualcomm | AC Mahendran (ac@qualcomm.com) | Rel-10 | SP-49 | Paolo | 26.114 |
| 118 | 41.5 | **CN aspects of Enabling Coder Selection and Rate Adaptation for UTRAN and E-UTRAN for Load Adaptive Applications** |  | 131d? | 2010-09-17 | 2011-03-18 |  |  | 2010-09-17 | 2011-03-18 | 131d? | 355.8d |  | C4,C3,C1 | 4192h |  | ECSRA_LAA-CN | PCG-25 | Ericsson | Philip.hodges@ericsson.com | Rel-10 | CP-49 | Kimmo |  |
| 119 | 41.5.1 | CT4 part of CN aspects of Enabling Coder Selection and Rate Adaptation for UTRAN and E-UTRAN for Load Adaptive Applications |  | 131d? | 2010-09-17 | 2011-03-18 |  |  | 2010-09-17 | 2011-03-18 | 131d? | 355.8d | start no earlier than 2010-09-17 | C4 | 1048h |  | ECSRA_LAA-CN | PCG-25 | Ericsson | Philip.hodges@ericsson.com | Rel-10 | CP-49 | Kimmo | 23.334,29.334, 29.238, 23.333, 29.333, 29.232, 29.332 |
| 120 | 41.5.2 | CT3 part of CN aspects of Enabling Coder Selection and Rate Adaptation for UTRAN and E-UTRAN for Load Adaptive Applications |  | 131d? | 2010-09-17 | 2011-03-18 |  |  | 2010-09-17 | 2011-03-18 | 131d? | 355.8d | start no earlier than 2010-09-17 | C3 | 1048h |  | ECSRA_LAA-CN | PCG-25 | Ericsson | Philip.hodges@ericsson.com | Rel-10 | CP-49 | Gwiho | 29.162, 29.163, 29.235, 29.292, |
| 121 | 41.5.3 | CT1 part of CN aspects of Enabling Coder Selection and Rate Adaptation for UTRAN and E-UTRAN for Load Adaptive Applications |  | 131d? | 2010-09-17 | 2011-03-18 |  |  | 2010-09-17 | 2011-03-18 | 131d? | 355.8d | start no earlier than 2010-09-17 | C1 | 1048h |  | ECSRA_LAA-CN | PCG-25 | Ericsson | Philip.hodges@ericsson.com | Rel-10 | CP-49 | Frederic | 24.229 |
| 122 | 42 | **Extended H(e)NB features** |  | 467d? | 2008-12-11 A | 2010-09-23 A | 100% |  | 2008-12-11 | 2010-09-23 | 467d? |  |  | S1,S2,S3 | 4344h | 4344h | EHNBF | PCG-23 | NEC | joerg.swetina@nw.neclab.eu | Rel-10 | SP-45 | Alain |  |
| 123 | 42.1 | Stage 1 of Extended H(e)NB features |  | 131d? | 2009-09-24 A | 2010-03-25 A | 100% |  | 2009-09-24 | 2010-03-25 | 131d? |  | finish no earlier than 2010-03-25 | S1 | 1048h | 1048h | EHNBF | PCG-23 | NEC | joerg.swetina@nw.neclab.eu | Rel-10 | SP-45 | Alain | 22.220 |
| 124 | 42.2 | IMS aspects of Architecture for Home NodeB |  | 336d? | 2008-12-11 A | 2010-03-25 A | 100% |  | 2008-12-11 | 2010-03-25 | 336d? |  | finish no earlier than 2010-03-25 | S2 | 2688h | 2688h | EHNB-IMS | PCG-22 | Alcatel-Lucent | Nicolas Drevon | Rel-10 | SP-42 | Maurice | new 23.832 |
| 125 | 42.3 | Extended H(e)NB Security features (Stage 2) |  | 76d? | 2010-06-10 A | 2010-09-23 A | 100% |  | 2010-06-10 | 2010-09-23 | 76d? |  | finish no earlier than 2010-09-23 | S3 | 608h | 608h | EHNBF-Sec | PCG-25 | Huawei | Marcus Wong (mwong@huawei.com) | Rel-10 | SP-48 | Dionisio | 33.320 |
| 126 | 43 | **Optimal Media Routeing** |  | 256d? | 2010-03-25 A | 2011-03-18 | 18% | 209.07d? | 2010-03-25 | 2011-03-18 | 256d? | 355.8d |  | S2,C3,C1,C4 | 8640h | 1584h | OMR | PCG-24 | Alcatel-Lucent | andy.bennett@alcatel-lucent.com | Rel-10 | SP-46 | Maurice |  |
| 127 | 43.1 | Stage 2 for Optimal Media Routeing | milestone | 0d? | 2010-03-25 A | 2010-03-25 A | 100% |  | 2010-03-25 | 2010-03-25 | 0d? |  |  | S2 |  |  | OMR | PCG-24 | Alcatel-Lucent | andy.bennett@alcatel-lucent.com | Rel-10 | SP-46 | Maurice | 23.228 |
| 128 | 43.2 | **Stage 3 for Optimal Media Routeing** |  | 206d? | 2010-06-04 A | 2011-03-18 | 18% | 168.23d? | 2010-06-04 | 2011-03-18 | 206d? | 355.8d |  | C3,C1,C4 | 6592h | 1208.53h | OMR | PCG-25 | Alcatel-Lucent | jim.calme@alcatel-lucent.com | Rel-10 | CP-48 | Gwiho |  |
| 129 | 43.2.1 | CT3 part of Stage 3 for Optimal Media Routeing |  | 206d? | 2010-06-04 A | 2011-03-18 | 55% | 92.7d? | 2010-06-04 | 2011-03-18 | 206d? | 355.8d | finish no earlier than 2011-03-18 | C3 | 1648h | 906.4h | OMR | PCG-25 | Alcatel-Lucent | jim.calme@alcatel-lucent.com | Rel-10 | CP-48 | Gwiho | 29.162, 29.163, 29.165, 29.235, new TS 29.079 |
| 130 | 43.2.2 | CT1 part of Stage 3 for Optimal Media Routeing |  | 206d? | 2010-06-04 | 2011-03-18 |  |  | 2010-06-04 | 2011-03-18 | 206d? | 355.8d | finish no earlier than 2011-03-18 | C1 | 1648h |  | OMR | PCG-25 | Alcatel-Lucent | jim.calme@alcatel-lucent.com | Rel-10 | CP-48 | Frederic | 24.229 |
| 131 | 43.2.3 | CT4 part of Stage 3 for Optimal Media Routeing |  | 206d? | 2010-06-04 | 2011-03-18 |  |  | 2010-06-04 | 2011-03-18 | 206d? | 355.8d | finish no earlier than 2011-03-18 | C4 | 1648h |  | OMR | PCG-25 | Alcatel-Lucent | jim.calme@alcatel-lucent.com | Rel-10 | CP-48 | Kimmo | 23.334 |
| 132 | 44 | **IMS Emergency Session Enhancements** |  | 131d? | 2010-03-25 A | 2010-09-23 A | 100% |  | 2010-03-25 | 2010-09-23 | 131d? |  |  | S2,S1 | 2104h | 2104h | IESE | PCG-24 | Deutsche Telekom, T-Mobile | michele.zarri@t-mobile.co.uk | Rel-10 | SP-47 | Maurice |  |
| 133 | 44.1 | Stage 1 for IMS Emergency Session Enhancements |  | 1d? | 2010-03-25 A | 2010-03-25 A | 100% |  | 2010-03-25 | 2010-03-25 | 1d? |  | start no earlier than 2010-03-25 | S1 | 8h | 8h | IESE | PCG-24 | Deutsche Telekom, T-Mobile | Kurt Bischinger | Rel-10 | SP-47 | Alain | 22.101 CR#0343 |
| 134 | 44.2 | Stage 2 for IMS Emergency Session Enhancements |  | 131d? | 2010-03-25 A | 2010-09-23 A | 100% |  | 2010-03-25 | 2010-09-23 | 131d? |  | finish no earlier than 2010-09-23 | S2 | 1048h | 1048h | IESE | PCG-24 | Deutsche Telekom, T-Mobile | Michele Zarri | Rel-10 | SP-47 | Maurice | 23.167 |

Notes:
- 110: -
- 111: -
- 112: -
- 113: SP#49 SA2 completed. Updated WID SP-090617=>SP-100467 (added SA4 specification part). Triggered by Rel-9 UID_440013 Vocoder rate adaptation for LTE
- 114: SP#48 completed
- 115: SP#49 completion 09/10=>12/10
- 116: SP#49 completed
- 117: SP#49 updated WID SP-090617=>SP-100467 (added SA4 specification part)
- 118: Stage 2/3
- 119: -
- 120: -
- 121: -
- 122: SP#49 completed. Adds extensions to Rel-9 functionality in UID_400035 Enhanced Home NodeB / eNodeB (EHNB)
- 123: SP#47 completed
- 124: SP#47 completed. Chosen solution has no normative impacts
- 125: SP#49 completed
- 126: SP#47 Stage 2 completed. Triggered by TR 23.894 (UID_370050 Study on System enhancements for the use of IMS services in local breakout)
- 127: SP#47 completed
- 128: -
- 129: -
- 130: -
- 131: -
- 132: SP#49 completed. Source of external requirements: ETSI TISPAN TS 181.019 (Business Communication Requirements)
- 133: SP#47 completed
- 134: SP#49 completed

| ID | WBS | Task | Duration | Start | Finish | Complete | Remaining | Baseline start | Baseline finish | Baseline duration | Total slack | Constraint | Resources | Work | Actual work | Text1 | Text2 | Text4 | Text5 | Text6 | Text7 | Text8 |
| --- | --- | --- | --- | --- | --- | --- | --- | --- | --- | --- | --- | --- | --- | --- | --- | --- | --- | --- | --- | --- | --- | --- |
| 135 | 45 | **User Data Convergence - Data Model** | 257d? | 2010-03-25 A | 2011-03-18 | 17% | 212.06d? | 2010-03-25 | 2011-03-18 | 257d? | 355.8d |  | S1,C4 | 5240h | 916.34h | UDC_DM | PCG-25 | Telecom Italia | mauro.ficaccio@telecomitalia.it | Rel-10 | CP-48 | Kimmo |
| 136 | 45.1 | Stage 1 for UDC Data Model | 56d? | 2010-03-25 A | 2010-06-10 A | 100% |  | 2010-03-25 | 2010-06-10 | 56d? |  | finish no earlier than 2010-06-10 | S1 | 448h | 448h | UDC_DM | PCG-25 | Telecom Italia | mauro.ficaccio@telecomitalia.it | Rel-10 | CP-48 | Alain |
| 137 | 45.2 | Study on User Data Convergence (UDC) Data Model | 136d? | 2010-06-04 A | 2010-12-10 | 10% | 122.4d? | 2010-06-04 | 2010-12-10 | 136d? | 425.8d | finish no earlier than 2010-12-10 | C4 | 1088h | 108.8h | UDC_DM | PCG-25 | Telecom Italia | mauro.ficaccio@telecomitalia.it | Rel-10 | CP-48 | Kimmo |
| 138 | 45.3 | User Data Convergence (UDC) Data Model | 206d? | 2010-06-04 | 2011-03-18 |  |  | 2010-06-04 | 2011-03-18 | 206d? | 355.8d | finish no earlier than 2011-03-18 | C4 | 1648h |  | UDC_DM | PCG-25 | Telecom Italia | mauro.ficaccio @ telecomitalia.it | Rel-10 | CP-48 | Kimmo |
| 139 | 46 | **S2b Mobility based on GTP** | 132d? | 2010-06-10 A | 2010-12-10 | 29% | 93.27d? | 2010-06-10 | 2010-12-10 | 132d? | 425.8d |  | S2,C4,C3,C1 | 3616h | 917.87h | SMOG | PCG-25 | Alcatel-Lucent | bruno.landais@alcatel-lucent.com | Rel-10 | SP-48 | Maurice |
| 140 | 46.1 | Stage 2 for S2b Mobility based on GTP | 76d? | 2010-06-10 A | 2010-09-23 A | 100% |  | 2010-06-10 | 2010-09-23 | 76d? |  | finish no earlier than 2010-09-23 | S2 | 608h | 608h | SMOG | PCG-25 | Alcatel-Lucent | bruno.landais@alcatel-lucent.com | Rel-10 | SP-48 | Maurice |
| 141 | 46.2 | **Stage 3 for S2b Mobility based on GTP** | 61d? | 2010-09-17 | 2010-12-10 |  |  | 2010-09-17 | 2010-12-10 | 61d? | 425.8d |  | C4,C3,C1 | 1952h |  | SMOG-St3 | PCG-25 | Alcatel-Lucent | bruno.landais@alcatel-lucent.com | Rel-10 | CP-49 | Kimmo |
| 142 | 46.2.1 | CT4 part of Stage 3 for S2b Mobility based on GTP | 61d? | 2010-09-17 | 2010-12-10 |  |  | 2010-09-17 | 2010-12-10 | 61d? | 425.8d | finish no earlier than 2010-12-10 | C4 | 488h |  | SMOG-St3 | PCG-25 | Alcatel-Lucent | bruno.landais@alcatel-lucent.com | Rel-10 | CP-49 | Kimmo |
| 143 | 46.2.2 | CT3 part of Stage 3 for S2b Mobility based on GTP | 61d? | 2010-09-17 | 2010-12-10 |  |  | 2010-09-17 | 2010-12-10 | 61d? | 425.8d | finish no earlier than 2010-12-10 | C3 | 488h |  | SMOG-St3 | PCG-25 | Alcatel-Lucent | bruno.landais@alcatel-lucent.com | Rel-10 | CP-49 | Gwiho |
| 144 | 46.2.3 | CT1 part of Stage 3 for S2b Mobility based on GTP | 61d? | 2010-09-17 | 2010-12-10 |  |  | 2010-09-17 | 2010-12-10 | 61d? | 425.8d | finish no earlier than 2010-12-10 | C1 | 488h |  | SMOG-St3 | PCG-25 | Alcatel-Lucent | bruno.landais@alcatel-lucent.com | Rel-10 | CP-49 | Frederic |
| 145 | 47 | Lawful Interception in the 3GPP Rel-10 | 191d? | 2010-03-25 A | 2010-12-16 | 40% | 114.6d? | 2010-03-25 | 2010-12-16 | 191d? | 421.8d | start no earlier than 2010-03-25 | S3 | 1528h | 611.2h | LI10 | PCG-24 | PIDS, Nortel | Koen Jaspers, Ronald Ryan | Rel-10 | SP-47 | Dionisio |
| 146 | 48 | Optimization of IMS based PSS and MBMS User Service | 260d? | 2010-03-25 A | 2011-03-23 | 35% | 168.65d? | 2010-03-25 | 2011-03-23 | 260d? | 352.8d | finish no earlier than 2011-03-23 | S4 | 2080h | 730.8h | OPT_IMS_PSS_MBMS_US | PCG-24 | Ericsson | markus.kampmann@ericsson.com | Rel-10 | SP-47 | Paolo |
| 147 | 49 | HTTP-based Streaming and Download Services | 260d? | 2010-03-25 A | 2011-03-23 | 25% | 194.75d? | 2010-03-25 | 2011-03-23 | 260d? | 352.8d | finish no earlier than 2011-03-23 | S4 | 2080h | 522h | HTTP_SDS | PCG-24 | Qualcomm | Thomas Stockhammer (c_tstock@qualcomm.com) | Rel-10 | SP-47 | Paolo |
| 148 | 50 | PSS and MBMS enhancements | 205d? | 2010-06-10 A | 2011-03-23 | 25% | 153.5d? | 2010-06-10 | 2011-03-23 | 205d? | 352.8d | finish no earlier than 2011-03-23 | S4 | 1640h | 412h | MBS_Enh | PCG-25 | Ericsson | Markus.Kampmann@ericsson.com | Rel-10 | SP-48 | Paolo |
| 149 | 51 | Enhancements and Addition of Audio Tests to 26.131 and 26.132 | 205d? | 2010-06-10 A | 2011-03-23 | 20% | 163.8d? | 2010-06-10 | 2011-03-23 | 205d? | 352.8d | finish no earlier than 2011-03-23 | S4 | 1640h | 329.6h | EAAT | PCG-25 | Vodafone | ramin.afchar@vodafone.com | Rel-10 | SP-48 | Paolo |
| 150 | 52 | **OAM&P 10** | 335d? | 2009-12-10 A | 2011-03-23 | 40% | 200.31d? | 2009-12-10 | 2011-03-23 | 335d? | 352.8d |  | S5 | 32024h | 12879.6h | OAM10 | PCG-24 |  |  | Rel-10 | SP-46 | Dionisio |
| 151 | 52.1 | **Network Infrastructure Management** | 335d? | 2009-12-10 A | 2011-03-23 | 35% | 218.2d? | 2009-12-10 | 2011-03-23 | 335d? | 352.8d |  | S5 | 9504h | 3313.59h | OAM10-NIM | PCG-24 |  |  | Rel-10 | SP-46 | Dionisio |
| 152 | 52.1.1 | Common RAT Network Resource Model (NRM) | 335d? | 2009-12-10 A | 2011-03-23 | 30% | 235.4d? | 2009-12-10 | 2011-03-23 | 335d? | 352.8d | finish no earlier than 2011-03-23 | S5 | 2680h | 796.8h | RAT_NRM_common | PCG-24 | Ericsson | robert.petersen@ericsson.com | Rel-10 | SP-46 | Dionisio |
| 153 | 52.1.2 | IRP Solution Set specification organisation improvements | 191d? | 2010-03-25 A | 2010-12-16 | 95% | 9.55d? | 2010-03-25 | 2010-12-16 | 191d? | 421.8d | finish no earlier than 2010-12-16 | S5 | 1528h | 1451.6h | OAM-IRP-SS | PCG-24 | Nokia Siemens Networks, Huawei | Jörg Schmidt (joerg@cox.net), Lan Zou (zlan@huawei.com) | Rel-10 | SP-47 | Dionisio |
| 154 | 52.1.3 | Service Oriented Architecture (SOA) for IRP continuation from Rel-9 | 191d? | 2010-03-25 A | 2010-12-16 | 5% | 181.45d? | 2010-03-25 | 2010-12-16 | 191d? | 421.8d | finish no earlier than 2010-12-16 | S5 | 1528h | 76.4h | OAM-SOA-IRP | PCG-24 | Nokia Siemens Networks, Ericsson | Jörg Schmidt (joerg@cox.net), edwin.tse@ericsson.com | Rel-10 | SP-47 | Dionisio |
| 155 | 52.1.4 | IRP Overview, Profiles & Usage Guide | 136d? | 2010-06-10 A | 2010-12-16 | 5% | 129.2d? | 2010-06-10 | 2010-12-16 | 136d? | 421.8d | finish no earlier than 2010-12-16 | S5 | 1088h | 54.4h | OAM-NIM-IRP_OPU | PCG-25 | Nokia Siemens Networks | Jörg Schmidt (joerg@cox.net) | Rel-10 | SP-48 | Dionisio |
| 156 | 52.2 | **Self-Organizing Networks (SON) - OAM aspects** | 335d? | 2009-12-10 A | 2011-03-23 | 40% | 201.25d? | 2009-12-10 | 2011-03-23 | 335d? | 352.8d |  | S5 | 9016h | 3599.57h | OAM10-SON | PCG-24 |  |  | Rel-10 | SP-46 | Dionisio |
| 157 | 52.2.1 | SON Self-optimization management continuation | 266d? | 2009-12-10 A | 2010-12-16 | 25% | 199.5d? | 2009-12-10 | 2010-12-16 | 266d? | 421.8d | finish no earlier than 2010-12-16 | S5 | 2128h | 532h | LTE-SON-OAM_SO | PCG-24 | Huawei | Lan Zou (zlan@huawei.com) | Rel-10 | SP-46 | Dionisio |
| 158 | 52.2.2 | SON Self-healing management | 266d? | 2009-12-10 A | 2010-12-16 | 45% | 146.3d? | 2009-12-10 | 2010-12-16 | 266d? | 421.8d | finish no earlier than 2010-12-16 | S5 | 2128h | 957.6h | LTE-SON-OAM_SH | PCG-24 | ZTE | zhu.weihong@zte.com.cn | Rel-10 | SP-46 | Dionisio |
| 159 | 52.2.3 | OAM aspects of Energy Saving in Radio Networks | 260d? | 2010-03-25 A | 2011-03-23 | 50% | 130d? | 2010-03-25 | 2011-03-23 | 260d? | 352.8d | finish no earlier than 2011-03-23 | S5 | 2080h | 1040h | OAM-ES | PCG-24 | Nokia Siemens Networks | clemens.suerbaum@nsn.com | Rel-10 | SP-47 | Dionisio |
| 160 | 52.3 | Subscription Management (SuM) evolution | 191d? | 2010-03-25 A | 2010-12-16 | 30% | 133.7d? | 2010-03-25 | 2010-12-16 | 191d? | 421.8d | finish no earlier than 2010-12-16 | S5 | 1528h | 458.4h | OAM10-SuM | PCG-24 | Ericsson | leo.yang@ericsson.com | Rel-10 | SP-47 | Dionisio |

Notes:
- 135: CP#49 updated WID CP-100422=>CP-100609. SP#48 Stage 1 completed
- 136: SP#48 completed / Text3: 22.101
- 137: CP#49 updated WID CP-100422=>CP-100609 (Also the integration of IMS AS user data into the UDR has to be studied, as this data is currently stored as transparent data by the HSS but conveyed over the Sh interface based on partial specification in 29.364) / Text3: new TR 29.935
- 138: CP#49 updated WID CP-100422=>CP-100609 / Text3: 29.335
- 139: SP#49 Stage 2 completed. Related to Rel-10 UID_470049 Study on S2b mobility based on GTP (TR23.834), UID_350027 SAE for support for non-3GPP accesses(SAES-SA-FP_n3GPP). Stage1 in Rel-8 UID_320022 Reqs for evolution of 3GPP system architecture (AIPN-SAE)
- 140: SP#49 completed / Text3: 23.002, 23.203, 23.402
- 141: Stage 3
- 142: - / Text3: 23.003, 23.007, 23.008, 29.273, 29.274, 29.281, 29.303
- 143: - / Text3: 29.212, 29.213, 29.215
- 144: - / Text3: 24.302
- 145: LI for CAT & CRS, VCC, IMS Media security, H(e)NB also with LIPA-SIPTO, eMBMS, LCLS, IMS/EPS enhancements / Text3: 33.106 (LI requirements), 33.107 (LI architecture and functions), 33.108 (Handover interface for LI)
- 146: Work to enhance UID_430046 Rel-9 IMS_PSS_MBMS_US_EXT / Text3: 26.237
- 147: SP#49 for Information TS 26.247v100 Progressive Download and Dynamic Adaptive Streaming over HTTP (3GP-DASH). Work to enhance UID_430038 Rel-9 PSS and MBMS extensions / Text3: 26.234, 26.244, 26.346, new 26.247 (Progressive Download and Dynamic Adaptive Streaming over HTTP (3GP-DASH))
- 148: Linked to Rel-9 Feature UID_430038 PSS and MBMS extensions (PMA-MBS_Ext). / Text3: 26.234, 26.346
- 149: Reduce fragmentation in acoustic testing (3GPP SA4, ETSI STQ, GCF CAG, CTIA) & Review existing acoustic tests to determine need for new spec (if need, be proactive to review/introduce test material and drive alignment between the bodies in charge) / Text3: 26.131, 26.132
- 150: umbrella Feature
- 151: umbrella BB
- 152: To reduce costs, some eqpmt can be shared btw several RATs, e.g. RET, TMA and repeaters. With existing modelling is difficult for an OP to see that several cells are affected when an antenna tilt is changed etc / Text3: 32.616, 32.642, 32.646, 32.652, 32.656, 32.762, 32.766 new (32.791, 32.792, 32.796)
- 153: SP#48 updated WID SP-100079=>SP-100294 / Text3: 32.153, new (32.111-6,32.126,32.176,32.306,32.316,32.326,32.336,32.346,32.356,32.366,32.376,32.386,32.396,32.416,32.446,32.506,32.536,32.606,32.616,32.626,32.636,32.646,32.656,32.666,32.676,32.696,32.716,32.726,32.736,32.746,32.756,32.766,32.776,32.786)
- 154: Continuation of Rel-9 UID_440065 SOA for IRP (covering SOA Architecture & SOA-supporting Solution Set) to address SOA conforming Registration & Discovery capabilities / Text3: 32.101, 32.150
- 155: - / Text3: new TS 32.xyz
- 156: umbrella BB
- 157: Continuation of Rel-9 work UID_390007 SON self-optimization management / Text3: 32.425, 32.521, 32.522, 32.752, 32.753, 32.755, 32.762, 32.763, 32.765
- 158: Work moved to Rel-10 after split of the Rel-9 UID_390007 SON self-optimization (removed Self-Healing handling) / Text3: new TS (32.541, 32.542, 32.543), 32.752, 32.753, 32.755, 32.762, 32.763, 32.765
- 159: SP#49 TS 32.551v100 for Information. Stage 3. Triggered by Rel-10 TR 32.826 Study on Telecommunication Management; Energy Savings Management (FS_OAM_ESM) UID_430044 / Text3: 32.425, 32.762, 32.763, 32.765, 32.767 or new 32.551 (Energy Saving Management (ESM); Concepts and requirements), 32.es2
- 160: Stage 3 / Text3: 32.172, 32.175

| ID | WBS | Task | Duration | Start | Finish | Complete | Remaining | Baseline start | Baseline finish | Baseline duration | Total slack | Constraint | Resources | Work | Actual work | Text1 | Text2 | Text6 | Text7 | Text8 | Text4 | Text11 |
| --- | --- | --- | --- | --- | --- | --- | --- | --- | --- | --- | --- | --- | --- | --- | --- | --- | --- | --- | --- | --- | --- | --- |
| 161 | 52.4 | **Performance Management** | 260d? | 2010-03-25 A | 2011-03-23 | 48% | 136.08d? | 2010-03-25 | 2011-03-23 | 260d? | 352.8d |  | S5 | 9296h | 4430.54h | OAM10-PM | PCG-24 | Rel-10 | SP-47 | Dionisio |  |  |
| 162 | 52.4.1 | Key Performance Indicators (KPIs) for IMS | 191d? | 2010-03-25 A | 2010-12-16 | 80% | 38.2d? | 2010-03-25 | 2010-12-16 | 191d? | 421.8d | finish no earlier than 2010-12-16 | S5 | 1528h | 1222.4h | OAM-PM-KPI_IMS | PCG-24 | Rel-10 | SP-47 | Dionisio | China Mobile |  |
| 163 | 52.4.2 | Key Performance Indicators (KPIs) for EPC | 260d? | 2010-03-25 A | 2011-03-23 | 40% | 157.2d? | 2010-03-25 | 2011-03-23 | 260d? | 352.8d | finish no earlier than 2011-03-23 | S5 | 2080h | 822.4h | OAM-PM-KPI_EPC | PCG-24 | Rel-10 | SP-47 | Dionisio | China Mobile |  |
| 164 | 52.4.3 | Management of UE based network performance measurements | 260d? | 2010-03-25 A | 2011-03-23 | 45% | 143d? | 2010-03-25 | 2011-03-23 | 260d? | 352.8d | finish no earlier than 2011-03-23 | S5 | 2080h | 936h | OAM-PM-UE | PCG-24 | Rel-10 | SP-47 | Dionisio | Huawei, Nokia Siemens Networks, Ericsson |  |
| 165 | 52.4.4 | 3G HNB and LTE HeNB Subsystem performance measurements | 191d? | 2010-03-25 A | 2010-12-16 | 30% | 133.7d? | 2010-03-25 | 2010-12-16 | 191d? | 421.8d | finish no earlier than 2010-12-16 | S5 | 1528h | 458.4h | OAM-PM-HeNS | PCG-24 | Rel-10 | SP-47 | Dionisio | China Mobile |  |
| 166 | 53 | **Charging Management small Enhancements** | 470d? | 2009-06-04 A | 2011-03-23 | 37% | 296.29d? | 2009-06-04 | 2011-03-23 | 470d? | 352.8d |  | S5 | 9600h | 3548.05h | CH10 | PCG-24 | Rel-10 | SP-47 | Dionisio |  |  |
| 167 | 53.1 | IWLAN mobility charging | 470d? | 2009-06-04 A | 2011-03-23 | 30% | 330.2d? | 2009-06-04 | 2011-03-23 | 470d? | 352.8d | finish no earlier than 2011-03-23 | S5 | 3760h | 1118.4h | eIWLAN_Mob | PCG-23 | Rel-10 | SP-44 | Dionisio | Orange |  |
| 168 | 53.2 | Add solutions for Rc - reference point within the Online Charging System (OCS) | 260d? | 2010-03-25 A | 2011-03-23 | 50% | 130d? | 2010-03-25 | 2011-03-23 | 260d? | 352.8d | finish no earlier than 2011-03-23 | S5 | 2080h | 1040h | CH-Rc | PCG-24 | Rel-10 | SP-47 | Dionisio | Huawei |  |
| 169 | 54 | **Advice of Charge (AoC) service support enhancements** | 260d? | 2010-03-25 A | 2011-03-23 | 43% | 147.29d? | 2010-03-25 | 2011-03-23 | 260d? | 352.8d |  | S5,C1 | 4648h | 2014.86h | eAoC | PCG-24 | Rel-10 | SP-47 | Dionisio | Deutsche Telekom |  |
| 170 | 54.1 | SA5 part - AoC enhancements | 260d? | 2010-03-25 A | 2011-03-23 | 50% | 130d? | 2010-03-25 | 2011-03-23 | 260d? | 352.8d | finish no earlier than 2011-03-23 | S5 | 2080h | 1040h | eAoC | PCG-24 | Rel-10 | SP-47 | Dionisio | Deutsche Telekom |  |
| 171 | 54.2 | CT1 part - AoC enhancements (Stage 3) | 61d? | 2010-09-17 A | 2010-12-10 | 15% | 51.85d? | 2010-09-17 | 2010-12-10 | 61d? | 425.8d | start no earlier than 2010-09-17 | C1 | 488h | 73.2h | eAoC | PCG-25 | Rel-10 | CP-49 | Frederic | Deutsche Telekom |  |
| 172 | 55 | IMS Stage 3 - IETF Protocol Alignment | 261d? | 2010-03-19 A | 2011-03-18 | 40% | 156.6d? | 2010-03-19 | 2011-03-18 | 261d? | 355.8d | finish no earlier than 2011-03-18 | C1 | 2088h | 835.2h | IMSProtoc4 | PCG-24 | Rel-10 | CP-47 | Frederic | Alcatel-Lucent |  |
| 173 | 56 | Enhanced User Data Convergence (UDC) Model | 206d? | 2010-06-04 A | 2011-03-18 | 5% | 195.7d? | 2010-06-04 | 2011-03-18 | 206d? | 355.8d | finish no earlier than 2011-03-18 | C4 | 1648h | 82.4h | eUDC | PCG-25 | Rel-10 | CP-48 | Kimmo | China Mobile |  |
| 174 | 57 | Further improvements of II-NNI Stage 3 based on operational feedback and evolution of other specifications | 206d? | 2010-06-04 A | 2011-03-18 | 20% | 164.8d? | 2010-06-04 | 2011-03-18 | 206d? | 355.8d | start no earlier than 2010-06-04 | C3 | 1648h | 329.6h | II-NNI2 | PCG-25 | Rel-10 | CP-48 | Gwiho | Orange |  |
| 175 | 58 | AT Commands for IMS-configuration | 206d? | 2010-06-04 A | 2011-03-18 | 60% | 82.4d? | 2010-06-04 | 2011-03-18 | 206d? | 355.8d |  | C1 | 1648h | 988.8h | AT_IMS | PCG-25 | Rel-10 | CP-48 | Frederic | Ericsson |  |
| 176 | 59 | AT Commands for USIM Application Toolkit (USAT) | 131d? | 2010-09-17 A | 2011-03-18 | 60% | 52.4d? | 2010-09-17 | 2011-03-18 | 131d? | 355.8d | finish no earlier than 2011-03-18 | C1 | 1048h | 628.8h | AT_UICC | PCG-25 | Rel-10 | CP-49 | Frederic | ST-Ericsson |  |
| 177 | 60 | Communication Control for IMS by USIM (Stage 3) | 131d? | 2010-09-17 | 2011-03-18 |  |  | 2010-09-17 | 2011-03-18 | 131d? | 355.8d | start no earlier than 2010-09-17 | C6 | 1048h |  | CC_IMS_USIM | PCG-25 | Rel-10 | CP-49 | Xavier | Gemalto |  |
| 178 | 61 | 1.28 Mcps TDD Repeater | 599d? | 2007-12-04 A | 2010-03-19 A | 100% |  | 2007-12-04 | 2010-03-19 | 599d? |  | finish no earlier than 2010-03-19 | R4 | 4792h | 4792h | RANimp-Repeaters1.28TDD | PCG-21 | Rel-10 | RP-38 | Issam | RITT | RP-100039 |
| 179 | 62 | 1.28 Mcps TDD Multi-carrier HSUPA | 321d? | 2009-09-18 A | 2010-12-10 | 75% | 80.25d? | 2009-09-18 | 2010-12-10 | 321d? | 425.8d | finish no earlier than 2010-12-10 | R1,R2,R3,R4 | 2568h | 1926h | TDD_MC_HSUPA | PCG-23 | Rel-10 | RP-45 | Patrick | CATR | RP-100748 |
| 180 | 63 | **1.28 Mcps TDD Home NodeB RF requirements** | 266d? | 2009-12-04 A | 2010-12-10 | 66% | 89.11d? | 2009-12-04 | 2010-12-10 | 266d? | 425.8d |  | R4 | 5304h | 3527.09h | HNB_LCRTDD_RF | PCG-24 | Rel-10 | RP-46 | Issam | TD Tech |  |
| 181 | 63.1 | Core part: 1.28Mcps TDD Home NodeB RF requirements | 131d? | 2009-12-04 A | 2010-06-04 A | 100% |  | 2009-12-04 | 2010-06-04 | 131d? |  | finish no earlier than 2010-12-10 | R4 | 1048h | 1048h | HNB_LCRTDD_RF-Core | PCG-24 | Rel-10 | RP-46 | Issam | TD Tech | RP-100446 |
| 182 | 63.2 | Perf. part: 1.28Mcps TDD Home NodeB RF requirements | 266d? | 2009-12-04 A | 2010-12-10 | 50% | 133d? | 2009-12-04 | 2010-12-10 | 266d? | 425.8d | finish no earlier than 2010-12-10 | R4 | 2128h | 1064h | HNB_LCRTDD_RF-Perf | PCG-24 | Rel-10 | RP-46 | Issam | TD Tech | RP-100750 |
| 183 | 64 | UE Over The Air (Antenna) conformance testing methodology - Laptop mounted equipment Free Space test | 521d? | 2009-09-18 A | 2011-09-16 | 45% | 286.55d? | 2009-09-18 | 2011-09-16 | 521d? | 225.8d | finish no earlier than 2011-09-16 | R4 | 4168h | 1875.6h | UEAnt_FSTest | PCG-23 | Rel-10 | RP-45 | Issam | CATR | RP-100749 |
| 184 | 65 | **AGNSS Minimum Performance for UTRAN** | 391d? | 2009-09-18 A | 2011-03-18 | 77% | 88.33d? | 2009-09-18 | 2011-03-18 | 391d? | 355.8d |  | R4,R5 | 7344h | 5684.98h | AGNSSPerf_UTRAN | PCG-23 | Rel-10 | RP-45 | Issam | Thales |  |
| 185 | 65.1 | AGNSS Minimum Performance Specification Development | 321d? | 2009-09-18 A | 2010-12-10 | 95% | 16.05d? | 2009-09-18 | 2010-12-10 | 321d? | 425.8d | finish no earlier than 2010-12-10 | R4 | 2568h | 2439.6h | AGNSSPerf_UTRAN | PCG-23 | Rel-10 | RP-45 | Issam | Thales | RP-100747 |
| 186 | 65.2 | AGNSS test case development for UMTS | 206d? | 2010-06-04 A | 2011-03-18 | 50% | 103d? | 2010-06-04 | 2011-03-18 | 206d? | 355.8d | finish no earlier than 2011-03-18 | R5 | 1648h | 824h | AGNSSTest_UTRAN | PCG-25 | Rel-10 | RP-48 | Ingbert | Thales | RP-100744 |

Notes:
- 161: umbrella BB
- 162: Stage 3 / Text3: new 32.454 / Text5: Li Jian (lijian@chinamobile.com), Liang Shuangchun (liangshuangchun@cmdi.chinamobile.com)
- 163: Stage 3 / Text3: new 32.455 / Text5: Li Jian (lijian@chinamobile.com), Liang Shuangchun (liangshuangchun@cmdi.chinamobile.com)
- 164: SP#49 updated WID SP-100215=>SP-100612. Stage 2/3. Linked to UID_460003 Minimization of drive tests for E-UTRAN and UTRAN (MDT_UMTSLTE) / Text3: 32.421, 32.422, 32.423, 32.441, 32.442, 32.446 / Text5: Zou Lan (zlan@huawei.com), gyula.bodog@nsn.com, ulf.hubinette@ericsson.com
- 165: Stage 3 / Text3: 32.582, 32.592, new 32.452, 32.453 / Text5: Chen Gang (chengang@chinamobile.com)
- 166: umbrella Feature
- 167: RAT differentiation for charging. Completes Rel-8 Feature IWLAN_Mob UID_370049 Mobility between 3GPP-WLAN Interworking and 3GPP Systems. Cooperation with CT1,CT3 on affected protocols / Text3: 32.240, 32.252, 32.298, 32.299 / Text5: Jean-Luc Garcia (jl.garcia@orange-ftgroup.com)
- 168: Stage 3 (Stage 1 in 22.115). Triggered by Rel-10 TR 32.825 SA5 Study on Rc Reference Point Functionalities and Message Flows (UID_410044) / Text3: 32.296, 32.299 / Text5: shan.mingjun@huawei.com
- 169: Continuation of Rel-8 BB UID_80042: Advice of Charge (AoC) support in IMS Charging (IMSTSS). Stage 2/3 work / Text5: matthias.seibel@telekom.de
- 170: SA1 Stage 1 in 22.115 / Text3: 32.275, 32.280, 32.298, 32.299 / Text5: matthias.seibel@telekom.de
- 171: SA1 Stage 1 in 22.115, 22.173, 22.024. Add mobile-specific CAI format and volume charging elements. Extensions to existing AoC XML / Text3: 24.647 / Text5: reinhard.lauster@t-mobile.at
- 172: Ensure protocol alignment between 3GPP Stage 3 IMS work and IETF. Review capabilities provided in SIP by IETF and document whether these capabilities are supported in the IM CN Subsystem or not / Text3: 23.218, 24.229, 24.930 / Text5: keith.drage@alcatel-lucent.com
- 173: To specify the CRUD (Create/Read/Update/Delete) operations based on SOAP protocol, which may be used by the applications having no high real-time requirement to the data access operations / Text3: 29.335 / Text5: Lan Sizhong (lansizhong@chinamobile.com)
- 174: Improvements of Rel-9 Feature UID_440027 Operational description of the Inter-IMS Network to Network Interface (II-NNI) / Text3: 29.165 / Text5: beata.dobrowolska@orange-ftgroup.com
- 175: Specify 1) IMS-related AT-commands to configure MT and 2) IMS-related unsolicited response codes from MT to present to end-user / Text3: 27.007 / Text5: atle.monrad@ericsson.com
- 176: - / Text3: 27.007 / Text5: Magnus Karlsson
- 177: Stage 1 in TS 22.038 USAT service description. Linked to CT6's UID_1273 Rel-5 BB Provisioning of IP-based multimedia services (24.229, 31.103) and UID_390021 Rel-8 BB CT6 aspects of SAE (31.102, 31.111) / Text3: 31.102, 31.103, 31.111 / Text5: Denis L'Heriteau (Denis.Lheriteau@gemalto.com)
- 178: RP#47 completed / Text3: UTRA 25.113, new 25.116, 25.153 (testing) / Text5: qinyan@chinattl.com
- 179: - / Text3: UTRA 25.102, 25.105, 25.123, 25.221, 25.222, 25.223, 25.224, 25.225, 25.306, 25.319, 25.321, 25.331, 25.423, 25.427, 25.433 / Text5: Aihui Song (songaihui@mail.ritt.com.cn)
- 180: RP#48 Core completed. Triggered by FS_RAN-HNBLCRTDD UID_410016 Study on 1.28 Mcps TDD Home NodeB (TR 25.866) / Text3: UTRA / Text5: Li Rong (lirong@td-tech.com)
- 181: RP#48 completed / Text3: 25.105 / Text5: Li Rong (lirong@td-tech.com)
- 182: RP#48 updated WID RP-091435=>RP-100607 / Text3: 25.142, new TR 25.968 / Text5: Li Rong (lirong@td-tech.com)
- 183: - / Text3: UTRA 25.144, 25.914, 34.114 / Text5: Guo Lin (guolin@emcite.com)
- 184: Triggered by Rel-7 UID_20050 (GNSS in UTRAN) and Rel-8 UID_400051 (Support for Additional NSS). Linked to GERAN Rel-9 UID_38002 (A-GNSS Performances and Testing Procedures) / Text3: UTRA / Text5: Michel.monnerat@thalesaleniaspace.com
- 185: RP#49 completion 09/10=>12/10 / Text3: new 25.172 / Text5: Michel.monnerat@thalesaleniaspace.com
- 186: - / Text3: 34.108, 34.109,34.123-1, 34.123-2, 34.123-3, new 34.172, TS 36.xy (Conformance specification; Location Services (LCS) test scenarios and assistance) / Text5: Michel.monnerat@thalesaleniaspace.com

| ID | WBS | Task | Duration | Start | Finish | Complete | Remaining | Baseline start | Baseline finish | Baseline duration | Total slack | Constraint | Resources | Work | Actual work | Text1 | Text2 | Text4 | Text5 | Text6 | Text7 | Text8 | Text11 | Text9 | Text12 |
| --- | --- | --- | --- | --- | --- | --- | --- | --- | --- | --- | --- | --- | --- | --- | --- | --- | --- | --- | --- | --- | --- | --- | --- | --- | --- |
| 187 | 66 | **Inclusion of "RF Pattern Matching Technologies" as positioning method in the UTRAN** | 266d? | 2009-12-04 A | 2010-12-10 | 70% | 79.8d? | 2009-12-04 | 2010-12-10 | 266d? | 425.8d |  | R2,R3 | 4256h | 2979.2h | LCS_UMTS_RFPMT | PCG-24 | Polaris Wireless | Norman Shaw (nshaw@polariswireless.com) | Rel-10 | RP-46 | Joern | RP-100753 |  |  |
| 188 | 66.1 | Core part: Inclusion of RF Pattern Matching Technologies as positioning method in the UTRAN | 266d? | 2009-12-04 A | 2010-12-10 | 70% | 79.8d? | 2009-12-04 | 2010-12-10 | 266d? | 425.8d | finish no earlier than 2010-12-10 | R2,R3 | 2128h | 1489.6h | LCS_UMTS_RFPMT-Core | PCG-24 | Polaris Wireless | Norman Shaw (nshaw@polariswireless.com) | Rel-10 | RP-46 | Joern | RP-100753 |  |  |
| 189 | 67 | **Four carrier HSDPA** | 401d? | 2009-12-04 A | 2011-06-17 | 38% | 248.96d? | 2009-12-04 | 2011-06-17 | 401d? | 290.8d |  | R1,R2,R3,R4 | 8544h | 3239.55h | 4C_HSDPA | PCG-24 | Qualcomm | Arjun Bharadwaj (arjunb@qualcomm.com) | Rel-10 | RP-46 | Patrick |  |  |  |
| 190 | 67.1 | Core part: Four carrier HSDPA | 266d? | 2009-12-04 A | 2010-12-10 | 80% | 53.2d? | 2009-12-04 | 2010-12-10 | 266d? | 425.8d | finish no earlier than 2010-12-10 | R1,R2,R3,R4 | 2128h | 1702.4h | 4C_HSDPA-Core | PCG-24 | Qualcomm | Arjun Bharadwaj (arjunb@qualcomm.com) | Rel-10 | RP-46 | Patrick | RP-100751 |  |  |
| 191 | 67.2 | Perf. part: Four carrier HSDPA | 401d? | 2009-12-04 A | 2011-06-17 | 10% | 360.9d? | 2009-12-04 | 2011-06-17 | 401d? | 290.8d | finish no earlier than 2011-06-17 | R4 | 3208h | 320.8h | 4C_HSDPA-Perf | PCG-24 | Qualcomm | Arjun Bharadwaj (arjunb@qualcomm.com) | Rel-10 | RP-46 | Issam | RP-100752 |  |  |
| 192 | 68 | **Multi-User Multiple-Input and Multiple-Output (MU-MIMO) for 1.28Mcps TDD** | 261d? | 2010-03-19 A | 2011-03-18 | 30% | 183.8d? | 2010-03-19 | 2011-03-18 | 261d? | 355.8d |  | R1,R2,R3,R4 | 5704h | 1687.22h | MUMIMO_LCR_TDD | PCG-24 | CATT | Yanping Xing (xingyanping@datangmobile.cn) | Rel-10 | RP-47 | Patrick |  |  |  |
| 193 | 68.1 | Core part: MU-MIMO for 1.28Mcps TDD | 191d? | 2010-03-19 A | 2010-12-10 | 70% | 57.3d? | 2010-03-19 | 2010-12-10 | 191d? | 425.8d | finish no earlier than 2010-12-10 | R1,R2,R3 | 1528h | 1069.6h | MUMIMO_LCR_TDD-Core | PCG-24 | CATT | Yanping Xing (xingyanping@datangmobile.cn) | Rel-10 | RP-47 | Patrick | RP-100755 |  |  |
| 194 | 68.2 | Perf. part: MU-MIMO for 1.28Mcps TDD | 261d? | 2010-03-19 | 2011-03-18 |  |  | 2010-03-19 | 2011-03-18 | 261d? | 355.8d | finish no earlier than 2011-03-18 | R4 | 2088h |  | MUMIMO_LCR_TDD-Perf | PCG-24 | CATT | Sanjun Feng (fengsanjun@datangmobile.cn) | Rel-10 | RP-47 | Issam | RP-100756 |  |  |
| 195 | 69 | **Performance Requirements for two-antenna 1.28Mcps TDD Type 1 and Type 2 UE receiver** | 191d? | 2010-03-19 A | 2010-12-10 | 57% | 81.23d? | 2010-03-19 | 2010-12-10 | 191d? | 425.8d |  | R4 | 3504h | 2013.73h | 2ant_UE_LCR_TDD | PCG-24 | TD Tech | dafei.wang@td-tech.com | Rel-10 | RP-47 | Issam |  |  |  |
| 196 | 69.1 | Core part: Performance Requirements for two-antenna 1.28Mcps TDD Type 1 and Type 2 UE receiver | 56d? | 2010-03-19 A | 2010-06-04 A | 100% |  | 2010-03-19 | 2010-06-04 | 56d? |  | finish no earlier than 2010-06-04 | R4 | 448h | 448h | 2ant_UE_LCR_TDD-Core | PCG-24 | TD Tech | dafei.wang@td-tech.com | Rel-10 | RP-47 | Issam | RP-100454 |  |  |
| 197 | 69.2 | Perf. part: Performance Requirements for two-antenna 1.28Mcps TDD Type 1 and Type 2 UE receiver | 191d? | 2010-03-19 A | 2010-12-10 | 45% | 105.05d? | 2010-03-19 | 2010-12-10 | 191d? | 425.8d | finish no earlier than 2010-12-10 | R4 | 1528h | 687.6h | 2ant_UE_LCR_TDD-Perf | PCG-24 | TD Tech | dafei.wang@td-tech.com | Rel-10 | RP-47 | Issam | RP-100757 |  |  |
| 198 | 70 | **Automatic Neighbour Relation (ANR) for UTRAN** | 136d? | 2010-06-04 A | 2010-12-10 | 8% | 125.12d? | 2010-06-04 | 2010-12-10 | 136d? | 425.8d |  | R3,R2 | 2176h | 174.07h | ANR_UTRAN | PCG-25 | ZTE | Zhai hengxing | Rel-10 | RP-48 | Juha |  |  |  |
| 199 | 70.1 | Core part: Automatic Neighbour Relation (ANR) for UTRAN | 136d? | 2010-06-04 A | 2010-12-10 | 8% | 125.12d? | 2010-06-04 | 2010-12-10 | 136d? | 425.8d | finish no earlier than 2010-12-10 | R3,R2 | 1088h | 87.03h | ANR_UTRAN-Core | PCG-25 | ZTE | Zhai hengxing | Rel-10 | RP-48 | Juha | RP-100761 |  |  |
| 200 | 71 | **Support of New Band Combinations for Dual-Band Dual Cell HSDPA** | 206d? | 2010-06-04 A | 2011-03-18 | 31% | 142.99d? | 2010-06-04 | 2011-03-18 | 206d? | 355.8d |  | R4,R2 | 3904.02h | 1194.05h | DB_DC_HSDPA | PCG-25 | AT&T | Vince Spatafora (vs5785@att.com) | Rel-10 | RP-48 | Issam |  |  |  |
| 201 | 71.1 | Core part: Support of New Band Combinations for Dual-Band Dual Cell HSDPA | 206d? | 2010-06-04 A | 2011-03-18 | 5% | 195.75d? | 2010-06-04 | 2011-03-18 | 206d? | 355.8d | finish no earlier than 2011-03-18 | R4,R2 | 1648h | 82h | DB_DC_HSDPA-Core | PCG-25 | AT&T | Vince Spatafora (vs5785@att.com) | Rel-10 | RP-48 | Issam | RP-100758 |  |  |
| 202 | 71.2 | Deleted - Perf. part: Support of New Band Combinations for Dual-Band Dual Cell HSDPA | 76d? | 2010-06-04 A | 2010-09-17 A | 100% |  | 2010-06-04 | 2010-09-17 | 76d? |  | finish no earlier than 2010-09-17 | R4,R2 | 608h | 608h | DB_DC_HSDPA-Perf | PCG-25 | AT&T | Vince Spatafora (vs5785@att.com) | Rel-10 | RP-48 | Issam | RP-100759 | PCG-25 | RP-49 |
| 203 | 72 | **MIMO operation with non-MIMO coexistence in HSDPA** | 271d? | 2010-06-04 A | 2011-06-17 | 13% | 234.46d? | 2010-06-04 | 2011-06-17 | 271d? | 290.8d |  | R4 | 5384h | 725.9h | MIMO_HSDPA | PCG-25 | Qualcomm | Heechoon Lee | Rel-10 | RP-48 | Issam |  |  |  |
| 204 | 72.1 | Core part: MIMO operation with non-MIMO coexistence in HSDPA | 131d? | 2010-09-17 | 2011-03-18 |  |  | 2010-09-17 | 2011-03-18 | 131d? | 355.8d | finish no earlier than 2011-03-18 | R4 | 1048h |  | MIMO_HSDPA-Core | PCG-25 | Qualcomm | Heechoon Lee | Rel-10 | RP-49 | Issam |  |  |  |
| 205 | 72.2 | Perf. part: MIMO operation with non-MIMO coexistence in HSDPA | 271d? | 2010-06-04 A | 2011-06-17 | 20% | 216.8d? | 2010-06-04 | 2011-06-17 | 271d? | 290.8d | finish no earlier than 2011-06-17 | R4 | 2168h | 433.6h | MIMO_HSDPA-Perf | PCG-25 | Qualcomm | Heechoon Lee | Rel-10 | RP-48 | Issam | RP-100760 |  |  |
| 206 | 73 | Interfrequency detected set measurements for UMTS | 61d? | 2010-09-17 | 2010-12-10 |  |  | 2010-09-17 | 2010-12-10 | 61d? | 425.8d | finish no earlier than 2010-12-10 | R2,R4 | 488h |  | Interf_dset_meas_UMTS | PCG-25 | Nokia | Chris Callender | Rel-10 | RP-49 | Joern |  |  |  |
| 207 | 74 | Network-Based Positioning Support in LTE | 531d? | 2009-03-09 A | 2011-03-18 | 30% | 371.7d? | 2009-03-09 | 2011-03-18 | 531d? | 355.8d | finish no earlier than 2011-03-18 | R2,R3,R4 | 4248h | 1274.4h | LCS_LTE-NBPS | PCG-22 | TruePosition | terri.brooks@trueposition.com | Rel-10 | RP-43 | Joern | RP-100769 |  |  |
| 208 | 75 | **Carrier Aggregation for LTE** | 400d? | 2009-12-04 A | 2011-06-16 | 31% | 276.16d? | 2009-12-04 | 2011-06-16 | 400d? | 291.8d |  | R1,R2,R3,R4 | 8528h | 2640.35h | LTE_CA | PCG-24 | Nokia | Asbjorn.grovlen@nokia.com | Rel-10 | RP-46 | Patrick |  |  |  |
| 209 | 75.1 | Core part: Carrier Aggregation for LTE | 266d? | 2009-12-04 A | 2010-12-10 | 70% | 79.8d? | 2009-12-04 | 2010-12-10 | 266d? | 425.8d | finish no earlier than 2010-12-10 | R1,R2,R3,R4 | 2128h | 1489.6h | LTE_CA-Core | PCG-24 | Nokia | Asbjorn.grovlen@nokia.com | Rel-10 | RP-46 | Patrick | RP-100775 |  |  |
| 210 | 75.2 | Perf. part: Carrier Aggregation for LTE | 400d? | 2009-12-04 A | 2011-06-16 | 5% | 380d? | 2009-12-04 | 2011-06-16 | 400d? | 291.8d | finish no earlier than 2011-06-16 | R4 | 3200h | 160h | LTE_CA-Perf | PCG-24 | Nokia | Asbjorn.grovlen@nokia.com | Rel-10 | RP-46 | Issam | RP-100776 |  |  |

Notes:
- 187: RP#48 completion 06/10=>12/10. Triggered by Study UID_380079 Evaluation of the inclusion of Path Loss Based Technology in the UTRAN (25.907) / Text3: UTRA
- 188: RP#48 completion 06/10=>12/10 / Text3: 25.305, 25.453
- 189: RP#49 updated WID RP-091438=>RP-100991 (Core only) / Text3: UTRA
- 190: RP#49 updated WID RP-091438=>RP-100891 (Core only - added new TR 25.864) / Text3: 25.101, 25.104, 25.133, 25.211, 25.212, 25.213, 25.214, 25.215, 25.308, 25.331, 25.423, 25.433, 26.306, new TR 25.864
- 191: RP#49 updated WID RP-091438=>RP-100991 (Core only) / Text3: 25.101, 25.104, 25.133, 25.141
- 192: - / Text3: UTRA
- 193: - / Text3: 25.221, 25.222, 25.224, 25.306, 25.308, 25.319, 25.331, 25.423, 25.425, 25.433, 25.435
- 194: - / Text3: 25.102, 25.105, 25.142
- 195: Stage 3. RP#48 Core completed / Text3: UTRA
- 196: RP#48 completed / Text3: 25.102
- 197: - / Text3: 25.102
- 198: Automatic Neighbour Relation (ANR) function for UTRAN relieves operators from the burden of manually managing the Neighbour cell Relations (NRs) / Text3: UTRA
- 199: - / Text3: 25.331, 25.413, 25.423, new TS 25.4xy Automatic Neighbour Relation (ANR) for UTRAN; Stage 2
- 200: Rel-9 Dual-Band Dual-Cell HSDPA (UID_430015 Support for different bands for Dual-Cell HSDPA) has one combination per region in principle. This work adds additional combinations: Band I and XI (Region 3) and Band II and V (Region 2) / Text3: UTRA
- 201: - / Text3: 25.101, 25.104, 25.141, 25.317
- 202: RP#49 stopped (Reason: no need for Perforance work) / Text3: 25.101, 25.104, 25.141, 25.317
- 203: RP#49 updated WID RP-100687=>RP-100993 (added Core WID, changed WID: Title MIMO Testing in HSDPA => MIMO operation with non-MIMO coexistence in HSDPA) / Text3: UTRA
- 204: RP#49 added Core WID / Text3: 25.104
- 205: RP#49 updated WID RP-100687=>RP-100993 (added Core WID, changed WID: Title MIMO Testing in HSDPA => MIMO operation with non-MIMO coexistence in HSDPA) / Text3: 25.101, 25.141
- 206: UTRA / Text3: UTRA 25.133, 25.331
- 207: RP#49 completion 12/10=>03/11 / Text3: LTE 36.300, 36.331, 36.355, 36.413, new R4 36.xxx (Performance Requirements for LMU)
- 208: RP#48 updated WID RP-091440=>RP-100661. Triggered by FS_RAN_LTEA (Study on LTE-Advanced) 36.912, 36. 814 / Text3: LTE
- 209: RP#48 updated WID RP-091440=>RP-100661 / Text3: 36.101, 36.104, 36.133, 36.211, 36.212, 36.213, 36.300, 36.302, 36.306, 36.321, 36.331, 36.413, 36.423, 37.104
- 210: RP#48 updated WID RP-091440=>RP-100661 / Text3: 36.101, 36.104, 36.133, 36.141, 37.141, new TR (36.807, 36.808)

| ID | WBS | Task | Duration | Start | Finish | Complete | Remaining | Baseline start | Baseline finish | Baseline duration | Total slack | Constraint | Resources | Work | Actual work | Text1 | Text2 | Text4 | Text5 | Text6 | Text7 | Text8 | Text11 |
| --- | --- | --- | --- | --- | --- | --- | --- | --- | --- | --- | --- | --- | --- | --- | --- | --- | --- | --- | --- | --- | --- | --- | --- |
| 211 | 76 | **Enhanced Downlink Multiple Antenna Transmission for LTE** | 400d? | 2009-12-04 A | 2011-06-16 | 32% | 272.19d? | 2009-12-04 | 2011-06-16 | 400d? | 291.8d |  | R1,R2,R4 | 8528h | 2724.86h | LTE_eDL_MIMO | PCG-24 | NTT DoCoMo | Hidekazu Taoka (taoka@nttdocomo.com) | Rel-10 | RP-46 | Patrick |  |
| 212 | 76.1 | Core part: Enhanced Downlink Multiple Antenna Transmission for LTE | 266d? | 2009-12-04 A | 2010-12-10 | 80% | 53.2d? | 2009-12-04 | 2010-12-10 | 266d? | 425.8d | finish no earlier than 2010-12-10 | R1,R2,R4 | 2128h | 1702.4h | LTE_eDL_MIMO-Core | PCG-24 | NTT DoCoMo | Hidekazu Taoka (taoka@nttdocomo.com) | Rel-10 | RP-46 | Patrick | RP-100771 |
| 213 | 76.2 | Perf. part: Enhanced Downlink Multiple Antenna Transmission for LTE | 400d? | 2009-12-04 | 2011-06-16 |  |  | 2009-12-04 | 2011-06-16 | 400d? | 291.8d | finish no earlier than 2011-06-16 | R4 | 3200h |  | LTE_eDL_MIMO-Perf | PCG-24 | NTT DoCoMo | Hidekazu Taoka (taoka@nttdocomo.com) | Rel-10 | RP-46 | Issam | RP-100772 |
| 214 | 77 | **Uplink Multiple Antenna Transmission for LTE** | 400d? | 2009-12-04 A | 2011-06-16 | 34% | 264.14d? | 2009-12-04 | 2011-06-16 | 400d? | 291.8d |  | R1,R2,R4 | 8528h | 2896.45h | LTE_UL_MIMO | PCG-24 | Huawei | Mattias.wennstrom@huawei.com | Rel-10 | RP-46 | Patrick |  |
| 215 | 77.1 | Core part: UL multiple antenna transmission for LTE | 266d? | 2009-12-04 A | 2010-12-10 | 70% | 79.8d? | 2009-12-04 | 2010-12-10 | 266d? | 425.8d | finish no earlier than 2010-12-10 | R1,R2,R4 | 2128h | 1489.6h | LTE_UL_MIMO-Core | PCG-24 | Huawei | Mattias.wennstrom@huawei.com | Rel-10 | RP-46 | Patrick | RP-100773 |
| 216 | 77.2 | Perf. part: UL multiple antenna transmission for LTE | 400d? | 2009-12-04 A | 2011-06-16 | 10% | 360d? | 2009-12-04 | 2011-06-16 | 400d? | 291.8d | finish no earlier than 2011-06-16 | R4 | 3200h | 320h | LTE_UL_MIMO-Perf | PCG-24 | Huawei | Mattias.wennstrom@huawei.com | Rel-10 | RP-46 | Issam | RP-100774 |
| 217 | 78 | **Fixed Wireless Customer-Premises Equipment (CPE) RF Requirements** | 401d? | 2009-12-04 A | 2011-06-17 | 18% | 327.87d? | 2009-12-04 | 2011-06-17 | 401d? | 290.8d |  | R4,R5 | 9104h | 1660.21h | FW_CPE_RF | PCG-24 | Verizon Wireless | zheng.zhao@verizonwireless.com | Rel-10 | RP-46 | Issam |  |
| 218 | 78.1 | Core part: Fixed Wireless Customer-Premises Equipment (CPE) RF Requirements | 336d? | 2009-12-04 A | 2011-03-18 | 40% | 201.6d? | 2009-12-04 | 2011-03-18 | 336d? | 355.8d | finish no earlier than 2011-03-18 | R4 | 2688h | 1075.2h | FW_CPE_RF-Core | PCG-24 | Verizon Wireless | zheng.zhao@verizonwireless.com | Rel-10 | RP-46 | Issam | RP-100770 |
| 219 | 78.2 | Test part: Fixed Wireless Customer-Premises Equipment (CPE) RF Requirements | 401d? | 2009-12-04 | 2011-06-17 |  |  | 2009-12-04 | 2011-06-17 | 401d? | 290.8d | finish no earlier than 2011-06-17 | R5 | 3208h |  | FW_CPE_RF-UEConTest | PCG-24 | Verizon Wireless | zheng.zhao@verizonwireless.com | Rel-10 | RP-46 | Ingbert | RP-100741 |
| 220 | 79 | **Latency reductions for LTE** | 266d? | 2009-12-04 A | 2010-12-10 | 20% | 212.8d? | 2009-12-04 | 2010-12-10 | 266d? | 425.8d |  | R2,R1 | 4256h | 851.2h | LTE_LATRED | PCG-24 | Ericsson | henrik.enbuske@ericsson.com | Rel-10 | RP-46 | Joern |  |
| 221 | 79.1 | Core part: Latency reductions for LTE | 266d? | 2009-12-04 A | 2010-12-10 | 20% | 212.8d? | 2009-12-04 | 2010-12-10 | 266d? | 425.8d | finish no earlier than 2010-12-10 | R2,R1 | 2128h | 425.6h | LTE_LATRED-Core | PCG-24 | Ericsson | henrik.enbuske@ericsson.com | Rel-10 | RP-46 | Joern | RP-100779 |
| 222 | 80 | **Relays for LTE** | 336d? | 2009-12-04 A | 2011-03-18 | 22% | 261.77d? | 2009-12-04 | 2011-03-18 | 336d? | 355.8d |  | R1,R2,R4 | 7504h | 1657.86h | LTE_Relay | PCG-24 | Ericsson | christian.hoymann@ericsson.com | Rel-10 | RP-46 | Patrick |  |
| 223 | 80.1 | Core part: Relays for LTE | 266d? | 2009-12-04 A | 2010-12-10 | 50% | 133d? | 2009-12-04 | 2010-12-10 | 266d? | 425.8d | finish no earlier than 2010-12-10 | R1,R2,R4 | 2128h | 1064h | LTE_Relay-Core | PCG-24 | Ericsson | christian.hoymann@ericsson.com | Rel-10 | RP-46 | Patrick | RP-100952 |
| 224 | 80.2 | Perf. part: Relays for LTE | 336d? | 2009-12-04 | 2011-03-18 |  |  | 2009-12-04 | 2011-03-18 | 336d? | 355.8d | finish no earlier than 2011-03-18 | R4 | 2688h |  | LTE_Relay-Perf | PCG-24 | Ericsson | christian.hoymann@ericsson.com | Rel-10 | RP-46 | Issam | RP-100778 |
| 225 | 81 | **Enhanced Inter-Cell Interference Control (ICIC) for non-Carrier Aggregation (CA) based deployments of heterogeneous networks for LTE** | 326d? | 2010-03-19 A | 2011-06-17 | 21% | 258.97d? | 2010-03-19 | 2011-06-17 | 326d? | 290.8d |  | R1,R2,R3,R4 | 7304h | 1501.86h | ECIC_LTE | PCG-24 | China Mobile | Xiaodong XU (xuxiaodong@chinamobile.com) | Rel-10 | RP-47 | Patrick |  |
| 226 | 81.1 | Core part: Enhanced ICIC for non-CA based deployments of heterogeneous networks for LTE | 261d? | 2010-03-19 A | 2011-03-18 | 40% | 156.6d? | 2010-03-19 | 2011-03-18 | 261d? | 355.8d | finish no earlier than 2011-03-18 | R1,R2,R3,R4 | 2088h | 835.2h | ECIC_LTE-Core | PCG-24 | China Mobile | Xiaodong XU (xuxiaodong@chinamobile.com) | Rel-10 | RP-47 | Patrick | RP-100968 |
| 227 | 81.2 | Perf. part: Enhanced ICIC for non-CA based deployments of heterogeneous networks for LTE | 326d? | 2010-03-19 A | 2011-06-17 | 5% | 309.7d? | 2010-03-19 | 2011-06-17 | 326d? | 290.8d | finish no earlier than 2011-06-17 | R4 | 2608h | 130.4h | ECIC_LTE-Perf | PCG-24 | China Mobile | Xiaodong XU (xuxiaodong@chinamobile.com) | Rel-10 | RP-47 | Issam | RP-100781 |
| 228 | 82 | **LTE TDD in 2600MHz for US** | 261d? | 2010-03-19 A | 2011-03-18 | 58% | 109.14d? | 2010-03-19 | 2011-03-18 | 261d? | 355.8d |  | R4,R2,R3,R5 | 5832h | 2178.4h | LTE_TDD_2600_US | PCG-24 | Clearwire | michael.hart@clearwire.com | Rel-10 | RP-47 | Issam |  |
| 229 | 82.1 | Core part: LTE TDD in 2600MHz for US | 131d? | 2010-03-19 A | 2010-09-17 A | 100% |  | 2010-03-19 | 2010-09-17 | 131d? |  | finish no earlier than 2010-09-17 | R4,R2,R3 | 1048h | 1048h | LTE_TDD_2600_US-Core | PCG-24 | Clearwire | michael.hart@clearwire.com | Rel-10 | RP-47 | Issam | RP-100782 |
| 230 | 82.2 | Perf. part: LTE TDD in 2600MHz for US | 131d? | 2010-03-19 A | 2010-09-17 A | 100% |  | 2010-03-19 | 2010-09-17 | 131d? |  | finish no earlier than 2010-09-17 | R4 | 1048h | 1048h | LTE_TDD_2600_US-Perf | PCG-24 | Clearwire | michael.hart@clearwire.com | Rel-10 | RP-47 | Issam | RP-100783 |
| 231 | 82.3 | UE conformance test part: LTE TDD in 2600MHz for US | 206d? | 2010-06-04 A | 2011-03-18 | 5% | 195.7d? | 2010-06-04 | 2011-03-18 | 206d? | 355.8d | finish no earlier than 2011-03-18 | R5 | 1648h | 82.4h | LTE_TDD_2600_US-UEConTest | PCG-25 | Clearwire | michael.hart@clearwire.com | Rel-10 | RP-48 | Ingbert | RP-100745 |
| 232 | 83 | **Adding 2 GHz band LTE for Ancillary Terrestrial Component (ATC) of Mobile Satellite Service (MSS) in North America** | 326d? | 2010-03-19 A | 2011-06-17 | 28% | 233.18d? | 2010-03-19 | 2011-06-17 | 326d? | 290.8d |  | R4,R2 | 6744h | 1920.15h | S_Band_LTE_ATC_MSS | PCG-24 | TerreStar | Eric.Jacks@skyterra.com, Maqbool.Aliani@skyterra.com | Rel-10 | RP-47 | Issam |  |
| 233 | 83.1 | Core part: Adding 2 GHz band LTE for ATC of MSS in North America | 191d? | 2010-03-19 A | 2010-12-10 | 60% | 76.4d? | 2010-03-19 | 2010-12-10 | 191d? | 425.8d | finish no earlier than 2010-12-10 | R4,R2 | 1528h | 916.8h | S_Band_LTE_ATC_MSS-Core | PCG-24 | TerreStar | Rhys.Robinson@terrestar.com | Rel-10 | RP-47 | Issam | RP-100784 |
| 234 | 83.2 | Perf. part: Adding 2 GHz band LTE for ATC of MSS in North America | 326d? | 2010-03-19 A | 2011-06-17 | 10% | 293.4d? | 2010-03-19 | 2011-06-17 | 326d? | 290.8d | finish no earlier than 2011-06-17 | R4 | 2608h | 260.8h | S_Band_LTE_ATC_MSS-Perf | PCG-24 | TerreStar | Rhys.Robinson@terrestar.com | Rel-10 | RP-47 | Issam | RP-100785 |

Notes:
- 211: Triggered by FS_RAN_LTEA (Study on LTE-Advanced) 36.912, 36. 814 / Text3: LTE
- 212: - / Text3: 36.101, 36.104, 36.133, 36.201, 36.211, 36.212, 36.213, 36.300, 36.306, 36.321, 36.331
- 213: - / Text3: 36.101, 36.104, 36.133, 36.141
- 214: RP#49 updated WID RP-091430=>RP-100959 (added new RAN4 TR 36.817). Triggered by FS_RAN_LTEA (Study on LTE-Advanced) 36.912, 36. 814 / Text3: LTE
- 215: RP#49 updated WID RP-091430=>RP-100959 (added new RAN4 TR 36.817) / Text3: 36.101, 36.104, 36.133, 36.201, 36.211, 36.212, 36.213, 36.300, 36.306, 36.321, 36.331, new RAN4 TR 36.817
- 216: RP#49 updated WID RP-091430=>RP-100959 (added impacted RAN4 TR 36.817) / Text3: 36.101, 36.104, 36.133, 36.141, 36.817
- 217: Add new power classes in E-UTRAN UL to allow CPE type applications to be operated at higher max output power / Text3: LTE
- 218: RP#49 completion 09/10=>03/11 / Text3: 36.101
- 219: RP#49 completion 12/10=>06/11 / Text3: 36.521-1
- 220: Triggered by FS_RAN_LTEA (Study on LTE-Advanced) 36.912, 36. 814 / Text3: LTE
- 221: RP#49 on hold until 12/10 / Text3: 36.213, 36.300, 36.306, 36.321, 36.331
- 222: RP#49 updated WID RP-091434=>RP-100953 (added new TS 36.216 to Core part only). Triggered by FS_RAN_LTEA (Study on LTE-Advanced) 36.912, 36. 814 / Text3: LTE
- 223: RP#49 updated WID RP-091434=>RP-100953 (added new TS 36.216). TS 36.216v100 for Approval. / Text3: 36.133, 36.201, 36.211, 36.212, 36.213, 36.300, 36.321, 36.323, 36.331, new TS 36.216
- 224: RP#49 updated WID RP-091434=>RP-100953 (Core part only) / Text3: 36.133
- 225: Stage 3 Triggered by FS_RAN_LTEA (Study on LTE-Advanced) 36.912, 36.814 / Text3: LTE
- 226: RP#49 completion 12/10=>03/11 / Text3: 36.101, 36.133, 36.201, 36.211, 36.212, 36.213, 36.214, 36.300, 36.321, 36.331, 36.413, 36.423
- 227: - / Text3: 36.101, 36.133
- 228: RP#49 Core+Perf completed. Stage 3. Updated WID RP-100694=>RP-101003 / Text3: LTE
- 229: RP#49 completed (TR 36.812 v1.0.0 for Approval). Updated WID RP-100694=>RP-101003 / Text3: 25.461, 25.466, 36.101, 36.104, 36.113, 36.124, 36.133, 36.141, 36.307, 36.331, 37.104, 37.113, 37.141, new TR 36.812
- 230: RP#49 completed (TR 36.812 v1.0.0 for Approval). Updated WID RP-100694=>RP-101003 / Text3: 36.101, 36.104, 36.133, 36.141, 36.307, 37.104, 37.141, new TR 36.812
- 231: - / Text3: 36.508, 36.521-1, 36.521-2, 36.521-3, 36.523-1, 36.523-2, 36.523-3
- 232: Stage 3 / Text3: LTE
- 233: RP#49 TR 36.811v100 for information / Text3: 25.461, 25.466, 36.101, 36.104, 36.113, 36.124, 36.133, new TR 36.811
- 234: - / Text3: 36.101, 36.104, 36.113, 36.124, 36.133, 36.141

| ID | WBS | Task | Duration | Start | Finish | Complete | Remaining | Baseline start | Baseline finish | Baseline duration | Total slack | Constraint | Resources | Work | Actual work | Text1 | Text2 | Text4 | Text5 | Text6 | Text7 | Text8 | Text11 |
| --- | --- | --- | --- | --- | --- | --- | --- | --- | --- | --- | --- | --- | --- | --- | --- | --- | --- | --- | --- | --- | --- | --- | --- |
| 235 | 84 | **Adding L-Band LTE for Ancillary Terrestrial Component (ATC) of Mobile Satellite Service (MSS) in North America** | 326d? | 2010-03-19 A | 2011-06-17 | 28% | 233.18d? | 2010-03-19 | 2011-06-17 | 326d? | 290.8d |  | R4,R2 | 6744h | 1920.15h | L_Band_LTE_ATC_MSS | PCG-24 | LightSquared | Eric.Jacks@lightsquared.com, Maqbool.Aliani@lightsquared.com | Rel-10 | RP-47 | Issam |  |
| 236 | 84.1 | Core part: Adding L-Band LTE for ATC of MSS in North America | 191d? | 2010-03-19 A | 2010-12-10 | 60% | 76.4d? | 2010-03-19 | 2010-12-10 | 191d? | 425.8d | finish no earlier than 2010-12-10 | R4,R2 | 1528h | 916.8h | L_Band_LTE_ATC_MSS-Core | PCG-24 | LightSquared | Eric.Jacks@lightsquared.com, Maqbool.Aliani@lightsquared.com | Rel-10 | RP-47 | Issam | RP-100786 |
| 237 | 84.2 | Perf. part: Adding L-Band LTE for ATC of MSS in North America | 326d? | 2010-03-19 A | 2011-06-17 | 10% | 293.4d? | 2010-03-19 | 2011-06-17 | 326d? | 290.8d | finish no earlier than 2011-06-17 | R4 | 2608h | 260.8h | L_Band_LTE_ATC_MSS-Perf | PCG-24 | LightSquared | Eric.Jacks@lightsquared.com, Maqbool.Aliani@lightsquared.com | Rel-10 | RP-47 | Issam | RP-100787 |
| 238 | 85 | **LTE Self Optimizing Networks (SON) enhancements** | 191d? | 2010-03-19 A | 2010-12-10 | 25% | 143.25d? | 2010-03-19 | 2010-12-10 | 191d? | 425.8d |  | R3,R2,R4 | 3056h | 764h | SONenh_LTE | PCG-24 | Nokia Siemens Networks | krzysztof.kordybach@nsn.com | Rel-10 | RP-47 | Juha |  |
| 239 | 85.1 | Core part: LTE Self Optimizing Networks (SON) enhancements | 191d? | 2010-03-19 A | 2010-12-10 | 25% | 143.25d? | 2010-03-19 | 2010-12-10 | 191d? | 425.8d | finish no earlier than 2010-12-10 | R3,R2,R4 | 1528h | 382h | SONenh_LTE-Core | PCG-24 | Nokia Siemens Networks | krzysztof.kordybach@nsn.com | Rel-10 | RP-47 | Juha | RP-100788 |
| 240 | 86 | **LTE-Advanced Carrier Aggregation of Band 3 and Band 7** | 266d? | 2010-12-10 | 2011-12-16 |  |  | 2010-12-10 | 2011-12-16 | 266d? | 160.8d |  | R4 | 6384h |  | LTE_CA_B3_B7 | PCG-25 | TeliaSonera | Ralf.Schuh@TeliaSonera.com | Rel-10 | RP-48 | Issam |  |
| 241 | 86.1 | Core part: LTE-Advanced Carrier Aggregation of Band 3 and Band 7 | 266d? | 2010-12-10 | 2011-12-16 |  |  | 2010-12-10 | 2011-12-16 | 266d? | 160.8d | start no earlier than 2010-12-10 | R4 | 2128h |  | LTE_CA_B3_B7-Core | PCG-25 | TeliaSonera | Ralf.Schuh@TeliaSonera.com | Rel-10 | RP-48 | Issam | RP-100789 |
| 242 | 86.2 | Perf. part: LTE-Advanced Carrier Aggregation of Band 3 and Band 7 | 266d? | 2010-12-10 | 2011-12-16 |  |  | 2010-12-10 | 2011-12-16 | 266d? | 160.8d | start no earlier than 2010-12-10 | R4 | 2128h |  | LTE_CA_B3_B7-Perf | PCG-25 | TeliaSonera | Ralf.Schuh@TeliaSonera.com | Rel-10 | RP-48 | Issam | RP-100790 |
| 243 | 87 | **Service continuity in connected mode and location information for MBMS for LTE** | 271d? | 2010-06-04 | 2011-06-17 |  |  | 2010-06-04 | 2011-06-17 | 271d? | 290.8d |  | R2,R3 | 4336h |  | MBMS_LTE_SC | PCG-25 | Huawei | Zhao Junhui | Rel-10 | RP-48 | Joern |  |
| 244 | 87.1 | Core part: Service continuity in connected mode and location information for MBMS for LTE | 271d? | 2010-06-04 | 2011-06-17 |  |  | 2010-06-04 | 2011-06-17 | 271d? | 290.8d | finish no earlier than 2011-06-17 | R2,R3 | 2168h |  | MBMS_LTE_SC-Core | PCG-25 | Huawei | Zhao Junhui | Rel-10 | RP-48 | Joern | RP-100792 |
| 245 | 88 | **Further enhancements to MBMS for LTE** | 136d? | 2010-06-04 A | 2010-12-10 | 30% | 95.2d? | 2010-06-04 | 2010-12-10 | 136d? | 425.8d |  | R2,R3 | 2176h | 652.8h | MBMS_LTE_enh | PCG-25 | Huawei | Zhao Junhui | Rel-10 | RP-48 | Joern |  |
| 246 | 88.1 | Core part: Further enhancements to MBMS for LTE | 136d? | 2010-06-04 A | 2010-12-10 | 30% | 95.2d? | 2010-06-04 | 2010-12-10 | 136d? | 425.8d | finish no earlier than 2010-12-10 | R2,R3 | 1088h | 326.4h | MBMS_LTE_enh-Core | PCG-25 | Huawei | Zhao Junhui | Rel-10 | RP-48 | Joern | RP-100791 |
| 247 | 89 | **UMTS/LTE 3500 MHz** | 792d? | 2007-11-30 A | 2010-12-10 | 31% | 550.3d? | 2007-11-30 | 2010-12-10 | 792d? | 425.8d |  | R4,R2,R3,R5 | 18074h | 5515.82h | RInImp8-UMTSLTE3500 | PCG-21 | Ericsson | johan.skold@ericsson.com | Rel-10 | RP-38 | Issam |  |
| 248 | 89.1 | UMTS/LTE 3500 MHz | 780d? | 2007-11-30 A | 2010-12-10 | 65% | 273d? | 2007-11-30 | 2010-12-10 | 780d? | 425.8d | finish no earlier than 2010-12-10 | R4,R2,R3 | 6240h | 4056h | RInImp8-UMTSLTE3500 | PCG-21 | Ericsson | Jjohan.skold@ericsson.com | Rel-10 | RP-38 | Issam | RP-100762 |
| 249 | 89.2 | Conformance Test Aspects – LTE 3500 | 527d? | 2008-12-05 A | 2010-12-10 | 5% | 500.65d? | 2008-12-05 | 2010-12-10 | 527d? | 425.8d | finish no earlier than 2010-12-10 | R5 | 4216h | 210.8h | LTE-UEConTest_LTE3500 | PCG-22 | Ericsson | fredrik.sundstrom@ericsson.com | Rel-10 | RP-42 | Ingbert | RP-100733 |
| 250 | 89.3 | Conformance Test Aspects – UMTS 3500 | 527d? | 2008-12-05 A | 2010-12-10 | 5% | 500.65d? | 2008-12-05 | 2010-12-10 | 527d? | 425.8d | finish no earlier than 2010-12-10 | R5 | 4216h | 210.8h | RInImp-UEConTest_UMTS3500 | PCG-22 | Nokia | jukka.vikstedt@nokia.com | Rel-10 | RP-42 | Ingbert | RP-100734 |
| 251 | 90 | **Minimization of Drive Tests for E-UTRAN and UTRAN** | 266d? | 2009-12-04 A | 2010-12-10 | 60% | 106.4d? | 2009-12-04 | 2010-12-10 | 266d? | 425.8d |  | R2,R4,R3 | 4256h | 2553.6h | MDT_UMTSLTE | PCG-24 | Nokia Siemens Networks | malgorzata.tomala@nsn.com | Rel-10 | RP-46 | Joern |  |
| 252 | 90.1 | Core part: Minimization of Drive Tests for E-UTRAN and UTRAN | 266d? | 2009-12-04 A | 2010-12-10 | 60% | 106.4d? | 2009-12-04 | 2010-12-10 | 266d? | 425.8d | finish no earlier than 2010-12-10 | R2,R4,R3 | 2128h | 1276.8h | MDT_UMTSLTE-Core | PCG-24 | Nokia Siemens Networks | malgorzata.tomala@nsn.com | Rel-10 | RP-46 | Joern | RP-100763 |
| 253 | 91 | **HNB and HeNB Mobility Enhancements** | 191d? | 2010-03-19 A | 2010-12-10 | 50% | 95.5d? | 2010-03-19 | 2010-12-10 | 191d? | 425.8d |  | R3,R2 | 3056h | 1528h | HNB_HENB_mob_enh | PCG-24 | Alcatel-Lucent | Martin,Warner@alcatel-lucent.com | Rel-10 | RP-47 | Juha |  |
| 254 | 91.1 | Core part: HNB and HeNB Mobility Enhancements | 191d? | 2010-03-19 A | 2010-12-10 | 50% | 95.5d? | 2010-03-19 | 2010-12-10 | 191d? | 425.8d | start no earlier than 2010-03-19 | R3,R2 | 1528h | 764h | HNB_HENB_mob_enh-Core | PCG-24 | Alcatel-Lucent | Martin.Warner@alcatel-lucent.com | Rel-10 | RP-47 | Juha | RP-100764 |
| 255 | 92 | **Expanded 1900 MHz Band for UTRA and LTE** | 136d? | 2010-06-04 A | 2010-12-10 | 5% | 129.2d? | 2010-06-04 | 2010-12-10 | 136d? | 425.8d |  | R4,R2 | 3264h | 163.2h | E1900 | PCG-25 | Sprint | nick.j.baustert@sprint.com | Rel-10 | RP-48 | Issam |  |
| 256 | 92.1 | Core part: Expanded 1900 MHz Band for UTRA and LTE | 136d? | 2010-06-04 A | 2010-12-10 | 5% | 129.2d? | 2010-06-04 | 2010-12-10 | 136d? | 425.8d | finish no earlier than 2010-12-10 | R4,R2 | 1088h | 54.4h | E1900-Core | PCG-25 | Sprint | nick.j.baustert@sprint.com | Rel-10 | RP-48 | Issam | RP-100765 |
| 257 | 92.2 | Perf. part: Expanded 1900 MHz Band for UTRA and LTE | 136d? | 2010-06-04 A | 2010-12-10 | 5% | 129.2d? | 2010-06-04 | 2010-12-10 | 136d? | 425.8d | finish no earlier than 2010-12-10 | R4,R2 | 1088h | 54.4h | E1900-Perf | PCG-25 | Sprint | nick.j.baustert@sprint.com | Rel-10 | RP-48 | Issam | RP-100766 |
| 258 | 93 | **Multi-standard radio Base Station RF requirements for non-contiguous spectrum deployments** | 336d? | 2010-06-04 A | 2011-09-16 | 1% | 331.71d? | 2010-06-04 | 2011-09-16 | 336d? | 225.8d |  | R4,G1 | 9112h | 116.32h | MSR_NC | PCG-25 | Ericsson | johan.skold@ericsson.com | Rel-10 | RP-48 | Issam |  |
| 259 | 93.1 | Core part: Multi-standard radio Base Station RF requirements for non-contiguous spectrum deployments | 206d? | 2010-06-04 A | 2011-03-18 | 5% | 195.75d? | 2010-06-04 | 2011-03-18 | 206d? | 355.8d | finish no earlier than 2011-03-18 | R4 | 1648h | 82h | MSR_NC-Core | PCG-25 | Ericsson | johan.skold@ericsson.com | Rel-10 | RP-48 | Issam | RP-100767 |
| 260 | 93.2 | Perf. part: Multi-standard radio Base Station RF requirements for non-contiguous spectrum deployments | 336d? | 2010-06-04 | 2011-09-16 |  |  | 2010-06-04 | 2011-09-16 | 336d? | 225.8d | finish no earlier than 2011-09-16 | R4 | 2688h |  | MSR_NC-Perf | PCG-25 | Ericsson | johan.skold@ericsson.com | Rel-10 | RP-48 | Issam | RP-100768 |
| 261 | 93.3 | GERAN part: Multi-standard radio Base Station RF requirements for non-contiguous spectrum deployments | 261d? | 2010-09-03 | 2011-09-02 |  |  | 2010-09-03 | 2011-09-02 | 261d? | 235.8d | finish no earlier than 2011-09-02 | G1 | 2088h |  | MSR_NC-GERAN | PCG-25 | Ericsson | mats.y.samuelsson@ericsson.com | Rel-10 | GP-47 | Paolo |  |

Notes:
- 235: RP#49 changed Skyterra => LightSquared / Text3: LTE
- 236: RP#49 TR 36.813v100 for Information. Changed Skyterra => LightSquared / Text3: 25.461, 25.466, 34.124, 36.101, 36.104, 36.113, 36.124, 36.133, 36.307, new RAN4 TR 36.813
- 237: RP#49 changed Skyterra => LightSquared / Text3: 36.101, 36.104, 36.113, 36.124, 36.133, 36.141, 36.307, 36.813
- 238: SP#49 updated WID RP-100606=>RP-101004. Stage 1,2,3 / Text3: LTE
- 239: SP#49 updated WID RP-100606=>RP-101004 (added one impacted spec) / Text3: 36.300, 36.331, 36.413, 36.423
- 240: RP#49 Work start on hold until RP#50. In Europe Band 3, Band 7 and Band 20 are interesting for LTE and LTE-Advanced deployment. Different CA combinations for these bands are of high priority for Region 1. This work covers the Band 3 and Band 7 combination / Text3: LTE
- 241: RP#49 Work start on hold until RP#50 / Text3: 36.101, 36.104, 36.113, 36.124, 36.133, 36.141, 36.307, 36.331, new TR 36.cde (LTE-Advanced CA of Band 3 and Band 7 for DL/UL with 40 MHz/20 MHz)
- 242: RP#49 Work start on hold until RP#50 / Text3: 36.101, 36.104, 36.133, 36.307, new TR 36.cde (LTE-Advanced CA of Band 3 and Band 7 for DL/UL with 40 MHz/20 MHz)
- 243: - / Text3: LTE
- 244: RP#49 on hold until 12/10 / Text3: 25.446, 36.300, 36.321, 36.322, 36.323, 36.331, 36.440, 36.441, 36.442, 36.443, 36.444, 36.445
- 245: - / Text3: LTE
- 246: - / Text3: 25.446, 36.300, 36.321, 36.322, 36.323, 36.331, 36.440, 36.441, 36.442, 36.443, 36.444, 36.445
- 247: - / Text3: UTRA, LTE
- 248: RP#48 completion 06/10=>12/10 / Text3: 25.101, 25.104, 25.113, 25.133, 25.141, 25.307, 25.307, 25.331, 25.461, 25.463, 34.124, 36.101, 36.104, 36.113, 36.141, 36.331, new 37.801
- 249: RP#47 completion 06/10=>12/10 / Text3: 36.508, 36.521-1, 36.521-2, 36.521-3
- 250: RP#47 completion 06/10=>12/10 / Text3: 34.108, 34.121-1, 34.121-2
- 251: Triggered by UID_430021 TR 36.805 (Study on Minimization of drive-tests in NGN) / Text3: UTRA, LTE
- 252: RP#49 Stage 2 TS 37.320v1.0.0 for RAN information / Text3: 25.133, 25.215, 25.304, 25.331, 25.423, 36.133, 36.214, 36.300, 36.304, 36.331, 36.413, 36.423, new 37.320 (Stage 2)
- 253: RP#49 updated WID RP-100371=>RP-100874. Common UTRA and E-UTRA Work Item to ensure that divergence between the systems is minimized / Text3: UTRA, LTE
- 254: RP#49 updated WID RP-100371=>RP-100874 / Text3: 25.413, 25.467, 25.468, 25.469, 36.300, 36.401, 36.413, 36.423, new TS 25.4xx UTRAN Iuhr interface Home Radio Network Subsystem Application Part (HRNSAP)
- 255: Create a new band that expands UTRA and E-UTRA band 2 to include frequencies between 1910 1915 MHz and 1990-1995 MHz (US FCC allocation) / Text3: UTRA, LTE
- 256: - / Text3: 25.101, 25.104, 25.113, 25.133, 25.141, 25.461, 25.466, 36.101, 36.104, 36.113, 36.124, 36.133, 36.141, 36.307, 36.331, new TR 36.8xy (Expanding 1900MHz Technical report)
- 257: - / Text3: 25.101, 25.104, 25.113, 25.133, 25.141, 25.461, 25.466, 36.101, 36.104, 36.113, 36.124, 36.133, 36.141, 36.307, 36.331, new TR 36.8xy (Expanding 1900MHz Technical report)
- 258: RP#49 updated WID RP-100689=>RP-100960 / Text3: UTRA, LTE, GERA
- 259: RP#49 updated WID RP-100689=>RP-100960 (add new TR 37.802) / Text3: 25.104, 36.104, 37.104, new TR 37.802
- 260: RP#49 updated WID RP-100689=>RP-100960 (add impacted TR 37.802) / Text3: 25.141, 36.141, 37.141, 37.802
- 261: GP#47 approved WID / Text3: 45.005, 51.021

| ID | WBS | Task | Duration | Start | Finish | Complete | Remaining | Baseline start | Baseline finish | Baseline duration | Total slack | Constraint | Resources | Work | Actual work | Text1 | Text2 | Text4 | Text6 | Text7 | Text8 | Text9 | Text12 |
| --- | --- | --- | --- | --- | --- | --- | --- | --- | --- | --- | --- | --- | --- | --- | --- | --- | --- | --- | --- | --- | --- | --- | --- |
| 262 | 94 | **Local Call Local Switch** | 542d? | 2009-02-20 A | 2011-03-18 | 86% | 78.52d? | 2009-02-20 | 2011-03-18 | 542d? | 355.8d |  | GP,C4 | 21592h | 17449.2h | LCLS | PCG-22 | Huawei | Rel-10 | GP-41 | Paolo |  |  |
| 263 | 94.1 | Local Call Local Switch | 531d? | 2009-02-20 A | 2011-03-04 | 75% | 132.75d? | 2009-02-20 | 2011-03-04 | 531d? | 365.8d | finish no earlier than 2011-03-04 | GP | 4248h | 3186h | LCLS | PCG-22 | Huawei | Rel-10 | GP-41 | Paolo |  |  |
| 264 | 94.2 | **CN aspects of Local Call Local Switch** | 472d? | 2009-05-29 A | 2011-03-18 | 90% | 45.54d? | 2009-05-29 | 2011-03-18 | 472d? | 355.8d |  | C4 | 13008h | 11069.2h | LCLS-CN | PCG-23 | Vodafone | Rel-10 | CP-44 | Kimmo |  |  |
| 265 | 94.2.1 | Study on CN aspects of Local Call Local Switch | 341d? | 2009-05-29 A | 2010-09-17 A | 100% |  | 2009-05-29 | 2010-09-17 | 341d? |  | finish no earlier than 2010-09-17 | C4 | 2728h | 2728h | LCLS-CN | PCG-23 | Vodafone | Rel-10 | CP-44 | Kimmo |  |  |
| 266 | 94.2.2 | CN aspects of Local Call Local Switch | 131d? | 2010-09-17 A | 2011-03-18 | 15% | 111.35d? | 2010-09-17 | 2011-03-18 | 131d? | 355.8d | finish no earlier than 2011-03-18 | C4 | 1048h | 157.2h | LCLS-CN | PCG-25 | Vodafone | Rel-10 | CP-49 | Kimmo |  |  |
| 267 | 94.2.3 | Deleted - CT3 aspects of Local Call Local Switch | 341d? | 2009-05-29 A | 2010-09-17 A | 100% |  | 2009-05-29 | 2010-09-17 | 341d? |  | finish no earlier than 2010-09-17 | C3 | 2728h | 2728h | LCLS-CN | PCG-23 | Vodafone | Rel-10 | CP-44 | Gwiho | PCG-25 | CP-49 |
| 268 | 94.2.4 | Deleted - CT1 aspects of Local Call Local Switch | 341d? | 2009-05-29 A | 2010-09-17 A | 100% |  | 2009-05-29 | 2010-09-17 | 341d? |  | finish no earlier than 2010-09-17 | C1 | 2728h | 2728h | LCLS-CN | PCG-23 | Vodafone | Rel-10 | CP-44 | Frederic | PCG-25 | CP-49 |
| 269 | 95 | **Tightened Link Level Performance Requirements for Single Antenna MS** | 261d? | 2010-09-03 A | 2011-09-02 | 1% | 257.79d? | 2010-09-03 | 2011-09-02 | 261d? | 235.8d |  | G1,G2,C1,G3new | 6352h | 78.06h | TIGHTER | PCG-25 | Nokia | Rel-10 | GP-46 | Paolo |  |  |
| 270 | 95.1 | CT1 part for TIGHTER | 141d? | 2010-09-03 | 2011-03-18 |  |  | 2010-09-03 | 2011-03-18 | 141d? | 355.8d | finish no earlier than 2011-03-18 | C1 | 1128h |  | TIGHTER | PCG-25 | Nokia | Rel-10 | GP-46 | Frederic |  |  |
| 271 | 95.2 | TIGHTER Performance Requirements | 131d? | 2010-09-03 A | 2011-03-04 | 5% | 124.45d? | 2010-09-03 | 2011-03-04 | 131d? | 365.8d | finish no earlier than 2011-03-04 | G1,G2 | 1048h | 52.4h | TIGHTER | PCG-25 | Nokia | Rel-10 | GP-46 | Paolo |  |  |
| 272 | 95.3 | TIGHTER Testing | 261d? | 2010-09-03 | 2011-09-02 |  |  | 2010-09-03 | 2011-09-02 | 261d? | 235.8d | finish no earlier than 2011-09-02 | G3new,G1,G2 | 2088h |  | TIGHTER | PCG-25 | Nokia | Rel-10 | GP-46 | Ingbert |  |  |
| 273 | 96 | **Support of Multi-Operator Core Network by GERAN** | 149d? | 2010-05-21 A | 2010-12-15 | 7% | 138.24d? | 2010-05-21 | 2010-12-15 | 149d? | 422.8d |  | G2,S2,C1 | 4072h | 294.09h | MOCN–GERAN | PCG-25 | Alcatel-Lucent | Rel-10 | GP-47 | Gert |  |  |
| 274 | 96.1 | Stage 2 for MOCN–GERAN | 149d? | 2010-05-21 | 2010-12-15 |  |  | 2010-05-21 | 2010-12-15 | 149d? | 422.8d | finish no earlier than 2010-12-15 | S2 | 1192h |  | MOCN–GERAN | PCG-25 | Alcatel-Lucent | Rel-10 | GP-47 | Maurice |  |  |
| 275 | 96.2 | Stage 3 for MOCN–GERAN (CT1 part) | 146d? | 2010-05-21 | 2010-12-10 |  |  | 2010-05-21 | 2010-12-10 | 146d? | 425.8d | finish no earlier than 2010-12-10 | C1 | 1168h |  | MOCN–GERAN | PCG-25 | Alcatel-Lucent | Rel-10 | GP-47 | Frederic |  |  |
| 276 | 96.3 | Stage 3 for MOCN–GERAN (G2 part) | 65d? | 2010-08-30 A | 2010-11-26 | 40% | 39d? | 2010-08-30 | 2010-11-26 | 65d? | 435.8d | finish no earlier than 2010-11-26 | G2 | 520h | 208h | MOCN–GERAN | PCG-25 | Alcatel-Lucent | Rel-10 | GP-47 | Gert |  |  |
| 277 | 97 | **Enhancements of Iur-g interface** | 141d? | 2010-09-03 | 2011-03-18 |  |  | 2010-09-03 | 2011-03-18 | 141d? | 355.8d |  | G2,R3 | 3304h |  | eIurg | PCG-25 | China Mobile, ZTE | Rel-10 | GP-47 | Gert |  |  |
| 278 | 97.1 | GERAN Stage 2/3 for Enhancements of Iur-g interface | 131d? | 2010-09-03 | 2011-03-04 |  |  | 2010-09-03 | 2011-03-04 | 131d? | 365.8d | finish no earlier than 2011-03-04 | G2 | 1048h |  | eIurg-GERAN | PCG-25 | China Mobile, ZTE | Rel-10 | GP-47 | Gert |  |  |
| 279 | 97.2 | Core part: Enhancements of Iur-g interface (Stage 2/3) | 141d? | 2010-09-03 | 2011-03-18 |  |  | 2010-09-03 | 2011-03-18 | 141d? | 355.8d | finish no earlier than 2011-03-18 | R3 | 1128h |  | eIurg-RAN | PCG-25 | ZTE | Rel-10 | RP-49 | Juha |  |  |
| 280 | 98 | (Small) Technical Enhancements and Improvements for Rel-10 | 466d? | 2009-06-04 A | 2011-03-17 | 60% | 186.4d? | 2009-06-04 | 2011-03-17 | 466d? | 356.8d | finish no earlier than 2011-03-17 | All | 3728h | 2236.8h | TEI10 | PCG-23 |  | Rel-10 | SP-44 |  |  |  |
| 281 | 99 | **Deleted - Registration in Densely-populated area (RED)** | 665d? | 2007-03-12 A | 2009-09-24 A | 100% |  | 2007-03-12 | 2009-09-24 | 665d? |  |  | S1 | 9544h | 9544h | RED |  | NTT DoCoMo | Rel-10 | SP-35 | Alain | PCG-24 | SP-46 |
| 282 | 99.1 | Deleted - Stage 1 for RED | 4d? | 2007-03-12 A | 2007-03-15 A | 100% |  | 2007-03-12 | 2007-03-15 | 4d? |  | start no earlier than 2007-03-12 | S1 | 32h | 32h | RED |  | NTT DoCoMo | Rel-10 | SP-35 | Alain | PCG-24 | SP-46 |
| 283 | 99.2 | Deleted - Stage 2 for RED | 524d? | 2007-09-25 A | 2009-09-24 A | 100% |  | 2007-09-25 | 2009-09-24 | 524d? |  | finish no earlier than 2009-09-24 | S2 | 4192h | 4192h | RED |  | NTT DoCoMo | Rel-10 | SP-37 | Maurice | PCG-23 | SP-45 |
| 284 | 100 | **Deleted - Network Selection for non-3GPP Access** | 471d? | 2007-12-07 A | 2009-09-24 A | 100% |  | 2007-12-07 | 2009-09-24 | 471d? |  |  | S1,C6 | 10452.8h | 10452.8h | N3GtoNSP | PCG-21 | Telefonica O2 | Rel-10 | SP-38 | Alain | PCG-23 | SP-45 |
| 285 | 100.1 | Deleted - Stage 1 for N3GtoNSP | 471d? | 2007-12-07 A | 2009-09-24 A | 100% |  | 2007-12-07 | 2009-09-24 | 471d? |  | finish no earlier than 2009-12-10 | S1 | 3768h | 3768h | N3GtoNSP | PCG-21 | Telefonica O2 | Rel-10 | SP-38 | Alain | PCG-23 | SP-45 |
| 286 | 100.2 | Deleted - CT6 issues for N3GtoNSP | 471d? | 2007-12-07 A | 2009-09-24 A | 100% |  | 2007-12-07 | 2009-09-24 | 471d? |  | finish no earlier than 2009-12-04 | C6 | 3768h | 3768h | N3GtoNSP | PCG-21 | Telefonica O2 | Rel-10 | CP-38 | Xavier | PCG-23 | CP-45 |

Notes:
- 262: CP#49 WID updated CP-090812=>CP-100470 / Text3: GERA / Text5: Xing Zhu
- 263: GP#41 WID approved / Text3: 48.008 (MSC-BSS interface; Layer 3 specification) / Text5: Xing Zhu
- 264: CP#49 WID updated CP-090812=>CP-100470 / Text5: David Hutton
- 265: CT#49 completed / Text3: new 23.889 / Text5: David Hutton
- 266: CP#49 WID updated CP-090812=>CP-100470 / Text3: 23.003, 23.205, 23.231, 29.002, 29.205, 29.232, new TS 23.284 / Text5: David Hutton
- 267: CP#49 stopped. Result of study TR 23.889: no CT3 specification impact / Text5: David Hutton
- 268: CP#49 stopped. Result of study TR 23.889: no CT1 specification impact / Text5: David Hutton
- 269: GP#46 approved WID. Tighten single antenna MS link level performance reqs by at least 2dB for all relevant GSM services (Speech, AMR-NB GMSK, AMR-WB GMSK, GPRS, EGPRS, and EGPRS2, thereby improving the spectral efficiency) / Text3: GERA / Text5: Carsten.Juncker@nokia.com
- 270: - / Text3: 24.008 / Text5: Carsten.Juncker@nokia.com
- 271: - / Text3: 45.005, 45.015 / Text5: Carsten.Juncker@nokia.com
- 272: - / Text3: 51.010 / Text5: Carsten.Juncker@nokia.com, Shrihari.Varadaraju@nokia.com
- 273: GP#47 approved WID. 900 MHz spectrum re-farming to other RATs lead operators to reduce GSM capacity and therefore share their GSM networks. Hence the need for the most suitable (GE)RAN sharing method. / Text3: GERA / Text5: michel.robert@alcatel-lucent.com
- 274: - / Text3: 23.251 (Network sharing; Architecture and functional description) / Text5: michel.robert@alcatel-lucent.com
- 275: - / Text3: 24.008 (Mobile radio interface Layer 3 specification; Core network protocols; Stage 3) / Text5: michel.robert@alcatel-lucent.com
- 276: - / Text3: 48.008, 48.018 / Text5: michel.robert@alcatel-lucent.com
- 277: GP#47 approved WID / Text3: GERA,UTRA / Text5: Ms Juan Deng (dengjuan@chinamobile.com), Xinhui Wang (wangxinhui@zte.com.cn)
- 278: GP#47 approved WID / Text3: 43.130 / Text5: Ms Juan Deng (dengjuan@chinamobile.com), Xinhui Wang (wangxinhui@zte.com.cn)
- 279: UTRA RP#49 LS from GERAN in RP-100718 / Text3: Stage 2: 25.401, 25.420, Stage 3: 25.423 / Text5: Liu Junqiang (liu.junqiang@zte.com.cn)
- 280: -
- 281: SP#35 Stage 1 completed. SP#45 Stage 2 work stopped. SP#46 work stopped/abandoned / Text3: WID identifies also impacted CT1 24.008, RAN2 25.331 / Text5: tanakai@nttdocomo.co.jp
- 282: SP#35 completed. SP#46 work stopped/abandoned / Text3: 22.101 CR#0207 / Text5: takakurat@s1.nttdocomo.co.jp
- 283: SP#45 Stage 2 work stopped / Text3: draft TR 23.880 withdrawn, 23.002, 23.060, 23.221, 23.236 / Text5: tanakai@nttdocomo.co.jp
- 284: SP#45 work stopped/abandoned / Text5: chris.friel@O2.com
- 285: SP#45 work stopped/abandoned / Text3: 22.011 / Text5: chris.friel@O2.com
- 286: SP#45 work stopped/abandoned / Text3: 36.300 / Text5: chris.friel@O2.com

| ID | WBS | Task | Type | Duration | Start | Finish | Complete | Remaining | Baseline start | Baseline finish | Baseline duration | Total slack | Constraint | Resources | Work | Actual work | Text1 | Text2 | Text4 | Text6 | Text7 | Text8 | Text9 | Text12 | Text11 |
| --- | --- | --- | --- | --- | --- | --- | --- | --- | --- | --- | --- | --- | --- | --- | --- | --- | --- | --- | --- | --- | --- | --- | --- | --- | --- |
| 287 | 101 | **Deleted - GTP-based S8 chaining** |  | 337d? | 2008-12-11 A | 2010-03-25 A | 100% |  | 2008-12-11 | 2010-03-25 | 337d? |  |  | S2 | 5392h | 5392h | GTPchaining | PCG-22 | Huawei | Rel-10 | SP-42 | Maurice | PCG-24 | SP-47 |  |
| 288 | 101.1 | Deleted - Stage 2 for GTPchaining |  | 337d? | 2008-12-11 A | 2010-03-25 A | 100% |  | 2008-12-11 | 2010-03-25 | 337d? |  | finish no earlier than 2010-03-25 | S2 | 2696h | 2696h | GTPchaining | PCG-22 | Huawei | Rel-10 | SP-42 | Maurice | PCG-24 | SP-47 |  |
| 289 | 102 | Deleted - UTRAN 2 ms TTI uplink range improvement |  | 272d? | 2009-03-06 A | 2010-03-19 A | 100% |  | 2009-03-06 | 2010-03-19 | 272d? |  | finish no earlier than 2010-03-19 | R1,R2,R3,R4 | 2176h | 2176h | RANimp-2mTTI_ULimp | PCG-22 | Nokia Siemens Networks | Rel-10 | RP-43 | Patrick | PCG-24 | RP-47 | RP-100040 |
| 290 | 103 | Deleted - Enhanced Home NodeB / eNodeB continuation of Rel-9 |  | 337d? | 2008-12-11 A | 2010-03-25 A | 100% |  | 2008-12-11 | 2010-03-25 | 337d? |  |  | S2 | 2696h | 2696h | eEHNB | PCG-23 | Alcatel-Lucent | Rel-10 | SP-44 | Maurice | PCG-24 | SP-47 |  |
| 291 | 104 | **Deleted - Enhanced Interference Management for Home NodeBs** |  | 131d? | 2010-03-19 A | 2010-09-17 A | 100% |  | 2010-03-19 | 2010-09-17 | 131d? |  |  | R3 | 2096h | 2096h | HNB_IM | PCG-24 | Qualcomm | Rel-10 | RP-47 | Juha | PCG-25 | RP-49 | RP-100754 |
| 292 | 104.1 | Deleted - Core part: Enhanced Interference Management for Home NodeBs |  | 131d? | 2010-03-19 A | 2010-09-17 A | 100% |  | 2010-03-19 | 2010-09-17 | 131d? |  | finish no earlier than 2010-09-17 | R3 | 1048h | 1048h | HNB_IM-Core | PCG-24 | Qualcomm | Rel-10 | RP-47 | Juha | PCG-25 | RP-49 | RP-100754 |
| 293 | 105 | Release 10 Studies |  | 531d? | 2009-03-12 A | 2011-03-23 | 80% | 106.2d? | 2009-03-12 | 2011-03-23 | 531d? | 352.8d | finish no earlier than 2011-03-23 | CP,GP,RP,SP | 4248h | 3398.4h |  |  |  | Rel-10 |  |  |  |  |  |
| 294 | 106 | **Study on enhanced voice service requirements for the Evolved Packet System (EPS)** |  | 670d? | 2007-09-03 A | 2010-03-25 A | 100% |  | 2007-09-03 | 2010-03-25 | 670d? |  |  | S1,S4 | 13384h | 13384h | FS_EV_EPS |  | France Telecom | Rel-10 | SP-37 | Alain |  |  |  |
| 295 | 106.1 | Use cases definition and service and system requirements |  | 334d? | 2007-09-03 A | 2008-12-11 A | 100% |  | 2007-09-03 | 2008-12-11 | 334d? |  | finish no earlier than 2008-12-11 | S1 | 2672h | 2672h | FS_EV_EPS-S1 |  | France Telecom | Rel-10 | SP-37 | Alain |  |  |  |
| 296 | 106.2 | Codec specific part of FS_EV_EPS |  | 669d? | 2007-09-03 A | 2010-03-25 A | 100% |  | 2007-09-03 | 2010-03-25 | 669d? |  | finish no earlier than 2010-03-25 | S4 | 5352h | 5352h | FS_EV_EPS-S4 |  | Ericsson | Rel-10 | SP-37 | Paolo |  |  |  |
| 297 | 107 | Study on advanced requirements for IP interconnect |  | 528d? | 2007-12-04 A | 2009-12-10 A | 100% |  | 2007-12-04 | 2009-12-10 | 528d? |  | finish no earlier than 2009-12-10 | S1 | 4224h | 4224h | FS_IPXS | PCG-21 | Telefonica O2 | Rel-10 | SP-38 | Alain |  |  |  |
| 298 | 108 | Study on Personal Broadcast Service |  | 397d? | 2008-09-18 A | 2010-03-25 A | 100% |  | 2008-09-18 | 2010-03-25 | 397d? |  | finish no earlier than 2010-03-25 | S1 | 3168h | 3168h | FS_PBS | PCG-21 | ETRI | Rel-10 | SP-41 | Alain |  |  |  |
| 299 | 109 | Study on LCS support in SAE for non-3GPP accesses |  | 397d? | 2008-09-18 A | 2010-03-25 A | 100% |  | 2008-09-18 | 2010-03-25 | 397d? |  | finish no earlier than 2010-03-25 | S1 | 3168h | 3168h | FS_LCS_n3GPP | PCG-21 | SK Telecom | Rel-10 | SP-41 | Alain |  |  |  |
| 300 | 110 | Study on Haptic Services |  | 272d? | 2009-03-12 A | 2010-03-25 A | 100% |  | 2009-03-12 | 2010-03-25 | 272d? |  | finish no earlier than 2010-03-25 | S1 | 2168h | 2168h | FS_Haptics | PCG-22 | SK Telecom | Rel-10 | SP-43 | Alain |  |  |  |
| 301 | 111 | Study on System enhancements for the use of IMS services in Local BreakOut and Optimal Routing of Media |  | 575d? | 2007-10-01 A | 2009-12-10 A | 100% |  | 2007-10-01 | 2009-12-10 | 575d? |  | finish no earlier than 2009-12-10 | S2 | 4600h | 4600h | FS_IMS_LBO_ORM |  | Telecom Italia, BT | Rel-10 | SP-37 | Maurice |  |  |  |
| 302 | 112 | Study on Intra Domain Connection of RAN Nodes to Multiple CN Nodes |  | 533d? | 2008-03-12 A | 2010-03-25 A | 100% |  | 2008-03-12 | 2010-03-25 | 533d? |  | finish no earlier than 2010-03-25 | S2 | 4264h | 4264h | FS_IDC | PCG-21 | China Mobile | Rel-10 | SP-39 | Maurice |  |  |  |
| 303 | 113 | Study on IMS Evolution |  | 587d? | 2008-09-18 A | 2010-12-16 | 80% | 117.4d? | 2008-09-18 | 2010-12-16 | 587d? | 421.8d | finish no earlier than 2010-12-16 | S2 | 4696h | 3756.8h | FS_eIMS | PCG-21 | China Mobile | Rel-10 | SP-41 | Maurice |  |  |  |
| 304 | 114 | Study on enhancements to IMS border functions for IMS Interconnection of services |  | 587d? | 2008-09-18 A | 2010-12-16 | 35% | 381.55d? | 2008-09-18 | 2010-12-16 | 587d? | 421.8d | finish no earlier than 2010-12-16 | S2 | 4696h | 1643.6h | FS_eIMS_IBCF | PCG-21 | Starent Networks | Rel-10 | SP-41 | Maurice |  |  |  |
| 305 | 115 | Study on Multi Access PDN connectivity and IP flow Mobility |  | 587d? | 2008-09-18 A | 2010-12-16 | 75% | 146.75d? | 2008-09-18 | 2010-12-16 | 587d? | 421.8d | finish no earlier than 2010-12-16 | S2,S1 | 4696h | 3522h | FS_MAPIM | PCG-21 | Qualcomm | Rel-10 | SP-41 | Maurice |  |  |  |
| 306 | 116 | Study on Policy solutions and enhancements |  | 401d? | 2009-06-04 A | 2010-12-16 | 55% | 180.45d? | 2009-06-04 | 2010-12-16 | 401d? | 421.8d | finish no earlier than 2010-12-16 | S2,S1 | 3208h | 1764.4h | FS_PP | PCG-23 | AT&T | Rel-10 | SP-44 | Maurice |  |  |  |
| 307 | 117 | Study on IPv6 Migration |  | 470d? | 2009-06-04 A | 2011-03-23 | 70% | 141d? | 2009-06-04 | 2011-03-23 | 470d? | 352.8d | finish no earlier than 2011-03-23 | S2 | 3760h | 2632h | FS_IP6M | PCG-23 | China Mobile | Rel-10 | SP-44 | Maurice |  |  |  |
| 308 | 118 | Study on Single Radio Voice Call Continuity enhancements |  | 341d? | 2009-06-04 A | 2010-09-23 A | 100% |  | 2009-06-04 | 2010-09-23 | 341d? |  | finish no earlier than 2010-09-23 | S2 | 2728h | 2728h | FS_eSRVCC | PCG-23 | China Mobile | Rel-10 | SP-44 | Maurice |  |  |  |
| 309 | 119 | Study on Single Radio Voice Call Continuity from UTRAN/GERAN to E-UTRAN/HSPA |  | 266d? | 2009-12-10 A | 2010-12-16 | 60% | 106.4d? | 2009-12-10 | 2010-12-16 | 266d? | 421.8d | finish no earlier than 2010-12-16 | S2 | 2128h | 1276.8h | FS_rSRVCC | PCG-24 | Orange | Rel-10 | SP-46 | Maurice |  |  |  |
| 310 | 120 | Study on Single Radio Video Call Continuity for 3G-CS |  | 131d? | 2010-03-25 A | 2010-09-23 A | 100% |  | 2010-03-25 | 2010-09-23 | 131d? |  | finish no earlier than 2010-09-23 | S2 | 1048h | 1048h | FS_vSRVCC | PCG-24 | Samsung | Rel-10 | SP-47 | Maurice |  |  |  |
| 311 | 121 | Study on S2b Mobility based on GTP |  | 56d? | 2010-03-25 A | 2010-06-10 A | 100% |  | 2010-03-25 | 2010-06-10 | 56d? |  | finish no earlier than 2010-06-07 | S2 | 448h | 448h | FS_SMOG | PCG-24 | Alcatel-Lucent | Rel-10 | SP-47 | Maurice |  |  |  |
| 312 | 122 | Study on UTRAN key management enhancements |  | 782d? | 2007-12-20 A | 2010-12-16 | 70% | 234.6d? | 2007-12-20 | 2010-12-16 | 782d? | 421.8d | finish no earlier than 2010-12-16 | S3 | 6256h | 4379.2h | FS_UKM | PCG-21 | Ericsson | Rel-10 | SP-38 | Dionisio |  |  |  |
| 313 | 123 | Study on Extended IMS Media Plane Security features |  | 205d? | 2010-06-10 A | 2011-03-23 | 15% | 174.1d? | 2010-06-10 | 2011-03-23 | 205d? | 352.8d | finish no earlier than 2011-03-23 | S3 | 1640h | 247.2h | FS_eMEDIASEC | PCG-25 | Vodafone | Rel-10 | SP-48 | Dionisio |  |  |  |
| 314 | 124 | Study on Single Sign On (SSO) Application Security for IMS - based on SIP Digest |  | 205d? | 2010-06-10 A | 2011-03-23 | 20% | 163.8d? | 2010-06-10 | 2011-03-23 | 205d? | 352.8d | finish no earlier than 2011-03-23 | S3 | 1640h | 329.6h | FS_SSO_APS | PCG-25 | Nokia | Rel-10 | SP-48 | Dionisio |  |  |  |
| 315 | 125 | Study on Surround Sound codec extension for PSS and MBMS |  | 461d? | 2009-03-12 A | 2010-12-16 | 80% | 92.2d? | 2009-03-12 | 2010-12-16 | 461d? | 421.8d | finish no earlier than 2010-12-16 | S4 | 3688h | 2950.4h | FS_SS_PSS_MBMS | PCG-22 | Fraunhofer Gesellschaft | Rel-10 | SP-43 | Paolo |  |  |  |
| 316 | 126 | Study on Improved Video Coding Support |  | 205d? | 2010-06-10 A | 2011-03-23 | 20% | 163.8d? | 2010-06-10 | 2011-03-23 | 205d? | 352.8d | finish no earlier than 2011-03-23 | S4 | 1640h | 329.6h | FS_IVCS | PCG-25 | Nokia, ETRI | Rel-10 | SP-48 | Paolo |  |  |  |
| 317 | 127 | Study on Rc Reference Point Functionalities and Message Flows |  | 397d? | 2008-09-18 A | 2010-03-25 A | 100% |  | 2008-09-18 | 2010-03-25 | 397d? |  | finish no earlier than 2010-03-23 | S5 | 3170.08h | 3170.08h | FS_OAM_Rc | PCG-21 | Huawei | Rel-10 | SP-41 | Dionisio |  |  |  |
| 318 | 128 | Study on Telecommunication Management; Energy Savings Management |  | 271d? | 2009-03-12 A | 2010-03-25 A | 100% |  | 2009-03-12 | 2010-03-25 | 271d? |  | finish no earlier than 2010-03-25 | S5 | 2168h | 2168h | FS_OAM_ESM | PCG-22 | Orange, Vodafone | Rel-10 | SP-43 | Dionisio |  |  |  |
| 319 | 129 | Study on Integration of Device Management Information with Itf-N |  | 211d? | 2009-06-04 A | 2010-03-25 A | 100% |  | 2009-06-04 | 2010-03-25 | 211d? |  | finish no earlier than 2010-03-25 | S5 | 1688h | 1688h | FS_IDMI_Itf-N | PCG-23 | Motorola | Rel-10 | SP-44 | Dionisio |  |  |  |
| 320 | 130 | Study on Alignment of 3GPP Generic NRM IRP and TMF Shared Information Data (SID) model |  | 266d? | 2009-12-10 A | 2010-12-16 | 80% | 53.2d? | 2009-12-10 | 2010-12-16 | 266d? | 421.8d | finish no earlier than 2010-12-16 | S5 | 2128h | 1702.4h | FS_3GNRM_TMFSID | PCG-24 | Nokia Siemens Networks | Rel-10 | SP-46 | Dionisio |  |  |  |
| 321 | 131 | Study on Harmonization of 3GPP Alarm IRP and TMF Interface Program (TIP) Fault Management |  | 266d? | 2009-12-10 A | 2010-12-16 | 80% | 53.2d? | 2009-12-10 | 2010-12-16 | 266d? | 421.8d | finish no earlier than 2010-12-16 | S5 | 2128h | 1702.4h | FS_3G_TMF_FM | PCG-24 | Nokia Siemens Networks, Alcatel-Lucent | Rel-10 | SP-46 | Dionisio |  |  |  |
| 322 | 132 | Study on version handling |  | 260d? | 2010-03-25 A | 2011-03-23 | 25% | 196d? | 2010-03-25 | 2011-03-23 | 260d? | 352.8d | finish no earlier than 2011-03-23 | S5 | 2080h | 512h | FS_OAM_VH | PCG-24 | Ericsson | Rel-10 | SP-47 | Dionisio |  |  |  |
| 323 | 133 | Study on Alarm Correlation and Alarm Root Cause Analysis |  | 205d? | 2010-06-10 A | 2011-03-23 | 20% | 164.8d? | 2010-06-10 | 2011-03-23 | 205d? | 352.8d | finish no earlier than 2011-03-23 | S5 | 1640h | 321.6h | FS_AC_ARCA | PCG-25 | Ericsson | Rel-10 | SP-48 | Dionisio |  |  |  |
| 324 | 134 | Study on Alignment of 3GPP PM IRP and TMF Interface Program (TIP) PM |  | 131d? | 2010-06-10 A | 2010-12-09 | 5% | 124.45d? | 2010-06-10 | 2010-12-09 | 131d? | 426.8d | finish no earlier than 2010-12-09 | S5 | 1048h | 52.4h | FS_3G_TMF_PM | PCG-25 | Alcatel-Lucent | Rel-10 | SP-48 | Dionisio |  |  |  |
| 325 | 135 | Study on Management of Converged Networks |  | 205d? | 2010-06-10 A | 2011-03-23 | 5% | 194.95d? | 2010-06-10 | 2011-03-23 | 205d? | 352.8d | finish no earlier than 2011-03-23 | S5 | 1640h | 80.4h | FS_ManCon | PCG-25 | Nokia Siemens Networks | Rel-10 | SP-48 | Dionisio |  |  |  |
| 326 | 136 | Study on User Data Convergence (UDC) information model handling and provisioning: Example Use Cases |  | 130d? | 2010-09-23 | 2011-03-23 |  |  | 2010-09-23 | 2011-03-23 | 130d? | 352.8d | finish no earlier than 2011-03-23 | S5 | 1040h |  | FS_UDC_AppUseCase | PCG-25 | Alcatel-Lucent | Rel-10 | SP-49 | Dionisio |  |  |  |
| 327 | 137 | Study on Policy and Charging Rules Function (PCRF) failure and restoration |  | 261d? | 2009-08-18 A | 2010-09-17 A | 100% |  | 2009-08-18 | 2010-09-17 | 261d? |  | finish no earlier than 2010-09-17 | C3 | 2088h | 2088h | FS_PCRF-FR | PCG-23 | NEC | Rel-10 | CP-45 | Gwiho |  |  |  |
| 328 | 138 | Study on impacts on UE-Core Network signalling from Energy Saving |  | 206d? | 2010-06-04 A | 2011-03-18 | 20% | 164.8d? | 2010-06-04 | 2011-03-18 | 206d? | 355.8d | finish no earlier than 2011-03-18 | C1 | 1648h | 329.6h | FS_UE-CN_ES | PCG-25 | NEC | Rel-10 | CP-48 | Frederic |  |  |  |
| 329 | 139 | Study on User Data Convergence (UDC) evolution |  | 136d? | 2010-06-04 A | 2010-12-10 | 10% | 122.4d? | 2010-06-04 | 2010-12-10 | 136d? | 425.8d | finish no earlier than 2010-12-10 | C4 | 1088h | 108.8h | FS_UDCe | PCG-25 | Alcatel-Lucent | Rel-10 | CP-48 | Kimmo |  |  |  |
| 330 | 140 | Study on UICC access to IMS |  | 136d? | 2010-06-04 A | 2010-12-10 | 15% | 115.6d? | 2010-06-04 | 2010-12-10 | 136d? | 425.8d | finish no earlier than 2010-12-10 | C6 | 1088h | 163.2h | FS_IMS-UICC | PCG-25 | Gemalto | Rel-10 | CP-48 | Xavier |  |  |  |
| 331 | 141 | Study on EPC Nodes Restoration |  | 131d? | 2010-09-17 | 2011-03-18 |  |  | 2010-09-17 | 2011-03-18 | 131d? | 355.8d | finish no earlier than 2011-03-18 | C4 | 1048h |  | FS_EPC_NR | PCG-25 | ZTE | Rel-10 | CP-49 | Kimmo |  |  |  |
| 332 | 142 | Study on Uplink Tx Diversity for HSPA |  | 208.4d? | 2009-08-18 A | 2010-06-04 A | 100% |  | 2009-08-18 | 2010-06-04 | 208.4d? |  | finish no earlier than 2010-06-04 | R4 | 1667.2h | 1667.2h | FS_UL-TxDiv-HSPA | PCG-23 | Qualcomm | Rel-10 | RP-45 | Issam |  |  | RP-100499 |
| 333 | 143 | Study on Solutions for Energy Saving within UTRA Node B |  | 206d? | 2009-12-04 A | 2010-09-17 A | 100% |  | 2009-12-04 | 2010-09-17 | 206d? |  | finish no earlier than 2010-09-17 | R1,R3 | 1648h | 1648h | FS_Energy_UMTS | PCG-24 | Vodafone | Rel-10 | RP-46 | Patrick |  |  | RP-100796 |
| 334 | 144 | Study on Improvements of distributed antenna for 1.28Mcps TDD |  | 191d? | 2010-03-05 A | 2010-12-10 | 25% | 143.25d? | 2010-03-05 | 2010-12-10 | 191d? | 425.8d | finish no earlier than 2010-12-10 | R1,R2,R3 | 1528h | 382h | FS_distr_ant_LCR_TDD | PCG-24 | ZTE | Rel-10 | RP-47 | Patrick |  |  | RP-100799 |
| 335 | 145 | Study on Coordinated Multi-Point operation for LTE |  | 135d? | 2010-12-10 | 2011-06-16 |  |  | 2010-12-10 | 2011-06-16 | 135d? | 291.8d | start no earlier than 2010-12-10 | R1 | 1080h |  | FS_CoMP_LTE | PCG-24 | Samsung | Rel-10 | RP-47 | Patrick |  |  | RP-100797 |
| 336 | 146 | Study on Network Energy Saving for E-UTRAN |  | 191d? | 2010-02-02 A | 2010-12-10 | 40% | 114.6d? | 2010-02-02 | 2010-12-10 | 191d? | 425.8d | finish no earlier than 2010-12-10 | R3,R2 | 1528h | 611.2h | FS_Energy_LTE | PCG-24 | China Mobile | Rel-10 | RP-47 | Juha |  |  | RP-101010 |
| 337 | 147 | Study on Signalling and procedure for interference avoidance for in-device coexistence |  | 136d? | 2010-06-04 A | 2010-12-10 | 25% | 102d? | 2010-06-04 | 2010-12-10 | 136d? | 425.8d | finish no earlier than 2010-12-10 | R2,R4 | 1088h | 272h | FS_SPIA_IDC | PCG-25 | China Mobile | Rel-10 | RP-48 | Joern |  |  | RP-100800 |
| 338 | 148 | Study on Measurement of Radiated Performance for MIMO and multi-antenna reception for HSPA and LTE terminals |  | 391.8d? | 2009-03-06 A | 2010-12-10 | 85% | 58.77d? | 2009-03-06 | 2010-12-10 | 391.8d? | 425.8d | finish no earlier than 2010-09-10 | R4 | 3134.4h | 2664.24h | FS_HSPA_LTE_measRP_MIMO_multi-antenna | PCG-22 | Vodafone | Rel-10 | RP-43 | Issam |  |  | RP-100793 |
| 339 | 149 | Study on Extending 850 MHz |  | 401d? | 2009-05-30 A | 2010-12-10 | 45% | 220.55d? | 2009-05-30 | 2010-12-10 | 401d? | 425.8d | finish no earlier than 2010-12-10 | R4 | 3208h | 1443.6h | FS_e850 | PCG-23 | Ericsson | Rel-10 | RP-44 | Issam |  |  | RP-100794 |
| 340 | 150 | Study on RAN improvements for Machine-Type Communications |  | 321d? | 2009-09-18 A | 2010-12-10 | 40% | 192.6d? | 2009-09-18 | 2010-12-10 | 321d? | 425.8d | finish no earlier than 2010-12-10 | R2,R1,R3,R4 | 2568h | 1027.2h | FS_NIMTC_RAN | PCG-23 | Huawei | Rel-10 | RP-45 | Joern |  |  | RP-100795 |
| 341 | 151 | Study on GERAN improvements for Machine-Type Communications |  | 197.5d? | 2010-05-24 A | 2011-03-04 | 15% | 167.88d? | 2010-05-24 | 2011-03-04 | 197.5d? | 365.8d | finish no earlier than 2011-03-04 | G1,G2 | 1580h | 237h | FS_NIMTC_GERAN | PCG-24 | Ericsson | Rel-10 | GP-44 | Paolo |  |  |  |
| 342 | 152 | Study on Signal Precoding enhancements for EGPRS2 DL |  | 61d? | 2010-09-03 A | 2010-11-26 | 15% | 51.85d? | 2010-09-03 | 2010-11-26 | 61d? | 435.8d | finish no earlier than 2010-11-26 | G1,G2 | 488h | 73.2h | FS_SPEED | PCG-25 | Ericsson | Rel-10 | GP-46 | Paolo |  |  |  |
| 343 | 153 | Deleted - Study on Unauthenticated PS Emergency Calls |  | 471d? | 2008-06-05 A | 2010-03-25 A | 100% |  | 2008-06-05 | 2010-03-25 | 471d? |  | finish no earlier than 2010-03-25 | S1 | 3768h | 3768h | FS_UAPSEC | PCG-21 | Nokia Siemens Networks | Rel-10 | SP-40 | Alain | PCG-24 | SP-47 |  |
| 344 | 154 | Deleted - Study on EPC Charging enhancement |  | 211d? | 2009-06-04 A | 2010-03-25 A | 100% |  | 2009-06-04 | 2010-03-25 | 211d? |  | finish no earlier than 2010-03-25 | S5 | 1688h | 1688h | FS_EPCcharg | PCG-23 | Nokia Siemens Networks | Rel-10 | SP-44 | Dionisio | PCG-24 | SP-47 |  |
| 345 | 155 | Deleted - Study on Interworking Proxy between GTP based and PMIP based interfaces |  | 186d? | 2009-09-18 A | 2010-06-04 A | 100% |  | 2009-09-18 | 2010-06-04 | 186d? |  | finish no earlier than 2010-06-04 | C4 | 1488h | 1488h | FS_GTP-MIP-IW | PCG-23 | NTT DoCoMo | Rel-10 | CP-45 | Kimmo | PCG-25 | CP-48 |  |
| 346 | 156 | Release 9 Features | milestone | 0d? | 2008-06-05 A | 2008-06-05 | 99% | 0d? | 2008-06-05 | 2008-06-05 | 0d? | 0d |  | CP,GP,RP,SP |  |  |  |  |  | Rel-9 |  |  |  |  |  |

Notes:
- 287: SP#47 work stopped (depending on ongoing related CT4 work). Stage 1 in UID_320022 Rel-8 Requirements for evolution of the 3GPP system architecture (AIPN-SAE): 22.278, 22.011, 22.246 / Text5: Haining Wang (wanghaining@huawei.com)
- 288: SP#47 work stopped / Text3: 23.402 / Text5: Haining Wang (wanghaining@huawei.com)
- 289: RP#47 work stopped/abandoned (no CR approved). Cell sets the TTI (Transmission Time Interval) to 2 ms / Text3: 25.133, 25.212, 25.214, 25.321, 25.331 / Text5: Karri Ranta-aho (karri.ranta-aho@nsn.com)
- 290: SP#47 deleted (SA2 work moved under SA1 UID_450053). SP#44 Umbrella Feature created to host WIs moved out of Rel-9 (SA2 UID_420034 on IMS aspects of Architecture for Home NodeB) / Text5: Nicolas Drevon
- 291: RP#49 stopped (no further standardization needed). Ensure that Enhanced Interference Management methods identified in Rel-9 for HNBs do not fail in deployments with a large penetration of CSG-aware UEs / Text3: UTRA / Text5: Andrei Radulescu (aradules@qualcomm.com)
- 292: RP#49 stopped (no further standardization needed) / Text3: 25.413, 25.467, 25.469 / Text5: Andrei Radulescu (aradules@qualcomm.com)
- 293: -
- 294: SP#47 completed. TR 22.813-100 for Approval. Spin-off Feature UID_470030 Codec for Enhanced Voice Services / Text3: 22.813 / Text5: LOTTIN, Philippe
- 295: SP#47 completed. TR 22.813-100 for Approval / Text3: 22.813 / Text5: LOTTIN, Philippe
- 296: SP#47 completed. TR 22.813-100 for Approval / Text3: 22.813 / Text5: stefan.bruhn@ericson.com
- 297: SP#46 completed. Linked to Rel-8 Feature UID_380060 IP Interconnection of Services (IPinterc). Spin-off Feature Rel-11 UID_470051 Advanced IP Interconnection of Services / Text3: 22.893 / Text5: chris.friel@O2.com
- 298: SP#47 completed / Text3: 22.947 / Text5: Jaihyung Cho
- 299: SP#47 completed / Text3: 22.814 / Text5: jinhan.song@sktelecom.com
- 300: SP#47 completed. Covers Mobile/Fixed/Cordless/etc terminals. Haptic (human-machine tactile communication) extend service offering & richness of user experience beyond current visual & auditory senses / Text3: 22.987 / Text5: jinhan.song@sktelecom.com
- 301: SP#46 completed. Spin-off Feature UID_460028 Optimal Media Routeing (OMR). Linked to Study on Multimedia Session Continuity UID_350051, Study on Centralized IMS Service Control UID_330012, IMS inter-operator service interconnection interface UID_360011 / Text3: 23.894 / Text5: mario.madella@telecomitalia.it, victor.kueh@bt.com
- 302: SP#47 completed. Concluded no further normative work expected. Linked to 23.236 / Text3: 23.924 (was 23.823) / Text5: LIU HONG (liuhongyfw@chinamobile.com)
- 303: SP#48 updated WID SP-080558=>SP-100360 / Text3: 23.812 / Text5: Li Gang (ligangyf@chinamobile.com), Yu Qing (yuqing@chinamobile.com)
- 304: SP#49 completion 09/10=>12/10 / Text3: 23.848 / Text5: Rajat Ghai (rghai@starentnetworks.com)
- 305: SP#49 completion 09/10=>12/10 (No consensus on starting normative work for network-based mobility (PMIP) option. Note: DSMIPv6-based option already pursued in 23.261). Spin-off UID_430035 MAPCON and UID_450041 IFOM / Text3: 23.861 / Text5: Gerardo Giaretta (gerardog@qualcomm.com)
- 306: Study an evolved policy solution through enhancement of 3GPP policy framework (Stage 2). Consider aspects such as DPI, traffic steering, enhancing service policies / Text3: 23.813 / Text5: farooq.bari@att.com
- 307: SP#49 completion 09/10=>03/11. Some of these solutions may have impacts on 3GPP network elements and terminals. / Text3: 23.975 / Text5: Li Lianyuan (lilianyuan@chinamobile.com), Liu Hong (liuhongyfw@chinamobile.com)
- 308: SP#49 completed (Conclusion: select the SIP anchoring based solution for normative work CR (TEI10) introducing and completing stage-2). Analyzed performance of Rel-8 SRVCC solution from E-UTRAN/HSPA to UTRAN/GERAN / Text3: 23.856 / Text5: Hou zhiqiang (houzhiqiang@chinamobile.com), Jiang Yi (jiangyi@chinamobile.com)
- 309: SP#49 completion 09/10=>12/10. TR 23.885v100 for Information. Study on "reverse direction" from UTRAN/GERAN to E-UTRAN/HSPA (Rel-8 SRVCC was in the other direction E-UTRAN/HSPA to GERAN/UTRAN) / Text3: 23.885 / Text5: delphin.barankanira@orange-ftgroup.com
- 310: SP#49 completed. TR 23.886v100 for Approval. Related to Rel-8 UID_350030 Single Radio Voice Call Continuity for 3GPP (SAES-SRVCC). Study how to provide Video Call seamless service continuity for 3G/LTE terminal user / Text3: 23.886 / Text5: Haris Zisimopoulos (haris.z@samsung.com)
- 311: SP#48 completed. Triggered by Rel-8 UID_350027 SAE for support for non-3GPP accesses. Nature of relationship: S2b one of the interfaces defined for non-3GPP accesses support in EPS. Stage 1 in Rel-8 UID_320022 (AIPN-SAE) 22.278,22.101 / Text3: 23.834 / Text5: bruno.landais@alcatel-lucent.com
- 312: - / Text3: 33.859 / Text5: Karl Norrman
- 313: Continuation of Rel-9 Feature UID_430036 IMS Media Plane Security (MEDIASEC). Study solutions and extensions to features and functionality described in TR 33.828 and TS 33.328. / Text3: 33.8xy / Text5: Peter.Howard@vodafone.com
- 314: SP#49 updated WID SP-100438=>SP-100639. Study reuse of non-UICC credentials (in particular SIP Digest) to provide security for the access to applications. Provide reference material for IMS based non-UICC based SSO to applications / Text3: 33.8xy / Text5: Silke.Holtmanns@nokia.com
- 315: SP#49 completion 09/10=12/10. Extend Rel-8 UID_34043 (Extending PSS and MBMS User Services for optimized Mobile TV) / Text3: 26.950 / Text5: jan.plogsties@iis.franhofer.de
- 316: Continues and extends Rel-9 Improved Video Support for PSS and MBMS (UID_430039). Mobile terminals shipped nowadays are compatible with several access technologies and equipped with larger screens and higher screen resolutions / Text3: 26.9xy / Text5: imed.bouazizi@nokia.com, jaihyung@etri.re.kr
- 317: SP#47 completed / Text3: 32.825 / Text5: shan.mingjun@huawei.com
- 318: SP#47 completed. Study result might impact Feature UID_420011 Self Organising Networks (SON) / Text3: 32.826 / Text5: Jean-Michel Cornilly (Orange)
- 319: SP#47 completed. TR 32.827 v100 for Information + Approval. WID updated SP-090462=>SP-100088. Study the missing Itf-N part in the Framework. Study changes to Itf-N to utilize UE based measurements / Text3: 32.827 / Text5: Yizhi Yao (yzyao@motorola.com)
- 320: SP#48 TR 32.828 v100 for Information / Text3: 32.828 / Text5: olaf.pollakowski@nsn.com
- 321: SP#48 TR 32.829 v100 for Information / Text3: 32.829 / Text5: olaf.pollakowski@nsn.com, Padma.Sudarsan@alcatel-lucent.com
- 322: SP#49 completion 09/10=>03/11 / Text3: 32.830 / Text5: thomas.tovinger@ericsson.com
- 323: - / Text3: 32.832 / Text5: edwin.tse@ericsson.com
- 324: - / Text3: 32.831 / Text5: Padma.Sudarsan@alcatel-lucent.com
- 325: - / Text3: 32.8xy / Text5: olaf.pollakowski@nsn.com
- 326: - / Text3: 32.9xy / Text5: Linda.Garbanati@alcatel-lucent.com
- 327: CP#49 completed (the solution will be choosen during a separate implementation work) / Text3: 29.816 / Text5: gottfried.punz@nw.neclab.eu
- 328: Linked to SA5 UID_430044 (FS_OAM-ESM) & UID_470037 (OAM-ES), RAN3 UID_470015 (FS_Energy_LTE), RAN1 UID_460016 (FS_Energy_UMTS) / Text3: 24.826 / Text5: gottfried.punz@nw.neclab.eu
- 329: Study UDC evolution from Features in Rel-9 UID_400034 and Rel-10 UID_480011 UDC Data Model / Text3: 23.845 / Text5: jean-jacques.trottin@alcatel-lucent.com
- 330: - / Text3: 31.828 / Text5: Denis L'Heriteau (Denis.Lheriteau@gemalto.com)
- 331: Linked to SA2 UID_490036 Study on Core Network Overload solutions / Text3: 23.857 / Text5: lu.fei1@zte.com.cn
- 332: RP#48 completed / Text3: UTRA 25.863 / Text5: Heechoon Lee (heechoon@qualcomm.com)
- 333: RP#49 completed. Based on ETSI EE TS 102 706. / Text3: UTRA 25.927 / Text5: Prakash.bhat@vodafone.com
- 334: - / Text3: UTRA 25.8xy / Text5: huang.he4@zte.com.cn
- 335: RP#49 start on hold until 12/10 / Text3: LTE 36.8xx / Text5: bruno.clerckx@samsung.com
- 336: RP#48 updated WID RP-100393=>RP-100674 / Text3: LTE 36.8xx (Potential solutions for energy saving for E-UTRAN) / Text5: Yang Ning (yangning@chinamobile.com)
- 337: Study coexistence scenario of LTE and Industrial, Scientific and Medical (ISM) Radio within the same device working in adjacent frequencies. Investigate suitable mechanisms for interference avoidance from signalling and procedure point of view. / Text3: LTE 36.816 / Text5: Zhenping Hu (huzhenping@chinamobile.com)
- 338: Work on hold / Text3: UTRA, LTE 37.976 / Text5: soonleh.ling@vodafone.com
- 339: RP#48 completion 06/10=>12/10 / Text3: UTRA, LTE TR 37.806 / Text5: christian.bergljung@stericsson.com
- 340: On hold until closing WI UID_490023 NIMTC-RAN_overload. Triggered by UID_7027 Study on Facilitating Machine to Machine Communication in GSM and UMTS (M2M) TR 22.868 and Rel-10 UID_410030 Network Improvements for Machine-Type Communications (NIMTC) / Text3: UTRA, LTE 37.868 / Text5: Jeff Gao (gaoyq@huawei.com)
- 341: GP#47 completion 09/10=>03/11. GP#44 approved SID / Text3: GERA 43.868 / Text5: paul.schliwa-bertling@ericsson.com
- 342: GP#46 approved SID. The concept of Precoded EGPRS2 DL provides significant performance gains for EGPRS2 (in interference and sensitivity limited scenarios, allowing significant increase to data capacity and spectral efficiency) / Text3: GERA 45.860 / Text5: marten.sundberg@ericsson.com
- 343: SP#47 work stopped/abandoned / Text3: 22.984 / Text5: Juergen Merkel
- 344: SP#47 work stopped. Issue covered by Rel-10 UID_460039 Charging for LIPA_SIPTO and UID_4700xy Charging for IFOM / Text5: Gerald.Goermer@nsn.com
- 345: CP#48 work stopped/abandoned / Text3: 29.875 / Text5: takaaki.matsuura.sp@s1.nttdocomo.com
- 346: -

| ID | WBS | Task | Duration | Start | Finish | Complete | Remaining | Baseline start | Baseline finish | Baseline duration | Total slack | Constraint | Resources | Work | Actual work | Text1 | Text2 | Text4 | Text5 | Text6 | Text7 | Text8 | Text11 |
| --- | --- | --- | --- | --- | --- | --- | --- | --- | --- | --- | --- | --- | --- | --- | --- | --- | --- | --- | --- | --- | --- | --- | --- |
| 347 | 157 | **Enhanced Home NodeB / eNodeB** | 923d? | 2008-06-05 A | 2011-12-16 | 91% | 82.73d? | 2008-06-05 | 2011-12-16 | 923d? | 160.8d |  | S1,S2,S3,S5,C1,C6,R2,R3,R4,GP | 35808h | 27783.6h | EHNB | PCG-21 | T-Mobile | michael.kurz@t-mobile.at | Rel-9 | SP-40 | Alain |  |
| 348 | 157.1 | Stage 1 for EHNB | 261d? | 2008-06-05 A | 2009-06-04 A | 100% |  | 2008-06-05 | 2009-06-04 | 261d? |  | finish no earlier than 2009-06-04 | S1 | 2088h | 2088h | EHNB | PCG-21 | T-Mobile | michael.kurz@t-mobile.at | Rel-9 | SP-40 | Alain |  |
| 349 | 157.2 | Architecture aspects of EHNB | 266d? | 2008-09-18 A | 2009-09-24 A | 100% |  | 2008-09-18 | 2009-09-24 | 266d? |  | finish no earlier than 2009-09-22 | S2 | 2128h | 2128h | EHNB | PCG-21 | T-Mobile | Sebastian Speicher | Rel-9 | SP-41 | Maurice |  |
| 350 | 157.3 | Security aspects of Enhanced Home NodeB / eNodeB | 262d? | 2008-12-11 A | 2009-12-10 A | 100% |  | 2008-12-11 | 2009-12-10 | 262d? |  | finish no earlier than 2009-12-10 | S3 | 2096h | 2096h | EHNB-Sec | PCG-22 | Huawei | Marcus Wong (mwong@huawei.com) | Rel-9 | SP-42 | Dionisio |  |
| 351 | 157.4 | CT1 aspects - Support of Home NB and Home eNB enhancements | 321d? | 2009-09-18 A | 2010-12-10 | 95% | 16.05d? | 2009-09-18 | 2010-12-10 | 321d? | 425.8d | finish no earlier than 2010-12-10 | C1 | 2568h | 2439.6h | EHNB-CT1 | PCG-23 | Qualcomm | Ramachandran Subramanian (rsubrama@qualcomm.com) | Rel-9 | CP-45 | Frederic |  |
| 352 | 157.5 | CT6 aspects - Support of Home NB and Home eNB enhancements | 131d? | 2009-09-18 A | 2010-03-19 A | 100% |  | 2009-09-18 | 2010-03-19 | 131d? |  | finish no earlier than 2010-03-19 | C6 | 1048h | 1048h | EHNB-CT6 | PCG-23 | Qualcomm | Alfredo Ruvacalba | Rel-9 | CP-45 | Xavier |  |
| 353 | 157.6 | 3G HNB Gateway and LTE HeNB Gateway OAM&P | 336d? | 2008-12-11 A | 2010-03-25 A | 100% |  | 2008-12-11 | 2010-03-25 | 336d? |  | finish no earlier than 2010-03-25 | S5 | 2688h | 2688h | HNB-OAM_GW | PCG-22 | China Mobile | GangChen (chengang@chinamobile.com) | Rel-9 | SP-42 | Dionisio |  |
| 354 | 157.7 | 3G HNB and LTE HeNB OAM&P Type 1 Interface | 272d? | 2009-03-12 A | 2010-03-25 A | 100% |  | 2009-03-12 | 2010-03-25 | 272d? |  | finish no earlier than 2010-03-25 | S5 | 2168h | 2168h | HNB_eHNB-OAM_Type1 | PCG-22 | Huawei | Zou Lan (zlan@huawei.com) | Rel-9 | SP-43 | Dionisio |  |
| 355 | 157.8 | 3G HNB and LTE HeNB OAM&P Type 2 Interface | 225d? | 2009-05-15 A | 2010-03-25 A | 100% |  | 2009-05-15 | 2010-03-25 | 225d? |  | finish no earlier than 2010-03-25 | S5 | 1800h | 1800h | HNB_eHNB-OAM_Type2 | PCG-23 | Ericsson | edwin.tse@ericsson.com | Rel-9 | SP-44 | Dionisio |  |
| 356 | 157.9 | LTE FDD Home eNodeB RF Requirements | 336d? | 2008-12-05 A | 2010-03-19 A | 100% |  | 2008-12-05 | 2010-03-19 | 336d? |  | finish no earlier than 2010-03-19 | R4 | 2688h | 2688h | HeNB-RF_FDD | PCG-22 | Motorola | Ying Cai (yingcai@motorola.com) | Rel-9 | RP-42 | Issam | RP-100035 |
| 357 | 157.10 | LTE TDD Home eNodeB RF Requirements | 271d? | 2009-03-06 A | 2010-03-19 A | 100% |  | 2009-03-06 | 2010-03-19 | 271d? |  | finish no earlier than 2010-03-19 | R4 | 2168h | 2168h | HeNB-RF_TDD | PCG-22 | China Mobile | Nan Li (linan@chinamobile.com) | Rel-9 | RP-43 | Issam | RP-100036 |
| 358 | 157.11 | Home NB and Home eNB enhancements - RAN3 aspects | 197d? | 2009-03-06 A | 2009-12-04 A | 100% |  | 2009-03-06 | 2009-12-04 | 197d? |  | finish no earlier than 2009-12-04 | R3 | 1576h | 1576h | EHNB-RAN3 | PCG-22 | Alcatel-Lucent | Martin Warner (mw15@alcatel-lucent.com) | Rel-9 | RP-43 | Juha | RP-091050 |
| 359 | 157.12 | Home NB and Home eNB enhancements - RAN2 aspects | 271d? | 2009-03-06 A | 2010-03-19 A | 100% |  | 2009-03-06 | 2010-03-19 | 271d? |  | finish no earlier than 2010-03-19 | R2 | 2168h | 2168h | EHNB-RAN2 | PCG-22 | Huawei | Yang Xudong (yangxudong@huawei.com) | Rel-9 | RP-43 | Joern | RP-100037 |
| 360 | 157.13 | Conformance Test Aspects – Home NB enhancements for FDD | 326d? | 2010-09-17 | 2011-12-16 |  |  | 2010-09-17 | 2011-12-16 | 326d? | 160.8d | finish no earlier than 2011-12-16 | R5 | 2608h |  | EHNB-UTRA_FDD_UEConTest | PCG-25 | Huawei | trica_li@huawei.com | Rel-9 | RP-49 | Ingbert |  |
| 361 | 157.14 | Home NB and Home eNB enhancements - GERAN aspects | 341d? | 2009-05-18 A | 2010-09-03 A | 100% |  | 2009-05-18 | 2010-09-03 | 341d? |  | finish no earlier than 2010-09-03 | GP | 2728h | 2728h | EHNB-GERAN | PCG-23 | Nokia Siemens Networks | Leonardo Provvedi | Rel-9 | GP-42 | Paolo |  |
| 362 | 158 | **Value-Added Services for Short Message Service** | 586d? | 2007-09-10 A | 2009-12-04 A | 100% |  | 2007-09-10 | 2009-12-04 | 586d? |  |  | S1,C4,C1 | 10888h | 10888h | VAS4SMS |  | China Mobile | Wu Bin (wubin@chinamobile.com) | Rel-9 | SP-37 | Alain |  |
| 363 | 158.1 | Stage 1 for VAS4SMS | 133d? | 2007-09-10 A | 2008-03-12 A | 100% |  | 2007-09-10 | 2008-03-12 | 133d? |  | finish no earlier than 2008-03-21 | S1 | 1064h | 1064h | VAS4SMS |  | China Mobile | Wu Bin (wubin@chinamobile.com) | Rel-9 | SP-37 | Alain |  |
| 364 | 158.2 | CT4 aspects of VAS4SMS Interface and Signalling Flow | 322d? | 2008-09-12 A | 2009-12-04 A | 100% |  | 2008-09-12 | 2009-12-04 | 322d? |  | finish no earlier than 2009-12-04 | C4 | 2568h | 2568h | VAS4SMS | PCG-21 | China Mobile | Wu Bin (wubin@chinamobile.com) | Rel-9 | CP-41 | Kimmo |  |
| 365 | 158.3 | CT1 aspects of VAS4SMS Interface and Signalling Flow | 321d? | 2008-09-09 A | 2009-12-04 A | 100% |  | 2008-09-09 | 2009-12-04 | 321d? |  | finish no earlier than 2009-12-04 | C1 | 2568h | 2568h | VAS4SMS | PCG-21 | China Mobile | Wu Bin (wubin@chinamobile.com) | Rel-9 | CP-41 | Frederic |  |
| 366 | 159 | **Definition of End-User Identity** | 334d? | 2007-09-03 A | 2008-12-11 A | 100% |  | 2007-09-03 | 2008-12-11 | 334d? |  |  | S1 | 5344h | 5344h | EUI |  | Nokia Siemens Networks | Juergen.Merkel@nsn.com | Rel-9 | SP-38 | Alain |  |
| 367 | 159.1 | Definition of End-User Identity | 334d? | 2007-09-03 A | 2008-12-11 A | 100% |  | 2007-09-03 | 2008-12-11 | 334d? |  | finish no earlier than 2008-12-11 | S1 | 2672h | 2672h | EUI | PCG-21 | Nokia Siemens Networks | Juergen.Merkel@NSN.com | Rel-9 | SP-38 | Alain |  |
| 368 | 160 | **Customized Ringing Signal** | 653d? | 2007-12-06 A | 2010-06-04 A | 100% |  | 2007-12-06 | 2010-06-04 | 653d? |  |  | S1,C1 | 8168h | 8168h | CRS | PCG-21 | SK Telecom, China Mobile | Donghee Shim (SK Telecom), Jianping Zheng (China Mobile) | Rel-9 | SP-38 | Alain |  |
| 369 | 160.1 | Stage 1 for Customized Ringing Signal | 266d? | 2007-12-06 A | 2008-12-11 A | 100% |  | 2007-12-06 | 2008-12-11 | 266d? |  | finish no earlier than 2008-12-11 | S1 | 2128h | 2128h | CRS | PCG-21 | SK Telecom, China Mobile | Donghee Shim (SK Telecom), Jianping Zheng (China Mobile) | Rel-9 | SP-38 | Alain |  |
| 370 | 160.2 | Stage 3 for IMS Customized Ringing Signal (CRS) Service | 267d? | 2009-05-29 A | 2010-06-04 A | 100% |  | 2009-05-29 | 2010-06-04 | 267d? |  | finish no earlier than 2010-06-04 | C1 | 816h | 816h | CRS | PCG-23 | China Mobile | wangzhao | Rel-9 | CP-44 | Frederic |  |

Notes:
- 347: CP#49 the SA1-reqs are moving. CT1 will align when the work in SA1 is clear / Text3: UTRA, LTE
- 348: CP#49 the SA1-reqs are moving. CT1 will align when the work in SA1 is clear. (was SP#44 completed.) / Text3: 22.220, 22.011
- 349: SP#45 completed / Text3: 23.401, 23.402, 23.060, new 23.830
- 350: SP#46 completed / Text3: new 33.320
- 351: CP#49 the SA1-reqs are moving. CT1 will align when the work in SA1 is clear. Roaming aspects for manual CSG selection, Support of temporary users and CSG membership changes, Support of user controlled and operator controlled lists / Text3: 23.122, 24.008, 24.285, 24.301
- 352: CP#47 completed. Storing of CSG related data items on the USIM / Text3: 31.102
- 353: SP#47 completed / Text3: 32.632, 32.633, 32.635, new (32.771, 32.772, 32.773, 32.775, 32.781, 32.782, 32.783, 32.785)
- 354: SP#47 completed / Text3: 32.581, 32.582, 32.583, 32.584, new (32.591, 32.592, 32.593, 32.594)
- 355: SP#47 completed / Text3: new 32.571, 32.572
- 356: RP#47 completed / Text3: new TR 36.921, 36.104, 36.141
- 357: RP#47 completed / Text3: new TR 36.922, 36.104, 36.141, 36.300, 36.331, 36.413
- 358: RP#46 completed (based on high priority items specified in RP-090995) / Text3: 25.413, 25.467, 25.467, 25.468, 25.469, 25.469, 36.401, 36.413, new 25.444
- 359: RP#47 completed / Text3: 25.304, 25.331, 25.367, 36.300, 36.304, 36.331
- 360: UTRA. Testing for UID_430026 Support of Home NB and Home eNB enhancements RAN2 aspects (25.304, 25.331, 25.367) / Text3: 34.108, 34.123-1, 34.123-2, 34.123-3
- 361: GP#47 completed. GP#42 WID approved / Text3: 43.055, 43.129, 44.018, 44.060, 45.008, 48.008, 48.018
- 362: CP#46 completed
- 363: SP#39 completed. SP#43 Feature moved to Rel-9 / Text3: 22.142
- 364: CP#46 completed / Text3: new 23.142
- 365: CP#46 completed / Text3: 23.040
- 366: SP#42 closed. Stage 1 work closed at 5% completion due to lack of input (added only the EUI definition in 21.905)
- 367: SP#42 closed. Stage 1 work closed at 5% completion due to lack of input (added only the EUI definition in 21.905) / Text3: 21.905
- 368: CP#48 completed
- 369: SP#42 completed. / Text3: 22.173, new 22.183
- 370: CP#48 completed / Text3: 24.173, new 24.183

| ID | WBS | Task | Type | Duration | Start | Finish | Complete | Baseline start | Baseline finish | Baseline duration | Constraint | Resources | Work | Actual work | Text1 | Text2 | Text3 | Text4 | Text6 | Text7 | Text8 | Text11 |
| --- | --- | --- | --- | --- | --- | --- | --- | --- | --- | --- | --- | --- | --- | --- | --- | --- | --- | --- | --- | --- | --- | --- |
| 371 | 161 | **Public Warning System** |  | 523d? | 2007-12-06 A | 2009-12-04 A | 100% | 2007-12-06 | 2009-12-04 | 523d? |  | S1,C1,C4,R2 | 10232h | 10232h | PWS | PCG-21 | GERA, UTRA, LTE | T-Mobile | Rel-9 | SP-38 | Alain |  |
| 372 | 161.1 | Stage 1 for Public Warning System |  | 266d? | 2007-12-06 A | 2008-12-11 A | 100% | 2007-12-06 | 2008-12-11 | 266d? | finish no earlier than 2008-12-11 | S1 | 2128h | 2128h | PWS | PCG-21 | 22.268 | T-Mobile | Rel-9 | SP-38 | Alain |  |
| 373 | 161.2 | **Stage 3 for Public Warning System** |  | 137d? | 2009-05-29 A | 2009-12-04 A | 100% | 2009-05-29 | 2009-12-04 | 137d? |  | C1,C4 | 3272h | 3272h | PWS-St3 | PCG-23 |  | Qualcomm | Rel-9 | CP-44 | Frederic |  |
| 374 | 161.2.1 | CT1 aspects of Stage 3 for Public Warning System |  | 137d? | 2009-05-29 A | 2009-12-04 A | 100% | 2009-05-29 | 2009-12-04 | 137d? | finish no earlier than 2009-12-04 | C1 | 1088h | 1088h | PWS-St3 | PCG-23 | 23.041 | Qualcomm | Rel-9 | CP-44 | Frederic |  |
| 375 | 161.2.2 | CT4 aspects of Stage 3 for Public Warning System |  | 136d? | 2009-05-30 A | 2009-12-04 A | 100% | 2009-05-30 | 2009-12-04 | 136d? | finish no earlier than 2009-12-04 | C4 | 1088h | 1088h | PWS-St3 | PCG-23 | 29.168 | Qualcomm | Rel-9 | CP-44 | Kimmo |  |
| 376 | 161.3 | Public Warning System (PWS) – RAN aspects |  | 81d? | 2009-05-30 A | 2009-12-04 A | 100% | 2009-05-30 | 2009-12-04 | 81d? | finish no earlier than 2009-12-04 | R2,R3 | 648h | 648h | PWS-RAN | PCG-23 | LTE 36.300, 36.302, 36.331, 36.413 | AT&T | Rel-9 | RP-44 | Joern | RP-091052 |
| 377 | 162 | **Support of Personal Area Networks and Enhancements to Personal Network Management** |  | 523d? | 2008-06-05 A | 2010-06-04 A | 100% | 2008-06-05 | 2010-06-04 | 523d? |  | S1,C1 | 8360h | 8360h | PAN_EPNM | PCG-21 |  | Vodafone | Rel-9 | SP-40 | Alain |  |
| 378 | 162.1 | Stage 1 for PAN_EPNM | milestone | 0d? | 2008-06-05 A | 2008-06-05 A | 100% | 2008-06-05 | 2008-06-05 | 0d? | finish no earlier than 2008-06-05 | S1 |  |  | PAN_EPNM | PCG-21 | 22.259 | Vodafone | Rel-9 | SP-40 | Alain |  |
| 379 | 162.2 | Stage 2 for Support of Personal Area Networks and Enhancements to Personal Network Managemen |  | 196d? | 2009-03-06 A | 2009-12-04 A | 100% | 2009-03-06 | 2009-12-04 | 196d? | finish no earlier than 2009-12-04 | C1 | 1568h | 1568h | PAN_EPNM | PCG-22 | 23.259 | Huawei | Rel-9 | CP-43 | Frederic |  |
| 380 | 162.3 | Stage 3 for Support of Personal Area Networks and Enhancements to Personal Network Managemen |  | 326d? | 2009-03-09 A | 2010-06-04 A | 100% | 2009-03-09 | 2010-06-04 | 326d? | finish no earlier than 2010-06-04 | C1 | 2608h | 2608h | PAN_EPNM | PCG-22 | 24.259 | Huawei | Rel-9 | CP-43 | Frederic |  |
| 381 | 163 | **Multi-Media Telephony Service enhancements** |  | 472d? | 2008-06-05 A | 2010-03-25 A | 100% | 2008-06-05 | 2010-03-25 | 472d? |  | S1,S5,C1 | 10288h | 10288h | eMMTel | PCG-21 |  | France Telecom | Rel-9 | SP-40 | Alain |  |
| 382 | 163.1 | Stage 1 for eMMTel |  | 136d? | 2008-06-05 A | 2008-12-11 A | 100% | 2008-06-05 | 2008-12-11 | 136d? | start no earlier than 2008-06-05 | S1 | 1088h | 1088h | eMMTel | PCG-21 | 22.173 | France Telecom | Rel-9 | SP-40 | Alain |  |
| 383 | 163.2 | Multimedia Telephony (MMTel) Service and Supplementary Services - Online Charging and completion for Offline Charging (all supplementary services) |  | 272d? | 2009-03-12 A | 2010-03-25 A | 100% | 2009-03-12 | 2010-03-25 | 272d? | finish no earlier than 2010-03-25 | S5 | 2168h | 2168h | eMMTel-SS-CH | PCG-22 | 32.275, 32.298, 32.299 | Alcatel-Lucent | Rel-9 | SP-43 | Dionisio |  |
| 384 | 163.3 | Support of Real-time Transfer of Tariff Information (RTTI) in IMS charging |  | 271d? | 2009-03-12 A | 2010-03-25 A | 100% | 2009-03-12 | 2010-03-25 | 271d? | finish no earlier than 2010-03-25 | S5 | 2168h | 2168h | IMSTSS-RTTI-CH | PCG-22 | 32.240, 32.280, 32.298, 32.299 | Orange | Rel-9 | SP-43 | Dionisio |  |
| 385 | 163.4 | Stage 3 - Enhancements for Completion of Communications Supplementary service |  | 136d? | 2009-05-30 A | 2009-12-04 A | 100% | 2009-05-30 | 2009-12-04 | 136d? | finish no earlier than 2009-12-04 | C1 | 1088h | 1088h | eMMTel-CC | PCG-23 | 24.642 | France Telecom | Rel-9 | CP-44 | Frederic |  |
| 386 | 164 | **User Data Convergence (UDC)** |  | 527d? | 2008-06-05 A | 2010-06-10 A | 100% | 2008-06-05 | 2010-06-10 | 527d? |  | S1,S5,C4 | 14456h | 14456h | UDC | PCG-21 |  | Nokia Siemens Networks | Rel-9 | SP-40 | Alain |  |
| 387 | 164.1 | Stage 1 for User Data Convergence (UDC) |  | 136d? | 2008-06-05 A | 2008-12-11 A | 100% | 2008-06-05 | 2008-12-11 | 136d? | start no earlier than 2008-06-05 | S1 | 1088h | 1088h | UDC | PCG-21 | 22.985, 22.101 | Nokia Siemens Networks | Rel-9 | SP-40 | Alain |  |
| 388 | 164.2 | User Data Convergence (UDC) Technical Realization (Stage 2) |  | 271d? | 2009-03-06 A | 2010-03-19 A | 100% | 2009-03-06 | 2010-03-19 | 271d? | finish no earlier than 2010-03-19 | C4 | 2168h | 2168h | UDC-CN | PCG-22 | new 23.335 | Ericsson | Rel-9 | CP-43 | Kimmo |  |
| 389 | 164.3 | User Data Convergence (UDC) Protocol Description |  | 130d? | 2009-09-18 A | 2010-03-19 A | 100% | 2009-09-18 | 2010-03-19 | 130d? | finish no earlier than 2010-03-19 | C4 | 1040h | 1040h | UDC-CN | PCG-23 | new 29.335 | China Mobile, Ericsson | Rel-9 | CP-45 | Kimmo |  |
| 390 | 164.4 | **User Data Convergence (UDC) Modelling and Management** |  | 266d? | 2009-06-04 A | 2010-06-10 A | 100% | 2009-06-04 | 2010-06-10 | 266d? |  | S5 | 5944h | 5944h | UDC-MMAN | PCG-23 |  | T-Mobile, China Mobile, Ericsson | Rel-9 | SP-44 | Dionisio |  |
| 391 | 164.4.1 | UDC – Framework for Model Handling and Management |  | 266d? | 2009-06-04 A | 2010-06-10 A | 100% | 2009-06-04 | 2010-06-10 | 266d? | finish no earlier than 2010-06-10 | S5 | 2128h | 2128h | UDC-MMAN-MFRM | PCG-23 | 32.172, new 32.181 | T-Mobile | Rel-9 | SP-44 | Dionisio |  |
| 392 | 164.4.2 | UDC – Common Baseline Information Model |  | 211d? | 2009-06-04 A | 2010-03-25 A | 100% | 2009-06-04 | 2010-03-25 | 211d? | finish no earlier than 2010-03-25 | S5 | 1688h | 1688h | UDC-MMAN-CBIM | PCG-23 | 32.172, new 32.182 | China Mobile, Ericsson | Rel-9 | SP-44 | Dionisio |  |
| 393 | 165 | **IMS Services Centralization and Continuity** |  | 393d? | 2008-09-18 A | 2010-03-19 A | 100% | 2008-09-18 | 2010-03-19 | 393d? |  | S1,S2,C1 | 12160h | 12160h | IMS_SCC | PCG-21 |  | NEC | Rel-9 | SP-41 | Alain |  |
| 394 | 165.1 | Stage 1 - Inter-Device Transfer – Requirements |  | 61d? | 2008-09-18 A | 2008-12-11 A | 100% | 2008-09-18 | 2008-12-11 | 61d? | finish no earlier than 2009-06-18 | S1 | 488h | 488h | IMS_SCC-IDT | PCG-21 | 22.101, 22.228 | NEC | Rel-9 | SP-41 | Alain |  |
| 395 | 165.2 | Stage 2 - IMS Service Continuity Enhancements: Service, Policy and Interactions |  | 186d? | 2008-09-18 A | 2009-06-04 A | 100% | 2008-09-18 | 2009-06-04 | 186d? | finish no earlier than 2009-06-04 | S2 | 1488h | 1488h | IMS_SCC-SPI | PCG-21 | 23.838, 23.237, 23.292, 23.216 | Huawei | Rel-9 | SP-41 | Maurice |  |
| 396 | 165.3 | Stage 3 - IMS Service Continuity Enhancements: Service, Policy, Interactions and Inter UE Transfer |  | 212d? | 2009-05-29 A | 2010-03-19 A | 100% | 2009-05-29 | 2010-03-19 | 212d? | finish no earlier than 2010-03-19 | C1 | 1696h | 1696h | IMS_SCC-SPI | PCG-23 | 24.216, 24.229, 24.237 | Qualcomm | Rel-9 | CP-44 | Frederic |  |
| 397 | 165.4 | Stage 2 - IMS Centralized Services |  | 186d? | 2008-09-18 A | 2009-06-04 A | 100% | 2008-09-18 | 2009-06-04 | 186d? | finish no earlier than 2009-06-04 | S2 | 1488h | 1488h | IMS_SCC-ICS | PCG-21 | 23.292, new 23.883 | Alcatel-Lucent | Rel-9 | SP-41 | Maurice |  |
| 398 | 165.5 | Stage 3 - Enhancements to IMS Centralized Services |  | 212d? | 2009-05-29 A | 2010-03-19 A | 100% | 2009-05-29 | 2010-03-19 | 212d? | finish no earlier than 2010-03-19 | C1 | 1688h | 1688h | IMS_SCC-ICS | PCG-23 | 24.292, 24.604, 24.607, 24.608, 24.611, 24.623 | Nokia Siemens Networks | Rel-9 | CP-44 | Frederic |  |
| 399 | 165.6 | Stage 3 - IMS Centralized Services support via I1 interface |  | 271d? | 2009-03-06 A | 2010-03-19 A | 100% | 2009-03-06 | 2010-03-19 | 271d? | finish no earlier than 2010-03-19 | C1 | 2168h | 2168h | IMS_SCC-ICS_I1 | PCG-22 | 24.237, 24.292, new 24.294 | Huawei | Rel-9 | CP-43 | Frederic |  |

Notes:
- 371: TSG#46 completed. Larger scope than Rel-8 Feature UID_370051 (ETWS). Triggered by TR 22.968 Study UID_320025 (FS_PWS) / Text5: Mark.Younge@t-mobile.com
- 372: SP#42 completed / Text5: Mark.Younge@t-mobile.com
- 373: RP#46 completed / Text5: Ramachandran Subramanian (rsubrama@qualcomm.com)
- 374: CP#46 completed / Text5: Ramachandran Subramanian (rsubrama@qualcomm.com)
- 375: CP#46 completed / Text5: Ramachandran Subramanian (rsubrama@qualcomm.com)
- 376: RP#46 completed / Text5: don.zelmer@att.com
- 377: CP#48 completed / Text5: armin.toepfer@vodafone.com
- 378: SP#40 completed / Text5: armin.toepfer@vodafone.com
- 379: CP#46 completed / Text5: Lili Yang (kadyyang@huawei.com)
- 380: CP#48 completed / Text5: Lili Yang (kadyyang@huawei.com)
- 381: SP#47 completed / Text5: Philippe Lottin
- 382: SP#42 completed / Text5: Philippe Lottin
- 383: SA#47 completed / Text5: maryse.gardella@alcatel-lucent.com
- 384: SA#47 completed. Linked to SA5 Rel-8 UID_380042 AoC support in IMS Charging (IMSTSS) / Text5: Jean-Luc Garcia (jl.garcia@orange-ftgroup.com)
- 385: CP#46 completed / Text5: Youssef.chadli@orange-ftgroup.com
- 386: SP#48 completed. Triggered by Rel-8 SA5 Study of Common Profile Storage Framework of User Data for network services and management (UID_320006) TR 32.808 / Text5: juergen.merkel@nsn.com
- 387: SP#42 completed / Text5: juergen.merkel@nsn.com
- 388: CP#47 completed
- 389: CP#47 completed / Text5: Lan Si Zhong (lansizhong@chinamobile.com), emiliano.merino@ericsson.com
- 390: SP#48 completed / Text5: istvan.aba@t-mobile.at, lansizhong@chinamobile.com, miguel.a.garcia@ericsson.com
- 391: SP#48 completed / Text5: istvan.aba@t-mobile.at
- 392: SP#47 completed / Text5: Lan Si Zhong, Miguel Garcia
- 393: CP#47 completed / Text5: Joerg Swetina (joerg.swetina@nw.neclab.eu)
- 394: SP#42 completed / Text5: Joerg Swetina (joerg.swetina@nw.neclab.eu)
- 395: SP#44 completed. TR 23.838 for Approval / Text5: HengLiang Zhang (hl_zhang@huawei.com)
- 396: CP#47 completed / Text5: Roozbeh Atarius (ratarius@qualcomm.com)
- 397: SP#44 completed. TR 23.883 for Information + Approval / Text5: Andy Bennett (andybennett@alcatel-lucent.com)
- 398: CP#47 completed / Text5: Peter.Leis@nsn.com
- 399: CP#47 completed / Text5: Lili Yang(kadyyang@huawei.com)

| ID | WBS | Task | Duration | Start | Finish | Complete | Remaining | Baseline start | Baseline finish | Baseline duration | Total slack | Constraint | Resources | Work | Actual work | Text1 | Text2 | Text4 | Text5 | Text6 | Text7 | Text8 | Text11 |
| --- | --- | --- | --- | --- | --- | --- | --- | --- | --- | --- | --- | --- | --- | --- | --- | --- | --- | --- | --- | --- | --- | --- | --- |
| 400 | 166 | **Service Specific Access Control in EPS** | 333d? | 2008-12-11 A | 2010-03-19 A | 100% |  | 2008-12-11 | 2010-03-19 | 333d? |  |  | S1,C1 | 4368h | 4368h | SSAC | PCG-22 | NTT DoCoMo | Frederic Thepot (thepot@docomolab-euro.com) | Rel-9 | SP-42 | Alain |  |
| 401 | 166.1 | Stage 1 for Service Specific Access Control in EPS | 1d? | 2008-12-11 A | 2008-12-11 A | 100% |  | 2008-12-11 | 2008-12-11 | 1d? |  | start no earlier than 2008-12-11 | S1 | 8h | 8h | SSAC | PCG-22 | NTT DoCoMo | Frederic Thepot (thepot@docomolab-euro.com) | Rel-9 | SP-42 | Alain |  |
| 402 | 166.2 | Stage 3 for Service Specific Access Control in EPS | 212d? | 2009-05-29 A | 2010-03-19 A | 100% |  | 2009-05-29 | 2010-03-19 | 212d? |  | finish no earlier than 2010-03-19 | C1 | 1696h | 1696h | SSAC | PCG-23 | NTT DoCoMo | Hideyuki Yamashita (yamashitahi@s1.nttdocomo.co.jp) | Rel-9 | CP-44 | Frederic |  |
| 403 | 167 | **Support for IMS Emergency Calls over GPRS and EPS** | 831d? | 2008-01-14 A | 2011-03-18 | 89% | 88.43d? | 2008-01-14 | 2011-03-18 | 831d? | 355.8d |  | S1,S2,S3,C1,C3,C4,R2,R3,R5 | 32483.7h | 22396.5h | IMS_EMER_GPRS_EPS | PCG-21 | Alcatel-Lucent | Deborah Barclay | Rel-9 | SP-38 | Maurice |  |
| 404 | 167.1 | Stage 1 for IMS Emergency Calls over GPRS and EPS | 239d? | 2008-01-14 A | 2008-12-11 A | 100% |  | 2008-01-14 | 2008-12-11 | 239d? |  | finish no earlier than 2008-12-11 | S1 | 1912h | 1912h | IMS_EMER_GPRS_EPS | PCG-21 | Alcatel-Lucent | Deborah Barclay | Rel-9 | SP-38 | Alain |  |
| 405 | 167.2 | Stage 2 for IMS Emergency Calls over GPRS and EPS | 364d? | 2008-01-14 A | 2009-06-04 A | 100% |  | 2008-01-14 | 2009-06-04 | 364d? |  | finish no earlier than 2009-06-04 | S2 | 2912h | 2912h | IMS_EMER_GPRS_EPS | PCG-21 | Alcatel-Lucent | Deborah Barclay | Rel-9 | SP-38 | Maurice |  |
| 406 | 167.3 | Security aspects for IMS Emergency Calls over GPRS and EPS | 391d? | 2008-12-12 A | 2010-06-10 A | 100% |  | 2008-12-12 | 2010-06-10 | 391d? |  | finish no earlier than 2010-03-25 | S3 | 3128h | 3128h | IMS_EMER_GPRS_EPS-Sec | PCG-22 | Alcatel-Lucent | Deborah Barclay | Rel-9 | SP-42 | Dionisio |  |
| 407 | 167.4 | **Stage 3 for IMS Emergency Calls over GPRS and EPS** | 472d? | 2009-05-29 A | 2011-03-18 | 71% | 137.38d? | 2009-05-29 | 2011-03-18 | 472d? | 355.8d |  | C1,C3,C4,R5 | 8867.68h | 4264.48h | IMS_EMER_GPRS_EPS | PCG-23 | Alcatel-Lucent | Frank Alfano (falfano@alcatel-lucent.com) | Rel-9 | CP-44 | Frederic |  |
| 408 | 167.4.1 | CT1 aspects - Stage 3 for IMS Emergency Calls over GPRS and EPS | 212d? | 2009-05-29 A | 2010-03-19 A | 100% |  | 2009-05-29 | 2010-03-19 | 212d? |  | finish no earlier than 2010-03-19 | C1 | 1696h | 1696h | IMS_EMER_GPRS_EPS | PCG-23 | Alcatel-Lucent | Frank Alfano (falfano@alcatel-lucent.com) | Rel-9 | CP-44 | Frederic |  |
| 409 | 167.4.2 | Conformance Test Aspects - CT1 aspects for IMS Emergency Calls over GPRS and EPS | 206d? | 2010-06-04 A | 2011-03-18 | 10% | 185.4d? | 2010-06-04 | 2011-03-18 | 206d? | 355.8d | finish no earlier than 2011-03-18 | R5 | 1648h | 164.8h | IMS_EMER_GPRS_EPS_UEConTest | PCG-25 | Samsung | stoyan.baev@partner.samsung.com | Rel-9 | RP-48 | Ingbert | RP-100746 |
| 410 | 167.4.3 | CT3 aspects - Stage 3 for IMS Emergency Calls over GPRS and EPS | 82d? | 2009-05-29 A | 2009-09-18 A | 100% |  | 2009-05-29 | 2009-09-18 | 82d? |  | start no earlier than 2009-05-29 | C3 | 651.68h | 651.68h | IMS_EMER_GPRS_EPS | PCG-23 | Alcatel-Lucent | Frank Alfano (falfano@alcatel-lucent.com) | Rel-9 | CP-44 | Gwiho |  |
| 411 | 167.4.4 | CT4 aspects - Stage 3 for IMS Emergency Calls over GPRS and EPS | 137d? | 2009-05-29 A | 2009-12-04 A | 100% |  | 2009-05-29 | 2009-12-04 | 137d? |  | finish no earlier than 2009-12-04 | C4 | 1096h | 1096h | IMS_EMER_GPRS_EPS | PCG-23 | Alcatel-Lucent | Frank Alfano (falfano@alcatel-lucent.com) | Rel-9 | CP-44 | Kimmo |  |
| 412 | 167.5 | Support for IMS Emergency Calls over LTE | 206d? | 2008-12-05 A | 2009-09-18 A | 100% |  | 2008-12-05 | 2009-09-18 | 206d? |  |  | R2,R3 | 1648h | 1648h | IMS_EMER_LTE | PCG-22 | Alcatel-Lucent | Sudeep Palat (spalat@alcatel-lucent.com) | Rel-9 | RP-42 | Joern |  |
| 413 | 167.6 | Conformance Test Aspects – Support for IMS Emergency Calls over LTE | 187d? | 2010-03-25 A | 2010-12-10 | 50% | 93.5d? | 2010-03-25 | 2010-12-10 | 187d? | 425.8d | finish no earlier than 2010-12-10 | R5 | 1496h | 748h | IMS_EMER_LTE_UEConTest | PCG-24 | Ericsson | leif.mattisson@ericsson.com | Rel-9 | RP-47 | Ingbert | RP-100742 |
| 414 | 167.7 | **SRVCC support for IMS Emergency Calls** | 322d? | 2008-09-18 A | 2009-12-10 A | 100% |  | 2008-09-18 | 2009-12-10 | 322d? |  |  | S2,C1,C4,C3 | 5872h | 5872h | IMS_EMER_GPRS_EPS-SRVCC | PCG-21 | China Mobile | Yu Qing (Yuqing@chinamobile.com) | Rel-9 | SP-41 | Maurice |  |
| 415 | 167.7.1 | SRVCC support for IMS Emergency Calls | 322d? | 2008-09-18 A | 2009-12-10 A | 100% |  | 2008-09-18 | 2009-12-10 | 322d? |  | finish no earlier than 2009-12-10 | S2 | 2576h | 2576h | IMS_EMER_GPRS_EPS-SRVCC | PCG-21 | China Mobile | Yu Qing (Yuqing@chinamobile.com) | Rel-9 | SP-41 | Maurice |  |
| 416 | 167.7.2 | **CT aspects of SRVCC support for IMS Emergency Calls** | 137d? | 2009-05-29 A | 2009-12-04 A | 100% |  | 2009-05-29 | 2009-12-04 | 137d? |  |  | C1,C4,C3 | 3296h | 3296h | IMS_EMER_GPRS_EPS-SRVCC | PCG-24 | China Mobile | jiangyi@chinamobile.com | Rel-9 | CP-46 | Frederic |  |
| 417 | 167.7.2.1 | CT1 aspects of SRVCC support for IMS Emergency Calls | 137d? | 2009-05-29 A | 2009-12-04 A | 100% |  | 2009-05-29 | 2009-12-04 | 137d? |  | finish no earlier than 2009-12-04 | C1 | 1096h | 1096h | IMS_EMER_GPRS_EPS-SRVCC | PCG-23 | China Mobile | jiangyi@chinamobile.com | Rel-9 | CP-44 | Frederic |  |
| 418 | 167.7.2.2 | CT4 aspects of SRVCC support for IMS Emergency Calls | 137d? | 2009-05-29 A | 2009-12-04 A | 100% |  | 2009-05-29 | 2009-12-04 | 137d? |  | finish no earlier than 2009-12-04 | C4 | 1096h | 1096h | IMS_EMER_GPRS_EPS-SRVCC | PCG-23 | China Mobile | jiangyi@chinamobile.com | Rel-9 | CP-44 | Kimmo |  |
| 419 | 167.7.2.3 | CT3 aspects of SRVCC support for IMS Emergency Calls | 1d? | 2009-12-04 A | 2009-12-04 A | 100% |  | 2009-12-04 | 2009-12-04 | 1d? |  | finish no earlier than 2009-12-04 | C3 | 8h | 8h | IMS_EMER_GPRS_EPS-SRVCC | PCG-24 | China Mobile | jiangyi@chinamobile.com | Rel-9 | CP-46 | Kimmo |  |
| 420 | 168 | **LCS for LTE and EPS** | 723d? | 2008-06-05 A | 2011-03-11 | 88% | 83.31d? | 2008-06-05 | 2011-03-11 | 723d? | 360.8d |  | S2,C1,C4,R2,R1,R3,R4,R5 | 20192h | 15275.2h | LCS_LTE_EPS | PCG-22 |  |  | Rel-9 | SP-43 | Maurice |  |
| 421 | 168.1 | **LCS Control Plane Solution for EPS** | 468d? | 2008-06-05 A | 2010-03-19 A | 100% |  | 2008-06-05 | 2010-03-19 | 468d? |  |  | S2,C4,C1 | 9224h | 9224h | LCS_EPS-CPS | PCG-21 | Polaris Wireless | Robert Gross | Rel-9 | SP-40 | Maurice |  |
| 422 | 168.1.1 | Stage 2 for LCS Control Plane Solution for EPS | 261d? | 2008-06-05 A | 2009-06-04 A | 100% |  | 2008-06-05 | 2009-06-04 | 261d? |  | finish no earlier than 2009-06-04 | S2 | 2088h | 2088h | LCS_EPS-CPS | PCG-21 | Polaris Wireless | Robert Gross | Rel-9 | SP-40 | Maurice |  |
| 423 | 168.1.2 | CT4 aspects of Control Plane LCS in the EPC | 212d? | 2009-05-29 A | 2010-03-19 A | 100% |  | 2009-05-29 | 2010-03-19 | 212d? |  | finish no earlier than 2010-03-19 | C4 | 1696h | 1696h | LCS_EPS-CPS | PCG-23 | Polaris Wireless | Robert Gross | Rel-9 | CP-44 | Kimmo |  |
| 424 | 168.1.3 | CT1 aspects of Control Plane LCS in the EPC | 212d? | 2009-05-29 A | 2010-03-19 A | 100% |  | 2009-05-29 | 2010-03-19 | 212d? |  | finish no earlier than 2010-03-19 | C1 | 1696h | 1696h | LCS_EPS-CPS | PCG-23 | Polaris Wireless | Robert Gross | Rel-9 | CP-44 | Frederic |  |
| 425 | 168.2 | Positioning Support for LTE | 392d? | 2008-12-05 A | 2010-06-04 A | 100% |  | 2008-12-05 | 2010-06-04 | 392d? |  | finish no earlier than 2010-06-04 | R2,R1,R3,R4 | 3136h | 3136h | LCS_LTE | PCG-22 | Qualcomm | Nathan Tenny (ntenny@qualcomm.com) | Rel-9 | RP-42 | Joern | RP-100442 |
| 426 | 168.3 | Conformance Test Aspects – Positioning Support for LTE | 256d? | 2010-03-19 A | 2011-03-11 | 40% | 153.6d? | 2010-03-19 | 2011-03-11 | 256d? | 360.8d | start no earlier than 2010-03-19 | R5 | 2048h | 819.2h | LCS_LTE_UEConTest | PCG-24 | Alcatel-Lucent | nidal.khrais@alcatel-lucent.com | Rel-9 | RP-47 | Ingbert | RP-100743 |

Notes:
- 400: CP#47 completed. Triggered by Study UID_400036 on Service Specific Access Control in EPS (FS_SSAC)
- 401: SP#42 completed / Text3: 22.011 CR0136
- 402: CP#47 completed / Text3: 24.173, 27.007
- 403: SP#48 completed / Text3: GERA, LTE
- 404: SP#42 completed / Text3: 22.101
- 405: SP#44 completed / Text3: 23.869, 23.060, 23.167, 23.203, 23.221, 23.228, 23.271, 23.401, 23.402
- 406: SP#48 completed / Text3: 33.401, 33.402
- 407: CP#47 completed / Text3: GERA, LTE
- 408: CP#47 completed / Text3: 23.122, 24.008, 24.229, 24.301, 24.302
- 409: Testing for UID_440036 CT1 aspects - Stage 3 of Support for IMS Emergency Calls over GPRS and EPS / Text3: 34.108, 34.123-1, 34.123-2, 34.123-3, 34.229-1, 34.229-2, 34.229-3, 36.508, 36.523-1, 36.523-2, 36.523-3
- 410: CP#45 completed / Text3: 29.212, 29.213, 29.214, 29.215
- 411: CP#46 completed / Text3: 23.003, 23.008, 29.060, 29.272, 29.273, 29.274, 29.275, 29.276
- 412: RP#45 completed / Text3: 36.331, 36.413
- 413: RP#49 completion 09/10=>12/10. Testing for UID_420041 Support for IMS Emergency Calls over LTE / Text3: 36.508, 36.523-1, 36.523-2, 36.523-3
- 414: CP/SP#46 completed
- 415: SP#46 completed. SP#43 WID updated SP-080562=>SP-090099 (added location continuity aspects) / Text3: 23.870, 23.216, 23.237
- 416: CP#46 completed. WID updated CP-090436=>CP-090882 (added CT3 part)
- 417: CP#46 completed / Text3: 24.229, 24.237
- 418: CP#46 completed / Text3: 29.205, 29.280
- 419: CP#46 completed / Text3: 29.163
- 420: RP#48 Core completed/Test ongoing / Text3: LTE
- 421: Triggered by abandoned Study UID_380068 (FS_LCS_EPS). Linked to Feature UID_380064 Support for IMS Emergency Calls over GPRS and EPS
- 422: SP#44 completed / Text3: 23.891, 23.271, 23.401, 23.402
- 423: CP#47 completed (IANA registrations outstanding). Stage 3 SLs and SLg interfaces & transport of positioning messages between E-SMLC and MME in the scope of UID_420006 (Positioning Support for LTE) / Text3: 24.080, 29.002, 29.272, 29.230, new 24.171, 29.171, 29.172, 29.173
- 424: CP#47 completed / Text3: 24.301
- 425: RP#48 completed. UID_400038 (LCS Control Plane Solution for EPS) depends on this WI / Text3: 34.213, 36.133, 36.211, 36.214, 36.300, 36.305, 36.331, 36.355, 36.410, 36.413, 36.455, new 36.171
- 426: RP#48 updated WID RP-100346=>RP-100617. Testing for UID_420006 Positioning Support for LTE / Text3: 36.508, 36.509, 36.521-3, new 36.571-1/2/3/4/5

| ID | WBS | Task | Duration | Start | Finish | Complete | Baseline start | Baseline finish | Baseline duration | Constraint | Resources | Work | Actual work | Text1 | Text2 | Text4 | Text5 | Text6 | Text7 | Text8 | Text11 |
| --- | --- | --- | --- | --- | --- | --- | --- | --- | --- | --- | --- | --- | --- | --- | --- | --- | --- | --- | --- | --- | --- |
| 427 | 169 | **MBMS support in EPS** | 468d? | 2008-06-05 A | 2010-03-19 A | 100% | 2008-06-05 | 2010-03-19 | 468d? |  | S2,S3,S5,C3,C4,R2,R3,R4 | 13880h | 13880h | MBMS_EPS | PCG-21 | China Mobile | Liu Hong (liuhongyfw@chinamobile.com) | Rel-9 | SP-40 | Maurice |  |
| 428 | 169.1 | Stage 2 for MBMS support in EPS | 261d? | 2008-06-05 A | 2009-06-04 A | 100% | 2008-06-05 | 2009-06-04 | 261d? | finish no earlier than 2009-06-04 | S2 | 2088h | 2088h | MBMS_EPS | PCG-21 | China Mobile | Liu Hong (liuhongyfw@chinamobile.com) | Rel-9 | SP-40 | Maurice |  |
| 429 | 169.2 | Security for MBMS support in EPS | 261d? | 2008-12-11 A | 2009-12-10 A | 100% | 2008-12-11 | 2009-12-10 | 261d? | finish no earlier than 2009-12-10 | S3 | 2088h | 2088h | MBMS_EPS | PCG-22 | China Mobile | Liu Hong (liuhongyfw@chinamobile.com) | Rel-9 | SP-42 | Dionisio |  |
| 430 | 169.3 | MBMS Charging in EPS | 201d? | 2009-03-06 A | 2009-12-10 A | 100% | 2009-03-06 | 2009-12-10 | 201d? | finish no earlier than 2009-12-10 | S5 | 1600h | 1600h | MBMS_EPS | PCG-22 | ZTE | guo.wenjie1@zte.com.cn | Rel-9 | SP-43 | Dionisio |  |
| 431 | 169.4 | CT4 aspects of MBMS support in EPS (Stage 3) | 137d? | 2009-05-29 A | 2009-12-04 A | 100% | 2009-05-29 | 2009-12-04 | 137d? | finish no earlier than 2009-12-04 | C4 | 1096h | 1096h | MBMS_EPS | PCG-23 | China Mobile, ZTE | wangjingyf@chinamobile.com, lu.fei1@zte.com.cn | Rel-9 | CP-44 | Kimmo |  |
| 432 | 169.5 | CT3 aspects of MBMS support in EPS (Stage 3) | 137d? | 2009-05-29 A | 2009-12-04 A | 100% | 2009-05-29 | 2009-12-04 | 137d? | start no earlier than 2009-05-29 | C3 | 1096h | 1096h | MBMS_EPS | PCG-23 | ZTE, China Mobile | zhou.xiaoyun@zte.com.cn, wangjingyf@chinamobile.com | Rel-9 | CP-44 | Gwiho |  |
| 433 | 169.6 | MBMS support in LTE | 271d? | 2009-03-06 A | 2010-03-19 A | 100% | 2009-03-06 | 2010-03-19 | 271d? | finish no earlier than 2010-03-19 | R2,R3,R4 | 2168h | 2168h | MBMS_LTE | PCG-22 | Huawei | arnaud.meylan@huawei.com | Rel-9 | RP-43 | Joern | RP-100033 |
| 434 | 170 | **Access Network Discovery and Selection Function enhancements** | 333d? | 2008-12-11 A | 2010-03-19 A | 100% | 2008-12-11 | 2010-03-19 | 333d? |  | S2,C1 | 4720h | 4720h | eANDSF | PCG-22 | Motorola | Apostolis Salkintzis (salki@motorola.com) | Rel-9 | SP-42 | Maurice |  |
| 435 | 170.1 | Stage 2 for Access Network Discovery and Selection Function enhancements | 126d? | 2008-12-11 A | 2009-06-04 A | 100% | 2008-12-11 | 2009-06-04 | 126d? | finish no earlier than 2009-06-04 | S2 | 1008h | 1008h | eANDSF | PCG-22 | Motorola | Apostolis Salkintzis (salki@motorola.com) | Rel-9 | SP-42 | Maurice |  |
| 436 | 170.2 | CT1 aspects of Access Network Discovery and Selection Function enhancements | 131d? | 2009-09-18 A | 2010-03-19 A | 100% | 2009-09-18 | 2010-03-19 | 131d? | finish no earlier than 2010-03-19 | C1 | 1048h | 1048h | eANDSF | PCG-23 | Panasonic | benjamin.limck@sg.panasonic.com | Rel-9 | CP-45 | Frederic |  |
| 437 | 171 | **Multiple PDN Connection to the Same APN for PMIP-based Interfaces** | 267d? | 2009-03-13 A | 2010-03-19 A | 100% | 2009-03-13 | 2010-03-19 | 267d? |  | S2,C4,C1 | 4120h | 4120h | MUPSAP | PCG-22 | Samsung | erik.guttman@partner.samsung.com | Rel-9 | SP-43 | Maurice |  |
| 438 | 171.1 | Stage 2 for Multiple PDN Connection to the Same APN for PMIP-based Interfaces | 61d? | 2009-03-13 A | 2009-06-04 A | 100% | 2009-03-13 | 2009-06-04 | 61d? | finish no earlier than 2009-06-04 | S2 | 488h | 488h | MUPSAP | PCG-22 | Samsung | erik.guttman@partner.samsung.com | Rel-9 | SP-43 | Maurice |  |
| 439 | 171.2 | CT4 aspects of Multiple PDN Connection to the Same APN for PMIP-based Interfaces | 56d? | 2009-09-18 A | 2009-12-04 A | 100% | 2009-09-18 | 2009-12-04 | 56d? | finish no earlier than 2009-12-04 | C4 | 448h | 448h | MUPSAP | PCG-23 | Samsung | Surjyakanta Mohapatra (surjya.kanta@samsung.com) | Rel-9 | CP-45 | Kimmo |  |
| 440 | 171.3 | CT1 aspects of Multiple PDN Connection to the Same APN for PMIP-based Interfaces | 131d? | 2009-09-18 A | 2010-03-19 A | 100% | 2009-09-18 | 2010-03-19 | 131d? | finish no earlier than 2010-03-19 | C1 | 1048h | 1048h | MUPSAP | PCG-23 | Samsung | Surjyakanta Mohapatra (surjya.kanta@samsung.com) | Rel-9 | CP-45 | Frederic |  |
| 441 | 172 | **System aspects of vocoder rate adaptation for LTE** | 140d? | 2009-05-30 A | 2009-12-10 A | 100% | 2009-05-30 | 2009-12-10 | 140d? |  | S2,S4,R2 | 3504h | 3504h | LTEimp-Vocoder | PCG-23 | Qualcomm | AC Mahendran (ac@qualcomm.com) | Rel-9 | SP-45 | Maurice |  |
| 442 | 172.1 | SA2 system aspects of vocoder rate adaptation for LTE | 81d? | 2009-06-04 A | 2009-09-24 A | 100% | 2009-06-04 | 2009-09-24 | 81d? | start no earlier than 2009-06-04 | S2 | 648h | 648h | LTEimp-Vocoder | PCG-23 | Qualcomm | AC Mahendran (ac@qualcomm.com) | Rel-9 | SP-45 | Maurice |  |
| 443 | 172.2 | SA4 system aspects of vocoder rate adaptation for LTE | 136d? | 2009-06-04 A | 2009-12-10 A | 100% | 2009-06-04 | 2009-12-10 | 136d? | finish no earlier than 2009-12-07 | S4 | 1088h | 1088h | LTEimp-Vocoder | PCG-23 | Qualcomm | Nikolai Leung | Rel-9 | SP-45 | Paolo |  |
| 444 | 172.3 | Vocoder rate adaptation for LTE | 81d? | 2009-05-30 A | 2009-09-18 A | 100% | 2009-05-30 | 2009-09-18 | 81d? | finish no earlier than 2009-09-18 | R2 | 648h | 648h | LTEimp-Vocoder | PCG-23 | Alcatel-Lucent | Sudeep Palat (spalat@alcatel-lucent.com) | Rel-9 | RP-44 | Joern | RP-090704 |
| 445 | 173 | Access Security Enhancements | 505d? | 2007-07-02 A | 2009-06-04 A | 100% | 2007-07-02 | 2009-06-04 | 505d? | finish no earlier than 2009-06-03 | S3 | 4040h | 4040h | ACCSEC2 |  | Ericsson | Bengt.Sahlin@ericsson.com | Rel-9 | SP-26 | Dionisio |  |
| 446 | 174 | **Protection against Unsolicited Communication for IMS (PUCI)** | 322d? | 2008-09-18 A | 2009-12-10 A | 100% | 2008-09-18 | 2009-12-10 | 322d? |  | S3,S1 | 5640h | 5640h | PUCI | PCG-21 | NEC | Anand R. Prasad (anand@bq.jp.nec.com) | Rel-9 | SP-41 | Alain |  |
| 447 | 174.1 | Stage 1 for PUCI | 61d? | 2008-09-18 A | 2008-12-11 A | 100% | 2008-09-18 | 2008-12-11 | 61d? | finish no earlier than 2009-06-18 | S1 | 488h | 488h | PUCI | PCG-21 | NEC | Anand R. Prasad (anand@bq.jp.nec.com) | Rel-9 | SP-41 | Alain |  |
| 448 | 174.2 | SA3 work on PUCI | 322d? | 2008-09-18 A | 2009-12-10 A | 100% | 2008-09-18 | 2009-12-10 | 322d? | finish no earlier than 2009-12-10 | S3 | 2576h | 2576h | PUCI | PCG-21 | NEC | Anand R. Prasad (anand@bq.jp.nec.com) | Rel-9 | SP-41 | Dionisio |  |
| 449 | 175 | **IMS Media Plane Security** | 322d? | 2009-03-13 A | 2010-06-04 A | 100% | 2009-03-13 | 2010-06-04 | 322d? |  | S3,C1,C4,C3 | 7755.2h | 7755.2h | MEDIASEC | PCG-22 | Vodafone | Peter.Howard@vodafone.com | Rel-9 | SP-43 | Dionisio |  |
| 450 | 175.1 | SA3 aspects of IMS Media Plane Security | 271d? | 2009-03-13 A | 2010-03-25 A | 100% | 2009-03-13 | 2010-03-25 | 271d? | finish no earlier than 2010-03-25 | S3 | 2168h | 2168h | MEDIASEC | PCG-22 | Vodafone | Peter.Howard@vodafone.com | Rel-9 | SP-43 | Dionisio |  |

Notes:
- 427: RP#47 completed. SP#46, CP#46 completed / Text3: LTE
- 428: SP#44 completed / Text3: 23.246
- 429: SP#46 completed / Text3: 33.246
- 430: SP#46 completed / Text3: 32.273, 32.251, 32.298, 32.299
- 431: CP#46 completed / Text3: 29.274, 29.281, 23.007, 23.008
- 432: CP#46 completed / Text3: 29.061
- 433: RP#47 completed / Text3: 25.446, 36.101, 36.104, 36.141, 36.300, 36.304, 36.321, 36.322, 36.323, 36.331, 36.440, 36.441, 36.442, 36.444, 36.445
- 434: CP#47 completed. No new Rel-9 use cases defined. Implement service requirements not covered in Rel-8 / Text3: 22.278, SA3 33.402 CR#0055
- 435: SP#44 completed / Text3: 23.402, 23.002
- 436: CP#47 completed / Text3: 24.302, 24.312
- 437: CP#47 completed. Continues Rel-8 SAES Stage 2 UID_320005. Stage 1 in 22.278 (EPS Service requirements)
- 438: SP#44 completed / Text3: 23.060, 23.203, 23.401, 23.402
- 439: CP#46 completed / Text3: 29.275, 23.008, 29.282
- 440: CP#47 completed / Text3: 24.302
- 441: SP#46 completed. Triggered by RAN2 UID_440013 Vocoder rate adaptation for LTE / Text3: LTE
- 442: SP#45 completed (CR adding support for Explicit Congestion Notification) / Text3: 23.401 CR#1103r3
- 443: SP#46 completed / Text3: 26.114
- 444: RP#45 completed / Text3: 36.300 CR#0114
- 445: SP#44 completed. Stopped TR 33.801. CRs 33.102,43.020 on A5/2 removal done long time ago. A5/4 introduction CRs will be done under UID_440057 128 bit encryption for GSM and GPRS. SP#26 approved WID (improved GERAN security) / Text3: 33.102, 43.020
- 446: SP#46 TR 33.937 completed but no specification work done in Rel-9. Related work in OMA Categorization Based Content Screening
- 447: SP#42 completed / Text3: 22.228
- 448: SP#46 completed. No normative work done in Rel-9 / Text3: new 33.937
- 449: CP#48 completed
- 450: SP#47 completed / Text3: new 33.828, 33.328

| ID | WBS | Task | Duration | Start | Finish | Complete | Baseline start | Baseline finish | Baseline duration | Constraint | Resources | Work | Actual work | Text1 | Text2 | Text4 | Text5 | Text6 | Text7 | Text8 | Text3 | Text9 | Text12 |
| --- | --- | --- | --- | --- | --- | --- | --- | --- | --- | --- | --- | --- | --- | --- | --- | --- | --- | --- | --- | --- | --- | --- | --- |
| 451 | 175.2 | **CN aspects of IMS Media Plane Security** | 186d? | 2009-09-18 A | 2010-06-04 A | 100% | 2009-09-18 | 2010-06-04 | 186d? |  | C1,C4,C3 | 3011.2h | 3011.2h | MEDIASEC_CORE | PCG-23 | Vodafone | peter.dawes@vodafone.com | Rel-9 | CP-45 | Frederic |  |  |  |
| 452 | 175.2.1 | CT1 aspects of IMS Media Plane Security | 33d? | 2009-09-18 A | 2010-03-19 A | 100% | 2009-09-18 | 2010-03-19 | 33d? | finish no earlier than 2010-03-19 | C1 | 264h | 264h | MEDIASEC_CORE | PCG-23 | Vodafone | peter.dawes@vodafone.com | Rel-9 | CP-45 | Frederic | 23.218, 24.229 |  |  |
| 453 | 175.2.2 | CT4 aspects of IMS Media Plane Security | 131d? | 2009-09-18 A | 2010-03-19 A | 100% | 2009-09-18 | 2010-03-19 | 131d? | finish no earlier than 2010-03-19 | C4 | 1048h | 1048h | MEDIASEC_CORE | PCG-23 | Vodafone | peter.dawes@vodafone.com | Rel-9 | CP-45 | Kimmo | 29.238, 23.334, 29.334 |  |  |
| 454 | 175.2.3 | CT3 aspects of IMS Media Plane Security | 131d? | 2009-12-04 A | 2010-06-04 A | 100% | 2009-12-04 | 2010-06-04 | 131d? | finish no earlier than 2010-06-04 | C3 | 1048h | 1048h | MEDIASEC_CORE | PCG-24 | Vodafone | peter.dawes@vodafone.com | Rel-9 | CP-46 | Gwiho | 29.162 |  |  |
| 455 | 176 | **GBAPush enhancements (Generic push layer)** | 533d? | 2008-03-12 A | 2010-03-25 A | 100% | 2008-03-12 | 2010-03-25 | 533d? |  | S3 | 8528h | 8528h | eGBAPush | PCG-23 | Ericsson | Rolf Blom | Rel-9 | SP-44 | Dionisio | new 33.224 |  |  |
| 456 | 176.1 | SA3 part of eGBAPush (Generic push layer) | 533d? | 2008-03-12 A | 2010-03-25 A | 100% | 2008-03-12 | 2010-03-25 | 533d? | finish no earlier than 2010-03-25 | S3 | 4264h | 4264h | eGBAPush | PCG-21 | Ericsson | Rolf Blom | Rel-9 | SP-39 | Dionisio | new 33.224 |  |  |
| 457 | 177 | Extended Identity Management | 136d? | 2009-06-04 A | 2009-12-10 A | 100% | 2009-06-04 | 2009-12-10 | 136d? | finish no earlier than 2009-12-10 | S3 | 1088h | 1088h | GBA-IdM | PCG-23 | Nokia | Silke.Holtmanns@nokia.com | Rel-9 | SP-44 | Dionisio | new 33.924, CT4 29.109 (added service code) |  |  |
| 458 | 178 | **Network Domain Security (NDS) enhancements to support backhaul security** | 211d? | 2009-06-04 A | 2010-03-25 A | 100% | 2009-06-04 | 2010-03-25 | 211d? |  | S3,C4 | 4432h | 4432h | NDS_Backhaul | PCG-23 | Vodafone | Peter Howard | Rel-9 | SP-44 | Dionisio |  |  |  |
| 459 | 178.1 | SA3 part of Network Domain Security (NDS) enhancements to support backhaul security | 211d? | 2009-06-04 A | 2010-03-25 A | 100% | 2009-06-04 | 2010-03-25 | 211d? | finish no earlier than 2010-03-25 | S3 | 1688h | 1688h | NDS_Backhaul | PCG-23 | Vodafone | Peter Howard | Rel-9 | SP-44 | Dionisio | 33.102, 33.210, 33.310, 33.401, 33.402 |  |  |
| 460 | 178.2 | CT4 part of Network Domain Security (NDS) enhancements to support backhaul security | 132d? | 2009-06-04 A | 2009-12-04 A | 100% | 2009-06-04 | 2009-12-04 | 132d? | finish no earlier than 2009-12-04 | C4 | 1056h | 1056h | NDS_Backhaul | PCG-23 | Vodafone | Peter Howard | Rel-9 | SP-44 | Kimmo |  |  |  |
| 461 | 179 | **128 bit encryption for GSM and GPRS** | 136d? | 2009-06-04 A | 2009-12-10 A | 100% | 2009-06-04 | 2009-12-10 | 136d? |  | S3,C1,C4,G2,G3new | 6040h | 6040h | A5/4-GEA4 | PCG-23 | Ericsson | Karl Norrman | Rel-9 | SP-44 | Dionisio |  |  |  |
| 462 | 179.1 | SA3 part of 128 bit encryption for GSM and GPRS | 136d? | 2009-06-04 A | 2009-12-10 A | 100% | 2009-06-04 | 2009-12-10 | 136d? | finish no earlier than 2010-01-06 | S3 | 1088h | 1088h | A5/4-GEA4 | PCG-23 | Ericsson | Karl Norrman | Rel-9 | SP-44 | Dionisio | 33.102,43.020, new 55.226 |  |  |
| 463 | 179.2 | CT1 part of 128 bit encryption for GSM and GPRS | 77d? | 2009-06-04 A | 2009-09-18 A | 100% | 2009-06-04 | 2009-09-18 | 77d? | start no earlier than 2009-06-04 | C1 | 616h | 616h | A5/4-GEA4 | PCG-23 | Ericsson | Karl Norrman | Rel-9 | SP-44 | Frederic | 24.008,44.064 |  |  |
| 464 | 179.3 | CT4 part of 128 bit encryption for GSM and GPRS | 136d? | 2009-06-04 A | 2009-12-10 A | 100% | 2009-06-04 | 2009-12-10 | 136d? | start no earlier than 2009-06-04 | C4 | 1088h | 1088h | A5/4-GEA4 | PCG-23 | Ericsson | Karl Norrman | Rel-9 | SP-44 | Kimmo |  |  |  |
| 465 | 179.4 | GERAN2 part of 128 bit encryption for GSM and GPRS | 67d? | 2009-06-04 A | 2009-09-04 A | 100% | 2009-06-04 | 2009-09-04 | 67d? | finish no earlier than 2009-09-04 | G2 | 536h | 536h | A5/4-GEA4 | PCG-23 | Ericsson | Karl Norrman | Rel-9 | SP-44 | Gert | 44.018,48.008,48.018,48.058 |  |  |
| 466 | 179.5 | GERAN3new (testing) part of 128 bit encryption for GSM and GPRS | 122d? | 2009-06-04 A | 2009-11-20 A | 100% | 2009-06-04 | 2009-11-20 | 122d? | finish no earlier than 2009-11-20 | G3new | 976h | 976h | A5/4-GEA4 | PCG-23 | Ericsson | Karl Norrman | Rel-9 | SP-44 | Ingbert | 51.010 |  |  |
| 467 | 179.6 | Deleted - SA2 part of 128 bit encryption for GSM and GPRS | 81d? | 2009-06-04 A | 2009-09-24 A | 100% | 2009-06-04 | 2009-09-24 | 81d? | finish no earlier than 2009-09-24 | S2 | 648h | 648h | A5/4-GEA4 | PCG-23 | Ericsson | Karl Norrman | Rel-9 | SP-44 | Maurice | 23.060 | PCG-23 | SP-45 |
| 468 | 180 | Timed Graphics | 337d? | 2008-12-11 A | 2010-03-25 A | 100% | 2008-12-11 | 2010-03-25 | 337d? | finish no earlier than 2010-03-25 | S4 | 2696h | 2696h | TG | PCG-22 | Ericsson | clinton.priddle@ericsson.com | Rel-9 | SP-42 | Paolo | 26.114, 26.140, 26.234, 26.244, 26.245, 26.346, new 26.430 |  |  |
| 469 | 181 | Managing MTSI Media Adaptation | 272d? | 2009-03-12 A | 2010-03-25 A | 100% | 2009-03-12 | 2010-03-25 | 272d? | finish no earlier than 2009-12-10 | S4 | 1568h | 1568h | M3A | PCG-22 | Samsung | kyunghun.jung@samsung.com | Rel-9 | SP-43 | Paolo | 26.114 |  |  |
| 470 | 182 | **PSS and MBMS Aspects** | 272d? | 2009-03-12 A | 2010-03-25 A | 100% | 2009-03-12 | 2010-03-25 | 272d? |  | S4 | 6512h | 6512h | PMA | PCG-23 | Ericsson, Nokia | Clinton.Priddle@ericsson.com, imed.bouazizi@nokia.com | Rel-9 | SP-44 | Paolo |  |  |  |
| 471 | 182.1 | PSS and MBMS extensions | 271d? | 2009-03-12 A | 2010-03-25 A | 100% | 2009-03-12 | 2010-03-25 | 271d? | finish no earlier than 2010-03-25 | S4 | 2168h | 2168h | PMA-MBS_Ext | PCG-22 | Ericsson | Clinton.Priddle@ericsson.com | Rel-9 | SP-43 | Paolo | 26.234, 26.346 |  |  |
| 472 | 182.2 | Improved Video Support for PSS and MBMS | 271d? | 2009-03-12 A | 2010-03-25 A | 100% | 2009-03-12 | 2010-03-25 | 271d? | finish no earlier than 2010-03-25 | S4 | 2168h | 2168h | PMA-IVS | PCG-22 | Nokia | imed.bouazizi@nokia.com | Rel-9 | SP-43 | Paolo | 26.234, 26.244, 26.346, new 26.903 |  |  |
| 473 | 183 | IMS based PSS and MBMS User Service extensions | 197d? | 2009-03-12 A | 2009-12-10 A | 100% | 2009-03-12 | 2009-12-10 | 197d? | finish no earlier than 2009-12-10 | S4 | 1576h | 1576h | IMS_PSS_MBMS_US_EXT | PCG-22 | Ericsson | Markus Kampmann | Rel-9 | SP-43 | Paolo | 26.237 |  |  |
| 474 | 184 | Syndicated Feed Reception within 3GPP environments | 136d? | 2009-06-04 A | 2009-12-10 A | 100% | 2009-06-04 | 2009-12-10 | 136d? | start no earlier than 2009-06-04 | S4 | 1088h | 1088h | SFR | PCG-23 | Ericsson | Thorsten.Lohmar@ericsson.com | Rel-9 | SP-44 | Paolo | 26.150 |  |  |
| 475 | 185 | Distortion Measurement Test Methods and Requirements | 131d? | 2009-09-24 A | 2010-03-25 A | 100% | 2009-09-24 | 2010-03-25 | 131d? | finish no earlier than 2010-03-25 | S4 | 1048h | 1048h | DTMR | PCG-23 | Motorola | Stephen Kendall (wcsk01@motorola.com) | Rel-9 | SP-45 | Paolo | 26.131, 26.132 |  |  |

Notes:
- 451: CP#48 completed
- 452: CP#47 completed
- 453: CP#47 completed
- 454: CP#48 completed
- 455: SP#43 umbrella to host 33.224, moved from Rel-8 to Rel-9. SP#47 completed
- 456: SP#47 completed
- 457: SP#46 completed. Stage 1 not identified (GBA Liberty Interworking has been outlined and GBAOpenID interworking is analogous)
- 458: SP#47 completed. Continuation of Rel-8 UID_390044 SAE security architecture. Covers gaps in backhaul security in SAE (also applicable to UTRAN and GERAN backhaul)
- 459: SP#47 completed
- 460: CP#46 completed. No impact on CT4 specs
- 461: Allow 128 as an alternative to 64 bit keys (Stage 2/3 + Test spec)
- 462: SP#46 completed
- 463: CP#45 completed
- 464: CP#46 completed. Kc128 enhancements are carried as UMTS keys => no impact on CT4 29.002, 29.060
- 465: GP#43 WID approved + completed
- 466: GP#44 completed. GP#43 WID approved
- 467: SP#45 work stopped/abandoned
- 468: SP#47 completed. Provide graphics in parallel to a video stream (without requiring an umbrella scene descriptor such as 3GPP DIMS in TS 26.142)
- 469: SP#46 completed. Work extending Rel-8 UID_34041 MTSI Video - Dynamic Rate Adaptation/Signalling of Image Size. Update speech/video adaptation algorithms used by network to control MTSI client terminal in congestion or poor transmission conditions.
- 470: Umbrella WI
- 471: SP#47 completed. Extends Rel-8 UID_34043 (PSS_MBMS_OMTV) & ensures compatibility with UID_34046 (IMS_PSS_MBMS_US)
- 472: SP#47 completed
- 473: SP#46 completed. Work extending Rel-8 UID_34046 (IMS_PSS_MBMS_US), SA2 UID_410034 IMSSCC-SPI (IMS Service Continuity Enhancements: Service, Policy and Interactions)
- 474: SP#46 completed. TS 26.150v100 for Approval. RSS optimized for mobile use. Reuse/reference OMA's enabler DCD.
- 475: SP#47 completed

| ID | WBS | Task | Duration | Start | Finish | Complete | Baseline start | Baseline finish | Baseline duration | Constraint | Resources | Work | Actual work | Text1 | Text2 | Text6 | Text7 | Text8 | Text4 | Text9 | Text12 |
| --- | --- | --- | --- | --- | --- | --- | --- | --- | --- | --- | --- | --- | --- | --- | --- | --- | --- | --- | --- | --- | --- |
| 476 | 186 | **OAM&P 9** | 601d? | 2008-02-22 A | 2010-06-10 A | 100% | 2008-02-22 | 2010-06-10 | 601d? |  | S5 | 36890.4h | 36890.4h | OAM9 | PCG-22 | Rel-9 | SP-42 | Dionisio |  |  |  |
| 477 | 186.1 | **Network Infrastructure Management** | 337d? | 2008-12-11 A | 2010-03-25 A | 100% | 2008-12-11 | 2010-03-25 | 337d? |  | S5 | 8760h | 8760h | OAM9-NIM | PCG-22 | Rel-9 | SP-42 | Dionisio |  |  |  |
| 478 | 186.1.1 | Software Management for Network Elements | 336d? | 2008-12-11 A | 2010-03-25 A | 100% | 2008-12-11 | 2010-03-25 | 336d? | finish no earlier than 2010-03-25 | S5 | 2688h | 2688h | OAM9-NE_SWM | PCG-22 | Rel-9 | SP-42 | Dionisio | Huawei, Nokia Siemens Networks |  |  |
| 479 | 186.1.2 | Service Oriented Architecture (SOA) for IRP | 211d? | 2009-06-04 A | 2010-03-25 A | 100% | 2009-06-04 | 2010-03-25 | 211d? | finish no earlier than 2010-03-25 | S5 | 1688h | 1688h | OAM9 | PCG-23 | Rel-9 | SP-44 | Dionisio | Ericsson, Nokia Siemens Networks |  |  |
| 480 | 186.1.3 | IRP SOAP Solution Sets continuation from Rel-8 | 211d? | 2009-06-04 A | 2010-03-25 A | 100% | 2009-06-04 | 2010-03-25 | 211d? | finish no earlier than 2010-03-25 | S5 | 1688h | 1688h | OAM9 | PCG-23 | Rel-9 | SP-44 | Dionisio | Ericsson |  |  |
| 481 | 186.2 | **Performance Management** | 327d? | 2009-03-12 A | 2010-06-10 A | 100% | 2009-03-12 | 2010-06-10 | 327d? |  | S5 | 7890.41h | 7890.41h | OAM9-PM | PCG-22 | Rel-9 | SP-42 | Dionisio |  |  |  |
| 482 | 186.2.1 | Enhancement of UTRAN Performance Measurements | 136d? | 2009-06-04 A | 2009-12-10 A | 100% | 2009-06-04 | 2009-12-10 | 136d? | start no earlier than 2009-06-04 | S5 | 1088h | 1088h | OAM9 | PCG-23 | Rel-9 | SP-44 | Dionisio | China Mobile |  |  |
| 483 | 186.2.2 | Enhancement of E-UTRAN Performance Measurements | 327d? | 2009-03-12 A | 2010-06-10 A | 100% | 2009-03-12 | 2010-06-10 | 327d? | finish no earlier than 2010-06-10 | S5 | 2616h | 2616h | OAM9 | PCG-22 | Rel-9 | SP-43 | Dionisio | Motorola, Huawei |  |  |
| 484 | 186.2.3 | Enhancement of EPC Performance Measurements | 197d? | 2009-03-12 A | 2009-12-10 A | 100% | 2009-03-12 | 2009-12-10 | 197d? | finish no earlier than 2010-03-25 | S5 | 1570.41h | 1570.41h | OAM9 | PCG-22 | Rel-9 | SP-43 | Dionisio | China Mobile |  |  |
| 485 | 186.3 | **Self-Organizing Networks (SON) - OAM aspects** | 601d? | 2008-02-22 A | 2010-06-10 A | 100% | 2008-02-22 | 2010-06-10 | 601d? |  | S5 | 11736h | 11736h | OAM9-SON | PCG-22 | Rel-9 | SP-43 | Dionisio |  |  |  |
| 486 | 186.3.1 | SON self-optimization management | 600d? | 2008-02-22 A | 2010-06-10 A | 100% | 2008-02-22 | 2010-06-10 | 600d? | finish no earlier than 2010-06-10 | S5 | 4800h | 4800h | LTE_SON-OAM | PCG-21 | Rel-9 | SP-39 | Dionisio | Huawei |  |  |
| 487 | 186.3.2 | Automatic Radio Network Configuration Data Preparation | 266d? | 2009-06-04 A | 2010-06-10 A | 100% | 2009-06-04 | 2010-06-10 | 266d? | finish no earlier than 2010-06-10 | S5 | 2128h | 2128h | OAM9 | PCG-23 | Rel-9 | SP-44 | Dionisio | Nokia Siemens Networks |  |  |
| 488 | 186.4 | Subscription Management (SuM) evolution | 266d? | 2009-06-04 A | 2010-06-10 A | 100% | 2009-06-04 | 2010-06-10 | 266d? | finish no earlier than 2010-06-10 | S5 | 2128h | 2128h | OAM9-SuM | PCG-23 | Rel-9 | SP-44 | Dionisio | Ericsson |  |  |
| 489 | 186.5 | Deleted - Trace | 196d? | 2009-03-13 A | 2009-12-10 A | 100% | 2009-03-13 | 2009-12-10 | 196d? | finish no earlier than 2009-12-10 | S5 | 1568h | 1568h | OAM9-Trace | PCG-22 | Rel-9 | SP-42 | Dionisio |  | PCG-24 | SP-46 |
| 490 | 187 | Charging Management small Enhancements | 211d? | 2009-06-04 A | 2010-03-25 A | 100% | 2009-06-04 | 2010-03-25 | 211d? |  | S5 | 1688h | 1688h | CH9 | PCG-23 | Rel-9 | SP-44 | Dionisio |  |  |  |
| 491 | 188 | **CS-IBCF and CS-TrGW definition in 3GPP specifications** | 472d? | 2008-05-30 A | 2010-03-19 A | 100% | 2008-05-30 | 2010-03-19 | 472d? |  | C3,C4 | 10714.3h | 10714.3h | CS-IBCF | PCG-21 | Rel-9 | CP-40 | Gwiho | Telecom Italia |  |  |
| 492 | 188.1 | CT3 aspects of CS-IBCF and CS-TrGW definition in 3GPP specifications | 472d? | 2008-05-30 A | 2010-03-19 A | 100% | 2008-05-30 | 2010-03-19 | 472d? | finish no earlier than 2009-12-04 | C3 | 3770.34h | 3770.34h | CS-IBCF | PCG-21 | Rel-9 | CP-40 | Gwiho | Telecom Italia |  |  |
| 493 | 188.2 | CT4 aspects of CS-IBCF and CS-TrGW definition in 3GPP specifications | 396d? | 2008-05-30 A | 2009-12-04 A | 100% | 2008-05-30 | 2009-12-04 | 396d? | finish no earlier than 2009-12-04 | C4 | 3168h | 3168h | CS-IBCF | PCG-21 | Rel-9 | CP-40 | Kimmo | Telecom Italia |  |  |
| 494 | 189 | **IMS – Interconnection Border Control Function (IBCF) – Transition Gateway (TrGW); Ix Interface; Stage 3** | 322d? | 2008-09-12 A | 2009-12-04 A | 100% | 2008-09-12 | 2009-12-04 | 322d? |  | C4,C3 | 6858.4h | 6858.4h | IMS_IBCF | PCG-21 | Rel-9 | CP-41 | Kimmo | Alcatel-Lucent |  |  |
| 495 | 189.1 | CT4 part of IMS – Interconnection Border Control Function (IBCF) – Transition Gateway (TrGW); Ix Interface; Stage 3 | 321d? | 2008-09-12 A | 2009-12-04 A | 100% | 2008-09-12 | 2009-12-04 | 321d? | finish no earlier than 2009-12-04 | C4 | 2568h | 2568h | IMS_IBCF | PCG-21 | Rel-9 | CP-41 | Kimmo | Alcatel-Lucent |  |  |
| 496 | 189.2 | CT3 part of IMS – Interconnection Border Control Function (IBCF) – Transition Gateway (TrGW); Ix Interface; Stage 3 | 295.8d? | 2008-09-12 A | 2009-12-04 A | 100% | 2008-09-12 | 2009-12-04 | 295.8d? | finish no earlier than 2010-03-19 | C3 | 2366.4h | 2366.4h | IMS_IBCF | PCG-21 | Rel-9 | CP-41 | Gwiho | Alcatel-Lucent |  |  |
| 497 | 190 | IMS Application Level Gateway Control Function (ALGCF) – IMS Access Media Gateway (IMA-MGW); Iq Interface; Stage 2 and Stage 3 | 321d? | 2008-09-12 A | 2009-12-04 A | 100% | 2008-09-12 | 2009-12-04 | 321d? | finish no earlier than 2009-12-04 | C4 | 2568h | 2568h | IMS_AGCF | PCG-21 | Rel-9 | CP-41 | Kimmo | Alcatel-Lucent |  |  |
| 498 | 191 | **Enhancements of IMS Customized Alerting Tone (CAT) Service** | 392d? | 2008-12-05 A | 2010-06-04 A | 100% | 2008-12-05 | 2010-06-04 | 392d? |  | C1 | 5846.4h | 5846.4h | eCAT | PCG-22 | Rel-9 | CP-42 | Frederic | China Mobile |  |  |
| 499 | 191.1 | Stage 3 for Enhancements of IMS Customized Alerting Tone (CAT) Service | 391d? | 2008-12-05 A | 2010-06-04 A | 100% | 2008-12-05 | 2010-06-04 | 391d? | finish no earlier than 2010-06-04 | C1 | 3128h | 3128h | eCAT-SS | PCG-22 | Rel-9 | CP-42 | Frederic | China Mobile |  |  |

Notes:
- 476: SP#42 umbrella Feature created to host OAM WIs / Text3: TR 30.819
- 477: SP#42 umbrella BB created to host OAM WIs
- 478: SP#47 completed / Text3: 32.531, 32.532, 32.533, new 32.537 / Text5: Bidipta Das (bidipta@huawei.com), Clemens Suerbaum (clemens.suerbaum@nsn.com)
- 479: SP#47 completed (covering SOA Architecture & SOA-supporting Solution Set). Triggered by UID_400029 Study on Service Oriented Architecture (SOA) for IRP (TR 32.824) / Text3: 32.101, 32.102, 32.150 / Text5: edwin.tse@ericsson.com, Jörg Schmidt (joerg@cox.net)
- 480: SP#47 completed. Continuation of Rel-8 UID_400030 IRP SOAP Solution Sets / Text3: New (32.127/ 327/ 337/ 357/ 387/ 397/ 447/ 397/ 447/ 507/ 537), 32.121,32.122,32.123,32,32.321,32.322,32.323,32.325,32.331,32.332,32.333,32.335,32.351,32.352,32.353,32.381,32.382,32.383,32.385,32.391,32.392,32.393,32.395,32.441,32.442,32.443 / Text5: John Power
- 481: SP#42 umbrella BB created to host OAM WIs
- 482: SP#46 completed / Text3: 32.405 / Text5: Liang Shuangchun (liangshuangchun@cmdi.chinamobile.com), Li Jian (lijian@chinamobile.com), Bao Haitao
- 483: SP#48 completed / Text3: 32.425 / Text5: Yizhi Yao (yzyao@motorola.com),Lan Zou (zlan@huawei.com)
- 484: SP#46 completed / Text3: 32.426 / Text5: Li Jian (lijian@chinamobile.com), Liang Shuangchun (liangshuangchun@cmdi.chinamobile.com)
- 485: SP#43 umbrella BB created to host OAM WIs
- 486: SP#48 completed / Text3: 32.425, new 32.521, 32.522, 32.523, 32.525 / Text5: Lan Zou (zlan@huawei.com)
- 487: SP#48 completed / Text3: 32.501, 32.502, 32.503, 32.505, new 32.507 / Text5: clemens.suerbaum@nsn.com
- 488: SP#48 completed / Text3: 32.140, 32.141, 32.152, 32.172, 32.175 / Text5: frode.nergard@ericsson.com
- 489: SP#46 stopped (no work in Rel-9)
- 490: SP#47 completed / Text3: TR 30.819
- 491: CP#47 completed. Rel-8 UID_380061 (Ipinterc) covers Stage 1 in SA1 22.101, 22.228 / Text5: mauro.ficaccio@telecomitalia.it
- 492: CP#47 completed / Text3: 29.235 / Text5: mauro.ficaccio@telecomitalia.it
- 493: CP#46 completed / Text3: 23.231, 29.232, new 29.238 / Text5: mauro.ficaccio@telecomitalia.it
- 494: CP#46 completed / Text5: Bruno.Landais@alcatel-lucent.fr
- 495: CP#46 completed / Text3: new 29.238 / Text5: Bruno.Landais@alcatel-lucent.fr
- 496: CP#46 completed / Text3: 29.162, 29.235 / Text5: Bruno.Landais@alcatel-lucent.fr
- 497: CP#46 completed / Text3: new 23.334, 29.334 / Text5: bruno.landais@alcatel-lucent.fr
- 498: CP#48 completed. Stage 1 in 22.182 / Text5: Jiang Yi
- 499: CP#48 completed / Text3: 24.182 / Text5: Jiang Yi

| ID | WBS | Task | Duration | Start | Finish | Complete | Baseline start | Baseline finish | Baseline duration | Constraint | Resources | Work | Actual work | Text1 | Text2 | Text4 | Text5 | Text6 | Text7 | Text8 | Text11 |
| --- | --- | --- | --- | --- | --- | --- | --- | --- | --- | --- | --- | --- | --- | --- | --- | --- | --- | --- | --- | --- | --- |
| 500 | 192 | **Completion of IMS Restoration Procedures** | 212d? | 2009-05-29 A | 2010-03-19 A | 100% | 2009-05-29 | 2010-03-19 | 212d? |  | C3, C4,C1 | 6784h | 6784h | eIMS_RP | PCG-23 | Ericsson | Emiliano Merino (emiliano.merino@ericsson.com) | Rel-9 | CP-44 | Kimmo |  |
| 501 | 192.1 | CT4 aspects of Completion of IMS Restoration Procedures | 212d? | 2009-05-29 A | 2010-03-19 A | 100% | 2009-05-29 | 2010-03-19 | 212d? | finish no earlier than 2010-03-19 | C4 | 1696h | 1696h | eIMS_RP | PCG-23 | Ericsson | Emiliano Merino (emiliano.merino@ericsson.com) | Rel-9 | CP-44 | Kimmo |  |
| 502 | 192.2 | CT1 aspects of Completion of IMS Restoration Procedures | 212d? | 2009-05-29 A | 2010-03-19 A | 100% | 2009-05-29 | 2010-03-19 | 212d? | finish no earlier than 2010-03-19 | C1 | 1696h | 1696h | eIMS_RP | PCG-23 | Ericsson | Emiliano Merino (emiliano.merino@ericsson.com) | Rel-9 | CP-44 | Kimmo |  |
| 503 | 192.3 | CT3 aspects of Completion of IMS Restoration Procedures | 212d? | 2009-05-29 A | 2010-03-19 A | 100% | 2009-05-29 | 2010-03-19 | 212d? | finish no earlier than 2010-03-19 | C3 | 1696h | 1696h | eIMS_RP | PCG-24 | Ericsson | Emiliano Merino (emiliano.merino@ericsson.com) | Rel-9 | CP-46 | Kimmo |  |
| 504 | 193 | IMS Stage 3 - IETF Protocol Alignment | 212d? | 2009-05-29 A | 2010-03-19 A | 100% | 2009-05-29 | 2010-03-19 | 212d? | finish no earlier than 2010-03-19 | C1 | 1696h | 1696h | IMSProtoc3 | PCG-23 | Alcatel-Lucent | Keith Drage (drage@alcatel-lucent.com) | Rel-9 | CP-44 | Frederic |  |
| 505 | 194 | Operational description of the Inter-IMS Network to Network Interface (II-NNI) | 267d? | 2009-05-29 A | 2010-06-04 A | 100% | 2009-05-29 | 2010-06-04 | 267d? | finish no earlier than 2010-06-04 | C3 | 2136h | 2136h | II-NNI | PCG-23 | Orange | sebastien.daudet@orange-ftgroup.com | Rel-9 | CP-44 | Gwiho |  |
| 506 | 195 | Definition of Ml interface for Control Plane LCS (Stage 3) | 131d? | 2009-09-18 A | 2010-03-19 A | 100% | 2009-09-18 | 2010-03-19 | 131d? | finish no earlier than 2010-03-19 | C1 | 1048h | 1048h | EMC2 | PCG-23 | Alcatel-Lucent | Keith Drage (drage@alcatel-lucent.com) | Rel-9 | CP-45 | Frederic |  |
| 507 | 196 | PCC enhancements | 56d? | 2009-09-18 A | 2009-12-04 A | 100% | 2009-09-18 | 2009-12-04 | 56d? | finish no earlier than 2009-12-04 | C3 | 448h | 448h | PCC-Enh | PCG-23 | Huawei | Wei Weihua (weiwh@huawei.com) | Rel-9 | CP-45 | Gwiho |  |
| 508 | 197 | 3GPP IMS Conferencing Management Object (MO) | 2d? | 2009-12-03 A | 2009-12-04 A | 100% | 2009-12-03 | 2009-12-04 | 2d? | start no earlier than 2009-12-03 | C1 | 16h | 16h | IMS_ConfMO | PCG-24 |  |  | Rel-9 | CP-46 | Frederic |  |
| 509 | 198 | In Case of Emergency (ICE) Graphics | 3d? | 2010-03-17 A | 2010-03-19 A | 100% | 2010-03-17 | 2010-03-19 | 3d? | finish no earlier than 2010-03-19 | C6 | 24h | 24h | ICE_Graphics | PCG-24 | Sagem-Orga | heiko.kruse@sagem-orga.com | Rel-9 | CP-47 | Xavier |  |
| 510 | 199 | **Rel-9 Improvements of the Radio Interface** | 397d? | 2008-09-12 A | 2010-03-19 A | 100% | 2008-09-12 | 2010-03-19 | 397d? |  | RP,GP | 19147.6h | 19147.6h | RInImp9 | PCG-21 |  |  | Rel-9 | RP-41 | Issam |  |
| 511 | 199.1 | LCR TDD UE OTA Performance Requirements | 186d? | 2008-09-12 A | 2009-05-29 A | 100% | 2008-09-12 | 2009-05-29 | 186d? | finish no earlier than 2009-05-29 | R4 | 1488h | 1488h | RInImp9-RFLCROTA | PCG-21 | RITT | Wu Xiang (wuxiang@chinattl.com) | Rel-9 | RP-41 | Issam | RP-090389 |
| 512 | 199.2 | **RF requirements for Multicarrier and Multi-RAT BS** | 347d? | 2008-11-21 A | 2010-03-19 A | 100% | 2008-11-21 | 2010-03-19 | 347d? |  | R4,G1 | 7403.6h | 7403.6h | RInImp9-RFmulti | PCG-21 | Ericsson | Johan.skold@ericsson.com | Rel-9 | RP-41 | Issam |  |
| 513 | 199.2.1 | RAN4 part of RF requirements for Multicarrier and Multi RAT BS | 337d? | 2008-12-05 A | 2010-03-19 A | 100% | 2008-12-05 | 2010-03-19 | 337d? | finish no earlier than 2010-03-19 | R4 | 2696h | 2696h | RInImp9-Rfmulti | PCG-22 | Ericsson | Johan.skold@ericsson.com | Rel-9 | RP-42 | Issam | RP-100027 |
| 514 | 199.2.2 | GERAN part of RF requirements for Multicarrier and Multi RAT BS | 261d? | 2008-11-21 A | 2009-11-20 A | 100% | 2008-11-21 | 2009-11-20 | 261d? | finish no earlier than 2009-11-20 | G1 | 2088h | 2088h | RInImp9-RFmulti-GERAN | PCG-22 | Ericsson | mats.y.samuelsson@ericsson.com | Rel-9 | GP-40 | Paolo |  |
| 515 | 199.3 | Extended UMTS/LTE 800 MHz | 207d? | 2008-12-05 A | 2009-09-18 A | 100% | 2008-12-05 | 2009-09-18 | 207d? |  | R4,R2,R3 | 1648h | 1648h | RInImp9-UMTSLTE800 | PCG-22 | NTT DoCoMo | Shingo Suwa (suwas@nttdocomo.co.jp) | Rel-9 | RP-42 | Issam | RP-090687 |
| 516 | 199.4 | UMTS/LTE 800 MHz for Europe | 272d? | 2009-03-06 A | 2010-03-19 A | 100% | 2009-03-06 | 2010-03-19 | 272d? | finish no earlier than 2010-03-19 | R4,R2,R3 | 2176h | 2176h | RInImp9-UMTSLTE800EU | PCG-22 | Ericsson | olav.queseth@ericsson.com | Rel-9 | RP-43 | Issam | RP-100028 |
| 517 | 199.5 | Performance requirement for LCR TDD with UE speeds up to 350 km/h | 196d? | 2009-03-06 A | 2009-12-04 A | 100% | 2009-03-06 | 2009-12-04 | 196d? | finish no earlier than 2009-12-04 | R4 | 1568h | 1568h | RInImp9-LCRTDD350 | PCG-22 | CATT | Yuexia Song (songyuexia@datangmobile.cn) | Rel-9 | RP-43 | Issam | RP-091035 |
| 518 | 199.6 | Extended UMTS/LTE 1500 MHz | 211d? | 2009-05-30 A | 2010-03-19 A | 100% | 2009-05-30 | 2010-03-19 | 211d? | finish no earlier than 2010-03-19 | R4,R2,R3 | 1688h | 1688h | UMTSLTE1500 | PCG-23 | NTT DoCoMo | Shingo Suwa (suwas@nttdocomo.co.jp) | Rel-9 | RP-44 | Issam | RP-100029 |
| 519 | 200 | **Rel-9 Improvements of the Radio Interface - UE Conformance Testing** | 350d? | 2009-05-19 A | 2010-09-17 A | 100% | 2009-05-19 | 2010-09-17 | 350d? |  | R5 | 8184h | 8184h | RInImp-UEConTest | PCG-23 |  |  | Rel-9 | RP-44 | Ingbert |  |
| 520 | 200.1 | Conformance Test Aspects – UMTS/LTE in 800 MHz for Europe | 350d? | 2009-05-19 A | 2010-09-17 A | 100% | 2009-05-19 | 2010-09-17 | 350d? | finish no earlier than 2010-09-17 | R5 | 2800h | 2800h | RInImp-UEConTest-UMTSLTE800EU | PCG-23 | Ericsson | fredrik.sundstrom@ericsson.com | Rel-9 | RP-44 | Ingbert | RP-100736 |
| 521 | 200.2 | Conformance Test Aspects – Extended UMTS/LTE 1500 MHz | 186d? | 2009-09-18 A | 2010-06-04 A | 100% | 2009-09-18 | 2010-06-04 | 186d? | finish no earlier than 2010-06-04 | R5 | 1488h | 1488h | UMTSLTE1500_UEConTest | PCG-23 | NTT DoCoMo | Nguyen Dung Dao (dao@nttdocomo.co.jp) | Rel-9 | RP-45 | Ingbert | RP-100487 |
| 522 | 200.3 | TDD UE Over The Air (Antenna) conformance testing methodology | 81d? | 2009-05-30 A | 2009-09-18 A | 100% | 2009-05-30 | 2009-09-18 | 81d? | finish no earlier than 2009-09-18 | R5 | 648h | 648h | UEAnt_TDDTest | PCG-23 | CATR | Qu Yan (quyan@emcite.com) | Rel-9 | RP-44 | Ingbert | RP-090727 |
| 523 | 200.4 | Conformance Test Aspects – Performance requirement for LCR TDD with UE speeds up to 350 km/h | 56d? | 2010-03-19 A | 2010-06-04 A | 100% | 2010-03-19 | 2010-06-04 | 56d? | finish no earlier than 2010-06-04 | R5 | 448h | 448h | RInImp9-LCRTDD350_UEConTest | PCG-24 | CATT | Xiaozhong Chen (chexiaozhong@datangmobile.cn) | Rel-9 | RP-47 | Ingbert | RP-100496 |
| 524 | 201 | Conformance Test Aspects – SMS over IMS in E-UTRAN | 131d? | 2009-09-18 A | 2010-03-19 A | 100% | 2009-09-18 | 2010-03-19 | 131d? | finish no earlier than 2010-06-18 | R5 | 1048h | 1048h | SMSoverIMS_UEConTest | PCG-23 | Alcatel-Lucent | Nidal Khrais (khrais@alcatel-lucent.com) | Rel-9 | RP-45 | Ingbert | RP-100072 |

Notes:
- 500: CP#47 completed. Continuation of Rel-8 Feature UID_400012 IMS Restoration Procedures
- 501: CP#47 completed / Text3: 23.380, 23.820
- 502: CP#47 completed / Text3: 24.229
- 503: CP#47 completed / Text3: 29.061, 29.212, 29.213, 29.214, 29.215
- 504: CP#47 completed / Text3: 23.218, 24.229, 24.930
- 505: CP#48 completed / Text3: 29.165
- 506: CP#47 completed [Stage 3 for Rel-7 Emergency Calls (EMC1)]. Related to Rel-9 UID_400038 LCS Control Plane Solution for EPS. Stage 2 in Rel-9 UID_400038 (23.271), UID_410037 (23.167) / Text3: 24.229
- 507: CP#46 completed / Text3: 29.212, 29.213, 29.215
- 508: CP#46 completed. Linked to Rel-6 UID_11051 (IMS Management objects) under the Feature UID_32021 (IMS Phase 2). MO compatible with OMA DM v1.2 & upwards and defined using OMA DM Device Description Framework (OMA-ERELD _DM-V1_2) / Text3: new 24.166
- 509: CP#47 approved WID and completed. Added capability to store ICE graphical information (picture). Linked to CT6 Rel-8 ICE Feature UID_380059 In Case of Emergency numbers storage and easy access on UICC / Text3: 31.102 CR#0433
- 510: RP#41 umbrella Feature created to host Rel-9 WIs / Text3: GERA, UTRA, LTE
- 511: RP#44 completed technical work (RAN4 internal TR abandoned) / Text3: UTRA (no TR 25.8xy produced)
- 512: RP#47 completed. RF requirements specification applicable to Multi-Standard Radio (MSR) Base Station with multiple carriers and/or multiple 3GPP Radio Access Technologies (RAT) / Text3: GERA, UTRA, LTE
- 513: RP#48 completed / Text3: UTRA, LTE 25.104, 25.105, 36.104, new 37.104, 37.113, 37.141, 37.900
- 514: GP#44 Core spec completed (ongoing BS conformance spec). GP#40 WID approved / Text3: GERA 45.005, 51.021
- 515: RP#45 completed / Text3: UTRA, LTE 25.101, 25.104, 25.113, 25.133, 34.124, 36.101, 36.104, 36.113, 36.124, 36.133, 36.141, 25.306, 25.307, 25.331, 36.331, 25.461, 25.466, new 36.800
- 516: RP#47 completed / Text3: UTRA, LTE 25.101, 25.104, 25.113, 25.133, 25.141, 34.124, 36.101, 36.104, 36.113, 36.124, 36.133, 36.141, new 36.810, 25.306, 25.307, 25.331, 36.331, 25.461, 25.466
- 517: RP#46 completed / Text3: UTRA 25.102, 25.105, 25.142
- 518: RP#47 completed. For potential deployment in Japan / Text3: UTRA, LTE 25.101, 25.104, 25.113, 25.133, 25.141, 25.306, 25.307, 25.331, 25.461, 25.466, 34.124, 36.101, 36.104, 36.113, 36.124, 36.133, 36.141, 36.331, new (36.821, 36.307)
- 519: - / Text3: UTRA, LTE
- 520: RP#49 completed. Testing for UID_430009 UMTS/LTE 800 MHz for Europe / Text3: UTRA, LTE 34.108, 34.121-1, 34.121-2, 36.508, 36.521-1, 36.521-2, 36.521-3
- 521: RP#48 completed / Text3: UTRA, LTE 34.108, 34.121-1, 34.121-2, 34.123-1, 34.123-2, 36.508, 36.521-1, 36.521-2, 36.521-3, 36.523-1, 36.523-2, 36.523-3
- 522: RP#45 completed. Finalized TDD UE test methodology based on R4 TR 25.914 (UE and MS antenna performance evaluation method) and TS 25.144 Over the Air (Antenna) minimum performance requirements for the speech mode (terminal close to head) / Text3: UTRA 34.114
- 523: RP#48 completed. Testing for UID_430010 Performance requirement for LCR TDD with UE speeds up to 350 km/h / Text3: UTRA 34.122
- 524: RP#47 completed / Text3: LTE 34.229-1, 34.229-2, 34.229-3

| ID | WBS | Task | Duration | Start | Finish | Complete | Remaining | Baseline start | Baseline finish | Baseline duration | Total slack | Constraint | Resources | Work | Actual work | Text1 | Text2 | Text6 | Text7 | Text8 | Text4 | Text5 | Text11 |
| --- | --- | --- | --- | --- | --- | --- | --- | --- | --- | --- | --- | --- | --- | --- | --- | --- | --- | --- | --- | --- | --- | --- | --- |
| 525 | 202 | **Rel-9 RAN improvements** | 272d? | 2009-03-06 A | 2010-03-19 A | 100% |  | 2009-03-06 | 2010-03-19 | 272d? |  |  | RP | 9536h | 9536h | RANimp | PCG-22 | Rel-9 | RP-43 | Issam |  |  |  |
| 526 | 202.1 | Dual-Cell HSUPA | 272d? | 2009-03-06 A | 2010-03-19 A | 100% |  | 2009-03-06 | 2010-03-19 | 272d? |  | finish no earlier than 2010-03-19 | R1,R2,R3,R4 | 1568h | 1568h | RANimp-DC_HSUPA | PCG-22 | Rel-9 | RP-43 | Patrick | Nokia Siemens Networks | Karri Ranta-aho (karri.ranta-aho@nsn.com) | RP-100030 |
| 527 | 202.2 | Support for different bands for Dual-Cell HSDPA | 197d? | 2009-03-06 A | 2009-12-04 A | 100% |  | 2009-03-06 | 2009-12-04 | 197d? |  |  | R4,R2,R3 | 1568h | 1568h | RANimp-MultiBand_DC_HSDPA | PCG-22 | Rel-9 | RP-43 | Issam | Nokia Siemens Networks | Tuomo Säynäjäkangas (tuomo.saynajakangas@nsn.com) | RP-091038 |
| 528 | 202.3 | Combination of DC-HSDPA with MIMO | 197d? | 2009-03-06 A | 2009-12-04 A | 100% |  | 2009-03-06 | 2009-12-04 | 197d? |  |  | R1,R2,R3,R4 | 1568h | 1568h | RANimp-DC_MIMO | PCG-22 | Rel-9 | RP-43 | Patrick | Ericsson | johan.bergman@ericsson.com | RP-091039 |
| 529 | 202.4 | Transmit Antenna Array (TxAA) extension for non-MIMO UEs | 197d? | 2009-03-06 A | 2009-12-04 A | 100% |  | 2009-03-06 | 2009-12-04 | 197d? |  |  | R1,R2,R3,R4 | 1568h | 1568h | RANimp-TxAA_nonMIMO | PCG-22 | Rel-9 | RP-43 | Patrick | Nokia | Arto Lehti (arto.lehti@nokia.com) | RP-091040 |
| 530 | 202.5 | Cell Portion for 1.28 Mcps TDD | 136d? | 2009-05-30 A | 2009-12-04 A | 100% |  | 2009-05-30 | 2009-12-04 | 136d? |  |  | R3,R1,R4 | 1088h | 1088h | CP_LCRTDD | PCG-23 | Rel-9 | RP-44 | Juha | CATT | Ying Zhang (zhangying2@datangmobile.cn) | RP-091041 |
| 531 | 203 | **Rel-9 RAN improvements - UE Conformance Testing** | 196d? | 2010-09-17 | 2011-06-17 |  |  | 2010-09-17 | 2011-06-17 | 196d? | 290.8d |  | R5 | 3136h |  |  | PCG-25 | Rel-9 | RP-49 | Ingbert |  |  |  |
| 532 | 203.1 | Conformance Test Aspects – Combination of DC-HSDPA with MIMO | 196d? | 2010-09-17 | 2011-06-17 |  |  | 2010-09-17 | 2011-06-17 | 196d? | 290.8d | finish no earlier than 2011-06-17 | R5 | 1568h |  | RANimp-DC_MIMO_UEConTest | PCG-25 | Rel-9 | RP-49 | Ingbert | Ericsson | leif.mattisson@ericsson.com |  |
| 533 | 204 | **LTE improvements** | 532d? | 2009-03-06 A | 2011-03-18 | 78% | 116.35d? | 2009-03-06 | 2011-03-18 | 532d? | 355.8d |  | RP | 9048h | 6953.14h | LTEimp | PCG-22 | Rel-9 | RP-42 | Patrick |  |  |  |
| 534 | 204.1 | LTE Pico NodeB RF Requirements | 196d? | 2009-03-06 A | 2009-12-04 A | 100% |  | 2009-03-06 | 2009-12-04 | 196d? |  | finish no earlier than 2010-03-05 | R4 | 1568h | 1568h | LTEimp-Pico_eNB-RF | PCG-22 | Rel-9 | RP-43 | Issam | Huawei | Liyan Yin (yinliyan@huawei.com) | RP-091045 |
| 535 | 204.2 | Enhanced Dual-Layer transmission for LTE | 272d? | 2009-03-06 A | 2010-03-19 A | 100% |  | 2009-03-06 | 2010-03-19 | 272d? |  | finish no earlier than 2010-03-18 | R1,R2,R4 | 2176h | 2176h | LTEimp-eDL | PCG-22 | Rel-9 | RP-43 | Patrick | China Mobile | Xu Xiaodong (xuxiaodong@chinamobile.com) | RP-100034 |
| 536 | 204.3 | UE Conformance Test Aspects – Enhanced Dual-layer transmission for LTE TDD | 131d? | 2010-09-17 | 2011-03-18 |  |  | 2010-09-17 | 2011-03-18 | 131d? | 355.8d | finish no earlier than 2011-03-18 | R5 | 1048h |  | LTEimp-eDL_UEConTest | PCG-25 | Rel-9 | RP-49 | Ingbert | China Mobile | Shanpeng Xiao (xiaoshanpeng@chinamobile.com) |  |
| 537 | 205 | Self-Organizing Networks (SON) | 272d? | 2009-03-06 A | 2010-03-19 A | 100% |  | 2009-03-06 | 2010-03-19 | 272d? |  | finish no earlier than 2010-03-19 | R3,R2 | 2176h | 2176h | SON | PCG-22 | Rel-9 | SP-42 | Juha | Nokia Siemens Networks | krzysztof.kordybach@nsn.com | RP-100038 |
| 538 | 206 | **A-GNSS Performances and Testing Procedures** | 652d? | 2008-05-16 A | 2010-11-12 | 77% | 151.28d? | 2008-05-16 | 2010-11-12 | 652d? | 445.8d |  | GP | 14208h | 7223.2h | AGNSSPTP |  | Rel-9 |  | Paolo | Thales | Michel.monnerat@thalesaleniaspace.com |  |
| 539 | 206.1 | A-GNSS Minimum Performances | 472d? | 2008-05-16 A | 2010-03-05 A | 100% |  | 2008-05-16 | 2010-03-05 | 472d? |  | finish no earlier than 2010-03-05 | G1 | 3776h | 3776h | AGNSSPTP- Perfreq |  | Rel-9 |  | Paolo | Thales | Michel.monnerat@thalesaleniaspace.com |  |
| 540 | 206.2 | A-GNSS Testing Procedures | 652d? | 2008-05-16 A | 2010-11-12 | 60% | 260.8d? | 2008-05-16 | 2010-11-12 | 652d? | 445.8d | finish no earlier than 2010-11-12 | G3new | 5216h | 3129.6h | AGNSSPTP-MStest |  | Rel-9 |  | Ingbert | Thales | Michel.monnerat@thalesaleniaspace.com |  |
| 541 | 207 | Study on Multi-User Reusing-One-Slot | 782d? | 2007-11-16 A | 2010-11-12 | 98% | 15.64d? | 2007-11-16 | 2010-11-12 | 782d? | 445.8d | finish no earlier than 2010-11-12 | GP | 6248h | 6122.88h | MUROS |  | Rel-9 |  | Paolo | Nokia Siemens Networks | juergen.hofmann@nsn.com |  |
| 542 | 208 | **Voice services over Adaptive Multi-user channels on One Slot** | 857d? | 2008-11-21 A | 2012-03-02 | 74% | 225.76d? | 2008-11-21 | 2012-03-02 | 857d? | 105.8d |  | GP,G1,G2,G3new | 21536h | 13948.8h | VAMOS | PCG-22 | Rel-9 | SP-42 | Paolo | Nokia Siemens Networks, China Mobile | juergen.hofmann@nsn.com, liuxiaoyu@chinamobile.com | GP-092470 |
| 543 | 208.1 | VAMOS Stage 2 | 392d? | 2008-11-21 A | 2010-05-21 A | 100% |  | 2008-11-21 | 2010-05-21 | 392d? |  | finish no earlier than 2010-05-21 | GP,G1,G2 | 3136h | 3136h | VAMOS | PCG-22 | Rel-9 | GP-40 | Paolo | Nokia Siemens Networks, China Mobile | juergen.hofmann@nsn.com, liuxiaoyu@chinamobile.com |  |
| 544 | 208.2 | VAMOS Stage 3 | 526d? | 2008-11-24 A | 2010-11-26 | 95% | 26.3d? | 2008-11-24 | 2010-11-26 | 526d? | 435.8d | finish no earlier than 2010-11-26 | GP,G1,G2 | 4208h | 3997.6h | VAMOS | PCG-22 | Rel-9 | GP-40 | Paolo | Nokia Siemens Networks, China Mobile | juergen.hofmann@nsn.com, liuxiaoyu@chinamobile.com | GP-092470 |
| 545 | 208.3 | VAMOS Radio Performance Requirements | 526d? | 2008-11-24 A | 2010-11-26 | 80% | 105.2d? | 2008-11-24 | 2010-11-26 | 526d? | 435.8d | finish no earlier than 2010-11-26 | GP,G1,G2 | 4208h | 3366.4h | VAMOS | PCG-22 | Rel-9 | GP-40 | Paolo | Nokia Siemens Networks, China Mobile | juergen.hofmann@nsn.com, liuxiaoyu@chinamobile.com | GP-092470 |
| 546 | 208.4 | VAMOS - MS conformance testing | 391d? | 2010-09-03 A | 2012-03-02 | 10% | 351.9d? | 2010-09-03 | 2012-03-02 | 391d? | 105.8d | finish no earlier than 2012-03-02 | G3new | 3128h | 312.8h | VAMOS_MStest | PCG-25 | Rel-9 | GP-47 | Ingbert | Research In Motion | Raveendra Seetharam (rseetharam@rim.com) |  |
| 547 | 209 | **Cell Broadcast protocol Base Station Controller – Cell Broadcast Centre (BSC-CBC)** | 222d? | 2009-05-15 A | 2010-03-19 A | 100% |  | 2009-05-15 | 2010-03-19 | 222d? |  |  | GP,C1 | 5248h | 5248h | CEBRO | PCG-23 | Rel-9 | GP-42 | Paolo | Ericsson | Claes-Göran Persson |  |
| 548 | 209.1 | GERAN part of Cell Broadcast protocol Base Station Controller – Cell Broadcast Centre | 212d? | 2009-05-15 A | 2010-03-05 A | 100% |  | 2009-05-15 | 2010-03-05 | 212d? |  | finish no earlier than 2010-03-05 | GP | 1696h | 1696h | CEBRO | PCG-23 | Rel-9 | GP-42 | Paolo | Ericsson | Claes-Göran Persson |  |
| 549 | 209.2 | CT1 part of Cell Broadcast protocol Base Station Controller – Cell Broadcast Centre | 222d? | 2009-05-15 A | 2010-03-19 A | 100% |  | 2009-05-15 | 2010-03-19 | 222d? |  | finish no earlier than 2010-03-19 | C1 | 1776h | 1776h | CEBRO | PCG-23 | Rel-9 | GP-42 | Frederic | Ericsson | Claes-Göran Persson |  |
| 550 | 210 | Hybrid Location | 136d? | 2009-05-18 A | 2009-11-20 A | 100% |  | 2009-05-18 | 2009-11-20 | 136d? |  | finish no earlier than 2009-11-20 | GP | 1088h | 1088h | HILT | PCG-23 | Rel-9 | GP-42 | Paolo | TruePosition | Matt Ward (mward@trueposition.com) |  |
| 551 | 211 | (Small) Technical Enhancements and Improvements for Rel-9 | 325d? | 2008-09-15 A | 2009-12-10 A | 100% |  | 2008-09-15 | 2009-12-10 | 325d? |  | finish no earlier than 2009-12-10 | All | 2600h | 2600h | TEI9 | PCG-22 | Rel-9 | SP-42 | A |  |  |  |
| 552 | 212 | Test - (Small) Technical Enhancements and Improvements for Rel-9 | 286d? | 2009-11-20 A | 2010-12-24 | 80% | 57.2d? | 2009-11-20 | 2010-12-24 | 286d? | 415.8d | finish no earlier than 2010-12-24 | R5,G3new | 2288h | 1830.4h | TEI9_Test | PCG-24 | Rel-9 | GP-44 | Ingbert |  |  |  |

Notes:
- 525: RP#47 completed / Text3: UTRA
- 526: RP#47 completed / Text3: 25.101, 25.104, 25.133, 25.211, 25.212, 25.213, 25.214, 25.215, 25.319, 25.306, 25.321, 25.331, 25.423, 25.433
- 527: RP#46 completed / Text3: 25.101, 25.104, 25.133, 25.306, 25.308, 25.331, 25.423, 25.433, new 25.317 (Requirements on Ues supporting a release-independent frequency band combination)
- 528: RP#46 completed / Text3: 25.101, 25.104, 25.133, 25.211, 25.212, 25.213, 25.214, 25.215, 25.308, 25.321, 25.331, 26.306, 25.423, 25.433
- 529: RP#46 completed / Text3: 25.101, 25.104, 25.211, 25.212, 25.213, 25.214, 25.215, 25.308, 25.306, 25.321, 25.331, 25.423, 25.433
- 530: RP#46 completed / Text3: 25.102, 25.105, 25.123, 25.225, 25.423, 25.433
- 531: -
- 532: UTRA. Testing for Rel-9 UID_430016 Combination of DC-HSDPA with MIMO / Text3: 34.108, 34.121-1, 34.121-2, 34.123-1, 34.123-2, 34.123-3
- 533: - / Text3: LTE
- 534: RP#46 completed / Text3: 36.104, 36.141, new 36.931
- 535: RP#47 completed / Text3: 36.101, 36.211, 36.212, 36.213, 36.331
- 536: Testing for UID_430029 (Enhanced Dual-Layer transmission for LTE) / Text3: 36.508, 36.521-1, 36.521-2
- 537: RP#47 completed / Text3: LTE 25.413, 36.300, 36.413, 36.423, 48.018, new 36.902
- 538: GP#46 still ongoing MS testing. Linked to Rel-10 RAN4 UID_450027 (A-GNSS Minimum Performance for UTRAN)
- 539: GP#45 completed (open performance requirements alignment GPS/Galileo) / Text3: 45.005
- 540: GP#46 completion 05/10=>11/10. GP#44 exception to 05/10 in GP-092344 / Text3: 51.010-1, new 51.010-7
- 541: GP#46 completion =09/10=>11/10 (was 11/08=>02/09=>05/09=>11/09=>03/10=>09/10). Spin-off implementation WI UID_420002 VAMOS (Voice services over Adaptive Multi-user channels on One Slot) / Text3: 45.914
- 542: GP#46 completion 05/10=>09/10. GP#44 exception to 05/10 in GP-092470. GP#40 WID approved. Triggered by UID_50590 (MUROS) Study on Multi-User Reusing-One-Slot
- 543: GP#46 completed / Text3: 45.001
- 544: GP#47 completion 09/10=>11/10. GP#44 exception to 05/10 in GP-092470 / Text3: 24.008, 44.018, 45.002, 45.003, 45.004, 45.008, 48.008, 48.058
- 545: GP#47 completion 09/10=>11/10. GP#44 exception to 05/10 in GP-092470 / Text3: 45.005 (Test Scenarios for VAMOS Performance requirements)
- 546: GP#47 WID approved. / Text3: 51.010-1, 51.010-2
- 547: CP#47 completed. GP#45 completed. GP#42 WID approved
- 548: GP#45 completed. GP#42 WID approved / Text3: new 48.049
- 549: CP#47 completed / Text3: 23.041
- 550: GP#44 completed. GP#42 WID approved (Hybrid Integrated Location Technology=HILT) / Text3: 43.059, 48.071
- 551: SP#46 completed
- 552: GP#44 created

| ID | WBS | Task | Type | Duration | Start | Finish | Complete | Remaining | Baseline start | Baseline finish | Baseline duration | Total slack | Constraint | Resources | Work | Actual work | Text1 | Text4 | Text5 | Text6 | Text7 | Text8 | Text2 | Text9 | Text12 | Text11 |
| --- | --- | --- | --- | --- | --- | --- | --- | --- | --- | --- | --- | --- | --- | --- | --- | --- | --- | --- | --- | --- | --- | --- | --- | --- | --- | --- |
| 553 | 213 | **Services Alignment and Migration** |  | 467d? | 2006-12-06 A | 2008-09-18 A | 100% |  | 2006-12-06 | 2008-09-18 | 467d? |  |  | S1 | 7472h | 7472h | ServAl | Telefónica O2 Europe | chris.friel@o2.com | Rel-9 | SP-33 | Alain |  |  |  |  |
| 554 | 213.1 | Stage 1 for ServAl |  | 467d? | 2006-12-06 A | 2008-09-18 A | 100% |  | 2006-12-06 | 2008-09-18 | 467d? |  | finish no earlier than 2008-12-11 | S1 | 3736h | 3736h | ServAl | Telefónica O2 Europe | chris.friel@o2.com | Rel-9 | SP-33 | Alain | PCG-21 |  |  |  |
| 555 | 214 | Deleted - Harmonization of Gq'/Rx for Common IMS |  | 304d? | 2008-01-14 A | 2009-03-12 A | 100% |  | 2008-01-14 | 2009-03-12 | 304d? |  | finish no earlier than 2009-03-12 | S2 | 2432h | 2432h | IMS_Comm_GqRx_Harm | Alcatel-Lucent | geoffrey.cristallo@alcatel-lucent.be | Rel-9 | SP-38 | Maurice | PCG-21 | PCG-22 | SP-43 |  |
| 556 | 215 | Deleted - Support of WiMAX - LTE Mobility |  | 407d? | 2008-06-06 A | 2009-12-25 A | 100% |  | 2008-06-06 | 2009-12-25 | 407d? |  | start no earlier than 2008-06-06 | R2 | 3248h | 3248h | WiMAX_LTE_Mobility | Samsung |  | Rel-9 | RP-38 | Joern | PCG-21 | PCG-21 | SP-39 |  |
| 557 | 216 | Deleted - Support of WiMAX - UMTS Mobility |  | 407d? | 2008-06-06 A | 2009-12-25 A | 100% |  | 2008-06-06 | 2009-12-25 | 407d? |  | start no earlier than 2008-06-06 | R2 | 3248h | 3248h | WiMAX_UMTS_Mobility | Intel |  | Rel-9 | RP-38 | Joern | PCG-21 | PCG-21 | SP-39 |  |
| 558 | 217 | Deleted - Definition of 3GPP UICC services over the new high-speed interface | milestone | 0d? | 2010-03-19 A | 2010-03-19 A | 100% |  | 2010-03-19 | 2010-03-19 | 0d? |  |  | C6 |  |  | UICCHS | Gemalto | Denis L'Heriteau | Rel-9 | CP-38 | Xavier | PCG-21 | PCG-24 | CP-47 |  |
| 559 | 218 | **Deleted - SAES Enhancements (non RAN aspects)** |  | 381d? | 2007-06-25 A | 2008-12-08 A | 100% |  | 2007-06-25 | 2008-12-08 | 381d? |  |  | S2 | 11664h | 11664h | SAES_Ph2 | Nokia Siemens Networks |  | Rel-9 | SP-39 | Maurice | PCG-21 | PCG-21 | SP-39 |  |
| 560 | 218.1 | Deleted - Functions and procedures for SAE to support LTE MBMS |  | 381d? | 2007-06-25 A | 2008-12-08 A | 100% |  | 2007-06-25 | 2008-12-08 | 381d? |  | finish no earlier than 2008-12-08 | S2 | 3048h | 3048h | SAES_Ph2 |  |  | Rel-9 | SP-35 | Maurice |  | PCG-21 | SP-39 |  |
| 561 | 218.2 | Deleted - CS over EPS |  | 194d? | 2008-03-12 A | 2008-12-08 A | 100% |  | 2008-03-12 | 2008-12-08 | 194d? |  | finish no earlier than 2008-12-08 | S2 | 1552h | 1552h | SAES_Ph2 |  |  | Rel-9 | SP-39 | Maurice | PCG-21 | PCG-21 | SP-39 |  |
| 562 | 218.3 | **Deleted - SAE for generic support for non-3GPP accesses** |  | 251d? | 2007-06-25 A | 2008-06-09 A | 100% |  | 2007-06-25 | 2008-06-09 | 251d? |  |  | S2 | 4016h | 4016h | SAES_Ph2 |  |  | Rel-9 | SP-39 | Maurice | PCG-21 | PCG-21 | SP-39 |  |
| 563 | 218.3.1 | Deleted - Single Radio Aspects of SAE for Optimized Handover with WiMAX |  | 251d? | 2007-06-25 A | 2008-06-09 A | 100% |  | 2007-06-25 | 2008-06-09 | 251d? |  | finish no earlier than 2008-06-09 | S2 | 2008h | 2008h | SAES_Ph2 |  |  | Rel-9 | SP-39 | Maurice | PCG-21 | PCG-21 | SP-39 |  |
| 564 | 219 | Deleted - Lawful Interception in the 3GPP Rel-9 |  | 211d? | 2009-06-04 A | 2010-03-25 A | 100% |  | 2009-06-04 | 2010-03-25 | 211d? |  | finish no earlier than 2010-03-25 | S3 | 1688h | 1688h | LI9 | PIDS, Nortel | Koen Jaspers, Ronald Ryan | Rel-9 | SP-44 | Dionisio | PCG-23 | PCG-24 | SP-47 |  |
| 565 | 220 | Release 9 Studies |  | 468d? | 2008-06-05 A | 2010-03-19 A | 100% |  | 2008-06-05 | 2010-03-19 | 468d? |  |  | CP,RP,SP | 3744h | 3744h |  |  |  | Rel-9 |  |  |  |  |  |  |
| 566 | 221 | Study on Service Specific Access Control in EPS |  | 136d? | 2008-06-05 A | 2008-12-11 A | 100% |  | 2008-06-05 | 2008-12-11 | 136d? |  | start no earlier than 2008-06-05 | S1 | 1088h | 1088h | FS_SSAC | NTT DoCoMo | Shin-ichi Isobe (isobes@nttdocomo.co.jp) | Rel-9 | SP-40 | Alain | PCG-21 |  |  |  |
| 567 | 222 | Study on CS Domain Services over EPS access |  | 492d? | 2007-04-25 A | 2009-03-12 A | 100% |  | 2007-04-25 | 2009-03-12 | 492d? |  | finish no earlier than 2009-03-12 | S2 | 3936h | 3936h | FS_CSoPS | T-Mobile | Karl-Heinz.Nenner@T-Mobile.net | Rel-9 | SP-35 | Maurice |  |  |  |  |
| 568 | 223 | Study on Extended Support of IMS Emergency Calls |  | 319d? | 2007-09-24 A | 2008-12-11 A | 100% |  | 2007-09-24 | 2008-12-11 | 319d? |  | finish no earlier than 2009-06-18 | S2 | 2552h | 2552h | FS_IMS-eCall | Qualcomm | Stephen Edge | Rel-9 | SP-37 | Maurice |  |  |  |  |
| 569 | 224 | Study on Service Continuity for Emergency Voice Calls |  | 721d? | 2006-06-08 A | 2009-03-12 A | 100% |  | 2006-06-08 | 2009-03-12 | 721d? |  | finish no earlier than 2009-03-12 | S2 | 5768h | 5768h | FS_VCCEm | Nortel | Ricky Kaura (rkaura@nortel.com) | Rel-9 | SP-32 | Maurice |  |  |  |  |
| 570 | 225 | Study on Security Aspects of Remote Provisioning and Change of Subscription for M2M Equipment |  | 582d? | 2004-04-06 A | 2009-12-10 A | 100% |  | 2004-04-06 | 2009-12-10 | 582d? |  | finish no earlier than 2009-12-10 | S3,C6 | 4656h | 4656h | FS_UM2M | Ericsson | vesa.lehtovirta@ericsson.com | Rel-9 | SP-37 | Dionisio |  |  |  |  |
| 571 | 226 | Study on System Maintenance over Itf-N |  | 602d? | 2007-06-07 A | 2009-09-24 A | 100% |  | 2007-06-07 | 2009-09-24 | 602d? |  | finish no earlier than 2009-09-24 | S5 | 4808h | 4808h | FS_OAM-Maint-Itf-N | ZTE | Shuqiang Huang (huangsq@zte.com.cn) | Rel-9 | SP-36 | Dionisio |  |  |  |  |
| 572 | 227 | Study on Self-Organizing Networks (SON) related OAM interfaces for Home NodeB |  | 522d? | 2007-06-07 A | 2009-06-04 A | 100% |  | 2007-06-07 | 2009-06-04 | 522d? |  | finish no earlier than 2009-12-10 | S5 | 4168h | 4168h | FS_OAM-SON-HNB | Huawei | Zou Lan (zlan@huawei.com) | Rel-9 | SP-36 | Dionisio |  |  |  |  |
| 573 | 228 | Study on Self-healing of Self-Organizing Networks (SON) |  | 416d? | 2008-02-22 A | 2009-09-24 A | 100% |  | 2008-02-22 | 2009-09-24 | 416d? |  | finish no earlier than 2009-09-24 | S5 | 3320.15h | 3320.15h | FS_OAM-SON-SH | ZTE | zhu.weihong@zte.com.cn | Rel-9 | SP-39 | Dionisio | PCG-21 |  |  |  |
| 574 | 229 | Study on Service Oriented Architecture (SOA) for IRP |  | 262d? | 2008-06-05 A | 2009-06-04 A | 100% |  | 2008-06-05 | 2009-06-04 | 262d? |  | finish no earlier than 2009-05-20 | S5 | 2088h | 2088h | FS_OAM_SOA_IRP | Ericsson | edwin.tse@ericsson.com | Rel-9 | SP-40 | Dionisio | PCG-21 |  |  |  |
| 575 | 230 | Study on Evaluation of the inclusion of Path Loss Based Technology in the UTRAN |  | 516d? | 2007-12-17 A | 2009-12-04 A | 100% |  | 2007-12-17 | 2009-12-04 | 516d? |  | finish no earlier than 2009-09-18 | R4 | 4120h | 4120h | FS_RAN-Pathloss | Polaris Wireless | Norman Shaw (nshaw@polariswireless.com) | Rel-9 | RP-38 | Issam | PCG-21 |  |  | RP-091080 |
| 576 | 231 | Study on LTE-Advanced |  | 461d? | 2007-03-23 A | 2010-03-19 A | 100% |  | 2007-03-23 | 2010-03-19 | 461d? |  | finish no earlier than 2010-03-19 | R1,R2,R3,R4 | 3688h | 3688h | FS_RAN_LTEA | NTT DoCoMo | Tetsushi Abe | Rel-9 | RP-39 | Patrick | PCG-21 |  |  | RP-100080 |
| 577 | 232 | Study on 1.28 Mcps TDD Home NodeB |  | 387d? | 2008-02-20 A | 2009-12-04 A | 100% |  | 2008-02-20 | 2009-12-04 | 387d? |  | finish no earlier than 2009-12-04 | R4 | 3096h | 3096h | FS_RAN-HNBLCRTDD | TD Tech | Li Rong (lirong@td-tech.com) | Rel-9 | RP-41 | Issam | PCG-21 |  |  | RP-091081 |
| 578 | 233 | Study on E-UTRAN Mobility Evaluation and Enhancement |  | 126d? | 2008-12-05 A | 2009-05-29 A | 100% |  | 2008-12-05 | 2009-05-29 | 126d? |  | finish no earlier than 2009-05-29 | R1 | 1008h | 1008h | FS_EUTRAN_mob | Qualcomm | Rajat Prakash (rprakash@qualcomm.com) | Rel-9 | RP-42 | Patrick | PCG-22 |  |  | RP-090426 |
| 579 | 234 | Study on Minimization of drive-tests in Next Generation Networks |  | 196d? | 2009-03-06 A | 2009-12-04 A | 100% |  | 2009-03-06 | 2009-12-04 | 196d? |  | finish no earlier than 2009-12-04 | R2 | 1568h | 1568h | FS_NGN_min_drive-tests | Qualcomm | Masato Kitazoe (mkitazoe@qualcomm.com) | Rel-9 | RP-43 | Joern | PCG-22 |  |  | RP-091084 |
| 580 | 235 | Study on Enhanced Interference Management for HNBs |  | 61d? | 2009-03-06 A | 2009-05-29 A | 100% |  | 2009-03-06 | 2009-05-29 | 61d? |  | start no earlier than 2009-03-06 | R4 | 488h | 488h | FS_eInterfMgmt_HNB | Qualcomm | Farhad Meshkati (fmeshkat@qualcomm.com) | Rel-9 | RP-43 | Issam | PCG-22 |  |  | RP-090429 |
| 581 | 236 | Study on Enhanced Interference Management Mechanisms for HNBs |  | 81d? | 2009-05-30 A | 2009-09-18 A | 100% |  | 2009-05-30 | 2009-09-18 | 81d? |  | finish no earlier than 2009-09-18 | R3 | 648h | 648h | FS_eInterfMgmtMchsm_HNB | Qualcomm | Farhad Meshkati (fmeshkat@qualcomm.com) | Rel-9 | RP-44 | Juha | PCG-23 |  |  | RP-090733 |
| 582 | 237 | Deleted - Study on Protection against SMS and MMS spam |  | 862d? | 2006-06-08 A | 2009-09-24 A | 100% |  | 2006-06-08 | 2009-09-24 | 862d? |  | finish no earlier than 2009-09-24 | S3 | 6896h | 6896h | FS_CPSMal | Orange | eric.gauthier@orange.ch | Rel-9 | SP-32 | Dionisio |  | PCG-23 | SP-45 |  |
| 583 | 238 | Release 8 Features |  | 914.3d? | 2006-09-19 A | 2010-03-19 | 99% | 9.14d? | 2006-09-19 | 2010-03-19 | 914.3d? | 615.8d | start no earlier than 2000-01-03 | CP,GP,RP,SP | 7314.4h | 7241.26h |  |  |  | Rel-8 |  |  |  |  |  |  |

Notes:
- 553: SP#41 closed (no tangible result of this work; no CR against TR 22.983). Triggered by Study UID_370086 (FSServAl)
- 554: SP#41 closed (no tangible result of this work; no CR against TR 22.983) / Text3: 22.983
- 555: SP#43 stopped. LS_out to TISPAN informs about stopping this activity / Text3: 23.822, 23.203
- 556: RP#39: No agreed WID / Text3: 36.306, 36.331, 36.413, 36.300, 36.214, 36.133, 36.304
- 557: RP#39: No agreed WID / Text3: 25.306, 25.331, 25.413
- 558: CP#47 work stopped/abandoned / Text3: 31.xyz
- 559: SP#39 created to host Rel-9 Wis. BUT no agreed WID
- 560: SP#39 SAE functionality moved to Rel-9. WID returned to SA2 for re-consideration & remove MBMS for EPS from Rel 8
- 561: SP#39 SAE functionality moved to Rel-9. BUT no agreed WID
- 562: SP#39 SAE functionality moved to Rel-9. BUT no agreed WID
- 563: SP#39 SAE functionality moved to Rel-9. BUT no agreed WID
- 564: SP#47 stopped. WI + new topics moved to Rel-10 / Text3: 33.106, 33.107, 33.108
- 565: -
- 566: SP#42 completed. Spin-off Feature UID_420020 (SSAC) / Text3: 22.986
- 567: SP#43 completed. Linked to Combinational Services UID_31064, Services Alignment and Migration (ServAl) UID_330017 and 3GPP System Architecture Evolution (SAES) UID_3208 / Text3: 23.879
- 568: SP#42 completed / Text3: 23.868
- 569: SP#43 completed / Text3: 23.826
- 570: SP#46 completed. Triggered by the SA1 Rel-8 Study on Facilitating Machine to Machine Communication in GSM and UMTS (FS_M2M) UID_7027 in TR 22.868. / Text3: 33.812
- 571: SP#45 completed / Text3: 32.822
- 572: SP#44 completed. Linked to SA5 TR 32.816 Study of Management for LTE and SAE (UID_340036) / Text3: 32.821
- 573: SP#45 completed. Linked to SA5 TR 32.816 Study of Management for LTE and SAE (UID_340036) / Text3: 32.823
- 574: SP#44 completed. Spin-off implementation WI UID_440064 Service Oriented Architecture (SOA) for IRP / Text3: 32.824
- 575: RP#46 completed / Text3: 25.907
- 576: RP#47 completed / Text3: 36.913 , new 36.814, 36.912, R2 36.806 (Relay architectures for E-UTRA), R4 36.815 (LTE-Advanced feasibility studies in RAN4)
- 577: RP#46 completed / Text3: 25.866
- 578: RP#44 closed (RP-090452 R1 LS to RAN on Conclusions for LTE Mobility Study Item - no further Rel-9 action / no TR needed) / Text3: none
- 579: RP#46 completed / Text3: 36.805
- 580: RP#44 completed. Linked to UID_420008 LTE FDD Home eNodeB RF Requirements. Spin-off RAN3 UID_440015 Study on Enhanced Interference Management Mechanisms for HNBs / Text3: 25.967
- 581: RP#45 completed. Triggered by RAN4 UID_430027 Study on Enhanced Interference Management for HNBs / Text3: 25.967
- 582: SP#45 work stopped/abandoned / Text3: 33.9xx
- 583: -

| ID | WBS | Task | Duration | Start | Finish | Complete | Remaining | Baseline start | Baseline finish | Baseline duration | Total slack | Constraint | Resources | Work | Actual work | Text1 | Text4 | Text5 | Text6 | Text8 | Text7 | Text2 |
| --- | --- | --- | --- | --- | --- | --- | --- | --- | --- | --- | --- | --- | --- | --- | --- | --- | --- | --- | --- | --- | --- | --- |
| 584 | 239 | **3GPP System Architecture Evolution Specification - Evolved Packet System (non RAN aspects)** | 1354d? | 2006-04-12 A | 2011-06-17 | 99% | 11.15d? | 2006-04-12 | 2011-06-17 | 1354d? | 290.8d |  | SP,CP | 268388h | 262800h | SAES | T-Mobile | michael.kurz@t-mobile.at | Rel-8 | Alain |  |  |
| 585 | 239.1 | Requirements for evolution of the 3GPP system architecture | 395d? | 2006-06-08 A | 2007-12-12 A | 100% |  | 2006-06-08 | 2007-12-12 | 395d? |  | finish no earlier than 2007-11-30 | S1 | 3160h | 3160h | AIPN-SAE | T-Mobile | michael.kurz@t-mobile.at | Rel-8 | Alain |  |  |
| 586 | 239.2 | **High level and common (for all accesses) functions** | 629d? | 2007-01-02 A | 2009-05-29 A | 100% |  | 2007-01-02 | 2009-05-29 | 629d? |  |  | SP,CP | 42536h | 42536h | EPS-ComF | Nokia Siemens Networks | balazs.bertenyi@nsn.com | Rel-8 | Maurice | SP-37 |  |
| 587 | 239.2.1 | Stage 2 for High level functions | 370d? | 2007-01-02 A | 2008-06-02 A | 100% |  | 2007-01-02 | 2008-06-02 | 370d? |  | finish no earlier than 2008-06-02 | S2 | 2960h | 2960h | SAES-SA-HLF | Motorola | Irfan.Ali@motorola.com | Rel-8 | Maurice |  |  |
| 588 | 239.2.2 | Stage 2 Security Architecture | 197d? | 2008-03-12 A | 2008-12-11 A | 100% |  | 2008-03-12 | 2008-12-11 | 197d? |  | finish no earlier than 2008-12-11 | S3 | 1576h | 1576h | SAES | Nokia Siemens Networks | marc.blommaert.ext@nsn.com | Rel-8 | Dionisio | SP-39 | PCG-21 |
| 589 | 239.2.3 | Stage 3 (CT1) for SAE impact on services, network functions and capabilities | 545d? | 2007-02-05 A | 2009-03-06 A | 100% |  | 2007-02-05 | 2009-03-06 | 545d? |  | finish no earlier than 2009-03-06 | C1 | 4360h | 4360h | SAES | Nokia Siemens Networks | robert.zaus@nsn.com | Rel-8 | Frederic |  |  |
| 590 | 239.2.4 | Stage 3 SAE impact on existing capabilities | 480d? | 2007-02-05 A | 2008-12-05 A | 100% |  | 2007-02-05 | 2008-12-05 | 480d? |  | finish no earlier than 2008-12-12 | C3 | 3840h | 3840h | SAES | Huawei | Wei Weihua (weiwh@huawei.com) | Rel-8 | Gwiho |  |  |
| 591 | 239.2.5 | Stage 3 (CT4) of SAE impact on existing capabilities | 545d? | 2007-02-05 A | 2009-03-06 A | 100% |  | 2007-02-05 | 2009-03-06 | 545d? |  | finish no earlier than 2009-03-06 | C4 | 4360h | 4360h | SAES | Huawei | shahab.lavasani@huawei.com | Rel-8 | Kimmo |  |  |
| 592 | 239.2.6 | Stage 2/3 for Network selection procedures | 480d? | 2007-02-05 A | 2008-12-05 A | 100% |  | 2007-02-05 | 2008-12-05 | 480d? |  | finish no earlier than 2009-03-06 | C1 | 3840h | 3840h | SAES | Nokia Siemens Networks | robert.zaus@nsn.com | Rel-8 | Frederic |  |  |
| 593 | 239.2.7 | Stage 3 EPC interworking with external PDNs (SGi) | 605d? | 2007-02-05 A | 2009-05-29 A | 100% |  | 2007-02-05 | 2009-05-29 | 605d? |  | finish no earlier than 2009-05-29 | C3 | 4840h | 4840h | SAES-St3-intwk | Huawei | Wei Weihua (weiwh@huawei.com) | Rel-8 | Gwiho |  |  |
| 594 | 239.2.8 | Stage 3 PCC within SAE | 605d? | 2007-02-05 A | 2009-05-29 A | 100% |  | 2007-02-05 | 2009-05-29 | 605d? |  | finish no earlier than 2009-05-29 | C3 | 4840h | 4840h | SAES-St3-PCC | Ericsson | j.javier.pastor@ericsson.com | Rel-8 | Gwiho |  |  |
| 595 | 239.2.9 | Stage 3 for SAE / LTE identities | 545d? | 2007-02-05 A | 2009-03-06 A | 100% |  | 2007-02-05 | 2009-03-06 | 545d? |  | finish no earlier than 2009-03-06 | C4 | 4360h | 4360h | SAES | Huawei | shahab.lavasani@huawei.com | Rel-8 | Kimmo |  |  |
| 596 | 239.2.10 | Unified guidelines for Diameter usage within 3GPP | 316d? | 2007-09-21 A | 2008-12-05 A | 100% |  | 2007-09-21 | 2008-12-05 | 316d? |  | finish no earlier than 2008-12-05 | C3 | 2528h | 2528h | SAES-DIAM | Huawei | Javier Gonzalez Gallego | Rel-8 | Gwiho | CP-37 |  |
| 597 | 239.3 | **SAE for LTE access** | 569d? | 2007-01-02 A | 2009-03-06 A | 100% |  | 2007-01-02 | 2009-03-06 | 569d? |  |  | S2,C1,C3,C4 | 57824h | 57824h | SAES-LTE | Motorola | Irfan.Ali@motorola.com | Rel-8 | Maurice |  |  |
| 598 | 239.3.1 | CT4 Stage 3 for protocol between EPCs | 545d? | 2007-02-05 A | 2009-03-06 A | 100% |  | 2007-02-05 | 2009-03-06 | 545d? |  | finish no earlier than 2009-03-06 | C4 | 4360h | 4360h | SAES | Huawei | shahab.lavasani@huawei.com | Rel-8 | Kimmo |  |  |
| 599 | 7.2.2.1 | **SAES-SA-FP_LTE with GTP variant** | 569d? | 2007-01-02 A | 2009-03-06 A | 100% |  | 2007-01-02 | 2009-03-06 | 569d? |  |  | S2,C4 | 11896h | 11896h | SAES-SA-FP_LTE-GTP | Nokia Siemens Networks | balazs.bertenyi@nsn.com | Rel-8 | Maurice |  |  |
| 600 | 239.3.2.1 | Stage 2 for SAES-SA-FP_LTE with GTP variant | 373d? | 2007-01-02 A | 2008-06-05 A | 100% |  | 2007-01-02 | 2008-06-05 | 373d? |  | finish no earlier than 2008-06-02 | S2 | 2984h | 2984h | SAES-SA-FP_LTE-GTP-St2 | Nokia Siemens Networks | balazs.bertenyi@nsn.com | Rel-8 | Maurice |  |  |
| 601 | 239.3.2.2 | CT4 Stage 3 for GTP v2 protocol | 545d? | 2007-02-05 A | 2009-03-06 A | 100% |  | 2007-02-05 | 2009-03-06 | 545d? |  | finish no earlier than 2009-03-06 | C4 | 4360h | 4360h | SAES | Huawei | shahab.lavasani@huawei.com | Rel-8 | Kimmo |  |  |
| 602 | 7.2.2.2 | **SAES-SA-FP_LTE with PMIP variant** | 569d? | 2007-01-02 A | 2009-03-06 A | 100% |  | 2007-01-02 | 2009-03-06 | 569d? |  |  | S2,C4 | 15736h | 15736h | SAES-SA-FP_LTE-IETF | Nokia Siemens Networks | balazs.bertenyi@nsn.com | Rel-8 | Maurice |  |  |
| 603 | 239.3.3.1 | Stage 2 for SAES-SA-FP_LTE with PMIP variant | 373d? | 2007-01-02 A | 2008-06-05 A | 100% |  | 2007-01-02 | 2008-06-05 | 373d? |  | finish no earlier than 2008-06-02 | S2 | 2984h | 2984h | SAES-SA-FP_LTE-IETF-St2 | Nokia Siemens Networks | balazs.bertenyi@nsn.com | Rel-8 | Maurice |  |  |
| 604 | 239.3.3.2 | CT4 Stage 3 for PMIP protocol within EPC | 545d? | 2007-02-05 A | 2009-03-06 A | 100% |  | 2007-02-05 | 2009-03-06 | 545d? |  | finish no earlier than 2009-03-06 | C4 | 4360h | 4360h | SAES | Huawei | shahab.lavasani@huawei.com | Rel-8 | Kimmo | CP-37 |  |
| 605 | 239.3.3.3 | Mobile IPv4 (MIPv4) based Mobility protocols | 480d? | 2007-02-05 A | 2008-12-05 A | 100% |  | 2007-02-05 | 2008-12-05 | 480d? |  | finish no earlier than 2008-12-05 | C4 | 3840h | 3840h | SAES | Motorola | Lewis Milton | Rel-8 | Kimmo | CP-41 |  |
| 606 | 239.3.4 | Stage 3 for UE NAS mobility procedures in idle and active mode | 545d? | 2007-02-05 A | 2009-03-06 A | 100% |  | 2007-02-05 | 2009-03-06 | 545d? |  | finish no earlier than 2009-03-06 | C1 | 4360h | 4360h | SAES | Nokia Siemens Networks | robert.zaus@nsn.com | Rel-8 | Frederic |  |  |
| 607 | 239.3.5 | Stage 3 for Session management, bearer control and QoS aspects | 545d? | 2007-02-05 A | 2009-03-06 A | 100% |  | 2007-02-05 | 2009-03-06 | 545d? |  | finish no earlier than 2009-03-06 | C1 | 4360h | 4360h | SAES | Nokia Siemens Networks | robert.zaus@nsn.com | Rel-8 | Frederic |  |  |
| 608 | 239.3.6 | Stage 3 for security aspects of LTE Access | 545d? | 2007-02-05 A | 2009-03-06 A | 100% |  | 2007-02-05 | 2009-03-06 | 545d? |  | finish no earlier than 2009-03-06 | C1 | 4360h | 4360h | SAES | Nokia Siemens Networks | robert.zaus@nsn.com | Rel-8 | Frederic |  |  |
| 609 | 239.3.7 | Stage 3 for QoS mechanisms | 480d? | 2007-02-05 A | 2008-12-05 A | 100% |  | 2007-02-05 | 2008-12-05 | 480d? |  | finish no earlier than 2008-12-12 | C3 | 3840h | 3840h | SAES | Ericsson | j.javier.pastor@ericsson.com | Rel-8 | Gwiho |  |  |
| 610 | 239.3.8 | Stage 3 for EPC - HSS interface | 545d? | 2007-02-05 A | 2009-03-06 A | 100% |  | 2007-02-05 | 2009-03-06 | 545d? |  | finish no earlier than 2009-03-06 | C4 | 4360h | 4360h | SAES | Huawei | shahab.lavasani@huawei.com | Rel-8 | Kimmo |  |  |

Notes:
- 584: SP#39 WID updated SP-070933=>SP-080132. Role model for SAE/LTE system wide project management by SA2 in SP-060166
- 585: SP#38 completed / Text3: 22.011, 22.246, new 22.278
- 586: CP#44 completed
- 587: SP#40 completed / Text3: new 23.402
- 588: SP#42 completed / Text3: 33.210, 33.310, new 33.401
- 589: CP#43 completed / Text3: 24.229, 27.007, new 24.305
- 590: CP#42 completed / Text3: 29.061
- 591: CP#43 completed / Text3: new (29.274, 29.275)
- 592: CP#42 completed / Text3: 23.122, new 24.302
- 593: CP#44 completed / Text3: 29.061
- 594: CP#44 completed / Text3: 29.212, 29.213, 29.214, new 29.215
- 595: CP#43 completed / Text3: 23.003
- 596: CP#42 completed / Text3: new 29.909
- 597: CP#43 completed
- 598: CP#43 completed / Text3: 29.274, 29.275
- 599: CP#43 completed
- 600: SP#40 completed / Text3: 23.401, 23.060, 23.002, 23.246, 23.203, 23.107, 23.234, 23.271
- 601: CP#43 completed / Text3: 29.274
- 602: CP#43 completed
- 603: SP#40 completed
- 604: CP#43 completed / Text3: 29.275, 29.282
- 605: CP#42 completed / Text3: 29.279
- 606: CP#43 completed / Text3: 24.007, 24.301
- 607: CP#43 completed / Text3: 24.007, 24.301
- 608: CP#43 completed / Text3: 24.008, 24.301
- 609: CP#42 completed / Text3: 29.213
- 610: CP#43 completed / Text3: 29.272

| ID | WBS | Task | Type | Duration | Start | Finish | Complete | Baseline start | Baseline finish | Baseline duration | Constraint | Resources | Work | Actual work | Text1 | Text4 | Text5 | Text6 | Text8 | Text3 | Text7 | Text2 | Text12 |
| --- | --- | --- | --- | --- | --- | --- | --- | --- | --- | --- | --- | --- | --- | --- | --- | --- | --- | --- | --- | --- | --- | --- | --- |
| 611 | 239.4 | **SAE for Interoperation between LTE and legacy cellular PS accesses** |  | 545d? | 2007-02-05 A | 2009-03-06 A | 100% | 2007-02-05 | 2009-03-06 | 545d? |  | S2,C1,C4 | 40152h | 40152h | SAES-SA-FP_3GPP | Motorola | Irfan.Ali@motorola.com | Rel-8 | Maurice |  |  |  |  |
| 612 | 239.4.1 | Stage 2 for Interoperation between LTE and 2G/3G |  | 424d? | 2007-02-05 A | 2008-09-18 A | 100% | 2007-02-05 | 2008-09-18 | 424d? | finish no earlier than 2008-09-11 | S2 | 3392h | 3392h | EPSto2_3G | Motorola | Irfan.Ali@motorola.com | Rel-8 | Maurice | 23.401, 23.402 | SP-37 |  |  |
| 613 | 239.4.2 | Stage 3 for Inter-system mobility between E-UTRAN and 2G/3G |  | 545d? | 2007-02-05 A | 2009-03-06 A | 100% | 2007-02-05 | 2009-03-06 | 545d? | finish no earlier than 2009-03-06 | C1 | 4360h | 4360h | SAES | Nokia Siemens Networks | robert.zaus@nsn.com | Rel-8 | Frederic | 24.008, 24.301 | CP-38 | PCG-21 |  |
| 614 | 239.4.3 | Stage 2 GPRS enhancements for LTE access |  | 272d? | 2007-09-04 A | 2008-09-18 A | 100% | 2007-09-04 | 2008-09-18 | 272d? | start no earlier than 2007-09-04 | S2 | 2176h | 2176h | SAES-GPRS_LTE | Vodafone | chris.pudney@vodafone.com | Rel-8 | Maurice | 23.401 |  |  |  |
| 615 | 239.4.4 | Stage 2 GPRS for EPC (23.060, etc.) |  | 179d? | 2008-01-14 A | 2008-09-18 A | 100% | 2008-01-14 | 2008-09-18 | 179d? | finish no earlier than 2008-09-18 | S2 | 1432h | 1432h | SAES | Nokia Siemens Networks | balazs.bertenyi@nsn.com | Rel-8 | Maurice | 23.060 | SP-39 | PCG-21 |  |
| 616 | 239.4.5 | Stage 3 for EPC - GPRS |  | 545d? | 2007-02-05 A | 2009-03-06 A | 100% | 2007-02-05 | 2009-03-06 | 545d? | finish no earlier than 2009-03-06 | C4 | 4360h | 4360h | SAES | Huawei | shahab.lavasani@huawei.com | Rel-8 | Kimmo | 29.274, 29.275, 29.281 |  |  |  |
| 617 | 239.4.6 | Stage 3 for EPC to UTRAN |  | 545d? | 2007-02-05 A | 2009-03-06 A | 100% | 2007-02-05 | 2009-03-06 | 545d? | finish no earlier than 2009-03-06 | C4 | 4360h | 4360h | SAES | Huawei | shahab.lavasani@huawei.com | Rel-8 | Kimmo | 29.274, 29.275, 29.281 | CP-38 | PCG-21 |  |
| 618 | 239.4.7 | Stage 3 for EPC to 3GPP2 |  | 545d? | 2007-02-05 A | 2009-03-06 A | 100% | 2007-02-05 | 2009-03-06 | 545d? | finish no earlier than 2009-03-06 | C4 | 4360h | 4360h | SAES | Huawei | shahab.lavasani@huawei.com | Rel-8 | Kimmo | 29.277, 29.276 | CP-38 | PCG-21 |  |
| 619 | 239.4.8 | Stage 2 for Interoperation between LTE and CDMA2000 |  | 329d? | 2007-06-18 A | 2008-09-18 A | 100% | 2007-06-18 | 2008-09-18 | 329d? | finish no earlier than 2008-04-25 | S2 | 2632h | 2632h | EPStoC2k | Motorola, Vodafone | Irfan.Ali@motorola.com, chris.pudney@vodafone.com | Rel-8 | Maurice | 23.401, 23.402 | CP-37 |  |  |
| 620 | 239.4.9 | Stage 3 for Inter-system mobility between E-UTRAN and CDMA2000 |  | 545d? | 2007-02-05 A | 2009-03-06 A | 100% | 2007-02-05 | 2009-03-06 | 545d? | finish no earlier than 2009-03-06 | C1 | 4360h | 4360h | SAES | Nokia Siemens Networks | robert.zaus@nsn.com | Rel-8 | Frederic | 24.301, 24.302 |  |  |  |
| 621 | 239.4.10 | Stage 3 for MME - SGSN signalling free protocol |  | 545d? | 2007-02-05 A | 2009-03-06 A | 100% | 2007-02-05 | 2009-03-06 | 545d? | finish no earlier than 2009-03-06 | C4 | 4360h | 4360h | SAES | Huawei | shahab.lavasani@huawei.com | Rel-8 | Kimmo | 29.272, 29.274 |  |  |  |
| 622 | 239.5 | **SAE for support for non-3GPP accesses** |  | 569d? | 2007-01-02 A | 2009-03-06 A | 100% | 2007-01-02 | 2009-03-06 | 569d? |  | S2,S3,C1,C4 | 53872h | 53872h | SAES-SA-FP_n3GPP | Motorola | Irfan.Ali@motorola.com | Rel-8 | Maurice |  |  |  |  |
| 623 | 7.2.4.1 | Stage 2 for Host-based Mobility aspects |  | 373d? | 2007-01-02 A | 2008-06-05 A | 100% | 2007-01-02 | 2008-06-05 | 373d? | finish no earlier than 2008-04-11 | S2 | 2984h | 2984h | SAES-SA-FP_n3GPP-HBMob | Motorola | Irfan.Ali@motorola.com | Rel-8 | Maurice | 23.402 |  |  |  |
| 624 | 7.2.4.2 | Stage 2 for Network-based Mobility aspects |  | 448d? | 2007-01-02 A | 2008-09-18 A | 100% | 2007-01-02 | 2008-09-18 | 448d? | finish no earlier than 2008-09-18 | S2 | 3584h | 3584h | SAES-SA-FP_n3GPP-NBMob | Motorola | Irfan.Ali@motorola.com | Rel-8 | Maurice | 23.402 |  |  |  |
| 625 | 239.5.3 | Stage 3 for Mobility management based on DSMIPv6 |  | 480d? | 2007-02-05 A | 2008-12-05 A | 100% | 2007-02-05 | 2008-12-05 | 480d? | finish no earlier than 2008-12-05 | C1 | 3840h | 3840h | SAES | Nokia Siemens Networks | robert.zaus@nsn.com | Rel-8 | Frederic | 24.303 |  |  |  |
| 626 | 239.5.4 | Stage 3 for Mobility management based on MIP v4 |  | 480d? | 2007-02-05 A | 2008-12-05 A | 100% | 2007-02-05 | 2008-12-05 | 480d? | start no earlier than 2007-02-05 | C1 | 3840h | 3840h | SAES | Nokia Siemens Networks | robert.zaus@nsn.com | Rel-8 | Frederic | 24.304 | CP-39 | PCG-21 |  |
| 627 | 239.5.5 | Stage 3 for Inter-system mobility between E-UTRAN and non 3GPP accesses |  | 545d? | 2007-02-05 A | 2009-03-06 A | 100% | 2007-02-05 | 2009-03-06 | 545d? | finish no earlier than 2009-03-06 | C1 | 4360h | 4360h | SAES | Nokia Siemens Networks | robert.zaus@nsn.com | Rel-8 | Frederic | 24.008, 24.301 | CP-38 | PCG-21 |  |
| 628 | 239.5.6 | Stage 2 for Optimized Dual-Radio Handover with WiMAX |  | 249d? | 2007-06-25 A | 2008-06-05 A | 100% | 2007-06-25 | 2008-06-05 | 249d? | finish no earlier than 2008-06-09 | S2 | 1992h | 1992h | SAES-SA-FP_n3GPP-OptWIMAX | Motorola | Irfan.Ali@motorola.com | Rel-8 | Maurice | 23.402 |  |  |  |
| 629 | 239.5.7 | Stage 2 Security aspects for non-3GPP Access |  | 197d? | 2008-03-12 A | 2008-12-11 A | 100% | 2008-03-12 | 2008-12-11 | 197d? | finish no earlier than 2008-12-11 | S3 | 1576h | 1576h | SAES | Nokia Siemens Networks | marc.blommaert.ext@nsn.com | Rel-8 | Dionisio | 33.402, 33.210, 33.310 | SP-39 | PCG-21 |  |
| 630 | 239.5.8 | Stage 3 security aspects for DSMIPv6 Access |  | 480d? | 2007-02-05 A | 2008-12-05 A | 100% | 2007-02-05 | 2008-12-05 | 480d? | finish no earlier than 2008-12-05 | C1 | 3840h | 3840h | SAES | Nokia Siemens Networks | robert.zaus@nsn.com | Rel-8 | Frederic | 24.303 | CP-37 |  |  |
| 631 | 239.5.9 | Stage 3 security aspects for MIPv4 Access |  | 480d? | 2007-02-05 A | 2008-12-05 A | 100% | 2007-02-05 | 2008-12-05 | 480d? | finish no earlier than 2008-12-05 | C1 | 3840h | 3840h | SAES | Nokia Siemens Networks | robert.zaus@nsn.com | Rel-8 | Frederic | 24.304 | CP-39 | PCG-21 |  |
| 632 | 239.5.10 | Stage 3 for Access to the EPC via non-3GPP access networks |  | 545d? | 2007-02-05 A | 2009-03-06 A | 100% | 2007-02-05 | 2009-03-06 | 545d? | finish no earlier than 2009-03-06 | C1 | 4360h | 4360h | SAES | Nokia Siemens Networks | robert.zaus@nsn.com | Rel-8 | Frederic | 24.302, 24.312 |  |  |  |
| 633 | 239.5.11 | Stage 3 for interfaces within EPC |  | 383d? | 2007-09-19 A | 2009-03-06 A | 100% | 2007-09-19 | 2009-03-06 | 383d? | finish no earlier than 2009-03-06 | C4 | 3064h | 3064h | SAES | Huawei | shahab.lavasani@huawei.com | Rel-8 | Kimmo | 29.274, 29.281 | CP-37 |  |  |
| 634 | 239.5.12 | Stage 3 for Interfaces EPC - non-3GPP IP access |  | 545d? | 2007-02-05 A | 2009-03-06 A | 100% | 2007-02-05 | 2009-03-06 | 545d? | finish no earlier than 2009-03-06 | C4 | 4360h | 4360h | SAES | Huawei | shahab.lavasani@huawei.com | Rel-8 | Kimmo | 29.273, 29.275 |  |  |  |
| 635 | 239.5.13 | Stage 3 for AAA/HSS related |  | 480d? | 2007-02-05 A | 2008-12-05 A | 100% | 2007-02-05 | 2008-12-05 | 480d? | finish no earlier than 2008-12-05 | C4 | 3840h | 3840h | SAES | Huawei | shahab.lavasani@huawei.com | Rel-8 | Kimmo | 29.273 |  |  |  |
| 636 | 239.5.14 | Stage 3 for EPC - AAA interface |  | 480d? | 2007-02-05 A | 2008-12-05 A | 100% | 2007-02-05 | 2008-12-05 | 480d? | finish no earlier than 2008-12-05 | C4 | 3840h | 3840h | SAES | Huawei | shahab.lavasani@huawei.com | Rel-8 | Kimmo | 29.273 |  |  |  |
| 637 | 239.5.15 | Deleted (already covered) SAES-SA-FP_n3GPP Optimized Handover with CDMA | milestone | 0d? | 2007-06-25 A | 2007-06-25 A | 100% | 2007-06-25 | 2007-06-25 | 0d? | finish no earlier than 2007-06-25 | S2 |  |  | SAES-SA-FP_n3GPP-OptCDMA | Nokia Siemens Networks |  | Rel-8 | Maurice |  |  |  | SP-37 |

Notes:
- 611: CP#43 completed
- 612: SP#41 completed
- 613: CP#43 completed
- 614: SP#41 completed
- 615: SP#41 completed
- 616: CP#43 completed
- 617: CP#43 completed
- 618: CP#43 completed
- 619: SP#41 completed (except: Handover of multiple PDNs=>Rel-9)
- 620: CP#43 completed
- 621: CP#43 completed
- 622: CP#43 completed. SP#39 retained in Rel-8 (in addition to the essential functionality defined in SP-070699). Replaces UID_340037
- 623: SP#40 completed
- 624: SP#41 completed
- 625: CP#42 completed
- 626: CP#42 completed
- 627: CP#43 completed
- 628: SP#40 completed
- 629: SP#42 completed
- 630: CP#42 completed
- 631: CP#42 completed
- 632: CP#43 completed
- 633: CP#43 completed
- 634: CP#43 completed
- 635: CP#42 completed
- 636: CP#42 completed
- 637: SP#37 stopped

| ID | WBS | Task | Type | Duration | Start | Finish | Complete | Remaining | Baseline start | Baseline finish | Baseline duration | Total slack | Constraint | Resources | Work | Actual work | Text1 | Text4 | Text6 | Text8 | Text2 | Text7 | Text9 | Text12 | Text11 |
| --- | --- | --- | --- | --- | --- | --- | --- | --- | --- | --- | --- | --- | --- | --- | --- | --- | --- | --- | --- | --- | --- | --- | --- | --- | --- |
| 638 | 239.6 | **Single Radio Voice Call Continuity for 3GPP (SRVCC)** |  | 569d? | 2007-01-02 A | 2009-03-06 A | 100% |  | 2007-01-02 | 2009-03-06 | 569d? |  |  | S2,C1,C4 | 10752h | 10752h | SAES-SRVCC | Nokia Siemens Networks | Rel-8 | Maurice |  |  |  |  |  |
| 639 | 239.6.1 | Stage 2 for 2G/3G SRVCC |  | 448d? | 2007-01-02 A | 2008-09-18 A | 100% |  | 2007-01-02 | 2008-09-18 | 448d? |  | finish no earlier than 2008-09-15 | S2 | 3584h | 3584h | SAES-SRVCC | Nokia Siemens Networks | Rel-8 | Maurice |  |  |  |  |  |
| 640 | 239.6.2 | Stage 3 for SRVCC in EPS |  | 201d? | 2008-05-30 A | 2009-03-06 A | 100% |  | 2008-05-30 | 2009-03-06 | 201d? |  | finish no earlier than 2009-03-06 | C1 | 1608h | 1608h | SAES-SRVCC | Nokia Siemens Networks | Rel-8 | Frederic | PCG-21 | CP-41 |  |  |  |
| 641 | 239.6.3 | MME to MSC interface for SRVCC |  | 126d? | 2008-09-12 A | 2009-03-06 A | 100% |  | 2008-09-12 | 2009-03-06 | 126d? |  | finish no earlier than 2009-03-06 | C4 | 1008h | 1008h | SAES-SRVCC | Nokia Siemens Networks | Rel-8 | Kimmo | PCG-21 | CP-41 |  |  |  |
| 642 | 239.7 | Voice Call Continuity for CDMA2000 1X |  | 249d? | 2007-06-25 A | 2008-06-05 A | 100% |  | 2007-06-25 | 2008-06-05 | 249d? |  | finish no earlier than 2008-06-13 | S2 | 1992h | 1992h | SAES-VCC_1X | Nokia Siemens Networks | Rel-8 | Maurice |  |  |  |  |  |
| 643 | 239.8 | SAE impacts on IMS |  | 373d? | 2007-01-02 A | 2008-06-05 A | 100% |  | 2007-01-02 | 2008-06-05 | 373d? |  | finish no earlier than 2008-06-13 | S2 | 2984h | 2984h | SAES-SA_IMS | Nokia Siemens Networks | Rel-8 | Maurice |  |  |  |  |  |
| 644 | 239.9 | **CS Fallback in EPS** |  | 258d? | 2008-03-12 A | 2009-03-06 A | 100% |  | 2008-03-12 | 2009-03-06 | 258d? |  |  | S2,C1,C4 | 4800h | 4800h | SAES-CSFB | T-Mobile, Vodafone | Rel-8 | Maurice | PCG-21 | SP-39 |  |  |  |
| 645 | 239.9.1 | Stage 2 for CS Fallback in EPS |  | 62d? | 2008-03-12 A | 2008-06-05 A | 100% |  | 2008-03-12 | 2008-06-05 | 62d? |  | finish no earlier than 2008-12-05 | S2 | 496h | 496h | SAES-CSFB | T-Mobile, Vodafone | Rel-8 | Maurice | PCG-21 | SP-40 |  |  |  |
| 646 | 239.9.2 | Stage 3 for CS Fallback in EPS |  | 201d? | 2008-05-30 A | 2009-03-06 A | 100% |  | 2008-05-30 | 2009-03-06 | 201d? |  | finish no earlier than 2009-03-06 | C1 | 1608h | 1608h | SAES-CSFB | NEC | Rel-8 | Frederic | PCG-21 | CP-40 |  |  |  |
| 647 | 239.9.3 | Stage 3 for CS Fallback in EPS |  | 136d? | 2008-05-30 A | 2008-12-05 A | 100% |  | 2008-05-30 | 2008-12-05 | 136d? |  | finish no earlier than 2008-12-05 | C4 | 1088h | 1088h | SAES-CSFB | NEC | Rel-8 | Kimmo | PCG-21 | CP-40 |  |  |  |
| 648 | 239.10 | System enhancements for the use of IMS services in local breakout |  | 62d? | 2008-03-12 A | 2008-06-05 A | 100% |  | 2008-03-12 | 2008-06-05 | 62d? |  | finish no earlier than 2008-06-05 | S2 | 496h | 496h | SAES-IMS_LBO | Telecom Italia | Rel-8 | Maurice | PCG-21 | SP-39 |  |  |  |
| 649 | 239.11 | **EPC Data Definitions** |  | 309d? | 2008-01-07 A | 2009-03-12 A | 100% |  | 2008-01-07 | 2009-03-12 | 309d? |  |  | S5 | 7144h | 7144h | EPC-OAM |  | Rel-8 | Dionisio | PCG-21 | SP-39 |  |  |  |
| 650 | 239.11.1 | EPC Network Resource Model (NRM) Integration Reference Point (IRP) |  | 309d? | 2008-01-07 A | 2009-03-12 A | 100% |  | 2008-01-07 | 2009-03-12 | 309d? |  | finish no earlier than 2009-03-12 | S5 | 2472h | 2472h | EPC-OAM | Huawei | Rel-8 | Dionisio | PCG-21 | SP-38 |  |  |  |
| 651 | 239.11.2 | Performance measurements for EPC |  | 275d? | 2008-02-22 A | 2009-03-12 A | 100% |  | 2008-02-22 | 2009-03-12 | 275d? |  | finish no earlier than 2009-03-12 | S5 | 2200h | 2200h | EPC-OAM | China Mobile | Rel-8 | Dionisio | PCG-21 | SP-39 |  |  |  |
| 652 | 239.12 | EPC Charging |  | 309d? | 2008-01-07 A | 2009-03-12 A | 100% |  | 2008-01-07 | 2009-03-12 | 309d? |  | finish no earlier than 2009-03-12 | S5 | 2472h | 2472h | EPC-CH | Nokia Siemens Networks | Rel-8 | Dionisio | PCG-21 | SP-38 |  |  |  |
| 653 | 239.13 | Domain Name System Procedures for Evolved Packet System (DEPS) |  | 179.75d? | 2008-05-30 A | 2009-03-06 A | 100% |  | 2008-05-30 | 2009-03-06 | 179.75d? |  | finish no earlier than 2009-03-06 | C4 | 1438h | 1438h | SAES-DEPS | TeliaSonera | Rel-8 | Kimmo | PCG-21 | CP-40 |  |  |  |
| 654 | 239.14 | InterWorking Function (IWF) between MAP based and Diameter based interfaces |  | 126d? | 2008-09-12 A | 2009-03-06 A | 100% |  | 2008-09-12 | 2009-03-06 | 126d? |  | finish no earlier than 2009-03-06 | C4 | 1008h | 1008h | SAES-MAP2Diam | Huawei | Rel-8 | Kimmo | PCG-21 | CP-41 |  |  |  |
| 655 | 239.15 | **CT6 aspects of SAE** |  | 857d? | 2008-03-07 A | 2011-06-17 | 79% | 182.66d? | 2008-03-07 | 2011-06-17 | 857d? | 290.8d |  | C6 | 13640h | 10732.8h | SAES | Nokia | Rel-8 | Xavier | PCG-21 | SP-39 |  |  |  |
| 656 | 239.15.1 | CT6 aspects of SAE |  | 321d? | 2008-03-07 A | 2009-05-29 A | 100% |  | 2008-03-07 | 2009-05-29 | 321d? |  | finish no earlier than 2009-05-29 | C6 | 2568h | 2568h | SAES | Nokia | Rel-8 | Xavier | PCG-21 | CP-39 |  |  |  |
| 657 | 239.15.2 | Test interworking of LTE Terminals with the USIM |  | 526d? | 2008-12-05 A | 2010-12-10 | 95% | 26.3d? | 2008-12-05 | 2010-12-10 | 526d? | 425.8d | finish no earlier than 2010-12-10 | C6 | 4208h | 3997.6h | SAES-USIM_LTE-Test | Comprion | Rel-8 | Xavier | PCG-22 | CP-42 |  |  |  |
| 658 | 239.15.3 | Test interworking of IP Multimedia Services Identity Module (ISIM) terminals with IP Multimedia Subsystem (IMS) |  | 196d? | 2010-09-17 | 2011-06-17 |  |  | 2010-09-17 | 2011-06-17 | 196d? | 290.8d | start no earlier than 2010-09-17 | C6 | 1568h |  | SAES-ISIM_IMS_Test | Comprion | Rel-8 | Xavier | PCG-25 | CP-49 |  |  |  |
| 659 | 239.16 | Issues for CT1 TR 24.801 |  | 420d? | 2007-01-04 A | 2008-12-05 A | 100% |  | 2007-01-04 | 2008-12-05 | 420d? |  | finish no earlier than 2008-12-05 | C1 | 3360h | 3360h | SAES | Nokia Siemens Networks | Rel-8 | Frederic | PCG-21 | CP-39 |  |  |  |
| 660 | 239.17 | Issues for CT3 TR 29.804 |  | 420d? | 2007-02-05 A | 2008-09-12 A | 100% |  | 2007-02-05 | 2008-09-12 | 420d? |  | finish no earlier than 2008-12-12 | C3 | 3360h | 3360h | SAES | Ericsson | Rel-8 | Gwiho | PCG-21 | CP-39 |  |  |  |
| 661 | 239.18 | Deleted - Issues for CT4 TR 29.803 |  | 420d? | 2007-01-04 A | 2008-09-12 A | 100% |  | 2007-01-04 | 2008-09-12 | 420d? |  | finish no earlier than 2008-12-11 | C4 | 3360h | 3360h | SAES | Huawei | Rel-8 | Kimmo | PCG-21 | CP-39 | PCG-21 | CP-41 |  |
| 662 | 239.19 | Deleted (covered by 380068): Functions and procedures for SAE to support LCS | milestone | 0d? | 2008-03-03 A | 2008-03-03 A | 100% |  | 2008-03-03 | 2008-03-03 | 0d? |  | finish no earlier than 2008-03-03 | S2 |  |  | SAES-SA-FP_LCS | Nokia Siemens Networks | Rel-8 | Maurice |  |  |  | SP-37 |  |
| 663 | 239.20 | Deleted (covered by 380064): SAE aspects of Emergency Calls | milestone | 0d? | 2008-03-03 A | 2008-03-03 A | 100% |  | 2008-03-03 | 2008-03-03 | 0d? |  | start no earlier than 2008-03-03 | S2 |  |  | SAES-SA-EmCall | Nokia Siemens Networks | Rel-8 | Maurice |  |  |  | SP-37 |  |
| 664 | 239.21 | Deleted - CT1 aspects of SAES |  | 16.7d? | 2007-09-04 A | 2007-09-27 A | 100% |  | 2007-09-04 | 2007-09-27 | 16.7d? |  | start no earlier than 2007-09-04 | CP,C1 | 133.62h | 133.62h | SAES-St3 |  | Rel-8 | Frederic |  |  |  | SP-37 |  |
| 665 | 239.22 | Deleted - CT1 aspects of SAES | milestone | 0d? | 2007-09-04 A | 2007-09-04 A | 100% |  | 2007-09-04 | 2007-09-04 | 0d? |  | start no earlier than 2007-09-04 | C1 |  |  | SAES-St3 |  | Rel-8 | Frederic |  |  |  | SP-37 |  |
| 666 | 239.23 | Deleted - Interoperability | milestone | 0d? | 2008-03-14 A | 2008-03-14 A | 100% |  | 2008-03-14 | 2008-03-14 | 0d? |  | start no earlier than 2008-03-14 | C1 |  |  | SAES-St3-interop |  | Rel-8 | Frederic |  |  |  | SP-37 |  |
| 667 | 239.24 | Deleted - CT3 aspects of SAES | milestone | 0d? | 2007-09-04 A | 2007-09-04 A | 100% |  | 2007-09-04 | 2007-09-04 | 0d? |  | start no earlier than 2007-09-04 | C3 |  |  | SAES-St3 |  | Rel-8 | Gwiho |  |  |  | SP-37 |  |
| 668 | 239.25 | Deleted - CT4 aspects of SAES | milestone | 0d? | 2007-09-04 A | 2007-09-04 A | 100% |  | 2007-09-04 | 2007-09-04 | 0d? |  | start no earlier than 2007-09-04 | C4 |  |  | SAES-St3 |  | Rel-8 | Kimmo |  |  |  | SP-37 |  |
| 669 | 239.26 | Deleted - UE to EPC NAS signalling (incl. MBMS and QoS aspects) | milestone | 0d? | 2008-03-14 A | 2008-03-14 A | 100% |  | 2008-03-14 | 2008-03-14 | 0d? |  | start no earlier than 2008-03-14 | C1 |  |  | SAES-St3-sig |  | Rel-8 | Frederic |  |  |  | SP-37 |  |
| 670 | 239.27 | Deleted - User and Control plane protocols | milestone | 0d? | 2007-09-21 A | 2007-09-21 A | 100% |  | 2007-09-21 | 2007-09-21 | 0d? |  | start no earlier than 2007-09-21 | C4 |  |  | SAES-St3-prot |  | Rel-8 | Kimmo |  |  |  | SP-37 |  |
| 671 | 239.28 | Deleted - Architecture enhancements for non-3GPP accesses | milestone | 0d? | 2007-09-04 A | 2007-09-04 A | 100% |  | 2007-09-04 | 2007-09-04 | 0d? |  | start no earlier than 2007-09-04 | S2 |  |  | SAES-non_3GPP | Motorola | Rel-8 | Maurice |  |  |  | SP-34 |  |
| 672 | 239.29 | Deleted - Stage 2 of architecture for the 3GPP System Architecture Evolution | milestone | 0d? | 2007-10-02 A | 2007-10-02 A | 100% |  | 2007-10-02 | 2007-10-02 | 0d? |  | start no earlier than 2007-10-02 | S2 |  |  | SAES-St2 | Vodafone | Rel-8 | Maurice |  |  |  | SP-34 |  |
| 673 | 239.30 | Deleted - SA aspects of System Architecture Evolution |  | 384d? | 2006-04-12 A | 2007-10-01 A | 100% |  | 2006-04-12 | 2007-10-01 | 384d? |  | finish no earlier than 2007-10-02 | S2 | 3072h | 3072h | SAES-SA |  | Rel-8 | Maurice |  |  |  | SP-34 |  |
| 674 | 240 | Conformance Test Aspects – Mobility management based on DSMIPv6 (Dual-Stack Mobile IPv6) |  | 261d? | 2009-09-18 A | 2010-09-17 A | 100% |  | 2009-09-18 | 2010-09-17 | 261d? |  | finish no earlier than 2010-09-17 | R5 | 2088h | 2088h | DSMIPv6_UEConTest | Qualcomm | Rel-8 | Ingbert | PCG-23 | RP-45 |  |  | RP-100738 |

Notes:
- 638: CP#43 completed. SP#38 WID approved (extract from SAE WID SP-070817). / Text5: curt.c.wong@nokia.com
- 639: SP#41 completed. SP#38 WID approved / Text3: new 23.216 / Text5: curt.c.wong@nokia.com
- 640: CP#43 completed / Text3: 23.009, 24.008, new 24.301 / Text5: robert.zaus@nsn.com
- 641: CP#43 completed / Text3: 23.003, 23.008, new (29.274, 29.277, 29.280) / Text5: Giorgi Gulbani
- 642: SP#40 completed / Text5: balazs.bertenyi@nsn.com
- 643: SP#40 completed / Text5: balazs.bertenyi@nsn.com
- 644: CP#43 completed / Text5: sabine.demel@t-mobile.at, chris.pudney@vodafone.com
- 645: SP#40 completed / Text3: new (23.272, 23.401) / Text5: sabine.demel@t-mobile.at, chris.pudney@vodafone.com
- 646: CP#43 completed / Text3: 24.007, 24.008, 24.011, 29.018, new (24.301, 24.801, 29.118) / Text5: yannick.lair@nectech.fr
- 647: CP#42 completed / Text3: 23.007, 23.008, 29.274, new 29.277 / Text5: yannick.lair@nectech.fr
- 648: SP#40 completed / Text3: 23.228, 23.221, 23.203 / Text5: mario.madella@telecomitalia.it
- 649: SP#43 completed
- 650: SP#43 completed / Text3: new (32.751, 32.752, 32.753, 32.755) / Text5: WANG, Xuelong
- 651: SP#43 completed / Text3: new 32.426 / Text5: Li Jian (lijian@chinamobile.com), Liang Shuangchun (liangshuangchun@cmdi.chinamobile.com)
- 652: SP#43 completed / Text3: 32.240, 32.296, 32.251, 32.252, 32.298, 32.299 / Text5: Gerald.Goermer@nsn.com
- 653: CP#43 completed / Text3: 23.003, new 29.303 / Text5: jouni.korhonen@teliasonera.com
- 654: CP#43 completed. Triggered by UID_380023 (FS_MAP2Diam) / Text3: new 29.305 / Text5: liming49985@huawei.com
- 655: CP#44 completed core specification / Text5: Rune Lindholm
- 656: CP#44 completed (specified Network Measurement Results collection via USAT) / Text3: 31.102, 31.111 / Text5: Rune Lindholm
- 657: CP#49 update WID CP-090711=>CP-100598. Steering of Roaming test cases have been introduced. Remaining issues CSG display testing (Provide Local Information, Call Control for EPS/PDN, Event Download (Access Technology Change - Multiple Access Technologies) / Text3: 31.121, 31.124 / Text5: Udo Willenbrink (uwillenbrink@comprion.com )
- 658: Linked to Rel-5 UID_1273 Provisioning of IP-based multimedia services (24.229, 31.103), Rel-8 UID_390021 CT6 aspects of SAE, UID_420018 Test interworking of LTE Terminals with the USIM, Rel-9 UID_450018 Testing SMS over IMS in E-UTRAN (34.229). / Text3: 31.121, 31.124, new TS 31.134 Mobile Equipment (ME) conformance test specification; IP Multimedia Services Identity Module (ISIM) interworking with IP Multimedia Subsystem (IMS) test specification / Text5: Udo Willenbrink (uwillenbrink@comprion.com )
- 659: CP#43 completed / Text3: 24.801 / Text5: robert.zaus@nsn.com
- 660: CP#41 completed / Text3: 29.804 / Text5: j.javier.pastor@ericsson.com
- 661: CP#41 Work stopped and continued in Normative specifications / Text3: 29.803
- 662: SP#37 stopped
- 663: SP#37 stopped
- 664: SP#37 stopped
- 665: SP#37 stopped
- 666: SP#37 stopped
- 667: SP#37 stopped
- 668: SP#37 stopped / Text3: 29.803
- 669: SP#37 stopped
- 670: SP#37 stopped
- 671: SP#34 stopped. Replaced by UID_350027 and its children / Text3: 23.402 / Text5: Irfan.Ali@motorola.com
- 672: SP#34 stopped. Replaced by UIDs 340018 and 340037. (SP#34 report discussion of SP-060917.) / Text3: 23.002, 23.060, 23.107, 23.203, 23.228, 23.234, 23.246, 23.271, 23.279 / Text5: chris.pudney@vodafone.com
- 673: SP#34 stopped
- 674: RP#49 completed. Testing for CT1's UID_360022 (24.303) under Rel-8 Feature SAES / Text3: 36.508, 36.523-1, 36.523-2, 36.523-3 / Text5: Lena Chaponniere (lchaponn@qualcomm.com)

| ID | WBS | Task | Duration | Start | Finish | Complete | Baseline start | Baseline finish | Baseline duration | Constraint | Resources | Work | Actual work | Text1 | Text4 | Text5 | Text6 | Text7 | Text8 | Text2 | Text9 | Text12 |
| --- | --- | --- | --- | --- | --- | --- | --- | --- | --- | --- | --- | --- | --- | --- | --- | --- | --- | --- | --- | --- | --- | --- |
| 675 | 241 | **IMS Centralized Service Control (ICSRA)** | 395d? | 2007-09-03 A | 2009-03-06 A | 100% | 2007-09-03 | 2009-03-06 | 395d? |  | S1,S2,C1,C3,C4 | 10680h | 10680h | ICSRA | AT&T | Randolph Wohlert (rwohlert@tri.sbc.com) | Rel-8 | SP-37 | Alain |  |  |  |
| 676 | 241.1 | Stage 1 for ICSRA | 138d? | 2007-09-03 A | 2008-03-12 A | 100% | 2007-09-03 | 2008-03-12 | 138d? | finish no earlier than 2007-12-14 | S1 | 1104h | 1104h | ICSRA | AT&T | Randolph Wohlert (rwohlert@tri.sbc.com) | Rel-8 | SP-38 | Alain | PCG-21 |  |  |
| 677 | 241.2 | Stage 2 for ICSRA | 125d? | 2007-12-14 A | 2008-06-05 A | 100% | 2007-12-14 | 2008-06-05 | 125d? | start no earlier than 2007-12-14 | S2 | 1000h | 1000h | ICSRA-St2 | Alcatel-Lucent |  | Rel-8 | SP-38 | Maurice | PCG-21 |  |  |
| 678 | 241.3 | **Stage 3 for ICSRA – Protocol, Addressing, Subscriber Data** | 201d? | 2008-05-30 A | 2009-03-06 A | 100% | 2008-05-30 | 2009-03-06 | 201d? |  | C1,C3,C4 | 6520h | 6520h | ICSRA | Ericsson | Sean Schneyer | Rel-8 |  | Frederic |  |  |  |
| 679 | 241.3.1 | CT1 aspects - Stage 3 for ICSRA | 201d? | 2008-05-30 A | 2009-03-06 A | 100% | 2008-05-30 | 2009-03-06 | 201d? | finish no earlier than 2009-03-06 | C1 | 1608h | 1608h | ICSRA | Ericsson | Sean Schneyer | Rel-8 | CP-40 | Frederic | PCG-21 |  |  |
| 680 | 241.3.2 | CT3 aspects - Stage 3 for ICSRA | 201d? | 2008-05-30 A | 2009-03-06 A | 100% | 2008-05-30 | 2009-03-06 | 201d? | finish no earlier than 2009-03-06 | C3 | 1608h | 1608h | ICSRA | Mavenir | Brett Wallis | Rel-8 | CP-40 | Gwiho | PCG-21 |  |  |
| 681 | 241.3.3 | CT4 aspects - Stage 3 for ICSRA | 136d? | 2008-05-30 A | 2008-12-05 A | 100% | 2008-05-30 | 2008-12-05 | 136d? | start no earlier than 2008-05-30 | C4 | 1088h | 1088h | ICSRA | Ericsson | Sean Schneyer | Rel-8 | CP-40 | Kimmo | PCG-21 |  |  |
| 682 | 241.3.4 | Deleted - Stage 3 for ICSRA – I1 interface | 76d? | 2008-05-30 A | 2008-09-12 A | 100% | 2008-05-30 | 2008-09-12 | 76d? | finish no earlier than 2008-09-12 | C1 | 608h | 608h | ICSRA | Huawei | xupeili@huawei.com | Rel-8 | CP-40 | Frederic | PCG-21 | PCG-21 | CP-41 |
| 683 | 242 | **IMS Multimedia Telephony and Supplementary Services** | 487d? | 2007-05-02 A | 2009-03-12 A | 100% | 2007-05-02 | 2009-03-12 | 487d? |  | S1,S5,C1,C3,C4 | 46006.4h | 46006.4h | IMSTSS |  |  | Rel-8 | SP-37 | Alain |  |  |  |
| 684 | 242.1 | **General aspects of IMS Sup Services** | 395d? | 2007-09-03 A | 2009-03-06 A | 100% | 2007-09-03 | 2009-03-06 | 395d? |  | S1,C1,C3,C4 | 9752h | 9752h | IMSSS-Gal | Ericsson | Susana Sabater | Rel-8 | SP-37 | Alain |  |  |  |
| 685 | 242.1.1 | Service and Capability for Core IMS - inclusion of TISPAN requirements | 75d? | 2007-09-03 A | 2007-12-14 A | 100% | 2007-09-03 | 2007-12-14 | 75d? | finish no earlier than 2007-12-14 | S1 | 600h | 600h | TISCAPR8 | Ericsson | Susana Sabater | Rel-8 | SP-37 | Alain |  |  |  |
| 686 | 242.1.2 | Documentation of TISPAN R1 and R2 in CT1 | 208d? | 2007-11-28 A | 2008-09-12 A | 100% | 2007-11-28 | 2008-09-12 | 208d? | finish no earlier than 2008-09-12 | C1 | 1664h | 1664h | REDOC_TIS-C1 | Nokia Siemens Networks | peter.leis@nsn.com | Rel-8 | CP-38 | Frederic | PCG-21 |  |  |
| 687 | 242.1.3 | Documentation of TISPAN R1 and R2 in CT3 | 333d? | 2007-11-28 A | 2009-03-06 A | 100% | 2007-11-28 | 2009-03-06 | 333d? | finish no earlier than 2009-03-06 | C3 | 2664h | 2664h | REDOC_TIS-C3 | Nokia Siemens Networks | peter.leis@nsn.com | Rel-8 | CP-38 | Gwiho | PCG-21 |  |  |
| 688 | 242.1.4 | Documentation of TISPAN R1 and R2 in CT4 | 208d? | 2007-11-28 A | 2008-09-12 A | 100% | 2007-11-28 | 2008-09-12 | 208d? | finish no earlier than 2008-09-12 | C4 | 1664h | 1664h | REDOC_TIS-C4 | Nokia Siemens Networks | peter.leis@nsn.com | Rel-8 | CP-38 | Kimmo | PCG-21 |  |  |
| 689 | 242.2 | **IMS Multimedia Telephony Service** | 394d? | 2007-09-10 A | 2009-03-12 A | 100% | 2007-09-10 | 2009-03-12 | 394d? |  | S1,S5 | 5096h | 5096h | IMS-MMTel |  |  | Rel-8 | SP-37 | Alain |  |  |  |
| 690 | 242.2.1 | Merging TISPAN MMTel [requirements] for Common IMS | 65d? | 2007-09-10 A | 2007-12-07 A | 100% | 2007-09-10 | 2007-12-07 | 65d? | finish no earlier than 2007-12-07 | S1 | 520h | 520h | TMMTEL | Nokia Siemens Networks |  | Rel-8 | SP-37 | Alain |  |  |  |
| 691 | 242.2.2 | Multimedia Telephony Service and Supplementary Services (MMTel) offline Charging | 309d? | 2008-01-07 A | 2009-03-12 A | 100% | 2008-01-07 | 2009-03-12 | 309d? | finish no earlier than 2009-03-12 | S5 | 2472h | 2472h | MMTel-CH | Alcatel-Lucent | GARDELLA, Maryse | Rel-8 | SP-38 | Dionisio | PCG-21 |  |  |
| 692 | 242.3 | **Call Completion on Busy Subscriber (CCBS)/Call Completion on Non-Reachable (CCNR) on IMS** | 483d? | 2007-05-02 A | 2009-03-06 A | 100% | 2007-05-02 | 2009-03-06 | 483d? |  | C1,C3 | 11072h | 11072h | CCBS_CCNR | Deutsche Telekom | martin.huelsemann@telekom.de | Rel-8 | SP-38 | Frederic | PCG-21 |  |  |
| 693 | 242.3.1 | Stage 3 CCBS_CCNR | 483d? | 2007-05-02 A | 2009-03-06 A | 100% | 2007-05-02 | 2009-03-06 | 483d? | finish no earlier than 2009-03-06 | C1 | 3864h | 3864h | CCBS_CCNR | Deutsche Telekom | martin.huelsemann@telekom.de | Rel-8 | CP-38 | Frederic | PCG-21 |  |  |
| 694 | 242.3.2 | Stage 3 CCBS_CCNR | 418d? | 2007-05-02 A | 2008-12-05 A | 100% | 2007-05-02 | 2008-12-05 | 418d? | finish no earlier than 2008-12-05 | C3 | 3344h | 3344h | CCBS_CCNR | Deutsche Telekom | martin.huelsemann@telekom.de | Rel-8 | CP-38 | Gwiho | PCG-21 |  |  |
| 695 | 242.4 | **Flexible Alerting** | 288d? | 2008-01-30 A | 2009-03-06 A | 100% | 2008-01-30 | 2009-03-06 | 288d? |  | S1,C1 | 5278.4h | 5278.4h | FA | Nortel | milanpa@nortel.com | Rel-8 | SP-39 | Alain | PCG-21 |  |  |
| 696 | 242.4.1 | Stage 1 FA | 92d? | 2008-01-30 A | 2008-06-05 A | 100% | 2008-01-30 | 2008-06-05 | 92d? |  | S1 | 670.4h | 670.4h | FA | Telecom Italia |  | Rel-8 | SP-39 | Alain | PCG-21 |  |  |
| 697 | 242.4.2 | Stage 3 FA | 288d? | 2008-01-30 A | 2009-03-06 A | 100% | 2008-01-30 | 2009-03-06 | 288d? | finish no earlier than 2009-03-06 | C1 | 2304h | 2304h | FA | Nortel | milanpa@nortel.com | Rel-8 | CP-39 | Frederic | PCG-21 |  |  |
| 698 | 242.5 | **Communication Wait on IMS** | 331d? | 2007-11-30 A | 2009-03-06 A | 100% | 2007-11-30 | 2009-03-06 | 331d? |  | C1,C3 | 7416h | 7416h | CW_IMS | Deutsche Telekom | martin.huelsemann@telekom.de | Rel-8 | SP-38 | Frederic | PCG-21 |  |  |
| 699 | 242.5.1 | Stage 3 CW-IMS | 331d? | 2007-11-30 A | 2009-03-06 A | 100% | 2007-11-30 | 2009-03-06 | 331d? | finish no earlier than 2009-03-06 | C1 | 2648h | 2648h | CW_IMS | Deutsche Telekom | martin.huelsemann@telekom.de | Rel-8 | CP-38 | Frederic | PCG-21 |  |  |
| 700 | 242.5.2 | Stage 3 CW-IMS | 265d? | 2007-11-30 A | 2008-12-04 A | 100% | 2007-11-30 | 2008-12-04 | 265d? | finish no earlier than 2008-12-05 | C3 | 2120h | 2120h | CW_IMS | Deutsche Telekom | martin.huelsemann@telekom.de | Rel-8 | CP-38 | Gwiho | PCG-21 |  |  |
| 701 | 242.6 | Advice of Charge (AoC) support in IMS Charging | 309d? | 2008-01-07 A | 2009-03-12 A | 100% | 2008-01-07 | 2009-03-12 | 309d? | finish no earlier than 2009-03-12 | S5 | 2472h | 2472h | IMSTSS | Nokia Siemens Networks | Gerald.Goermer@nsn.com | Rel-8 | SP-38 | Dionisio | PCG-21 |  |  |
| 702 | 242.7 | Add Interconnection Border Control Function (IBCF) to IMS Charging | 128d? | 2007-09-17 A | 2008-03-12 A | 100% | 2007-09-17 | 2008-03-12 | 128d? | finish no earlier than 2008-03-12 | S5 | 1024h | 1024h | IMSTSS | Alcatel-Lucent | GARDELLA, Maryse | Rel-8 | SP-37 | Dionisio |  |  |  |

Notes:
- 675: CP#46 completed
- 676: SP#39 completed / Text3: 22.101
- 677: SP#40 completed / Text3: 23.292, 23.206
- 678: CP#46 completed
- 679: CP#46 completed / Text3: 24.229, new (24.292, 24.286)
- 680: CP#43 completed / Text3: new 29.292
- 681: CP#42 completed / Text3: 23.003, 29.232, 23.018, 29.002
- 682: CP#41 work stopped / Text3: 24.293
- 683: SP#43 completed
- 684: CP#43 completed
- 685: SP#39 completed / Text3: 22.228, 22.115, 22.101
- 686: CP#41 completed / Text3: 24.141, 24.147, 24.173, 24.229, 24.247, 24.341, 24.604, 24.605, 24.606, 24.607, 24.608, 24.610, 24.611, 24.616, 24.623, 24.628, 24.629, 24.647, 24.654
- 687: CP#43 completed / Text3: 29.162, 29.163, 29.658
- 688: CP#41 completed / Text3: 29.228, 29.229
- 689: SP#43 completed
- 690: SP#38 completed / Text3: 22.173
- 691: CP#43 completed / Text3: 32.275, 32.298/299
- 692: CP#43 completed
- 693: CP#43 completed / Text3: 24.642, 24.229, 24.173
- 694: CP#42 completed / Text3: 29.163
- 695: CP#43 completed
- 696: SP#40 completed / Text3: 22.173
- 697: CP#43 completed / Text3: 24.239, 24.173
- 698: CP#43 completed
- 699: CP#43 completed / Text3: 24.615, 24.229, 24.173
- 700: CP#42 completed / Text3: 29.163
- 701: SP#43 completed / Text3: 32.240, 32.260, 32.296, 32.298, 32.299, new 32.280
- 702: SP#39 completed / Text3: 32.260, 32.298

| ID | WBS | Task | Duration | Start | Finish | Complete | Baseline start | Baseline finish | Baseline duration | Constraint | Resources | Work | Actual work | Text1 | Text2 | Text4 | Text5 | Text6 | Text7 | Text8 |
| --- | --- | --- | --- | --- | --- | --- | --- | --- | --- | --- | --- | --- | --- | --- | --- | --- | --- | --- | --- | --- |
| 703 | 243 | **3GPP2 Input to Common IMS** | 200d? | 2008-03-07 A | 2008-12-11 A | 100% | 2008-03-07 | 2008-12-11 | 200d? |  | S1,S2,S3,C1,C3,C4 | 8653.2h | 8653.2h | CIMS_3GPP2 | PCG-21 | Nortel | Amar Deol (deola@nortelnetworks.com) | Rel-8 | SP-39 | Alain |
| 704 | 243.1 | Stage 1 CIMS_3GPP2 (SA1) | 30.65d? | 2008-03-12 A | 2008-06-05 A | 100% | 2008-03-12 | 2008-06-05 | 30.65d? | finish no earlier than 2008-06-12 | S1 | 245.2h | 245.2h | CIMS_3GPP2 | PCG-21 | Nortel | Amar Deol (deola@nortelnetworks.com) | Rel-8 | SP-39 | Alain |
| 705 | 243.2 | Stage 2 CIMS_3GPP2 (SA2) | 62d? | 2008-03-12 A | 2008-06-05 A | 100% | 2008-03-12 | 2008-06-05 | 62d? | finish no earlier than 2008-09-11 | S2 | 496h | 496h | IMS_Common | PCG-21 | Nortel | Amar Deol (deola@nortelnetworks.com) | Rel-8 | SP-39 | Maurice |
| 706 | 243.3 | Security CIMS_3GPP2 (SA3) | 197d? | 2008-03-12 A | 2008-12-11 A | 100% | 2008-03-12 | 2008-12-11 | 197d? | finish no earlier than 2008-12-11 | S3 | 1576h | 1576h | IMS_Common | PCG-21 | Nortel | Amar Deol (deola@nortelnetworks.com) | Rel-8 | SP-39 | Dionisio |
| 707 | 243.4 | Stage 3 CIMS_3GPP2 (CT1) | 196d? | 2008-03-07 A | 2008-12-05 A | 100% | 2008-03-07 | 2008-12-05 | 196d? | finish no earlier than 2008-12-11 | C1 | 1568h | 1568h | REDOC_3GPP2 | PCG-21 | Alcatel-Lucent | orsic@alcatel-lucent.com | Rel-8 | CP-39 | Frederic |
| 708 | 243.5 | Stage 3 CIMS_3GPP2 (CT3) | 196d? | 2008-03-07 A | 2008-12-05 A | 100% | 2008-03-07 | 2008-12-05 | 196d? | finish no earlier than 2008-12-05 | C3 | 1568h | 1568h | REDOC_3GPP2 | PCG-21 | Alcatel-Lucent | orsic@alcatel-lucent.com | Rel-8 | CP-39 | Gwiho |
| 709 | 243.6 | Stage 3 CIMS_3GPP2 (CT4) | 200d? | 2008-03-07 A | 2008-12-11 A | 100% | 2008-03-07 | 2008-12-11 | 200d? | finish no earlier than 2008-12-11 | C4 | 1600h | 1600h | REDOC_3GPP2 | PCG-21 | Alcatel-Lucent | orsic@alcatel-lucent.com | Rel-8 | CP-39 | Kimmo |
| 710 | 244 | **IMS Enhancements for support of Packet Cable access** | 388d? | 2006-12-06 A | 2008-05-30 A | 100% | 2006-12-06 | 2008-05-30 | 388d? |  | S2,S3,C1,C3,C4 | 27448h | 27448h | PktCbl |  | Cablelabs | Bernie McKibben | Rel-8 |  | Maurice |
| 711 | 244.1 | **IMS Enhancements for Cable Client Types and Deployment Models** | 345d? | 2007-02-05 A | 2008-05-30 A | 100% | 2007-02-05 | 2008-05-30 | 345d? |  | S2,C1 | 6992h | 6992h | PktCbl-Deploy |  | Cablelabs | Bernie McKibben | Rel-8 |  | Maurice |
| 712 | 244.1.1 | Architecture aspects of PktCbl-Deploy | 219d? | 2007-02-05 A | 2007-12-06 A | 100% | 2007-02-05 | 2007-12-06 | 219d? | finish no earlier than 2007-12-03 | S2 | 1752h | 1752h | PktCbl-Deploy |  | Cablelabs | Bernie McKibben | Rel-8 |  | Maurice |
| 713 | 244.1.2 | CT1 aspects of PktCbl-Deploy | 310d? | 2007-03-26 A | 2008-05-30 A | 100% | 2007-03-26 | 2008-05-30 | 310d? | finish no earlier than 2008-06-15 | C1 | 2480h | 2480h | PktCbl-Deploy |  | Cablelabs | D.Hancock@ CableLabs.com | Rel-8 |  | Frederic |
| 714 | 244.2 | **IMS Inter-working aspects in Support of Cable Regulatory requirements** | 290d? | 2007-02-05 A | 2008-03-14 A | 100% | 2007-02-05 | 2008-03-14 | 290d? |  | S2,C1,C3 | 5640h | 5640h | PktCbl-Intw |  | Cablelabs | B.McKibben@CableLabs.com | Rel-8 |  | Maurice |
| 715 | 244.2.1 | Architecture aspects of PktCbl-Interwork | 160d? | 2007-02-05 A | 2007-09-14 A | 100% | 2007-02-05 | 2007-09-14 | 160d? | start no earlier than 2007-02-05 | S2 | 1280h | 1280h | PktCbl-Intw |  | Cablelabs | B.McKibben@CableLabs.com | Rel-8 |  | Maurice |
| 716 | 244.2.2 | CT1,CT3 aspects of PktCbl-Interwork | 255d? | 2007-03-26 A | 2008-03-14 A | 100% | 2007-03-26 | 2008-03-14 | 255d? | finish no earlier than 2008-03-15 | C1,C3 | 2040h | 2040h | PktCbl-Intw |  | Cablelabs | D.Hancock@ CableLabs.com | Rel-8 |  | Frederic |
| 717 | 244.3 | **IMS Enhancements for Security Requirements in Support of Cable Deployments** | 388d? | 2006-12-06 A | 2008-05-30 A | 100% | 2006-12-06 | 2008-05-30 | 388d? |  | S3,C1,C3,C4 | 11712h | 11712h | PktCbl-Sec |  | Cablelabs | s.dotson@cablelabs.com | Rel-8 |  | Dionisio |
| 718 | 244.3.1 | SA3 aspects of PktCbl-Sec | 331d? | 2006-12-06 A | 2008-03-12 A | 100% | 2006-12-06 | 2008-03-12 | 331d? | finish no earlier than 2007-12-20 | S3 | 2648h | 2648h | PktCbl-Sec |  | Cablelabs | s.dotson@cablelabs.com | Rel-8 |  | Dionisio |
| 719 | 244.3.2 | CT1 aspects of PktCbl-Sec | 310d? | 2007-03-26 A | 2008-05-30 A | 100% | 2007-03-26 | 2008-05-30 | 310d? | finish no earlier than 2008-06-06 | C1 | 2480h | 2480h | PktCbl-Sec |  | Cablelabs | D.Hancock@ CableLabs.com | Rel-8 |  | Frederic |
| 720 | 244.3.3 | CT3 aspects of PktCbl-Sec | 180d? | 2007-03-26 A | 2007-11-30 A | 100% | 2007-03-26 | 2007-11-30 | 180d? | finish no earlier than 2008-03-15 | C3 | 1440h | 1440h | PktCbl-Intw | PCG-21 | Cablelabs | D.Hancock@ CableLabs.com | Rel-8 | CP-38 | Gwiho |
| 721 | 244.3.4 | CT4 aspects of PktCbl-Sec | 255d? | 2007-03-26 A | 2008-03-14 A | 100% | 2007-03-26 | 2008-03-14 | 255d? | finish no earlier than 2008-03-14 | C4 | 2040h | 2040h | PktCbl-Sec |  | Cablelabs | D.Hancock@ CableLabs.com | Rel-8 |  | Kimmo |
| 722 | 245 | **IMS System enhancements for corporate network access** | 717d? | 2007-06-22 A | 2010-03-19 A | 100% | 2007-06-22 | 2010-03-19 | 717d? |  | S2,S1,C1,C4 | 14336.9h | 14336.9h | IMS_Corp |  | Orange | Delphin Barankanira | Rel-8 |  | Maurice |
| 723 | 245.1 | SA1 aspects of IMS_Corp | 23.6d? | 2008-03-12 A | 2008-06-05 A | 100% | 2008-03-12 | 2008-06-05 | 23.6d? | finish no earlier than 2008-06-05 | S1 | 188.8h | 188.8h | IMS_Corp | PCG-21 | Telecom Italia |  | Rel-8 | SP-39 | Alain |
| 724 | 245.2 | SA2 aspects of IMS_Corp | 325d? | 2007-06-22 A | 2008-09-18 A | 100% | 2007-06-22 | 2008-09-18 | 325d? | finish no earlier than 2008-12-25 | S2 | 2600h | 2600h | IMS_Corp |  | Orange | Delphin Barankanira | Rel-8 |  | Maurice |
| 725 | 245.3 | CT1 aspects of IMS_Corp | 532d? | 2008-03-07 A | 2010-03-19 A | 100% | 2008-03-07 | 2010-03-19 | 532d? | finish no earlier than 2010-03-19 | C1 | 4244.09h | 4244.09h | IMS_Corp | PCG-21 | Alcatel-Lucent | Keith Drage (drage@alcatel-lucent.com) | Rel-8 | CP-39 | Frederic |
| 726 | 245.4 | CT4 aspects of IMS_Corp | 196d? | 2008-02-26 A | 2008-12-05 A | 100% | 2008-02-26 | 2008-12-05 | 196d? | finish no earlier than 2008-12-11 | C4 | 1568h | 1568h | IMS_Corp | PCG-21 | Alcatel-Lucent | Keith Drage (drage@alcatel-lucent.com) | Rel-8 | CP-39 | Kimmo |

Notes:
- 703: TSG#42 completed
- 704: SP#40 completed / Text3: 22.228, 22.173, 22.101, 22.153
- 705: SP#40 completed / Text3: 23.002, 23.141, 23.203, 23.167, 23.228
- 706: SP#42 completed [issues addressed under UID_370078 (IMS-Sec)] / Text3: 33.141, 33.203, 33.210
- 707: CP#42 completed / Text3: 23.218, 24.141, 24.147, 24.173, 24.229, 24.238, 24.247, 24.604, 24.605, 24.606, 24.607, 24.608, 24.610, 24.611, 24.629, 24.930
- 708: CP#42 completed / Text3: 29.163, 29.212, 29.213, 29.214
- 709: CP#42 completed / Text3: 29.228, 29.229, 29.328, 29.329
- 710: CP#40 completed
- 711: CP#40 completed
- 712: SP#38 completed / Text3: 23.228
- 713: CP#40 completed
- 714: CP#39 completed
- 715: SP#37 completed / Text3: 23.228
- 716: CP#39 completed / Text3: 24.229
- 717: CP#40 completed
- 718: SP#39 completed / Text3: 33.203, 33.210, 33.220
- 719: CP#40 completed / Text3: 24.229
- 720: CP#38 completed / Text3: 29.163
- 721: CP#39 completed / Text3: 29.228, 29.229, 23.008
- 722: CP#47 completed
- 723: SP#40 completed
- 724: no Stage 2 impacts / Text3: 23.228
- 725: CP#47 completed / Text3: 24.229, 24.503
- 726: CP#42 completed / Text3: 29.228, 29.229, 23.003, 23.008, 29.433

| ID | WBS | Task | Duration | Start | Finish | Complete | Baseline start | Baseline finish | Baseline duration | Constraint | Resources | Work | Actual work | Text1 | Text2 | Text6 | Text7 | Text8 | Text4 | Text5 |
| --- | --- | --- | --- | --- | --- | --- | --- | --- | --- | --- | --- | --- | --- | --- | --- | --- | --- | --- | --- | --- |
| 727 | 246 | **Maintenance of TISPAN documentation** | 244d? | 2007-07-02 A | 2008-06-05 A | 100% | 2007-07-02 | 2008-06-05 | 244d? |  | S2,C1,C3,C4 | 5984h | 5984h | MAINTISP | PCG-21 | Rel-8 | SP-38 | Maurice |  |  |
| 728 | 246.1 | Maintenance of TISPAN R1 | 86d? | 2007-11-09 A | 2008-03-07 A | 100% | 2007-11-09 | 2008-03-07 | 86d? | start no earlier than 2007-11-09 | C1,C3,C4 | 688h | 688h | MAINT_R1 | PCG-21 | Rel-7 | CP-38 | Frederic | Alcatel-Lucent | Keith Drage (drage@alcatel-lucent.com) |
| 729 | 246.2 | Maintenance of TISPAN R2 | 86d? | 2007-11-09 A | 2008-03-07 A | 100% | 2007-11-09 | 2008-03-07 | 86d? | start no earlier than 2007-11-09 | C1,C3,C4 | 688h | 688h | MAINT_R2 | PCG-21 | Rel-8 | CP-38 | Frederic | Alcatel-Lucent | Keith Drage (drage@alcatel-lucent.com) |
| 730 | 246.3 | Documentation of TISPAN NGN R1 and R2 in 3GPP SA2 | 104d? | 2008-01-14 A | 2008-06-05 A | 100% | 2008-01-14 | 2008-06-05 | 104d? | finish no earlier than 2008-06-20 | S2 | 832h | 832h | IMS_Comm_Doc | PCG-21 | Rel-8 | SP-38 | Maurice | Nokia Siemens Networks | jozsef.varga@nsn.com |
| 731 | 246.4 | Maintenance of TISPAN release 1 common IMS | 114d? | 2007-07-02 A | 2007-12-06 A | 100% | 2007-07-02 | 2007-12-06 | 114d? | finish no earlier than 2007-12-06 | S2,S1 | 912h | 912h | IMS_Comm_Mtce7 | PCG-21 | Rel-7 | SP-38 | Maurice | BT, Ericsson | Dick Knight, Raymond Forbes |
| 732 | 246.5 | Maintenance of TISPAN release 2 common IMS | 114d? | 2007-07-02 A | 2007-12-06 A | 100% | 2007-07-02 | 2007-12-06 | 114d? | finish no earlier than 2007-12-06 | S2 | 912h | 912h | IMS_Comm_Mtce8 | PCG-21 | Rel-8 | SP-38 | Maurice | Telecom Italia | antonio.ascolese@telecomitalia.it |
| 733 | 247 | **IMS Service Continuity** | 318d? | 2008-03-12 A | 2009-05-29 A | 100% | 2008-03-12 | 2009-05-29 | 318d? |  | S2,S1,C1 | 5624h | 5624h | IMS-Cont | PCG-21 | Rel-8 | SP-39 | Maurice | LG Electronics | JaeSeung SONG (anthonys@lge.com) |
| 734 | 247.1 | Stage 1 IMS Service Continuity | 62d? | 2008-03-12 A | 2008-06-05 A | 100% | 2008-03-12 | 2008-06-05 | 62d? | start no earlier than 2008-03-12 | S1 | 496h | 496h | IMS-Cont | PCG-21 | Rel-8 | SP-39 | Alain | LG Electronics | JaeSeung SONG (anthonys@lge.com) |
| 735 | 247.2 | Stage 2 IMS Service Continuity | 62d? | 2008-03-12 A | 2008-06-05 A | 100% | 2008-03-12 | 2008-06-05 | 62d? | finish no earlier than 2008-06-05 | S2 | 496h | 496h | IMS-Cont | PCG-21 | Rel-8 | SP-39 | Maurice | LG Electronics | JaeSeung SONG (anthonys@lge.com) |
| 736 | 247.3 | Stage 3 IMS Service Continuity | 261d? | 2008-05-30 A | 2009-05-29 A | 100% | 2008-05-30 | 2009-05-29 | 261d? | finish no earlier than 2009-05-29 | C1 | 2088h | 2088h | IMS-Cont | PCG-21 | Rel-8 | CP-40 | Frederic | Huawei | Lili Yang (kadyyang@huawei.com) |
| 737 | 248 | **Security Enhancements for IMS** | 643.3d? | 2006-09-19 A | 2009-03-06 A | 100% | 2006-09-19 | 2009-03-06 | 643.3d? |  | S3,C1,C4 | 18624h | 18624h | IMS-Sec |  | Rel-8 | SP-37 | Dionisio | Ericsson | Bengt.Sahlin@ericsson.com |
| 738 | 248.1 | Stage 2 for IMS-Sec | 466d? | 2007-03-01 A | 2008-12-11 A | 100% | 2007-03-01 | 2008-12-11 | 466d? | finish no earlier than 2008-12-11 | S3 | 3728h | 3728h | IMS-Sec |  | Rel-8 |  | Dionisio | Ericsson | Bengt.Sahlin@ericsson.com |
| 739 | 248.2 | CT1 part of Stage 3 for IMS-Sec | 392d? | 2006-09-19 A | 2008-12-05 A | 100% | 2006-09-19 | 2008-12-05 | 392d? | finish no earlier than 2008-12-05 | C1 | 3136h | 3136h | IMS-Sec | PCG-21 | Rel-8 | CP-39 | Frederic | Ericsson |  |
| 740 | 248.3 | CT4 part of Stage 3 for IMS-Sec | 457d? | 2007-06-07 A | 2009-03-06 A | 100% | 2007-06-07 | 2009-03-06 | 457d? | finish no earlier than 2009-03-06 | C4 | 3656h | 3656h | IMS-Sec | PCG-21 | Rel-8 | CP-39 | Kimmo | Ericsson |  |
| 741 | 248.4 | CT1 part of NASS Bundled Authentication | 343d? | 2007-11-14 A | 2009-03-06 A | 100% | 2007-11-14 | 2009-03-06 | 343d? | finish no earlier than 2009-03-06 | C1 | 2744h | 2744h | NBA | PCG-21 | Rel-8 | CP-39 | Frederic | Alcatel-Lucent | Keith Drage (drage@alcatel-lucent.com) |
| 742 | 248.5 | CT4 part of NASS Bundled Authentication | 143d? | 2007-11-14 A | 2008-05-30 A | 100% | 2007-11-14 | 2008-05-30 | 143d? | start no earlier than 2007-11-14 | C4 | 1144h | 1144h | NBA-CT4 | PCG-21 | Rel-8 | CP-39 | Kimmo | Alcatel-Lucent |  |
| 743 | 249 | IMS initiated and controlled PSS and MBMS User Service | 262d? | 2008-03-12 A | 2009-03-12 A | 100% | 2008-03-12 | 2009-03-12 | 262d? | finish no earlier than 2009-03-12 | S2,C3,C4 |  |  | IMS_PSS_MBMS_US |  | Rel-8 |  | Paolo | FT, Ericsson | olle.franceschi@ericsson.com |
| 744 | 250 | **Multimedia interworking between IMS and CS networks** | 836d? | 2005-09-23 A | 2008-12-05 A | 100% | 2005-09-23 | 2008-12-05 | 836d? |  | C3,C4 | 16112h | 16112h | MIW-IMS |  | Rel-8 |  | Gwiho | Vodafone | nico.gabriele@vodafone.com |
| 745 | 250.1 | Note: Stages 1 and 2 defined in earlier Release | 49d? | 2005-09-23 A | 2005-11-30 A | 100% | 2005-09-23 | 2005-11-30 | 49d? | start no earlier than 2005-09-23 | S2 | 392h | 392h | MIW-IMS |  | Rel-8 |  | Maurice | Vodafone | nico.gabriele@vodafone.com |
| 746 | 250.2 | Stage 3 of MW-IMS | 571d? | 2005-09-23 A | 2007-11-30 A | 100% | 2005-09-23 | 2007-11-30 | 571d? | finish no earlier than 2007-09-14 | C3 | 4568h | 4568h | MIW-IMS-St3 |  | Rel-8 |  | Gwiho | Vodafone | nico.gabriele@vodafone.com |
| 747 | 250.3 | Stage 3 for MW-IMS, MONA extension | 285d? | 2007-11-05 A | 2008-12-05 A | 100% | 2007-11-05 | 2008-12-05 | 285d? | finish no earlier than 2008-12-05 | C3 | 2280h | 2280h | MIW-IMS | PCG-21 | Rel-8 | CP-38 | Gwiho | Vodafone | Christer.Holmberg@ericsson.com |
| 748 | 250.4 | Mn interface (MGCF – IM MGW) | 273d? | 2007-11-21 A | 2008-12-05 A | 100% | 2007-11-21 | 2008-12-05 | 273d? | finish no earlier than 2008-12-19 | C4 | 2184h | 2184h | MIW-IMS | PCG-21 | Rel-8 | CP-38 | Kimmo | Vodafone | Christer.Holmberg@ericsson.com |
| 749 | 251 | IMS Stage 3 IETF Protocol Alignment | 446d? | 2007-06-22 A | 2009-03-06 A | 100% | 2007-06-22 | 2009-03-06 | 446d? | finish no earlier than 2009-03-06 | C1 | 3568h | 3568h | IMSProtoc2 |  | Rel-8 |  | Frederic | Alcatel-Lucent | Keith Drage (drage@alcatel-lucent.com) |
| 750 | 252 | **Interworking between User-to-User Signalling (UUS) and SIP** | 335d? | 2007-11-30 A | 2009-03-12 A | 100% | 2007-11-30 | 2009-03-12 | 335d? |  | C1,C3 | 7488h | 7488h | UUSIW | PCG-21 | Rel-8 | CP-38 | Kimmo | Huawei | Lili Yang (kadyyang@huawei.com) |
| 751 | 252.1 | Stage 3 MGCF UUSIW | 266d? | 2007-11-30 A | 2008-12-05 A | 100% | 2007-11-30 | 2008-12-05 | 266d? | finish no earlier than 2008-12-05 | C1 | 2128h | 2128h | UUSIW | PCG-21 | Rel-8 | CP-38 | Frederic | Huawei | Lili Yang (kadyyang@huawei.com) |
| 752 | 252.2 | Stage 3 MGCF UUSIW | 335d? | 2007-11-30 A | 2009-03-12 A | 100% | 2007-11-30 | 2009-03-12 | 335d? | finish no earlier than 2009-03-12 | C3 | 2680h | 2680h | UUSIW | PCG-21 | Rel-8 | CP-38 | Gwiho | Huawei | Lili Yang (kadyyang@huawei.com) |

Notes:
- 727: SP#40 completed
- 728: CP#39 completed / Text3: 24.404, 24.405, 24.406, 24.407, 24.408, 24.410, 24.411, 24.416, 29.421, 24.423, 24.428, 24.429, 29.433, 24.441, 24.403, 29.427, 24.430, 29.412
- 729: CP#39 completed / Text3: 24.406, 24.407, 24.410, 24.411, 24.423, 24.430, 24.447, 24.451, 24.454, 24.503, 24.505, 24.508, 24.516, 24.528, 24.529, 29.412, 29.421, 29.433, 29.458, 29.527, 29.624
- 730: SP#40 completed / Text3: 23.228, 23.204, 23.167
- 731: SP#38 completed / Text3: 22.273, 22.401, 23.406, 23.417, 23.508, 23.509, 23.511, 22.401, 22.173
- 732: SP#38 completed / Text3: 23.506, 23.507,23.517, 23.521
- 733: CP#44 completed
- 734: SP#40 completed
- 735: SP#40 completed / Text3: 23.237, 23.292
- 736: CP#44 completed / Text3: 24.237, 24.229, 24.216
- 737: CP#43 completed
- 738: SP#42 completed. SP#46 withdrawn draft 33.178-100 and 33.978 from Rel-8 onwards / Text3: 33.203, 33.141, 33.803
- 739: CP#42 completed
- 740: CP#43 completed
- 741: CP#43 completed / Text3: 24.229
- 742: CP#40 completed / Text3: 29.229, 29.228, 23.008
- 743: SP#43 completed. SP#39 WID approved / Text3: 26.237, 26.234, 26.346, 33.246
- 744: CP#42 completed
- 745: SP#31 Moved from FS section Feb 2006
- 746: Moved from Rel-7. Feature extended in Rel-8 by including Stage 3 covering MONA UID_380021 / Text3: 29.863, 29.163
- 747: CP#42 completed / Text3: 29.863, 29.163
- 748: CP#42 completed / Text3: 29.332
- 749: CP#43 completed / Text3: 23.218, 24.229, 24.930
- 750: CP#43 completed
- 751: CP#42 completed / Text3: 24.279, 24.229
- 752: CP#43 completed / Text3: 29.163

| ID | WBS | Task | Type | Duration | Start | Finish | Complete | Baseline start | Baseline finish | Baseline duration | Constraint | Resources | Work | Actual work | Text1 | Text2 | Text4 | Text5 | Text6 | Text7 | Text8 | Text3 | Text11 |
| --- | --- | --- | --- | --- | --- | --- | --- | --- | --- | --- | --- | --- | --- | --- | --- | --- | --- | --- | --- | --- | --- | --- | --- |
| 753 | 253 | **Support of Overlap signalling** |  | 331d? | 2007-11-30 A | 2009-03-06 A | 100% | 2007-11-30 | 2009-03-06 | 331d? |  | C3,C1,C4 | 10008.2h | 10008.2h | Overlap | PCG-21 | Deutsche Telekom | r.jesske@telekom.de | Rel-8 | CP-38 | Gwiho |  |  |
| 754 | 253.1 | Stage 3 Overlap (CT1) |  | 331d? | 2007-11-30 A | 2009-03-06 A | 100% | 2007-11-30 | 2009-03-06 | 331d? | finish no earlier than 2009-03-06 | C1 | 2648h | 2648h | Overlap | PCG-21 | Deutsche Telekom | r.jesske@telekom.de | Rel-8 | CP-38 | Frederic | 24.229 |  |
| 755 | 253.2 | Stage 3 Overlap (CT3) |  | 331d? | 2007-11-30 A | 2009-03-06 A | 100% | 2007-11-30 | 2009-03-06 | 331d? | finish no earlier than 2009-03-06 | C3 | 2648h | 2648h | Overlap | PCG-21 | Deutsche Telekom | r.jesske@telekom.de | Rel-8 | CP-38 | Gwiho | 29.163 |  |
| 756 | 253.3 | Stage 3 Overlap (CT4) |  | 258.02d? | 2007-11-30 A | 2008-12-05 A | 100% | 2007-11-30 | 2008-12-05 | 258.02d? | start no earlier than 2007-11-30 | C4 | 2064.16h | 2064.16h | Overlap | PCG-21 | Deutsche Telekom | r.jesske@telekom.de | Rel-8 | CP-38 | Kimmo | 29.228, 29.229 |  |
| 757 | 254 | AS/MRFC Stage 2 and 3 |  | 278d? | 2007-11-14 A | 2008-12-05 A | 100% | 2007-11-14 | 2008-12-05 | 278d? | finish no earlier than 2008-12-05 | C1 | 2224h | 2224h | MRFC_TS | PCG-21 | Hewlett-Packard | mark.syrett@hp.com | Rel-8 | CP-38 | Frederic | 23.218, 24.229, 24.147, 24.247 |  |
| 758 | 255 | **IMS Restoration Procedures** |  | 201d? | 2008-05-30 A | 2009-03-06 A | 100% | 2008-05-30 | 2009-03-06 | 201d? |  | C4,C1 | 4824h | 4824h | IMS_RP | PCG-21 | Ericsson | german.blanco@ericsson.com | Rel-8 | SP-40 | Kimmo |  |  |
| 759 | 255.1 | IMS Restoration Procedures (CT4) |  | 201d? | 2008-05-30 A | 2009-03-06 A | 100% | 2008-05-30 | 2009-03-06 | 201d? | finish no earlier than 2009-03-06 | C4 | 1608h | 1608h | IMS_RP | PCG-21 | Ericsson | german.blanco@ericsson.com | Rel-8 | SP-40 | Kimmo | 23.380, 29.228, 29.229, 29.230, 23.008 |  |
| 760 | 255.2 | IMS Restoration Procedures (CT1) |  | 201d? | 2008-05-30 A | 2009-03-06 A | 100% | 2008-05-30 | 2009-03-06 | 201d? | finish no earlier than 2009-03-06 | C1 | 1608h | 1608h | IMS_RP | PCG-21 | Ericsson | german.blanco@ericsson.com | Rel-8 | SP-40 | Frederic | 24.229 |  |
| 761 | 256 | IMS Application Server Service Data Descriptions for AS interoperability |  | 125d? | 2008-09-12 A | 2009-03-06 A | 100% | 2008-09-12 | 2009-03-06 | 125d? | finish no earlier than 2009-03-06 | C4 | 1000h | 1000h | IMS_ASIO | PCG-21 | Alcatel-Lucent | nhberry@alcatel-lucent.com | Rel-8 | CP-41 | Kimmo | 29.328, 29.329, 29.364 |  |
| 762 | 257 | **I-WLAN Network Selection Principle (NSP)** |  | 451d? | 2007-06-14 A | 2009-03-06 A | 100% | 2007-06-14 | 2009-03-06 | 451d? |  | S1,C1,C6 | 6643.2h | 6643.2h | IWLANNSP |  | Telefonica O2 | chris.friel@o2.com | Rel-8 |  | Alain |  |  |
| 763 | 257.1 | Stage 1 for I-WLAN NSP | milestone | 0d? | 2007-06-14 A | 2007-06-14 A | 100% | 2007-06-14 | 2007-06-14 | 0d? |  | S1 |  |  | IWLANNSP | PCG-21 | Telefonica O2 | chris.friel@o2.com | Rel-8 | SP-39 | Alain | 22.234 |  |
| 764 | 257.2 | Stage 3 for I-WLAN NSP |  | 261d? | 2008-03-07 A | 2009-03-06 A | 100% | 2008-03-07 | 2009-03-06 | 261d? | finish no earlier than 2008-12-05 | C1 | 2088h | 2088h | IWLANNSP | PCG-21 | RIM | Adrian Buckley (abuckley@rim.com) | Rel-8 | CP-39 | Frederic | 24.234 |  |
| 765 | 257.3 | Stage 3 for I-WLAN NSP |  | 118.4d? | 2008-03-07 A | 2008-12-11 A | 100% | 2008-03-07 | 2008-12-11 | 118.4d? | finish no earlier than 2008-12-11 | C6 | 947.2h | 947.2h | IWLANNSP | PCG-21 | RIM | Adrian Buckley (abuckley@rim.com) | Rel-8 | CP-39 | Xavier | 31.102, 31.111 |  |
| 766 | 258 | **Mobility between 3GPP-WLAN Interworking and 3GPP Systems** |  | 386d? | 2007-09-14 A | 2009-03-06 A | 100% | 2007-09-14 | 2009-03-06 | 386d? |  | S2,C1 | 6216h | 6216h | IWLAN_Mob |  | Orange | xiaobao.chen@orange-ftgroup.com | Rel-8 | SP-37 | Maurice |  |  |
| 767 | 258.1 | Stage 2: I-WLAN Mobility |  | 190d? | 2007-09-14 A | 2008-06-05 A | 100% | 2007-09-14 | 2008-06-05 | 190d? | finish no earlier than 2008-09-08 | S2 | 1520h | 1520h | IWLAN_Mob | PCG-21 | Orange | xiaobao.chen@orange-ftgroup.com | Rel-8 | SP-38 | Maurice | new 23.327 |  |
| 768 | 258.2 | CT1 aspects of I-WLAN Mobility |  | 201d? | 2008-05-30 A | 2009-03-06 A | 100% | 2008-05-30 | 2009-03-06 | 201d? | finish no earlier than 2009-03-06 | C1 | 1608h | 1608h | IWLAN_Mob | PCG-21 | Orange | reina.nader@orange-ftgroup.com | Rel-8 | CP-40 | Frederic | 24.303, new 24.327 |  |
| 769 | 259 | Conformance Test Aspects – Mobility between 3GPP WLAN Interworking and 3GPP Systems |  | 206d? | 2009-12-04 A | 2010-09-17 A | 100% | 2009-12-04 | 2010-09-17 | 206d? | finish no earlier than 2010-09-17 | R5 | 1648h | 1648h | IWLAN_Mob_UEConTest | PCG-24 | Qualcomm | Patrick Stupar (pstupar@qualcomm.com) | Rel-8 | RP-46 | Ingbert | 34.108, 34.123-1, 34.123-2, 34.123-3 | RP-100740 |
| 770 | 260 | **Enhancements for Voice Group Call Service (VGCS) Applications (EVA)** |  | 919d? | 2006-03-15 A | 2009-09-18 A | 100% | 2006-03-15 | 2009-09-18 | 919d? |  | S1,C1,C4,G2 | 23503.5h | 23503.5h | EVA |  | Nortel | Amar Deol (deola@nortelnetworks.com) | Rel-8 |  | Alain |  |  |
| 771 | 260.1 | SA1 aspects of EVA |  | 191d? | 2006-03-15 A | 2006-12-06 A | 100% | 2006-03-15 | 2006-12-06 | 191d? | finish no earlier than 2006-12-06 | S1 | 1528h | 1528h | EVA |  | Nortel | Amar Deol (deola@nortelnetworks.com) | Rel-8 |  | Alain | 42.068 |  |
| 772 | 260.2 | VGCS/VBS and GPRS Interactions |  | 145d? | 2007-09-03 A | 2008-03-21 A | 100% | 2007-09-03 | 2008-03-21 | 145d? | finish no earlier than 2008-03-21 | S1 | 1160h | 1160h | EVA |  | Huawei | Ling Liu | Rel-8 | SP-37 | Alain | 42.068, 42.069 |  |
| 773 | 260.3 | CT1 aspects of EVA |  | 862d? | 2006-06-02 A | 2009-09-18 A | 100% | 2006-06-02 | 2009-09-18 | 862d? | finish no earlier than 2009-12-04 | C1 | 6887.53h | 6887.53h | EVA |  | Nortel | milanpa@nortel.com | Rel-8 |  | Frederic | 43.068, 44.068 |  |
| 774 | 260.4 | CT4 aspects of EVA |  | 391d? | 2006-06-02 A | 2007-11-30 A | 100% | 2006-06-02 | 2007-11-30 | 391d? | finish no earlier than 2007-06-01 | C4 | 3128h | 3128h | EVA |  | Nortel |  | Rel-8 |  | Kimmo | 29.002 |  |
| 775 | 260.5 | GERAN2 aspects of EVA |  | 431d? | 2006-06-30 A | 2008-02-22 A | 100% | 2006-06-30 | 2008-02-22 | 431d? | finish no earlier than 2008-02-22 | G2 | 3448h | 3448h | EVA |  | Nortel | frank.billenkamp@nortel.com | Rel-8 |  | Gert | 44.018, 48.008 |  |
| 776 | 261 | **Personal Network Management** |  | 955d? | 2005-07-11 A | 2009-03-06 A | 100% | 2005-07-11 | 2009-03-06 | 955d? |  | S1,C1,S3 | 27008h | 27008h | PNM |  | Vodafone | armin.toepfer@vodafone.com | Rel-8 |  | Alain |  |  |
| 777 | 261.1 | Stage 1 for PNM |  | 276d? | 2005-07-11 A | 2006-07-31 A | 100% | 2005-07-11 | 2006-07-31 | 276d? | start no earlier than 2005-07-11 | S1 | 2208h | 2208h | PNM |  | Vodafone | armin.toepfer@vodafone.com | Rel-8 |  | Alain | 22.259 |  |
| 778 | 261.2 | Stage 2 for PNM |  | 445d? | 2007-03-26 A | 2008-12-05 A | 100% | 2007-03-26 | 2008-12-05 | 445d? | finish no earlier than 2008-12-05 | C1 | 3560h | 3560h | PNM |  | Vodafone | yang.lu@vodafone.com | Rel-8 |  | Frederic | 23.259 |  |

Notes:
- 753: CP#43 completed
- 754: CP#43 completed
- 755: CP#43 completed
- 756: CP#42 completed
- 757: CP#42 completed. Triggered by Study UID_7048 (MRFC)
- 758: CP#43 completed. Triggered by Study TR 23.820 (FS_IMS_RP) UID_350018
- 759: CP#43 completed
- 760: CP#43 completed
- 761: CP#43 completed. Triggered by UID_360030 (FS_IMS_ASIO)
- 762: CP#43 completed
- 763: SP#36 completed
- 764: CP#43 completed
- 765: CP#42 completed
- 766: CP#43 completed
- 767: SP#40 completed
- 768: CP#43 completed
- 769: RP#49 completed. Testing for Rel-8 UID_400013 CT1 aspects of mobility between 3GPP WLAN Interworking and 3GPP Systems (24.327)
- 770: CP#45 completed
- 771: SP#38 completed
- 772: SP#39 completed
- 773: CP#45 completed
- 774: CP#38 completed
- 775: GP#37 completed
- 776: CP#43 completed
- 777: SP#31 completed
- 778: CP#42 completed

| ID | WBS | Task | Type | Duration | Start | Finish | Complete | Baseline start | Baseline finish | Baseline duration | Constraint | Resources | Work | Actual work | Text1 | Text4 | Text5 | Text6 | Text8 | Text3 | Text12 | Text7 | Text2 | Text11 |
| --- | --- | --- | --- | --- | --- | --- | --- | --- | --- | --- | --- | --- | --- | --- | --- | --- | --- | --- | --- | --- | --- | --- | --- | --- |
| 779 | 261.3 | **Stage 3 for PNM** |  | 510d? | 2007-03-26 A | 2009-03-06 A | 100% | 2007-03-26 | 2009-03-06 | 510d? |  | C1,C4 | 11720h | 11720h | PNM | Vodafone | yang.lu@vodafone.com | Rel-8 | Frederic |  |  |  |  |  |
| 780 | 261.3.1 | CT1 aspects of Stage 3 PNM |  | 510d? | 2007-03-26 A | 2009-03-06 A | 100% | 2007-03-26 | 2009-03-06 | 510d? | finish no earlier than 2008-12-05 | C1 | 4080h | 4080h | PNM | Vodafone | yang.lu@vodafone.com | Rel-8 | Frederic | 24.259, 24.229 |  |  |  |  |
| 781 | 261.3.2 | Deleted - CT4 aspects of Stage 3 PNM |  | 445d? | 2007-03-26 A | 2008-12-05 A | 100% | 2007-03-26 | 2008-12-05 | 445d? | finish no earlier than 2008-12-11 | C4 | 3560h | 3560h | PNM | Vodafone | yang.lu@vodafone.com | Rel-8 | Kimmo |  |  |  |  |  |
| 782 | 261.4 | Key establishment between a UICC hosting device and a remote device |  | 235d? | 2006-12-06 A | 2007-10-30 A | 100% | 2006-12-06 | 2007-10-30 | 235d? | finish no earlier than 2007-10-30 | S3 | 1880h | 1880h | PNM | Ericsson | Vesa.Lehtovirta@ericsson.com | Rel-8 | Dionisio | 33.259 |  |  |  |  |
| 783 | 261.5 | Deleted - Actual Requirements of PNM | milestone | 0d? | 2007-03-26 A | 2007-03-26 A | 100% | 2007-03-26 | 2007-03-26 | 0d? | finish no earlier than 2007-03-26 | C1 |  |  | PNM | Ericsson |  | Rel-8 | Frederic |  | SP-37 |  |  |  |
| 784 | 262 | **eCall Data Transfer** |  | 637d? | 2006-09-28 A | 2009-03-06 A | 100% | 2006-09-28 | 2009-03-06 | 637d? |  | S1,C1 | 9744h | 9744h | EData | Airbiquity | rrobinson@airbiquity.com | Rel-8 | Alain |  |  |  |  |  |
| 785 | 262.1 | eData Requirements |  | 380d? | 2006-09-28 A | 2008-03-12 A | 100% | 2006-09-28 | 2008-03-12 | 380d? | finish no earlier than 2006-12-07 | S1 | 3040h | 3040h | EData | Airbiquity | rrobinson@airbiquity.com | Rel-8 | Alain | 22.101, 22.105 |  | SP-37 |  |  |
| 786 | 262.2 | Transfer of data during an emergency call |  | 201d? | 2008-05-30 A | 2009-03-06 A | 100% | 2008-05-30 | 2009-03-06 | 201d? | finish no earlier than 2009-03-06 | C1 | 1608h | 1608h | EData | T-Mobile | Dieter Jacobsohn | Rel-8 | Frederic | 24.008 |  | SP-40 | PCG-21 |  |
| 787 | 263 | eCall data transfer Phase 2: Comparison of alternative in-band modem solutions and standardization of one in-band modem solution |  | 472d? | 2007-12-06 A | 2009-09-24 A | 100% | 2007-12-06 | 2009-09-24 | 472d? | finish no earlier than 2009-09-24 | S4 | 3768.09h | 3768.09h | eCall_Phase2 | Airbiquity | lhong@airbiquity.com & rrobinson@airbiquity.com | Rel-8 | Paolo | 26.267, 26.268, 26.269, 26.967, 26.969 |  |  |  |  |
| 788 | 264 | eCall Conformance Testing |  | 261d? | 2009-09-04 A | 2010-09-03 A | 100% | 2009-09-04 | 2010-09-03 | 261d? | finish no earlier than 2010-09-03 | G3new | 2088h | 2088h | eCall_MSTest | Ericsson, Qualcomm | Vikrant Jain (vikrantj@qualcomm.com) | Rel-8 | Ingbert | 51.010-1, 51.010-2 |  | GP-45 | PCG-23 |  |
| 789 | 265 | Conformance Test Aspects – non-modem procedures of eCall sessions in UTRA |  | 186d? | 2009-09-18 A | 2010-06-04 A | 100% | 2009-09-18 | 2010-06-04 | 186d? | finish no earlier than 2010-06-04 | R5 | 1488h | 1488h | UMTS_eCall_UEConTest | Ericsson, Qualcomm | Shubhang Vora (svora@qualcomm.com) | Rel-8 | Ingbert | 34.108, 34.123-1, 34.123-2, 34.123-3 |  | RP-45 | PCG-23 | RP-100489 |
| 790 | 266 | **IP Interconnection of Services** |  | 668d? | 2006-08-16 A | 2009-03-06 A | 100% | 2006-08-16 | 2009-03-06 | 668d? |  | S1,S2,S5,C3 | 17520h | 17520h | IPinterc | Telefonica O2 | chris.friel@O2.com | Rel-8 | Alain |  |  | SP-38 | PCG-21 |  |
| 791 | 266.1 | Stage 1 for IPinterc |  | 70d? | 2007-12-06 A | 2008-03-12 A | 100% | 2007-12-06 | 2008-03-12 | 70d? | start no earlier than 2007-12-06 | S1 | 560h | 560h | IPinterc | Telefonica O2 | chris.friel@O2.com | Rel-8 | Alain | 22.101, 22.228 |  | SP-38 | PCG-21 |  |
| 792 | 266.2 | **System enhancements for interconnection interfaces between two IMSs** |  | 668d? | 2006-08-16 A | 2009-03-06 A | 100% | 2006-08-16 | 2009-03-06 | 668d? |  | S2,S5,C3 | 11616h | 11616h | IMS_NNI | Telecom Italia | Mario Madella (mario.madella@telecomitalia.it) | Rel-8 | Maurice |  |  |  |  |  |
| 793 | 266.2.1 | Stage 2 for IMS_NNI |  | 120d? | 2007-06-22 A | 2007-12-06 A | 100% | 2007-06-22 | 2007-12-06 | 120d? | finish no earlier than 2007-12-21 | S2 | 960h | 960h | IMS_NNI | Telecom Italia | Mario Madella (mario.madella@telecomitalia.it) | Rel-8 | Maurice | 23.002, 23.228 |  |  |  |  |
| 794 | 266.2.2 | IMS inter-operator service interconnection interface |  | 461d? | 2007-06-01 A | 2009-03-06 A | 100% | 2007-06-01 | 2009-03-06 | 461d? | finish no earlier than 2009-03-06 | C3 | 3688h | 3688h | FBI2-IOPSI | Telecom Italia | antonio.ascolese@telecomitalia.it | Rel-8 | Gwiho | 29.865, 29.165 |  |  |  |  |
| 795 | 266.2.3 | Charging harmonization for NGN between 3GPP and ATIS-TMOC |  | 51d? | 2006-09-28 A | 2006-12-07 A | 100% | 2006-09-28 | 2006-12-07 | 51d? | finish no earlier than 2006-12-07 | S5 | 408h | 408h | FBI2-TISP2-CH | Amdocs | yishai.brown@amdocs.com | Rel-8 | Dionisio | 32.297 |  |  |  |  |
| 796 | 266.2.4 | Deleted - Protocol impact of FBI for TISPAN R2 |  | 152d? | 2006-08-16 A | 2007-03-15 A | 100% | 2006-08-16 | 2007-03-15 | 152d? | finish no earlier than 2007-03-15 | C1 | 1216h | 1216h | FBI2-TISP2-c1 | Ericsson |  | Rel-8 | Frederic |  | SP-38 |  |  |  |
| 797 | 266.2.5 | Deleted (never approved) - Stage 2 of FBI for TISPAN R2 - Rel 8 | milestone | 0d? | 2007-11-30 A | 2007-11-30 A | 100% | 2007-11-30 | 2007-11-30 | 0d? | finish no earlier than 2007-11-30 | S2 |  |  | FBI2-TISP2-s2 | Nokia Siemens Networks |  | Rel-8 | Maurice |  | SP-36 |  |  |  |
| 798 | 267 | **Support of (G)MSC-S – (G)MSC-S Nc Interface based on the SIP-I protocol** |  | 386d? | 2007-09-14 A | 2009-03-06 A | 100% | 2007-09-14 | 2009-03-06 | 386d? |  | C4,C3 | 11872h | 11872h | SIP_Nc | Vodafone | David.Hutton@vodafone.com | Rel-8 | Kimmo |  |  |  |  |  |
| 799 | 267.1 | Stage 1 for SIP_Nc (covered by Feature IPinterc) |  | 70d? | 2007-12-06 A | 2008-03-12 A | 100% | 2007-12-06 | 2008-03-12 | 70d? | start no earlier than 2007-12-06 | S1 | 560h | 560h | IPinterc | Telefonica O2 | chris.friel@O2.com | Rel-8 | Alain | 22.101, 22.228 |  | CP-41 | PCG-21 |  |
| 800 | 267.2 | SIP-I based circuit-switched core network; Stage 2 |  | 321d? | 2007-09-14 A | 2008-12-05 A | 100% | 2007-09-14 | 2008-12-05 | 321d? | finish no earlier than 2008-12-11 | C4 | 2568h | 2568h | SIP_Nc-St2 | Vodafone | David.Hutton@vodafone.com | Rel-8 | Kimmo | 23.231, 23.153, 23.205 |  |  |  |  |
| 801 | 267.3 | Application of SIP-I Protocols to Circuit Switched (CS) core network architecture; Stage 3 |  | 321d? | 2007-09-14 A | 2008-12-05 A | 100% | 2007-09-14 | 2008-12-05 | 321d? | finish no earlier than 2008-12-11 | C4 | 2568h | 2568h | SIP_Nc-St3 | Vodafone | David.Hutton@vodafone.com | Rel-8 | Kimmo | 29.231, 29.232, 29.332 |  |  |  |  |
| 802 | 267.4 | Interworking between the 3GPP CS domain with SIP-I as signalling protocol and other networks |  | 386d? | 2007-09-14 A | 2009-03-06 A | 100% | 2007-09-14 | 2009-03-06 | 386d? | finish no earlier than 2009-03-06 | C3 | 3088h | 3088h | SIP_Nc | Nokia Siemens Networks | Thomas.Belling@nsn.com | Rel-8 | Gwiho | 29.235, 23.172, 23.202, 29.007, 29.163, 29.414 |  |  |  |  |

Notes:
- 779: CP#43 completed
- 780: CP#43 completed
- 781: CP#42 no impact on CT4 specs
- 782: SP#37 completed
- 783: SP#37 stopped
- 784: SP#39 completed. Linked to SA4 Feature UID_34042 (eCall_Phase2)
- 785: SP#39 completed
- 786: CP#43 completed
- 787: SP#45 completed. Triggered by Study UID_360015 (eCALLIBMS). Linked to SA1 Feature UID_330005 (EData)
- 788: GP#47 completed. GP#43 WID approved. Testing for Rel-8 eCall_Phase2 (UID_34042) and EData (UID_330005)
- 789: RP#48 completed. Testing for Rel-8 eCall_Phase2 (UID_34042) and Edata (UID_330005)
- 790: SP#43 completed
- 791: SP#39 completed.
- 792: CP#43 completed
- 793: SP#38 completed
- 794: CP#43 completed
- 795: SP#34 completed
- 796: SP#38 stopped
- 797: SP#36 stopped
- 798: CP#43 completed. Stage 1 in Feature UID_380060 (IPinterc). CP#40 updated WID CP-070517=>CP-080282
- 799: 22/07/08 Created. Stage 1 for SIP_Nc (covered by SA1 Feature UID_380060 Ipinterc)
- 800: CP#42 completed
- 801: CP#42 completed
- 802: CP#43 completed. CP#42 target 12/08=>03/09

| ID | WBS | Task | Type | Duration | Start | Finish | Complete | Baseline start | Baseline finish | Baseline duration | Constraint | Resources | Work | Actual work | Text1 | Text4 | Text5 | Text6 | Text7 | Text8 | Text3 | Text2 | Text11 | Text9 | Text12 |
| --- | --- | --- | --- | --- | --- | --- | --- | --- | --- | --- | --- | --- | --- | --- | --- | --- | --- | --- | --- | --- | --- | --- | --- | --- | --- |
| 803 | 268 | **Earthquake and Tsunami Warning System** |  | 440d? | 2007-09-10 A | 2009-05-15 A | 100% | 2007-09-10 | 2009-05-15 | 440d? |  | S1,S2,C1,C4,G2 | 7200h | 7200h | ETWS | NTT DoCoMo | kitaharar@nttdocomo.co.jp | Rel-8 | SP-37 | Alain |  |  |  |  |  |
| 804 | 268.1 | Stage 1 for ETWS |  | 133d? | 2007-09-10 A | 2008-03-12 A | 100% | 2007-09-10 | 2008-03-12 | 133d? | finish no earlier than 2008-03-12 | S1 | 1064h | 1064h | ETWS | NTT DoCoMo | kitaharar@nttdocomo.co.jp | Rel-8 | SP-37 | Alain | 22.168 |  |  |  |  |
| 805 | 268.2 | SA2 aspects of ETWS |  | 179d? | 2008-01-14 A | 2008-09-18 A | 100% | 2008-01-14 | 2008-09-18 | 179d? | finish no earlier than 2008-09-08 | S2 | 1432h | 1432h | ETWS | NTT DoCoMo | tanakai@nttdocomo.co.jp | Rel-8 | SP-38 | Maurice | 23.828, 23.401 | PCG-21 |  |  |  |
| 806 | 268.3 | CT1 aspects of ETWS |  | 50.5d? | 2008-05-30 A | 2008-12-05 A | 100% | 2008-05-30 | 2008-12-05 | 50.5d? | finish no earlier than 2008-12-05 | C1 | 404h | 404h | ETWS | NTT DoCoMo | yamashitahi@s1.nttdocomo.co.jp | Rel-8 | CP-40 | Frederic | 23.041 | PCG-21 |  |  |  |
| 807 | 268.4 | CT4 aspects of ETWS |  | 50.5d? | 2008-09-26 A | 2008-12-05 A | 100% | 2008-09-26 | 2008-12-05 | 50.5d? | finish no earlier than 2008-12-05 | C4 | 404h | 404h | ETWS | NTT DoCoMo | yamashitahi@s1.nttdocomo.co.jp | Rel-8 | CP-40 | Kimmo | 29.168 | PCG-21 |  |  |  |
| 808 | 268.5 | ETWS primary notification message definition in GERAN |  | 47d? | 2009-03-12 A | 2009-05-15 A | 100% | 2009-03-12 | 2009-05-15 | 47d? | finish no earlier than 2009-05-15 | G2 | 376h | 376h | ETWS | Ericsson | claes-goran.persson@ericsson.com | Rel-8 | SP-43 | Gert | 44.018, 44.060 | PCG-22 |  |  |  |
| 809 | 269 | Conformance Test Aspects – UMTS Earthquake and Tsunami Warning System (ETWS) FDD |  | 207d? | 2009-05-29 A | 2010-03-12 A | 100% | 2009-05-29 | 2010-03-12 | 207d? | finish no earlier than 2010-03-12 | R5 | 1656h | 1656h | ETWS_UMTS_UEConTestFDD | NTT DoCoMo | Makoto Ito (itohm@nttdocomo.co.jp) | Rel-8 | RP-44 | Ingbert | 34.108, 34.123-1, 34.123-2 | PCG-23 | RP-100068 |  |  |
| 810 | 270 | **In Case of Emergency numbers storage and easy access on UICC** |  | 519d? | 2007-03-13 A | 2009-03-06 A | 100% | 2007-03-13 | 2009-03-06 | 519d? |  | S1,C6 | 8864h | 8864h | ICE | Vodafone | armin.toepfer@vodafone.com | Rel-8 | SP-38 | Alain |  | PCG-21 |  |  |  |
| 811 | 270.1 | Stage 1 for ICE |  | 262d? | 2007-03-13 A | 2008-03-12 A | 100% | 2007-03-13 | 2008-03-12 | 262d? | finish no earlier than 2008-03-12 | S1 | 2096h | 2096h | ICE | Vodafone | armin.toepfer@vodafone.com | Rel-8 | SP-38 | Alain | 22.030, 22.101 | PCG-21 |  |  |  |
| 812 | 270.2 | CT6 aspects of ICE |  | 519d? | 2007-03-13 A | 2009-03-06 A | 100% | 2007-03-13 | 2009-03-06 | 519d? | finish no earlier than 2009-03-06 | C6 | 4152h | 4152h | ICE | Vodafone | armin.toepfer@vodafone.com | Rel-8 | SP-38 | Xavier | 31.102 | PCG-21 |  |  |  |
| 813 | 271 | Local Charging Zone Requirements |  | 380d? | 2006-09-28 A | 2008-03-12 A | 100% | 2006-09-28 | 2008-03-12 | 380d? | finish no earlier than 2006-12-07 | S1 | 3040h | 3040h | LCZR | China Mobile | liuhongyfw@chinamobile.com | Rel-8 |  | Alain | 22.115 |  |  |  |  |
| 814 | 272 | **Customized Alerting Tone (CAT) Service** |  | 729d? | 2006-12-06 A | 2009-09-18 A | 100% | 2006-12-06 | 2009-09-18 | 729d? |  | S1,C1,C3,C4 | 12302h | 12302h | CAT | China Mobile | fenglingjuan@chinamobile.com | Rel-8 |  | Alain |  |  |  |  |  |
| 815 | 272.1 | Stage 1 for CAT |  | 207d? | 2006-12-06 A | 2007-09-20 A | 100% | 2006-12-06 | 2007-09-20 | 207d? | start no earlier than 2006-12-06 | S1 | 1656h | 1656h | CAT | China Mobile | fenglingjuan@chinamobile.com | Rel-8 | SP-37 | Alain | 22.182 |  |  |  |  |
| 816 | 272.2 | TISPAN requirements for customized multimedia information services |  | 71d? | 2007-09-03 A | 2007-12-10 A | 100% | 2007-09-03 | 2007-12-10 | 71d? | finish no earlier than 2007-12-10 | S1 | 568h | 568h | TISCMI | China Mobile | fenglingjuan@chinamobile.com | Rel-8 | SP-37 | Alain | 22.182 |  |  |  |  |
| 817 | 272.3 | IMS CAT Supplementary Service |  | 164d? | 2008-04-21 A | 2008-12-04 A | 100% | 2008-04-21 | 2008-12-04 | 164d? | finish no earlier than 2008-12-05 | C1 | 1312h | 1312h | CAT-SS | Nortel | milanpa@nortel.com | Rel-8 | CP-39 | Frederic | 24.182 | PCG-21 |  |  |  |
| 818 | 272.4 | CAT solution for voice and video call in CS domain |  | 389.8d? | 2008-03-12 A | 2009-09-18 A | 100% | 2008-03-12 | 2009-09-18 | 389.8d? | finish no earlier than 2009-09-11 | C3 | 3118.4h | 3118.4h | CAT-SS | Nortel | milanpa@nortel.com | Rel-8 | CP-39 | Gwiho | 29.163 | PCG-21 |  |  |  |
| 819 | 272.5 | CAT Service in 3GPP CS domain |  | 126d? | 2008-09-12 A | 2009-03-06 A | 100% | 2008-09-12 | 2009-03-06 | 126d? | finish no earlier than 2009-03-06 | C4 | 1008h | 1008h | CAT-3G_CS | China Mobile | zhaoyuyi@chinamobile.com | Rel-8 | CP-41 | Kimmo | 23.205, 23.231, 29.002 | PCG-21 |  |  |  |
| 820 | 272.6 | CAT Service in 3GPP CS domain |  | 57.95d? | 2008-09-12 A | 2008-12-05 A | 100% | 2008-09-12 | 2008-12-05 | 57.95d? | start no earlier than 2008-09-12 | C1 | 463.6h | 463.6h | CAT-3G_CS | China Mobile | zhaoyuyi@chinamobile.com | Rel-8 | CP-41 | Frederic | 24.008, 23.014 | PCG-21 |  |  |  |
| 821 | 273 | **Service-Level Interworking for Messaging Services** |  | 509d? | 2007-03-26 A | 2009-03-06 A | 100% | 2007-03-26 | 2009-03-06 | 509d? |  | S1,S2,C3,C1 | 8584h | 8584h | MESSIW | Huawei | ling.liu@huawei.com; duanxiaoqin@huawei.com | Rel-8 |  | Alain |  |  |  |  |  |
| 822 | 273.1 | Stage 1 for MESSIW | milestone | 0d? | 2007-03-26 A | 2007-03-26 A | 100% | 2007-03-26 | 2007-03-26 | 0d? | finish no earlier than 2007-12-01 | S1 |  |  | MESSIW | Huawei | ling.liu@huawei.com | Rel-8 |  | Alain | 22.105, 22.340 |  |  |  |  |
| 823 | 273.2 | Stage 2 for MESSIW |  | 227d? | 2007-04-26 A | 2008-03-07 A | 100% | 2007-04-26 | 2008-03-07 | 227d? | finish no earlier than 2008-03-07 | S2 | 1816h | 1816h | MESSIW | Huawei | patrice.hede@huawei.com | Rel-8 |  | Maurice | 23.811, 23.204 |  |  |  |  |
| 824 | 273.3 | Stage 3 for MESSIW |  | 201d? | 2008-05-30 A | 2009-03-06 A | 100% | 2008-05-30 | 2009-03-06 | 201d? | finish no earlier than 2008-12-05 | C3 | 1608h | 1608h | MESSIW | Huawei | xupeili@huawei.com | Rel-8 | CP-40 | Gwiho | 29.311 | PCG-21 |  |  |  |
| 825 | 273.4 | Stage 3 for MESSIW |  | 136d? | 2008-05-30 A | 2008-12-05 A | 100% | 2008-05-30 | 2008-12-05 | 136d? | finish no earlier than 2008-12-12 | C1 | 1088h | 1088h | MESSIW | Huawei | xupeili@huawei.com | Rel-8 | CP-40 | Frederic | 24.229 | PCG-21 |  |  |  |
| 826 | 274 | **Multimedia Priority Service** |  | 858d? | 2006-06-08 A | 2009-09-18 A | 100% | 2006-06-08 | 2009-09-18 | 858d? |  | S1,C1,C3,C4 | 22424h | 22424h | PRIOR | Telcordia | jgarraha@telcordia.com | Rel-8 | SP-34 | Alain |  |  |  |  |  |
| 827 | 274.1 | Service Requirements for PRIOR |  | 391d? | 2006-06-08 A | 2007-12-06 A | 100% | 2006-06-08 | 2007-12-06 | 391d? | finish no earlier than 2007-11-30 | S1 | 3128h | 3128h | PRIOR-EMR | Telcordia | jgarraha@telcordia.com | Rel-8 | SP-32 | Alain | 22.153 |  |  |  |  |
| 828 | 274.2 | Stage 3 for PRIOR |  | 732d? | 2006-12-01 A | 2009-09-18 A | 100% | 2006-12-01 | 2009-09-18 | 732d? | finish no earlier than 2009-09-18 | C1 | 5856h | 5856h | PRIOR | Alcatel-Lucent | Keith Drage (drage@alcatel-lucent.com) | Rel-8 | CP-34 | Frederic | 24.229 |  |  |  |  |
| 829 | 274.3 | Stage 3 for PRIOR |  | 381d? | 2007-09-21 A | 2009-03-06 A | 100% | 2007-09-21 | 2009-03-06 | 381d? | finish no earlier than 2009-03-06 | C4 | 3048h | 3048h | PRIOR | Alcatel-Lucent | Keith Drage (drage@alcatel-lucent.com) | Rel-8 | CP-37 | Kimmo | 23.008, 29.228, 29.229 |  |  |  |  |
| 830 | 274.4 | Deleted - Stage 3 for PRIOR |  | 441d? | 2007-09-21 A | 2009-05-29 A | 100% | 2007-09-21 | 2009-05-29 | 441d? | finish no earlier than 2009-05-29 | C3 | 3528h | 3528h | PRIOR | Alcatel-Lucent | Keith Drage (drage@alcatel-lucent.com) | Rel-8 | CP-37 | Gwiho | 29.212, 29.213, 29.214, 29.163 |  |  | PCG-23 | CP-44 |

Notes:
- 803: SP#43 Larger scope Feature UID_380057 (PWS) moved to Rel-9
- 804: SP#39 completed
- 805: SP#41 completed
- 806: CP#42 completed
- 807: CP#42 completed
- 808: SP#44 completed with CT1 help (GERAN2 LS_in SP-090154)
- 809: RP#47 completed. Testing for Rel-8 ETWS UID_370051
- 810: CP#43 completed (ICE Graphics not included in Rel-8)
- 811: SP#39 Stage 1 completed
- 812: CP#43 completed (ICE Graphics not in Rel-8 / not explicitly in SA1 WID either)
- 813: SP#39 Stage 1 completed
- 814: CP#45 completed
- 815: -
- 816: SP#38 completed
- 817: CP#42 completed
- 818: CP#45 completed. Triggered by Study UID_360031 (TR 29.882)
- 819: CP#43 completed. Triggered by Study UID_360031 (TR 29.882)
- 820: CP#42 completed. Triggered by Study UID_360031 (TR 29.882)
- 821: CP#43 completed
- 822: SP#35 completed
- 823: SP#39 completed
- 824: CP#43 completed
- 825: CP#42 completed
- 826: CP#45 completed
- 827: SP#38 completed
- 828: CP#45 completed
- 829: CP#43 completed
- 830: CP#44 stopped (Reason: No Rel-8 solution expected (LS sent to SA2, but not prioritized in SA2)

| ID | WBS | Task | Duration | Start | Finish | Complete | Baseline start | Baseline finish | Baseline duration | Total slack | Constraint | Resources | Work | Actual work | Text1 | Text4 | Text5 | Text6 | Text8 | Text3 | Text7 | Text2 | Text9 | Text12 |
| --- | --- | --- | --- | --- | --- | --- | --- | --- | --- | --- | --- | --- | --- | --- | --- | --- | --- | --- | --- | --- | --- | --- | --- | --- |
| 831 | 275 | **OSA Rel-8** | 202d? | 2007-08-23 A | 2008-05-30 A | 100% | 2007-08-23 | 2008-05-30 | 202d? |  |  | S1,C5 | 23552h | 23552h | OSA8 | Orange | Song Dong | Rel-8 | Alain |  |  |  |  |  |
| 832 | 275.1 | OSA Stage 1 - Service Requirements | 145d? | 2007-08-23 A | 2008-03-12 A | 100% | 2007-08-23 | 2008-03-12 | 145d? |  | finish no earlier than 2007-12-04 | S1 | 1160h | 1160h | OSA8 | Orange, AePONA | Song Dong | Rel-8 | Alain | 22.127 |  |  |  |  |
| 833 | 275.2 | OSA Stage 1 - NGN Service Requirement | 140d? | 2007-09-03 A | 2008-03-14 A | 100% | 2007-09-03 | 2008-03-14 | 140d? |  | finish no earlier than 2008-03-14 | S1 | 1120h | 1120h | OSA8-IMS | Orange | Song Dong | Rel-8 | Alain | 22.127 | SP-37 |  |  |  |
| 834 | 275.3 | **OSA Stage 2/3 enhancements** | 157d? | 2007-10-25 A | 2008-05-30 A | 100% | 2007-10-25 | 2008-05-30 | 157d? |  |  | C5 | 20016h | 20016h | OSA8 | Alcatel-Lucent | unmehopa@alcatel-lucent.com | Rel-8 | Kimmo | 23.198, 29.198, 29.199 |  |  |  |  |
| 835 | 275.3.1 | Deleted - Ensure Parlay-X composable with identity management frameworks, in particular Liberty Alliance | 157d? | 2007-10-25 A | 2008-05-30 A | 100% | 2007-10-25 | 2008-05-30 | 157d? |  | finish no earlier than 2008-12-25 | C5 | 1256h | 1256h | OSA8 | Ericsson, FT/Orange, Sprint, Telecom Italia | catherine.mulligan@ericsson.com | Rel-8 | Kimmo | existing 29.199-xy | CP-37 | PCG-21 | PCG-21 | CP-40 |
| 836 | 275.3.2 | Parlay-X Content Management web service (store/manage meta-data) | 157d? | 2007-10-25 A | 2008-05-30 A | 100% | 2007-10-25 | 2008-05-30 | 157d? |  | finish no earlier than 2008-12-04 | C5 | 1256h | 1256h | OSA8 | Alcatel-Lucent | unmehopa@alcatel-lucent.com | Rel-8 | Kimmo | 29.199-21 | CP-37 |  |  |  |
| 837 | 275.3.3 | Parlay-X Policy web service | 157d? | 2007-10-25 A | 2008-05-30 A | 100% | 2007-10-25 | 2008-05-30 | 157d? |  | finish no earlier than 2008-12-04 | C5 | 1256h | 1256h | OSA8 | Alcatel-Lucent | unmehopa@alcatel-lucent.com | Rel-8 | Kimmo | 29.199-22 | CP-37 |  |  |  |
| 838 | 275.3.4 | Parlay-X Terminal status web service | 157d? | 2007-10-25 A | 2008-05-30 A | 100% | 2007-10-25 | 2008-05-30 | 157d? |  | finish no earlier than 2008-05-30 | C5 | 1256h | 1256h | OSA8 | Alcatel-Lucent | unmehopa@alcatel-lucent.com | Rel-8 | Kimmo | 29.199-08 | CP-37 |  |  |  |
| 839 | 275.3.5 | Deleted - Identify communication format used by a particular application | 157d? | 2007-10-25 A | 2008-05-30 A | 100% | 2007-10-25 | 2008-05-30 | 157d? |  | finish no earlier than 2008-05-30 | C5 | 1256h | 1256h | OSA8 | Ericsson | catherine.mulligan@ericsson.com | Rel-8 | Kimmo | existing 29.199-xy | CP-37 | PCG-21 | PCG-21 | CP-40 |
| 840 | 275.3.6 | Deleted - Security on User Profile Management - reuse GUP API (22.127 CR 0084 S1-071794) | 128d? | 2007-12-05 A | 2008-05-30 A | 100% | 2007-12-05 | 2008-05-30 | 128d? |  | finish no earlier than 2008-12-25 | C5 | 1024h | 1024h | OSA8 | Telecom Italia | vincenzo.amorino@telecomitalia.it | Rel-8 | Kimmo | PXWS Framework | CP-38 | PCG-21 | PCG-21 | CP-40 |
| 841 | 275.3.7 | Deleted - Privacy on Subscriber Identity (Liberty Alliance, OASIS) (22.127 CR 0085 S1-071835) | 128d? | 2007-12-05 A | 2008-05-30 A | 100% | 2007-12-05 | 2008-05-30 | 128d? |  | finish no earlier than 2008-12-25 | C5 | 1024h | 1024h | OSA8 | Telecom Italia | vincenzo.amorino@telecomitalia.it | Rel-8 | Kimmo | PXWS Framework | CP-38 | PCG-21 | PCG-21 | CP-40 |
| 842 | 275.3.8 | Deleted - Topology Hiding (22.127 CR 0086 S1-071838) | 128d? | 2007-12-05 A | 2008-05-30 A | 100% | 2007-12-05 | 2008-05-30 | 128d? |  | finish no earlier than 2008-12-25 | C5 | 1024h | 1024h | OSA8 | Telecom Italia | vincenzo.amorino@telecomitalia.it | Rel-8 | Kimmo | PXWS Framework | CP-38 | PCG-21 | PCG-21 | CP-40 |
| 843 | 275.3.9 | Deleted - Subscriber event notification (22.127 CR 0087 S1-071836) | 128d? | 2007-12-05 A | 2008-05-30 A | 100% | 2007-12-05 | 2008-05-30 | 128d? |  | finish no earlier than 2008-12-25 | C5 | 1024h | 1024h | OSA8 | Telecom Italia | vincenzo.amorino@telecomitalia.it | Rel-8 | Kimmo | PXWS Framework | CP-38 | PCG-21 | PCG-21 | CP-40 |
| 844 | 275.3.10 | Deleted - Event notification (22.127 CR 0088 S1-071762) | 128d? | 2007-12-05 A | 2008-05-30 A | 100% | 2007-12-05 | 2008-05-30 | 128d? |  | finish no earlier than 2008-12-25 | C5 | 1024h | 1024h | OSA8 | Telecom Italia | vincenzo.amorino@telecomitalia.it | Rel-8 | Kimmo | PXWS Framework | CP-38 | PCG-21 | PCG-21 | CP-40 |
| 845 | 275.3.11 | Deleted - Access policy (22.127 CR 0089 S1-071763) | 128d? | 2007-12-05 A | 2008-05-30 A | 100% | 2007-12-05 | 2008-05-30 | 128d? |  | finish no earlier than 2008-12-25 | C5 | 1024h | 1024h | OSA8 | Telecom Italia | vincenzo.amorino@telecomitalia.it | Rel-8 | Kimmo | PXWS Framework | CP-38 | PCG-21 | PCG-21 | CP-40 |
| 846 | 275.3.12 | Deleted - API usage accounting (22.127 CR 0090 S1-071792) | 128d? | 2007-12-05 A | 2008-05-30 A | 100% | 2007-12-05 | 2008-05-30 | 128d? |  | finish no earlier than 2008-12-25 | C5 | 1024h | 1024h | OSA8 | Telecom Italia | vincenzo.amorino@telecomitalia.it | Rel-8 | Kimmo | PXWS Framework | CP-38 | PCG-21 | PCG-21 | CP-40 |
| 847 | 275.3.13 | Presence alignment with OMA and IETF (22.127 CR 0092 S1-071764) | 128d? | 2007-12-05 A | 2008-05-30 A | 100% | 2007-12-05 | 2008-05-30 | 128d? |  | finish no earlier than 2008-05-30 | C5 | 1024h | 1024h | OSA8 | Alcatel-Lucent | unmehopa@alcatel-lucent.com | Rel-8 | Kimmo | 29.199-14/13 | CP-38 | PCG-21 |  |  |
| 848 | 275.3.14 | Deleted - Service identification (22.127 CR 0095 S1-071837) | 128d? | 2007-12-05 A | 2008-05-30 A | 100% | 2007-12-05 | 2008-05-30 | 128d? |  | finish no earlier than 2008-05-30 | C5 | 1024h | 1024h | OSA8 | Ericsson | catherine.mulligan@ericsson.com | Rel-8 | Kimmo | existing 29.199-xy | CP-38 | PCG-21 | PCG-21 | CP-40 |
| 849 | 275.3.15 | Framework Enterprise Operator (Service Subscription function) | 102d? | 2008-01-10 A | 2008-05-30 A | 100% | 2008-01-10 | 2008-05-30 | 102d? |  | finish no earlier than 2008-05-30 | C5 | 816h | 816h | OSA8 | Alcatel-Lucent | unmehopa@alcatel-lucent.com | Rel-8 | Kimmo | 29.198-03 | CP-39 | PCG-21 |  |  |
| 850 | 275.3.16 | Mobility Emergency Location | 102d? | 2008-01-10 A | 2008-05-30 A | 100% | 2008-01-10 | 2008-05-30 | 102d? |  | finish no earlier than 2008-05-30 | C5 | 816h | 816h | OSA8 | Alcatel-Lucent | unmehopa@alcatel-lucent.com | Rel-8 | Kimmo | 29.198-06 | CP-39 | PCG-21 |  |  |
| 851 | 275.3.17 | Connectivity Manager SCF | 102d? | 2008-01-10 A | 2008-05-30 A | 100% | 2008-01-10 | 2008-05-30 | 102d? |  |  | C5 | 816h | 816h | OSA8 | Alcatel-Lucent | unmehopa@alcatel-lucent.com | Rel-8 | Kimmo | 29.198-10 | CP-39 | PCG-21 |  |  |
| 852 | 275.3.18 | PAM Presence Agent | 102d? | 2008-01-10 A | 2008-05-30 A | 100% | 2008-01-10 | 2008-05-30 | 102d? |  | finish no earlier than 2008-05-30 | C5 | 816h | 816h | OSA8 | Alcatel-Lucent | unmehopa@alcatel-lucent.com | Rel-8 | Kimmo | 29.198-14 | CP-39 | PCG-21 |  |  |
| 853 | 276 | **Paging Permission with Access Control (PPACR)** | 389d? | 2007-06-12 A | 2008-12-05 A | 100% | 2007-06-12 | 2008-12-05 | 389d? |  |  | S1,C1 | 5888h | 5888h | PPACR | NTT DoCoMo | Morita Takashi | Rel-8 | Alain |  |  |  |  |  |
| 854 | 276.1 | Stage 1 for PPACR | 69d? | 2007-06-12 A | 2007-09-14 A | 100% | 2007-06-12 | 2007-09-14 | 69d? |  | finish no earlier than 2007-09-14 | S1 | 552h | 552h | PPACR-S1 | NTT DoCoMo | Morita Takashi | Rel-8 | Alain | 22.011 | SP-37 |  |  |  |
| 855 | 276.2 | Stage 3 for PPACR (CT1) | 278d? | 2007-11-14 A | 2008-12-05 A | 100% | 2007-11-14 | 2008-12-05 | 278d? |  | finish no earlier than 2008-12-05 | C1 | 2224h | 2224h | PPACR-CT1 | NTT DoCoMo |  | Rel-8 | Frederic | 24.008, 23.122, 24.301 | CP-38 | PCG-21 |  |  |
| 856 | 277 | Conformance Test Aspects – Paging Permission with Access Control (PPAC) | 196d? | 2010-09-17 | 2011-06-17 |  | 2010-09-17 | 2011-06-17 | 196d? | 290.8d | finish no earlier than 2011-06-17 | R5 | 1568h |  | PPAC_UEConTest | NTT DoCoMo | Takao.Shimizu.rp@nttdocomo.com | Rel-8 | Ingbert | UTRA 34.108, 34.123-1, 34.123-2, 34.123-3 | RP-49 | PCG-25 |  |  |

Notes:
- 831: SP#40 maintenance & new OSA work moved to OMA. Rel-9 onwards 3GPP references to 22.127 changed to OMA Parlay Service Access Requirements (OMA-RD-Parlay_Service_Access-V1_0-20100427-A).
- 832: SP#40 maintenance & new OSA work moved to OMA. Rel-9 onwards 3GPP references to 22.127 changed to OMA Parlay Service Access Requirements (OMA-RD-Parlay_Service_Access-V1_0-20100427-A).
- 833: SP#40 maintenance & new OSA work moved to OMA
- 834: SP#40 maintenance & new OSA work moved to OMA
- 835: CP#40: Work moved to OMA
- 836: CP#40 completed
- 837: CP#40 completed
- 838: CP#40 completed
- 839: CP#40: Work moved to OMA
- 840: SP#38 SP-070853 R8 CRs 22.127 OSA Stage 1. CP#40: Work moved to OMA
- 841: SP#38 SP-070853 R8 CRs 22.127 OSA Stage 1. CP#40: Work moved to OMA
- 842: SP#38 SP-070853 R8 CRs 22.127 OSA Stage 1. CP#40: Work moved to OMA
- 843: SP#38 SP-070853 R8 CRs 22.127 OSA Stage 1. CP#40: Work moved to OMA
- 844: SP#38 SP-070853 R8 CRs 22.127 OSA Stage 1. CP#40: Work moved to OMA
- 845: SP#38 SP-070853 R8 CRs 22.127 OSA Stage 1. CP#40: Work moved to OMA
- 846: SP#38 SP-070853 R8 CRs 22.127 OSA Stage 1. CP#40: Work moved to OMA
- 847: CP#40 completed
- 848: SP#38 SP-070853 R8 CRs 22.127 OSA Stage 1. CP#40: Work moved to OMA
- 849: CP#40 completed
- 850: CP#40 completed
- 851: CP#40 completed
- 852: CP#40 completed
- 853: CP#42 completed. Triggered by Study UID_330016 (PPAC).
- 854: SP#37 completed
- 855: CP#42 completed
- 856: UTRA

| ID | WBS | Task | Duration | Start | Finish | Complete | Baseline start | Baseline finish | Baseline duration | Constraint | Resources | Work | Actual work | Text1 | Text2 | Text4 | Text6 | Text7 | Text8 | Text11 |
| --- | --- | --- | --- | --- | --- | --- | --- | --- | --- | --- | --- | --- | --- | --- | --- | --- | --- | --- | --- | --- |
| 857 | 278 | **Charging for multi-phases services** | 70d? | 2007-12-06 A | 2008-03-12 A | 100% | 2007-12-06 | 2008-03-12 | 70d? |  | S1 | 560h | 560h | CHRGMPH | PCG-21 | Telecom Italia | Rel-8 | SP-38 | Alain |  |
| 858 | 278.1 | Stage 1 for CHRGMPH | 70d? | 2007-12-06 A | 2008-03-12 A | 100% | 2007-12-06 | 2008-03-12 | 70d? | start no earlier than 2007-12-06 | S1 | 560h | 560h | CHRGMPH-s1 | PCG-21 | Telecom Italia | Rel-8 | SP-38 | Alain |  |
| 859 | 279 | **Home NodeB / eNodeB** | 327d? | 2007-12-06 A | 2009-03-06 A | 100% | 2007-12-06 | 2009-03-06 | 327d? |  | S1,C1,C4 | 5720h | 5720h | HomeNB | PCG-21 | Vodafone | Rel-8 | SP-38 | Alain |  |
| 860 | 279.1 | Stage 1 for HNB_eHNB | 70d? | 2007-12-06 A | 2008-03-12 A | 100% | 2007-12-06 | 2008-03-12 | 70d? | start no earlier than 2007-12-06 | S1 | 560h | 560h | HomeNB-S1 | PCG-21 | Vodafone | Rel-8 | SP-38 | Alain |  |
| 861 | 279.2 | Support of Closed Subscriber Group (CSG) | 66d? | 2008-12-05 A | 2009-03-06 A | 100% | 2008-12-05 | 2009-03-06 | 66d? | finish no earlier than 2009-03-06 | C4 | 528h | 528h | HomeNB | PCG-22 | CT#42 | Rel-8 | CP-42 | Kimmo |  |
| 862 | 279.3 | CSG and Idle Mode Mobility for LTE Home eNodeB | 126d? | 2008-09-12 A | 2009-03-06 A | 100% | 2008-09-12 | 2009-03-06 | 126d? | finish no earlier than 2009-03-06 | C1 | 1008h | 1008h | HomeNB-LTE | PCG-21 | Huawei | Rel-8 | CP-41 | Frederic |  |
| 863 | 279.4 | CSG and Idle Mode Mobility for 3G Home NodeB | 126d? | 2008-09-12 A | 2009-03-06 A | 100% | 2008-09-12 | 2009-03-06 | 126d? | finish no earlier than 2009-03-06 | C1 | 1008h | 1008h | HomeNB-3G | PCG-21 | Qualcomm | Rel-8 | CP-41 | Frederic |  |
| 864 | 280 | **UTRA HNB** | 326d? | 2008-03-07 A | 2009-06-04 A | 100% | 2008-03-07 | 2009-06-04 | 326d? |  | RP,S5 | 6832h | 6832h | HNB | PCG-21 |  | Rel-8 | SP-39 | Issam |  |
| 865 | 280.1 | Support of UTRA HNB | 201d? | 2008-05-30 A | 2009-03-06 A | 100% | 2008-05-30 | 2009-03-06 | 201d? | finish no earlier than 2009-03-06 | R2 | 1608h | 1608h | HNB-supp | PCG-21 | Huawei | Rel-8 | SP-40 | Joern | RP-090040 |
| 866 | 280.2 | UTRAN Architecture for 3G HNB | 136d? | 2008-05-30 A | 2008-12-05 A | 100% | 2008-05-30 | 2008-12-05 | 136d? | finish no earlier than 2008-12-05 | R3 | 1088h | 1088h | HNB-arch | PCG-21 | Alcatel-Lucent | Rel-8 | SP-40 | Juha | RP-090042 |
| 867 | 280.3 | FDD Home NodeB RF requirements | 261d? | 2008-03-07 A | 2009-03-06 A | 100% | 2008-03-07 | 2009-03-06 | 261d? | finish no earlier than 2009-03-06 | R4 | 2088h | 2088h | HNB-RF | PCG-21 | Motorola | Rel-8 | SP-39 | Issam | RP-090041 |
| 868 | 280.4 | 3G Home NodeB OAM&P Type 1 Management Interface | 127d? | 2008-12-11 A | 2009-06-04 A | 100% | 2008-12-11 | 2009-06-04 | 127d? | finish no earlier than 2009-06-04 | S5 | 1008h | 1008h | HNB-3G_OAM | PCG-22 | Huawei | Rel-8 | SP-42 | Dionisio |  |
| 869 | 281 | **UTRA HNB – UE Conformance Testing** | 327d? | 2009-03-06 A | 2010-06-04 A | 100% | 2009-03-06 | 2010-06-04 | 327d? |  | R5 | 5224h | 5224h | HNB-UEConTest | PCG-22 |  | Rel-8 | RP-43 | Ingbert |  |
| 870 | 281.1 | Conformance Test Aspects – UTRA HNB (FDD) | 326d? | 2009-03-06 A | 2010-06-04 A | 100% | 2009-03-06 | 2010-06-04 | 326d? | finish no earlier than 2010-06-04 | R5 | 2608h | 2608h | HNB-UEConTestFDD | PCG-22 | Huawei | Rel-8 | RP-43 | Ingbert | RP-100482 |
| 871 | 282 | Lawful Interception in the 3GPP Rel-8 | 524d? | 2007-03-12 A | 2009-03-12 A | 100% | 2007-03-12 | 2009-03-12 | 524d? | finish no earlier than 2009-03-12 | S3 | 4192h | 4192h | LI8 |  | BMWI, Verizon | Rel-8 |  | Dionisio |  |
| 872 | 283 | **Generic Bootstrapping Architecture Push Function** | 258d? | 2008-03-12 A | 2009-03-06 A | 100% | 2008-03-12 | 2009-03-06 | 258d? |  | S3,C1,C4 | 6468.8h | 6468.8h | GBAPush | PCG-21 | Ericsson | Rel-8 | SP-39 | Dionisio |  |
| 873 | 283.1 | SA3 part of GBAPush (33.223) | 193d? | 2008-03-12 A | 2008-12-05 A | 100% | 2008-03-12 | 2008-12-05 | 193d? | finish no earlier than 2008-12-05 | S3 | 1544h | 1544h | GBAPush | PCG-21 | Ericsson | Rel-8 | SP-39 | Dionisio |  |
| 874 | 283.2 | CT1 part of GBAPush | 178.8d? | 2008-03-12 A | 2009-03-06 A | 100% | 2008-03-12 | 2009-03-06 | 178.8d? | finish no earlier than 2009-03-06 | C1 | 1430.4h | 1430.4h | GBAPush | PCG-21 | Ericsson | Rel-8 | SP-39 | Frederic |  |
| 875 | 283.3 | CT4 part of GBAPush | 178.8d? | 2008-03-12 A | 2009-03-06 A | 100% | 2008-03-12 | 2009-03-06 | 178.8d? | finish no earlier than 2009-03-06 | C4 | 1430.4h | 1430.4h | GBAPush | PCG-21 | Ericsson | Rel-8 | SP-39 | Kimmo |  |
| 876 | 284 | Requirements and Test methods for Wideband Terminals | 197d? | 2008-03-12 A | 2008-12-11 A | 100% | 2008-03-12 | 2008-12-11 | 197d? | start no earlier than 2008-03-12 | S4 | 1576h | 1576h | RETEM_WB_T |  | FT, Ericsson | Rel-8 |  | Paolo |  |
| 877 | 285 | Extending PSS and MBMS User Services for optimized Mobile TV | 266d? | 2007-12-06 A | 2008-12-11 A | 100% | 2007-12-06 | 2008-12-11 | 266d? | finish no earlier than 2008-12-11 | S4 | 2128h | 2128h | PSS_MBMS_OMTV |  | Ericsson | Rel-8 |  | Paolo |  |
| 878 | 286 | **Encoding formats, transport formats and media description signalling for interworking, QoE, and other enhancements to MTSI-MHI** | 331d? | 2007-12-06 A | 2009-03-12 A | 100% | 2007-12-06 | 2009-03-12 | 331d? |  | S4,C3,C4 | 9640h | 9640h | MTSI_eMHI | PCG-21 | Ericsson, Qualcomm | Rel-8 | SP-40 | Paolo |  |
| 879 | 286.1 | MTSI Video - Dynamic Rate Adaptation/Signalling of Image Size | 331d? | 2007-12-06 A | 2009-03-12 A | 100% | 2007-12-06 | 2009-03-12 | 331d? | finish no earlier than 2009-03-12 | S4 | 2648h | 2648h | MTSI_eMHI-DRASIS |  | Qualcomm, Samsung | Rel-8 |  | Paolo |  |
| 880 | 286.2 | CT3 part of Enhancement of interworking between MTSI and CS networks | 201d? | 2008-05-30 A | 2009-03-06 A | 100% | 2008-05-30 | 2009-03-06 | 201d? | finish no earlier than 2009-03-06 | C3 | 1608h | 1608h | MTSI_eMHI | PCG-21 | Huawei | Rel-8 | CP-40 | Gwiho |  |
| 881 | 286.3 | CT4 part of Enhancement of interworking between MTSI and CS networks | 201d? | 2008-05-30 A | 2009-03-06 A | 100% | 2008-05-30 | 2009-03-06 | 201d? | finish no earlier than 2009-03-06 | C4 | 1608h | 1608h | MTSI_eMHI | PCG-21 | Huawei | Rel-8 | CP-40 | Kimmo |  |
| 882 | 286.4 | Deleted - CT1 part of Enhancement of interworking between MTSI and CS networks | 141d? | 2008-05-30 A | 2008-12-12 A | 100% | 2008-05-30 | 2008-12-12 | 141d? | start no earlier than 2008-05-30 | C1 | 1128h | 1128h | MTSI_eMHI | PCG-21 | Huawei | Rel-8 | CP-40 | Frederic |  |

Notes:
- 857: SP#39 Stage 1 completed / Text3: 22.115 / Text5: Marco.DeLuca1@telecomitalia.it
- 858: SP#39 completed / Text3: 22.115 / Text5: Marco.DeLuca1@telecomitalia.it
- 859: CP#43 completed / Text5: John Watson
- 860: SP#39 completed / Text3: 22.011, 22.115 / Text5: John Watson
- 861: CP#43 completed. SP#42 SP-080874 22.011CR0141 confirmed Requirement to support roaming subscribers with CSG home network subscription but did NOT confirmed requirement for home network independent support of roamers in CSG / Text3: 29.002, 29.272, 23.008, 23.003 / Text5: Hannu Hietalahti
- 862: CP#43 completed / Text3: 23.122, new (24.285, 24.301, 24.801) / Text5: zhang.peng@huawei.com
- 863: CP#43 completed / Text3: 23.122, 24.008, new 24.285 / Text5: Osok Song
- 864: SP#44 completed
- 865: RP#43 completed / Text3: 25.304, 25.306, 25.331, new 25.367 / Text5: Yang Xudong (yangxudong@huawei.com)
- 866: RP#42 completed / Text3: 25.401, 25.410, 25.412, 25.413, 25.414, 25.415, new (25.467, 25.468, 25.469) / Text5: Martin Warner (mw15@alcatel-lucent.com)
- 867: RP#43 completed / Text3: 25.104, 25.141, new 25.967 / Text5: Ying Cai (yingcai@motorola.com)
- 868: SP#44 completed. Complements work in BroadBand Forum / Text3: new (32.581, 32.582, 32.583, 32.584) / Text5: Zou Lan (zlan@huawei.com)
- 869: RP#48 FDD completed. Testing for Feature UID_390033 UTRA HNB
- 870: RP#48 completed / Text3: 34.108, 34.123-1, 34.123-2, 34.123-3 / Text5: Trica Li (trica_li@huawei.com)
- 871: SP#43 completed / Text3: 33.106, 33.107, 33.108 / Text5: berthold.wilhelm@bnetza.de, ron_ryan@verizon.net
- 872: CP#43 completed / Text5: Rolf Blom
- 873: SP#42 completed 33.223 as Rel-8. TS 33.224 moved to Rel-9 under new UID_420039 / Text3: 33.223 / Text5: Rolf Blom
- 874: CP#43 completed / Text3: 24.109 / Text5: Rolf Blom
- 875: CP#43 completed / Text3: 29.109 / Text5: Rolf Blom
- 876: SP#42 completed. SP#39 WID approved. / Text3: 26.131, 26.132 / Text5: stephane.ragot@orange-ftgroup.com, wanqing.shi@sonyericsson.com
- 877: SP#42 completed. SP#38 WID approved. / Text3: 26.234, 26.346, 26.946 / Text5: thorsten.lohmar@ericsson.com
- 878: TSG#43 completed / Text5: olle.franceschi@ericsson.com, nleung@qualcomm.com
- 879: SP#43 completed / Text3: 26.114 / Text5: nleung@qualcomm.com & kyunghun.jung@samsung.com
- 880: CP#43 completed / Text3: 29.163 / Text5: Tingfang Tang (tagna_online@huawei.com)
- 881: CP#43 completed / Text3: 29.332 / Text5: Tingfang Tang (tagna_online@huawei.com)
- 882: CP#42 stopped (No CT1-impact). WID updated CP-080422=>CP-080774 / Text5: Tingfang Tang (tagna_online@huawei.com)

| ID | WBS | Task | Duration | Start | Finish | Complete | Baseline start | Baseline finish | Baseline duration | Constraint | Resources | Work | Actual work | Text1 | Text6 | Text8 | Text4 | Text2 | Text7 | Text9 | Text12 |
| --- | --- | --- | --- | --- | --- | --- | --- | --- | --- | --- | --- | --- | --- | --- | --- | --- | --- | --- | --- | --- | --- |
| 883 | 287 | **OAM&P 8** | 653d? | 2007-06-07 A | 2009-12-04 A | 100% | 2007-06-07 | 2009-12-04 | 653d? |  | S5,C1,C4 | 44177.6h | 44177.6h | OAM8 | Rel-8 | Dionisio |  |  |  |  |  |
| 884 | 287.1 | **Network Infrastructure Management** | 653d? | 2007-06-07 A | 2009-12-04 A | 100% | 2007-06-07 | 2009-12-04 | 653d? |  | S5 | 19464h | 19464h | OAM8-NIM | Rel-8 | Dionisio |  |  |  |  |  |
| 885 | 287.1.1 | Telecom Management Methodology | 461d? | 2007-06-07 A | 2009-03-12 A | 100% | 2007-06-07 | 2009-03-12 | 461d? | finish no earlier than 2009-03-12 | S5 | 3688h | 3688h | OAM8 | Rel-8 | Dionisio | Ericsson |  |  |  |  |
| 886 | 287.1.2 | Advanced Alarming on Itf-N | 266d? | 2007-06-07 A | 2008-06-12 A | 100% | 2007-06-07 | 2008-06-12 | 266d? | finish no earlier than 2008-12-11 | S5 | 2128h | 2128h | OAM8 | Rel-8 | Dionisio | Nokia Siemens Networks |  |  |  |  |
| 887 | 287.1.3 | CN CS Bearer Transport Network (BTN) relative NRM | 266d? | 2007-06-07 A | 2008-06-12 A | 100% | 2007-06-07 | 2008-06-12 | 266d? | finish no earlier than 2008-12-11 | S5 | 2128h | 2128h | OAM8 | Rel-8 | Dionisio | China Mobile |  |  |  |  |
| 888 | 287.1.4 | Alignment with eTOM and M.3060 architectural concepts | 210d? | 2008-02-22 A | 2008-12-11 A | 100% | 2008-02-22 | 2008-12-11 | 210d? | start no earlier than 2008-02-22 | S5 | 1680h | 1680h | OAM8 | Rel-8 | Dionisio | TeliaSonera | PCG-21 | SP-39 |  |  |
| 889 | 287.1.5 | IRP SOAP Solution Sets | 201d? | 2008-06-05 A | 2009-03-12 A | 100% | 2008-06-05 | 2009-03-12 | 201d? | finish no earlier than 2009-03-12 | S5 | 1608h | 1608h | OAM8 | Rel-8 | Dionisio | Ericsson | PCG-21 | SP-40 |  |  |
| 890 | 287.1.6 | Create missing specifications for IRP XML definitions | 52d? | 2009-09-24 A | 2009-12-04 A | 100% | 2009-09-24 | 2009-12-04 | 52d? | finish no earlier than 2010-03-12 | S5 | 416h | 416h | OAM8 | Rel-8 | Dionisio | ZTE | PCG-23 | SP-45 |  |  |
| 891 | 287.1.7 | Deleted - End point modelling for reference point | 324d? | 2007-09-17 A | 2008-12-11 A | 100% | 2007-09-17 | 2008-12-11 | 324d? | finish no earlier than 2008-12-11 | S5 | 2592h | 2592h | OAM8 | Rel-8 | Dionisio | Motorola |  | SP-37 | PCG-21 | SP-41 |
| 892 | 287.2 | **Performance Management** | 461d? | 2007-06-07 A | 2009-03-12 A | 100% | 2007-06-07 | 2009-03-12 | 461d? |  | S5 | 13712h | 13712h | OAM8-PM | Rel-8 | Dionisio |  |  |  |  |  |
| 893 | 287.2.1 | IP bearer network Performance measurement definitions | 396d? | 2007-06-07 A | 2008-12-11 A | 100% | 2007-06-07 | 2008-12-11 | 396d? | finish no earlier than 2008-12-11 | S5 | 3168h | 3168h | OAM8 | Rel-8 | Dionisio | China Mobile |  |  |  |  |
| 894 | 287.2.2 | HSUPA performance measurements | 396d? | 2007-06-07 A | 2008-12-11 A | 100% | 2007-06-07 | 2008-12-11 | 396d? | finish no earlier than 2008-12-11 | S5 | 3168h | 3168h | OAM8 | Rel-8 | Dionisio | China Mobile |  |  |  |  |
| 895 | 287.2.3 | Key Performance Indicators (KPIs) for UMTS and GSM | 461d? | 2007-06-07 A | 2009-03-12 A | 100% | 2007-06-07 | 2009-03-12 | 461d? | finish no earlier than 2009-03-12 | S5 | 3688h | 3688h | OAM8 | Rel-8 | Dionisio | China Mobile |  |  |  |  |
| 896 | 287.3 | **Trace Management** | 196d? | 2008-03-07 A | 2008-12-05 A | 100% | 2008-03-07 | 2008-12-05 | 196d? |  | S5,C1,C3,C4 | 5777.6h | 5777.6h | OAM8-Trace | Rel-8 | Dionisio |  |  |  |  |  |
| 897 | 287.3.1 | Service Level Tracing in IMS | 196d? | 2008-03-07 A | 2008-12-05 A | 100% | 2008-03-07 | 2008-12-05 | 196d? | finish no earlier than 2008-12-05 | C1 | 1568h | 1568h | OAM8-Trace | Rel-8 | Frederic | Vodafone |  |  |  |  |
| 898 | 287.3.2 | Service Level Tracing in IMS | 175.4d? | 2008-03-07 A | 2008-12-05 A | 100% | 2008-03-07 | 2008-12-05 | 175.4d? | finish no earlier than 2008-12-05 | C4 | 1403.2h | 1403.2h | OAM8-Trace | Rel-8 | Frederic | Vodafone | PCG-21 | CP-40 |  |  |
| 899 | 287.3.3 | Deleted - Service Level Tracing in IMS | 175.4d? | 2008-03-07 A | 2008-12-05 A | 100% | 2008-03-07 | 2008-12-05 | 175.4d? | finish no earlier than 2008-12-05 | C3 | 1403.2h | 1403.2h | OAM8-Trace | Rel-8 | Gwiho | Vodafone | PCG-21 | CP-40 |  |  |
| 900 | 288 | **Charging Management small Enhancements** | 716d? | 2006-03-16 A | 2008-12-11 A | 100% | 2006-03-16 | 2008-12-11 | 716d? |  | S5 | 12544h | 12544h | CH8 | Rel-8 | Dionisio |  |  |  |  |  |
| 901 | 288.1 | Online charging correlation | 457d? | 2006-03-16 A | 2007-12-14 A | 100% | 2006-03-16 | 2007-12-14 | 457d? | start no earlier than 2006-03-16 | S5 | 3656h | 3656h | CH8 | Rel-8 | Dionisio | Orange |  |  |  |  |
| 902 | 288.2 | SMS online charging | 137d? | 2007-06-07 A | 2007-12-14 A | 100% | 2007-06-07 | 2007-12-14 | 137d? | finish no earlier than 2007-12-14 | S5 | 1096h | 1096h | CH8 | Rel-8 | Dionisio | Vodafone |  |  |  |  |
| 903 | 288.3 | Introduce Online Charging from SMS-SC into the SMS Charging Specifications | 61d? | 2008-09-18 A | 2008-12-11 A | 100% | 2008-09-18 | 2008-12-11 | 61d? | finish no earlier than 2008-12-11 | S5 | 488h | 488h | CH8 | Rel-8 | Dionisio | Acision | PCG-21 | SP-41 |  |  |
| 904 | 288.4 | Deleted - WLAN Offline Charging | 244d? | 2008-01-07 A | 2008-12-11 A | 100% | 2008-01-07 | 2008-12-11 | 244d? | finish no earlier than 2008-12-11 | S5 | 1952h | 1952h | CH8 | Rel-8 | Dionisio | Alcatel-Lucent | PCG-21 | SP-38 | PCG-22 | SP-42 |
| 905 | 289 | **Conferencing enhancements for Mp interface** | 266d? | 2007-11-30 A | 2008-12-05 A | 100% | 2007-11-30 | 2008-12-05 | 266d? |  | C4 | 6384h | 6384h | eMp | Rel-8 | Kimmo | Huawei | PCG-21 |  |  |  |
| 906 | 289.1 | Stage 2 for eMp | 266d? | 2007-11-30 A | 2008-12-05 A | 100% | 2007-11-30 | 2008-12-05 | 266d? | finish no earlier than 2008-12-11 | C4 | 2128h | 2128h | eMp | Rel-8 | Kimmo | Huawei | PCG-21 | CP-38 |  |  |
| 907 | 289.2 | Stage 3 for eMp | 266d? | 2007-11-30 A | 2008-12-05 A | 100% | 2007-11-30 | 2008-12-05 | 266d? | finish no earlier than 2008-12-05 | C4 | 2128h | 2128h | eMp | Rel-8 | Kimmo | Huawei | PCG-21 | CP-38 |  |  |

Notes:
- 883: - / Text3: TR 30.818
- 884: -
- 885: SP#43 completed / Text3: 32.155, 32.153 / Text5: thomas.tovinger@ericsson.com
- 886: SP#40 completed / Text3: 32.121, 32.122, 32.123 / Text5: SUERBAUM, Clemens
- 887: SP#40 completed / Text3: 32.632, 32.633, 32.635 / Text5: Li Jian (lijian@chinamobile.com)
- 888: SP#42 completed / Text3: 32.101/2, 32-series / Text5: tommy.berggren@teliasonera.com
- 889: SP#43 completed / Text3: 32.111-7, 32.617, 32.417, 32.367, 32.347, 32.111-1, 32.111-2, 32.111-3, 32.111-5, 32.307, 32.317, 32.341, 32.342, 32.343, 32.345, 32.361, 32.362, 32.363, 32.365, 32.411, 32.412, 32.413, 32.415, 32.611, 32.612, 32.613, 32.615, 32.625 / Text5: edwin.tse@ericsson.com
- 890: SP#46 completed. Create missing XML definitions specs for IRPs (Advanced Alarm Management, Communication Surveillance, Self-Configuration of Network Elements, Software Management) needed for implementation of Rel-8 Notification Log IRP (TS 32.33x) / Text3: new (32.125, 32.355, 32.505, 32.535), 32.150, 32.153, 32.335 / Text5: Shuqiang Huang (huangsq@zte.com.cn)
- 891: SP#41 Work stopped. Contributions related to E-UTRAN/EPC to be submitted to UID_380036 E-UTRAN NRM IRP/ UID_380037 EPC NRM IRP / Text3: 32.152, 32.62/3/4x, 32.73x / Text5: Yizhi Yao (yzyao@motorola.com)
- 892: - / Text5: Li Jian (lijian@chinamobile.com)
- 893: SP#42 completed / Text3: 32.321, 32.322, 32.323, 32.325 / Text5: lilianyuan@chinamobile.com
- 894: SP#42 completed / Text3: 32.405 / Text5: Li Jian (lijian@chinamobile.com)
- 895: SP#43 completed / Text3: 32.410 / Text5: Li Jian (lijian@chinamobile.com), Liang Shuangchun (liangshuangchun@cmdi.chinamobile.com)
- 896: -
- 897: CP#42 completed / Text3: 24.323, 24.229 / Text5: peter.dawes@vodafone.com
- 898: CP#42 completed / Text3: 29.228, 29.229 / Text5: peter.dawes@vodafone.com
- 899: CP#42 stopped (No CT3-impact) / Text5: peter.dawes@vodafone.com
- 900: SP#42 completed / Text3: TR 30.818
- 901: SP#38 completed / Text3: 32.296 / Text5: Chahine, Rony
- 902: SP#38 completed / Text3: 32.240, 32.299, new 32.274 / Text5: WONG, Gavin
- 903: SP#42 completed. Linked to SA2 UID 32081 (Support of SMS over IP networks) and CT4 UID 340016 (Routeing of MT-SMS via the HPLMN). / Text3: 32.274, 32.299 / Text5: Gebler, Erik - Acision [erik.gebler (at) acision.com]
- 904: SP#42 stopped / Text3: 32.252, 32.298, 32.299 / Text5: GARDELLA, Maryse
- 905: CP#42 completed / Text5: Chencheng@huawei.com
- 906: CP#42 completed / Text3: 23.333 / Text5: Chencheng@huawei.com
- 907: CP#42 completed / Text3: 29.333 / Text5: Chencheng@huawei.com

| ID | WBS | Task | Type | Duration | Start | Finish | Complete | Baseline start | Baseline finish | Baseline duration | Constraint | Resources | Work | Actual work | Text1 | Text4 | Text5 | Text6 | Text8 | Text7 | Text12 | Text11 | Text2 | Text9 |
| --- | --- | --- | --- | --- | --- | --- | --- | --- | --- | --- | --- | --- | --- | --- | --- | --- | --- | --- | --- | --- | --- | --- | --- | --- |
| 908 | 290 | **Contact Manager for 3GPP UICC applications** |  | 642d? | 2006-06-22 A | 2008-12-05 A | 100% | 2006-06-22 | 2008-12-05 | 642d? |  | C6 | 13352h | 13352h | eUPHBOOK | Gemalto | Jacques.seif@gemalto.com | Rel-8 | Xavier |  |  |  |  |  |
| 909 | 290.1 | Requirements for Contact Manager |  | 392d? | 2006-06-22 A | 2007-12-21 A | 100% | 2006-06-22 | 2007-12-21 | 392d? | finish no earlier than 2007-12-21 | C6 | 3136h | 3136h | eUPHBOOK-St1 | Gemalto | Jacques.seif@gemalto.com | Rel-8 | Xavier |  |  |  |  |  |
| 910 | 290.2 | External interface for eUPHBOOK |  | 220d? | 2007-05-07 A | 2008-03-07 A | 100% | 2007-05-07 | 2008-03-07 | 220d? | finish no earlier than 2008-03-07 | C6 | 1760h | 1760h | eUPHBOOK-Ext_Spec | Gemalto | Jacques.seif@gemalto.com | Rel-8 | Xavier |  |  |  |  |  |
| 911 | 290.3 | Internal interface for eUPHBOOK |  | 415d? | 2007-05-07 A | 2008-12-05 A | 100% | 2007-05-07 | 2008-12-05 | 415d? | finish no earlier than 2008-12-05 | C6 | 3320h | 3320h | eUPHBOOK-Int_Spec | Gemalto | Jacques.seif@gemalto.com | Rel-8 | Xavier | CP-37 |  |  |  |  |
| 912 | 290.4 | Deleted - Implementation of eUPHBOOK | milestone | 0d? | 2007-06-21 A | 2007-06-21 A | 100% | 2007-06-21 | 2007-06-21 | 0d? | start no earlier than 2007-06-21 | C6 |  |  | eUPHBOOK-St23 | Giesecke & Devrient | Claus Dietze | Rel-8 | Xavier |  | SP-33 |  |  |  |
| 913 | 291 | **Rel-8 LTE – 3G Long Term Evolution - Evolved Packet System RAN part** |  | 644d? | 2006-09-25 A | 2009-03-12 A | 100% | 2006-09-25 | 2009-03-12 | 644d? |  | RP,S5 | 44896h | 44896h | LTE | NTT DoCoMo | Takehiro Nakamura (nakamurata@nttdocomo.co.jp) | Rel-8 |  |  |  | RP-080741 |  |  |
| 914 | 291.1 | LTE – Physical Layer |  | 380d? | 2006-09-25 A | 2008-03-07 A | 100% | 2006-09-25 | 2008-03-07 | 380d? | finish no earlier than 2007-09-14 | R1 | 3040h | 3040h | LTE-Phys | NTT DoCoMo | Sadayuki Abeta | Rel-8 | Patrick |  |  | RP-080741 |  |  |
| 915 | 291.2 | LTE – Radio Interface Layer 2 and 3 Protocol Aspect |  | 575d? | 2006-09-25 A | 2008-12-05 A | 100% | 2006-09-25 | 2008-12-05 | 575d? | finish no earlier than 2008-12-11 | R2 | 4600h | 4600h | LTE-L23 | Nokia Siemens Networks | benoist.sebire@nokia.com | Rel-8 | Joern |  |  | RP-080741 |  |  |
| 916 | 291.3 | LTE – eUTRAN Interfaces |  | 575d? | 2006-09-25 A | 2008-12-05 A | 100% | 2006-09-25 | 2008-12-05 | 575d? | finish no earlier than 2008-12-11 | R3 | 4600h | 4600h | LTE-interfaces | Ericsson | Martin Israelsson | Rel-8 | Juha |  |  | RP-080741 |  |  |
| 917 | 291.4 | LTE – Evolved UTRA and UTRAN RF Radio Transmission/Reception, System Performance Requirements and Conformance Testing |  | 575d? | 2006-09-25 A | 2008-12-05 A | 100% | 2006-09-25 | 2008-12-05 | 575d? | finish no earlier than 2008-12-11 | R4 | 4600h | 4600h | LTE-RF | Nokia Siemens Networks | Tuomo Saynajakangas | Rel-8 | Issam |  |  | RP-080741 |  |  |
| 918 | 291.5 | LTE – FDD repeaters |  | 386d? | 2007-09-14 A | 2009-03-06 A | 100% | 2007-09-14 | 2009-03-06 | 386d? | finish no earlier than 2009-03-06 | R4 | 3088h | 3088h | LTE-Repeaters | Powerwave Technologies, Andrew Wireless | ralf.michanikl@andrew.com, Alf.Ahlstrom@pwav.com | Rel-8 | Issam | RP-37 |  | RP-090037 |  |  |
| 919 | 291.6 | **E-UTRAN Data Definitions** |  | 389d? | 2007-09-17 A | 2009-03-12 A | 100% | 2007-09-17 | 2009-03-12 | 389d? |  | S5 | 13096h | 13096h | E-UTRAN-OAM |  |  | Rel-8 | Dionisio | SP-39 |  |  | PCG-21 |  |
| 920 | 291.6.1 | Subscriber and Equipment Trace for E-UTRAN and EPC |  | 389d? | 2007-09-17 A | 2009-03-12 A | 100% | 2007-09-17 | 2009-03-12 | 389d? | finish no earlier than 2009-03-12 | S5 | 3112h | 3112h | E-UTRAN-OAM | Ericsson | robert.petersen@ericsson.com | Rel-8 | Dionisio | SP-37 |  |  |  |  |
| 921 | 291.6.2 | E-UTRAN Network Resource Model (NRM) Integration Reference Point (IRP) |  | 309d? | 2008-01-07 A | 2009-03-12 A | 100% | 2008-01-07 | 2009-03-12 | 309d? | finish no earlier than 2009-03-12 | S5 | 2472h | 2472h | E-UTRAN-OAM | Ericsson | ELMDAHL, Per | Rel-8 | Dionisio | SP-38 |  |  | PCG-21 |  |
| 922 | 291.6.3 | Performance measurements for E-UTRAN |  | 275d? | 2008-02-22 A | 2009-03-12 A | 100% | 2008-02-22 | 2009-03-12 | 275d? | finish no earlier than 2009-03-12 | S5 | 2200h | 2200h | E-UTRAN-OAM | Motorola, Huawei | Yizhi Yao (yzyao@motorola.com) | Rel-8 | Dionisio | SP-39 |  |  | PCG-21 |  |
| 923 | 291.6.4 | Key Performance Indicators (KPIs) for E-UTRAN |  | 275d? | 2008-02-22 A | 2009-03-12 A | 100% | 2008-02-22 | 2009-03-12 | 275d? | finish no earlier than 2009-03-12 | S5 | 2200h | 2200h | E-UTRAN-OAM | Ericsson | ulf.hubinette@ericsson.com | Rel-8 | Dionisio | SP-39 |  |  | PCG-21 |  |
| 924 | 291.7 | **Self-Organizing Networks (SON)** |  | 210d? | 2008-02-22 A | 2008-12-11 A | 100% | 2008-02-22 | 2008-12-11 | 210d? |  | S5 | 6720h | 6720h | LTE_SON-OAM | Vodafone | GOMPAKIS, Panagiotis | Rel-8 | Dionisio | SP-39 |  |  | PCG-21 |  |
| 925 | 291.7.1 | SON Concepts and requirements |  | 210d? | 2008-02-22 A | 2008-12-11 A | 100% | 2008-02-22 | 2008-12-11 | 210d? |  | S5 | 1680h | 1680h | LTE_SON-OAM | Vodafone | GOMPAKIS, Panagiotis | Rel-8 | Dionisio | SP-39 |  |  | PCG-21 |  |
| 926 | 291.7.2 | Self-Establishment of eNBs, including automated Software Management |  | 210d? | 2008-02-22 A | 2008-12-11 A | 100% | 2008-02-22 | 2008-12-11 | 210d? | start no earlier than 2008-02-22 | S5 | 1680h | 1680h | LTE_SON-OAM | Nokia Siemens Networks | SUERBAUM, Clemens | Rel-8 | Dionisio | SP-39 |  |  | PCG-21 |  |
| 927 | 291.7.3 | SON Automatic Neighbour Relations (ANR) List Management |  | 210d? | 2008-02-22 A | 2008-12-11 A | 100% | 2008-02-22 | 2008-12-11 | 210d? | finish no earlier than 2008-12-11 | S5 | 1680h | 1680h | LTE_SON-OAM | Ericsson | edwin.tse@ericsson.com | Rel-8 | Dionisio | SP-39 |  |  | PCG-21 |  |
| 928 | 292 | **Rel-8 LTE – Terminal Conformance Test Specification** |  | 657d? | 2007-06-01 A | 2009-12-04 A | 100% | 2007-06-01 | 2009-12-04 | 657d? |  | R5 | 14336h | 14336h | LTE-UEConTest |  |  | Rel-8 | Ingbert |  |  |  |  |  |
| 929 | 292.1 | 3G LTE – Terminal Protocol Conformance Test Specifications |  | 657d? | 2007-06-01 A | 2009-12-04 A | 100% | 2007-06-01 | 2009-12-04 | 657d? | finish no earlier than 2009-12-04 | R5 | 5256h | 5256h | LTE-UEConTest_SIG | NEC, Motorola | david.lecompte@nectech.fr, Jacob.John@motorola.com | Rel-8 | Ingbert |  |  | RP-091060 |  |  |
| 930 | 292.2 | LTE – Terminal Radio Transmission and Reception Conformance Test Specifications |  | 657d? | 2007-06-01 A | 2009-12-04 A | 100% | 2007-06-01 | 2009-12-04 | 657d? |  | R5 | 5256h | 5256h | LTE-UEConTest_RF | Agilent | andrea_leonardi@agilent.com | Rel-8 | Ingbert |  |  | RP-091059 |  |  |
| 931 | 293 | **Rel-8 Improvements of the Radio Interface** |  | 525d? | 2007-03-05 A | 2009-03-06 A | 100% | 2007-03-05 | 2009-03-06 | 525d? |  | RP | 18152h | 18152h | RInImp8 |  |  | Rel-8 | Issam |  |  |  |  |  |
| 932 | 293.1 | UMTS 1500 MHz |  | 140d? | 2007-03-05 A | 2007-09-14 A | 100% | 2007-03-05 | 2007-09-14 | 140d? | finish no earlier than 2007-09-14 | R4 | 1120h | 1120h | RInImp8-UMTS1500 | NTT DoCoMo | Takehiro Nakamura (nakamurata@nttdocomo.co.jp) | Rel-8 | Issam |  |  | RP-070526 |  |  |
| 933 | 293.2 | UMTS 700 MHz FDD |  | 325d? | 2007-03-05 A | 2008-05-30 A | 100% | 2007-03-05 | 2008-05-30 | 325d? | finish no earlier than 2008-06-12 | R4 | 2600h | 2600h | RInImp8-UMTS700 | Nokia | Tuomo Saynajakangas | Rel-8 | Issam |  |  | RP-080260 |  |  |
| 934 | 293.3 | UMTS 1880 MHz TDD |  | 126d? | 2008-09-12 A | 2009-03-06 A | 100% | 2008-09-12 | 2009-03-06 | 126d? | finish no earlier than 2009-03-09 | R4 | 1008h | 1008h | RInImp9-UMTS1880TDD | CATT | Yuexia Song (songyuexia@datangmobile.cn) | Rel-8 | Issam | RP-41 |  | RP-090044 | PCG-21 |  |
| 935 | 293.4 | UMTS 2300 MHz TDD LCR |  | 195d? | 2007-12-17 A | 2008-09-12 A | 100% | 2007-12-17 | 2008-09-12 | 195d? | finish no earlier than 2008-09-12 | R4 | 1560h | 1560h | RInImp8-UMTS2300TDD | CATT | songyuexia@datangmobile.cn | Rel-8 | Issam | RP-38 |  | RP-080517 | PCG-21 |  |
| 936 | 293.5 | Further Improved Minimum Performance Requirements for HSDPA UE (FDD) - Two-Branch Interference Cancellation |  | 265d? | 2007-03-05 A | 2008-03-07 A | 100% | 2007-03-05 | 2008-03-07 | 265d? | finish no earlier than 2008-03-12 | R4 | 2120h | 2120h | RInImp8-2BIC | AT&T | Marc Grant | Rel-8 | Issam |  |  | RP-080041 |  |  |
| 937 | 293.6 | CS Voice Service over HSPA |  | 167d? | 2007-07-19 A | 2008-03-07 A | 100% | 2007-07-19 | 2008-03-07 | 167d? |  | R2 | 1336h | 1336h | RInImp8-CsHspa | Nokia Siemens Networks | woonhee.hwang@nsn.com | Rel-8 | Joern | RP-37 |  | RP-080042 |  |  |
| 938 | 293.7 | Performance requirements for 15 code reception with 16QAM/QPSK (FDD) |  | 126d? | 2007-06-11 A | 2008-03-07 A | 100% | 2007-06-11 | 2008-03-07 | 126d? | finish no earlier than 2008-06-12 | R4 | 1008h | 1008h | RInImp8-Hsdpa15codes | Vodafone | tim.frost@vodafone.com | Rel-8 | Issam | RP-37 |  | RP-080043 |  |  |
| 939 | 293.8 | Deleted - UMTS 2300 MHz FDD/TDD |  | 400d? | 2007-03-05 A | 2008-09-12 A | 100% | 2007-03-05 | 2008-09-12 | 400d? | finish no earlier than 2008-12-11 | R4 | 3200h | 3200h | RInImp8-UMTS2300 | AT&T | Marc Grant | Rel-8 | Issam |  | RP-41 | RP-080515 |  | PCG-21 |

Notes:
- 908: CP#42 completed. CP#40: WID updated CP-070622=>CP-080382. aka Enhanced USIM phonebook
- 909: CP#38 completed / Text3: 21.111
- 910: CP#39 completed / Text3: new 31.220
- 911: CP#42 completed / Text3: new 31.221
- 912: SP#33 stopped / Text3: 31.102
- 913: RP#43 completed. Role model for SAE/LTE system wide project management by SA2 in SP-060166 / Text3: 36.300, 36.938
- 914: RP#39 completed / Text3: 36.201, 36.211, 36.212, 36.213, 36.214, 25.215, 25.225
- 915: RP#42 completed / Text3: 36.302, 36.304, 36.306, 36.314, 36.321, 36.322, 36.323, 36.331, 25.302, 25.304, 25.331
- 916: RP#42 completed / Text3: 36.401, 36.410, 36.411, 36.412, 36.413, 36.414, 36.420, 36.421, 36.422, 36.423, 36.424, 25.413
- 917: RP#42 completed. RP#47 abandoned draft 36.801, 36.803, 36.804 / Text3: 36.101, 36.104, 36.113, 36.124, 36.133, 36.141, 36.942, 25.123, 25.133
- 918: RP#43 completed. RP#47 create Rel-9 TR 36.956 (see R4-100386, RP-100320_RAN4 Report) / Text3: 36.106, 36.143, 25.113
- 919: SP#43 completed
- 920: SP#43 completed / Text3: 32.421, 2.422, 32.423, 2.441, 32.442, 32.443, 32.445
- 921: SP#43 completed / Text3: new (32.761, 32.762, 32.763, 32.765)
- 922: SP#43 completed / Text3: new 32.425
- 923: SP#43 completed / Text3: new (32.450, 32.451)
- 924: SP#42 completed (WT UID_390007 moved to Rel-9)
- 925: SP#42 completed / Text3: new 32.500
- 926: SP#42 completed / Text3: new (32.501, 32.502, 32.503, 32.531, 32.532, 32.533)
- 927: SP#42 completed / Text3: 32.761, 32.762, 32.763, 32.765, new 32.511
- 928: Testing for Feature UID_20068 (LTE)
- 929: RP#46 completed / Text3: 36.521-1, 36.521-2, 36.508, 36.509, 36.523-1, 36.523-2, 36.523-3
- 930: RP#46 completed / Text3: 36.521-1, 36.521-2, 36.521-3
- 931: -
- 932: RP#37 completed / Text3: 25.101, 25.104, 25.133, 25.141, 25.331, 25.942, 25.306, 25.307, 34.121
- 933: RP#40 completed / Text3: 25.101, 25.104, 25.133, 25.141, 25.331, 25.942, 25.306, 25.307, 34.121
- 934: RP#43 completed / Text3: 25.102, 25.105, 25.113, 25.123, 25.142, 34.124, 25.307
- 935: RP#41 completed. RP#47 abandoned draft 25.828 / Text3: 25.102, 25.105, 25.113, 25.123, 25.142, 34.124, 25.306, 25.331, 34.122
- 936: RP#39 completed / Text3: 25.101
- 937: RP#39 completed / Text3: 25.323, 25.331, 25.322
- 938: RP#39 completed / Text3: 25.101
- 939: RP#41 stopped / Text3: 25.101, 25.104, 25.133, 25.141, 25.331, 25.942, 25.306, 25.307, 34.121

| ID | WBS | Task | Duration | Start | Finish | Complete | Baseline start | Baseline finish | Baseline duration | Constraint | Resources | Work | Actual work | Text1 | Text6 | Text8 | Text4 | Text5 | Text11 | Text2 | Text7 |
| --- | --- | --- | --- | --- | --- | --- | --- | --- | --- | --- | --- | --- | --- | --- | --- | --- | --- | --- | --- | --- | --- |
| 940 | 294 | **Rel-8 Improvements of the Radio Interface - UE Conformance Testing** | 396d? | 2007-06-01 A | 2008-12-05 A | 100% | 2007-06-01 | 2008-12-05 | 396d? |  | R5 | 6256h | 6256h | RInImp-UEConTest | Rel-8 | Ingbert |  |  |  |  |  |
| 941 | 294.1 | Conformance Test Aspects – CS Voice Service over HSPA | 336d? | 2007-06-01 A | 2008-09-12 A | 100% | 2007-06-01 | 2008-09-12 | 336d? | finish no earlier than 2008-09-12 | R5 | 2688h | 2688h | RInImp8-CsHspa_UEConTest | Rel-8 | Ingbert | Huawei | baoyi@huawei.com | RP-080542 |  |  |
| 942 | 294.2 | Conformance Test Aspects – Performance requirements for 15 code reception with 16QAM/QPSK (FDD) | 195d? | 2008-03-07 A | 2008-12-05 A | 100% | 2008-03-07 | 2008-12-05 | 195d? | finish no earlier than 2008-12-05 | R5 | 1560h | 1560h | RInImp8-UEConTest_ Hsdpa15codes | Rel-8 | Ingbert | Ericsson | Mikael.Ziren@Ericsson.com | RP-080818 | PCG-21 | RP-40 |
| 943 | 295 | **Rel-8 RAN improvements** | 520d? | 2007-06-04 A | 2009-05-29 A | 100% | 2007-06-04 | 2009-05-29 | 520d? |  | RP | 29776h | 29776h | RANimp | Rel-8 |  |  |  |  |  |  |
| 944 | 295.1 | Combination of 64QAM and MIMO for HSDPA (FDD) | 205d? | 2007-06-04 A | 2008-09-12 A | 100% | 2007-06-04 | 2008-09-12 | 205d? | finish no earlier than 2008-09-12 | R1 | 1640h | 1640h | RANimp-64QamMimoHsdpa | Rel-8 | Patrick | Ericsson | Johan.Bergman@ericsson.com | RP-080518 |  |  |
| 945 | 295.2 | Improved L2 for uplink | 186d? | 2007-09-14 A | 2008-05-30 A | 100% | 2007-09-14 | 2008-05-30 | 186d? | finish no earlier than 2008-05-30 | R2 | 1488h | 1488h | RANimp-UplinkL2dataRates | Rel-8 | Joern | Ericsson | Janne.Peisa@ericsson.com | RP-080265 |  | RP-37 |
| 946 | 295.3 | Enhanced Uplink for CELL_FACH State in FDD | 321d? | 2007-09-14 A | 2008-12-05 A | 100% | 2007-09-14 | 2008-12-05 | 321d? | finish no earlier than 2008-12-12 | R2 | 2568h | 2568h | RANimp-UplinkEnhState | Rel-8 | Joern | Nokia Siemens Networks | markus.wimmer@nsn.com | RP-080804 |  | RP-37 |
| 947 | 295.4 | Enhanced UE Discontinuous Reception (DRX) for FDD | 261d? | 2007-09-14 A | 2008-09-12 A | 100% | 2007-09-14 | 2008-09-12 | 261d? | finish no earlier than 2008-09-12 | R2 | 2088h | 2088h | RANimp-DRX | Rel-8 | Joern | Nokia | luis.barreto@nokia.com | RP-080520 |  | RP-37 |
| 948 | 295.5 | Enhancements for Serving Radio Network Subsystem (SRNS) Relocation Procedure | 261d? | 2007-09-14 A | 2008-09-12 A | 100% | 2007-09-14 | 2008-09-12 | 261d? | finish no earlier than 2008-09-12 | R3 | 2088h | 2088h | RANimp-SrnsReloc | Rel-8 | Juha | Nokia Siemens Networks | masatoshi.nakamata@nsn.com | RP-080521 |  | RP-37 |
| 949 | 295.6 | Enhancements for FDD HSPA Evolution | 321d? | 2007-09-14 A | 2008-12-05 A | 100% | 2007-09-14 | 2008-12-05 | 321d? | finish no earlier than 2008-12-05 | R3,R2 | 2568h | 2568h | RANimp-HSPAEvo | Rel-8 | Juha | Nokia Siemens Networks | masatoshi.nakamata@nsn.com | RP-080805 |  | RP-37 |
| 950 | 295.7 | 64QAM for 1.28 Mcps TDD HSDPA | 264d? | 2007-12-04 A | 2008-12-05 A | 100% | 2007-12-04 | 2008-12-05 | 264d? | finish no earlier than 2008-12-05 | R1 | 2112h | 2112h | RANimp-64Qam1.28TDD | Rel-8 | Patrick | ZTE | zfmail@zte.com.cn | RP-080806 | PCG-21 | RP-38 |
| 951 | 295.8 | Enhanced CELL_FACH state in 1.28 Mcps TDD | 264d? | 2007-12-04 A | 2008-12-05 A | 100% | 2007-12-04 | 2008-12-05 | 264d? | finish no earlier than 2008-12-12 | R2 | 2112h | 2112h | RANimp-EnhState1.28TDD | Rel-8 | Joern | ZTE | zhang.yincheng@zte.com.cn | RP-080807 | PCG-21 | RP-38 |
| 952 | 295.9 | Continuous Connectivity for packet data users for 1.28 Mcps TDD | 321d? | 2008-03-07 A | 2009-05-29 A | 100% | 2008-03-07 | 2009-05-29 | 321d? | finish no earlier than 2009-05-29 | R1 | 2568h | 2568h | RANimp-LCRCPC | Rel-8 | Patrick | TD Tech | chenying@td-tech.com | RP-090394 | PCG-21 | RP-39 |
| 953 | 295.10 | HSPA VoIP to WCDMA/GSM CS continuity | 261d? | 2008-03-07 A | 2009-03-06 A | 100% | 2008-03-07 | 2009-03-06 | 261d? | finish no earlier than 2009-03-06 | R2 | 2088h | 2088h | RANimp-HSPAVoIP | Rel-8 | Joern | Nokia | Simone.Provvedi@nokia.com | RP-090050 | PCG-21 | RP-39 |
| 954 | 295.11 | HS-DSCH Serving Cell Change Enhancements | 196d? | 2008-03-07 A | 2008-12-05 A | 100% | 2008-03-07 | 2008-12-05 | 196d? | finish no earlier than 2008-12-12 | R2 | 1568h | 1568h | RANimp-HSDSCH | Rel-8 | Joern | Ericsson | henrik.enbuske@ericsson.com | RP-080811 | PCG-21 | RP-39 |
| 955 | 295.12 | MIMO for 1.28 Mcps TDD. Linked to Rel-8 Study on Scope of future HSPA Evolution for 1.28 Mcps TDD (UID_370041) TR 25.824 | 201d? | 2007-11-01 A | 2009-03-06 A | 100% | 2007-11-01 | 2009-03-06 | 201d? | finish no earlier than 2009-05-29 | R1,R4 | 1608h | 1608h | RANimp-MIMOLCR | Rel-8 | Patrick | CATT | wangke@datangmobile.cn | RP-090313 | PCG-21 | RP-40 |
| 956 | 295.13 | Dual-Cell HSDPA operation on adjacent carriers | 140d? | 2008-05-30 A | 2008-12-11 A | 100% | 2008-05-30 | 2008-12-11 | 140d? | finish no earlier than 2009-05-29 | R1,R4 | 1120h | 1120h | RANimp-DCHSDPA | Rel-8 | Patrick | Ericsson | johan.bergman@ericsson.com | RP-080814 | PCG-21 | RP-40 |
| 957 | 296 | **Rel-8 RAN improvements - UE Conformance Testing** | 602d? | 2008-05-30 A | 2010-09-17 A | 100% | 2008-05-30 | 2010-09-17 | 602d? |  | R5 | 29391.2h | 29391.2h | RANimp-UEConTest | Rel-8 | Ingbert |  |  |  |  |  |
| 958 | 296.1 | Conformance Test Aspects – Combination of 64QAM and MIMO for HSDPA (FDD) | 322d? | 2008-09-12 A | 2009-12-04 A | 100% | 2008-09-12 | 2009-12-04 | 322d? | finish no earlier than 2009-12-04 | R5 | 2576h | 2576h | RANimp-UEConTest_64QamMimoHsdpa | Rel-8 | Ingbert | Ericsson | leif.mattisson@ericsson.com | RP-091058 | PCG-21 | RP-41 |
| 959 | 296.2 | Conformance Test Aspects – Improved L2 for uplink | 341d? | 2008-05-30 A | 2009-09-18 A | 100% | 2008-05-30 | 2009-09-18 | 341d? | finish no earlier than 2009-09-18 | R5 | 2728h | 2728h | RANimp-UEConTest_UplinkL2dataRates | Rel-8 | Ingbert | Ericsson | leif.mattisson@ericsson.com | RP-090712 | PCG-21 | RP-40 |
| 960 | 296.3 | Conformance Test Aspects – 1.28 Mcps TDD Improved L2 support for high data rates | 342d? | 2009-05-29 A | 2010-09-17 A | 100% | 2009-05-29 | 2010-09-17 | 342d? | finish no earlier than 2010-09-17 | R5 | 2736h | 2736h | RANimp-UEConTest_ImprovedL2LCRTDD | Rel-8 | Ingbert | CATT | Xiaozhong Chen (chenxiaozhong@datangmobile.cn) | RP-100737 | PCG-23 | RP-44 |
| 961 | 296.4 | Conformance Test Aspects – 64QAM for 1.28 Mcps TDD HSDPA | 261d? | 2008-05-30 A | 2009-05-29 A | 100% | 2008-05-30 | 2009-05-29 | 261d? | finish no earlier than 2009-05-29 | R5 | 2088h | 2088h | RANimp-UEConTest_64Qam1.28TDD | Rel-8 | Ingbert | ZTE | ma.zijiang@zte.com.cn | RP-090415 | PCG-21 | RP-40 |
| 962 | 296.5 | Conformance Test Aspects – Dual-Cell HSDPA operation on adjacent carriers | 391d? | 2008-12-05 A | 2010-06-04 A | 100% | 2008-12-05 | 2010-06-04 | 391d? | finish no earlier than 2010-06-04 | R5 | 3128h | 3128h | RANimp-UEConTest_DCHSDPA | Rel-8 | Ingbert | Qualcomm | Shubhang Vora (svora@qualcomm.com) | RP-100479 | PCG-22 | RP-42 |
| 963 | 296.6 | Conformance Test Aspects – Enhanced Uplink for CELL_FACH State in FDD | 326d? | 2009-03-06 A | 2010-06-04 A | 100% | 2009-03-06 | 2010-06-04 | 326d? | finish no earlier than 2010-06-04 | R5 | 2608h | 2608h | RANimp-UEConTest_EnhancedRACHCellFACHState | Rel-8 | Ingbert | Nokia | jarkko.hellsten@nokia.com | RP-100483 | PCG-22 | RP-43 |
| 964 | 296.7 | Conformance Test Aspects – Receiver Type3i | 196d? | 2009-03-06 A | 2009-12-04 A | 100% | 2009-03-06 | 2009-12-04 | 196d? | finish no earlier than 2009-12-04 | R5 | 1568h | 1568h | RANimp-UEConTest_ReceiverType3i | Rel-8 | Ingbert | Qualcomm | Ashok Kumar Narayanaswamy (anarayan@qualcomm.com) | RP-091066 | PCG-22 | RP-43 |
| 965 | 296.8 | Conformance Test Aspects – Enhanced CELL_FACH State in LCR TDD | 341d? | 2009-05-30 A | 2010-09-17 A | 100% | 2009-05-30 | 2010-09-17 | 341d? | finish no earlier than 2010-09-17 | R5 | 2728h | 2728h | RANimp-UEConTest_EnhancedCellFACHStateLCRTDD | Rel-8 | Ingbert | CATT | Xiaozhong Chen (chenxiaozhong@datangmobile.cn) | RP-100735 | PCG-23 | RP-44 |
| 966 | 296.9 | Conformance Test Aspects – Continuous Connectivity for packet data users for 1.28 Mcps TDD | 261d? | 2009-09-18 A | 2010-09-17 A | 100% | 2009-09-18 | 2010-09-17 | 261d? | finish no earlier than 2010-09-17 | R5 | 2088h | 2088h | RANimp-UEConTest_CPCLCRTDD | Rel-8 | Ingbert | ZTE | huang.he4@zte.com.cn | RP-100739 | PCG-23 | RP-45 |
| 967 | 296.10 | Conformance Test Aspects – MIMO for 1.28 Mcps TDD | 186d? | 2009-09-18 A | 2010-06-04 A | 100% | 2009-09-18 | 2010-06-04 | 186d? | finish no earlier than 2010-06-04 | R5 | 1488h | 1488h | RANimp-UEConTest_MIMOLCRTDD | Rel-8 | Ingbert | ZTE | huang.chun2@zte.com.cn | RP-100660 | PCG-23 | RP-45 |
| 968 | 296.11 | Conformance Test Aspects – HS-DSCH Serving Cell Change Enhancements | 131d? | 2009-09-18 A | 2010-03-19 A | 100% | 2009-09-18 | 2010-03-19 | 131d? | finish no earlier than 2010-03-12 | R5 | 1048h | 1048h | HSDSCH_UEConTest | Rel-8 | Ingbert | Qualcomm | Shubhang Vora (svora@qualcomm.com) | RP-100077 | PCG-23 | RP-45 |
| 969 | 297 | 3.84 Mcps TDD MBSFN Integrated Mobile Broadcast | 395d? | 2007-06-04 A | 2008-12-05 A | 100% | 2007-06-04 | 2008-12-05 | 395d? |  | R1 | 3160h | 3160h | MBSFN-DOB | Rel-8 | Patrick | Ericsson | Lars.Lindbom@ericsson.com | RP-080218 |  |  |
| 970 | 298 | Conformance Test Aspects – 3.84 Mcps TDD MBSFN Integrated Mobile Broadcast | 211d? | 2009-05-30 A | 2010-03-19 A | 100% | 2009-05-30 | 2010-03-19 | 211d? | finish no earlier than 2010-03-19 | R5 | 1688h | 1688h | MBSFN_IMB_UEConTest | Rel-8 | Ingbert | IPwireless | Phil Young (pyoung@ipwireless.com) | RP-100070 | PCG-23 | RP-44 |

Notes:
- 940: 05/08: Linked to Feature UID_20028 (RInImp)
- 941: RP#41 completed / Text3: 34.108, 34.123-1, 34.123-2, 34.123-3
- 942: RP#42 completed / Text3: 34.121-1, 34.121-2
- 943: -
- 944: RP#41 completed / Text3: 25.308, 25.211, 25.212, 25.213, 25.306, 25.331, 25.433, 25.435, 25.423, 25.425, 25.101, 25.104, 25.141
- 945: RP#40 completed. Linked to UID_370037 Enhanced Uplink for CELL_FACH State in FDD / Text3: 25.319, 25.301, 25.306, 25.321, 25.331, 25.433, 25.435, 25.423, 25.425, 25.427
- 946: RP#42 completed. Linked to UID_370036 Improved L2 for uplink / Text3: 25.309, 25.211, 25.214, 25.321, 25.331, 25.423, 25.433
- 947: RP#41 completed. Continuation of Rel-7 work item "Continuous connectivity for packet data users" UID_20046. / Text3: 25.306, 25.308, 25.321, 25.331, 25.423
- 948: RP#41 completed. Linked to UID_370040 Enhancements for FDD HSPA Evolution / Text3: 25.306, 25.308, 25.321, 25.331, 25.423, 25.433, 25.214, 25.133
- 949: RP#42 completed. Triggered by Rel-7 Study on Scope of future FDD HSPA Evolution (UID_20065) TR 25.999 / Text3: 25.401, 25.413, 25.420, 25.423, 25.427, 25.433, 25.446, 25.301, 25.346
- 950: RP#42 completed. Linked to Rel-8 Study on Scope of future HSPA Evolution for 1.28 Mcps TDD (UID_370041) TR 25.824 / Text3: 25.102, 25.105, 25.123, 25.142, 25.201, 25.221, 25.222, 25.223, 25.224, 25.306, 25.308, 25.321, 25.331, 25.423, 25.433
- 951: RP#42 completed. Linked to Rel-8 Study on Scope of future HSPA Evolution for 1.28 Mcps TDD (UID_370041) TR 25.824 / Text3: 25.123, 25.221, 25.222, 25.224, 25.301, 25.302, 25.304, 25.306, 25.308, 25.319, 25.321, 25.331, 25.401, 25.423, 25.425, 25.433, 25.435
- 952: RP#44 completed. Linked to Rel-8 Study on Scope of future HSPA Evolution for 1.28 Mcps TDD (UID_370041) TR 25.824 / Text3: 25.929, 25.308, 25.319
- 953: RP#43 completed / Text3: 25.331, 25.413
- 954: RP#42 completed / Text3: 25.101, 25.104, 25.133, 25.212, 25.214, 25.308, 25.321, 25.331, 25.423, 25.433
- 955: RP#43 completed / Text3: 25.201, 25.221, 25.222, 25.223, 25.224, 25.306, 25.308, 25.321, 25.331, 25.423, 25.433, 25.102, 25.105, 25.142
- 956: RP#42 completed. Triggered by UID_390032 Study on Dual-Cell HSDPA (withdrawn TR 25.825 v100). / Text3: 25.101, 25.104, 25.133, 25.141, 25.211, 25.212, 25.213, 25.214, 25.215, 25.306, 25.308, 25.321, 25.331, 25.423, 25.433
- 957: Linked to Feature UID_20029 (RANimp)
- 958: RP#46 completed. Testing for UID_360013 / Text3: 34.108, 34.121-1, 34.121-2, 34.123-1, 34.123-2
- 959: RP#45 completed. Testing for UID_370036 / Text3: 34.108, 34.123-1, 34.123-2, 34.123-3
- 960: RP#49 completed. Testing for Rel-7 UID_340039 Improved L2 support for high data rates and Rel-8 UID_370036 Improved L2 for uplink / Text3: 34.108, 34.123-1, 34.123-2, 34.123-3
- 961: RP#44 completed. Testing for UID_380075 / Text3: 34.108, 34.122, 34.123-1, 34.123-2, 34.123-3
- 962: RP#48 completed. Testing for UID_400052 / Text3: 34.108, 34.121-1, 34.121-2, 34.123-1, 34.123-2, 34.123-3
- 963: RP#48 completed. Testing for UID_370037 / Text3: 34.108, 34.121-1, 34.121-2, 34.123-1, 34.123-2, 34.123-3
- 964: RP#46 completed. Testing for Receiver Type3i in 25.101 UE radio Tx and Rx FDD / Text3: 34.108, 34.121-1, 34.121-2
- 965: RP#49 completed. Testing for UID_380076 / Text3: 34.108, 34.123-1, 34.123-2, 34.123-3
- 966: RP#49 completed. Testing for UID_390028 / Text3: 34.108, 34.123-1, 34.123-2, 34.123-3
- 967: PR#48 completed. Testing for UID_400050 / Text3: 34.108, 34.122, 34.123-1, 34.123-2, 34.123-3
- 968: RP#47 completed. Testing for UID_390030 / Text3: 34.108, 34.121-1, 34.121-2, 34.123-1, 34.123-2, 34.123-3
- 969: RP#42 completed. WID updated RP-070493=>RP-081124 (changed WI title "MBSFN Downlink Optimized Broadcast (DOB) 3.84 Mcps TDD" => "3.84Mcps TDD MBSFN Integrated Mobile Broadcast"). / Text3: 25.102, 25.105, 25.123, 25.201, 25.221, 25.222, 25.223, 25.224, 25.304, 25.306, 25.331, 25.346, 25.402, 25.433
- 970: RP#47 completed. Testing for Rel-8 MBSFN-DOB UID_360008 / Text3: 34.108, 34.122, 34.123-1, 34.123-2, 34.123-3

| ID | WBS | Task | Duration | Start | Finish | Complete | Remaining | Baseline start | Baseline finish | Baseline duration | Total slack | Constraint | Resources | Work | Actual work | Text1 | Text4 | Text6 | Text8 | Text2 | Text7 | Text11 |
| --- | --- | --- | --- | --- | --- | --- | --- | --- | --- | --- | --- | --- | --- | --- | --- | --- | --- | --- | --- | --- | --- | --- |
| 971 | 299 | **GERAN support for GERAN - 3G Long Term Evolution interworking** | 1102d? | 2006-09-08 A | 2010-11-26 | 81% | 210.68d? | 2006-09-08 | 2010-11-26 | 1102d? | 435.8d |  | GP,G1,C1 | 33016h | 26704h | GELTE | Nokia, Nokia Siemens Networks | Rel-8 | Paolo |  |  |  |
| 972 | 299.1 | G1 part of GERAN support for GERAN - 3G Long Term Evolution interworking | 641d? | 2006-09-08 A | 2009-02-20 A | 100% |  | 2006-09-08 | 2009-02-20 | 641d? |  | finish no earlier than 2009-02-20 | G1 | 5128h | 5128h | GELTE | Nokia, Nokia Siemens Networks | Rel-8 | Paolo |  |  |  |
| 973 | 299.2 | G2 part of GERAN support for GERAN - 3G Long Term Evolution interworking | 641d? | 2006-09-08 A | 2009-02-20 A | 100% |  | 2006-09-08 | 2009-02-20 | 641d? |  | finish no earlier than 2009-02-20 | G2 | 5128h | 5128h | GELTE | Nokia, Nokia Siemens Networks | Rel-8 | Paolo |  |  |  |
| 974 | 299.3 | CT1 part of GERAN support for GERAN - 3G Long Term Evolution interworking | 641d? | 2006-09-08 A | 2009-02-20 A | 100% |  | 2006-09-08 | 2009-02-20 | 641d? |  | finish no earlier than 2009-02-20 | C1 | 5128h | 5128h | GELTE | Nokia, Nokia Siemens Networks | Rel-8 | Paolo |  |  |  |
| 975 | 299.4 | Testing for GERAN support for GERAN - 3G Long Term Evolution interworking | 1102d? | 2006-09-08 A | 2010-11-26 | 48% | 578.32d? | 2006-09-08 | 2010-11-26 | 1102d? | 435.8d | finish no earlier than 2010-11-26 | G3new | 8816h | 4189.44h | GELTE | Nokia, Nokia Siemens Networks | Rel-8 | Ingbert |  |  |  |
| 976 | 300 | U-TDOA Enhancement | 131d? | 2007-05-18 A | 2007-11-16 A | 100% |  | 2007-05-18 | 2007-11-16 | 131d? |  | finish no earlier than 2007-05-18 | GP | 1048h | 1048h | GUTEN | TruePosition | Rel-8 | Paolo |  |  |  |
| 977 | 301 | **GAN Enhancements** | 604.2d? | 2007-05-15 A | 2009-09-04 A | 100% |  | 2007-05-15 | 2009-09-04 | 604.2d? |  |  | GP | 9432h | 9432h | GANENH | T-Mobile | Rel-8 | Paolo |  |  |  |
| 978 | 301.1 | Update to GAN specifications | 126d? | 2007-08-31 A | 2008-02-22 A | 100% |  | 2007-08-31 | 2008-02-22 | 126d? |  | finish no earlier than 2008-02-22 | GP | 1008h | 1008h | GANENH-SPEC | T-Mobile | Rel-8 | Paolo |  |  |  |
| 979 | 301.2 | Update TS 51.010 Mobile Station (MS) Conformance Specification for GAN Enhancements | 526d? | 2007-05-15 A | 2009-09-04 A | 100% |  | 2007-05-15 | 2009-09-04 | 526d? |  | finish no earlier than 2009-09-04 | G3new | 4208h | 4208h | GANENH-MStest | T-Mobile | Rel-8 | Ingbert |  |  |  |
| 980 | 302 | **AoIP (A-interface over IP)** | 2335d? | 2000-01-03 A | 2008-12-11 A | 100% |  | 2000-01-03 | 2008-12-11 | 2335d? |  |  | GP,S4,C4,C1,C3 | 41412.1h | 41412.1h | AoIP | China Mobile, Ericsson | Rel-8 | Paolo | PCG-21 |  |  |
| 981 | 302.1 | GERAN aspects of AoIP | 2321d? | 2000-01-03 A | 2008-11-21 A | 100% |  | 2000-01-03 | 2008-11-21 | 2321d? |  | finish no earlier than 2008-11-21 | GP | 18560h | 18560h | AoIP | China Mobile, Ericsson | Rel-8 | Paolo | PCG-21 | SP-40 |  |
| 982 | 302.2 | Media Requirements for CS over IP based User Plane | 267d? | 2007-12-05 A | 2008-12-11 A | 100% |  | 2007-12-05 | 2008-12-11 | 267d? |  | finish no earlier than 2008-12-11 | S4 | 1996.09h | 1996.09h | AoIP-CSoIP | China Mobile, Ericsson | Rel-8 | Paolo | PCG-21 | SP-40 |  |
| 983 | 302.3 | Core Network Impacts for A-Interface User Plane over IP | 136d? | 2008-05-30 A | 2008-12-05 A | 100% |  | 2008-05-30 | 2008-12-05 | 136d? |  | start no earlier than 2008-05-30 | C4 | 1088h | 1088h | AoIP-CN | Ericsson | Rel-8 | Kimmo | PCG-21 | CP-40 |  |
| 984 | 302.4 | Core Network Impacts for A-Interface User Plane over IP | 68d? | 2008-05-30 A | 2008-12-05 A | 100% |  | 2008-05-30 | 2008-12-05 | 68d? |  | finish no earlier than 2008-12-05 | C1 | 544h | 544h | AoIP-CN | Ericsson | Rel-8 | Frederic | PCG-21 | CP-40 |  |
| 985 | 302.5 | Core Network Impacts for A-Interface User Plane over IP | 68d? | 2008-05-30 A | 2008-12-05 A | 100% |  | 2008-05-30 | 2008-12-05 | 68d? |  | finish no earlier than 2008-12-05 | C3 | 544h | 544h | AoIP-CN | Ericsson | Rel-8 | Gwiho | PCG-21 | CP-40 |  |
| 986 | 303 | New multicarrier BTS class | 261d? | 2007-08-31 A | 2008-08-29 A | 100% |  | 2007-08-31 | 2008-08-29 | 261d? |  | finish no earlier than 2008-08-29 | G1 | 2088h | 2088h | MCBTS | Alcatel-Lucent | Rel-8 | Paolo |  |  |  |
| 987 | 304 | **Support for Additional Navigation Satellite Systems (ANSS) for LCS** | 150d? | 2008-05-16 A | 2008-12-11 A | 100% |  | 2008-05-16 | 2008-12-11 | 150d? |  |  | S1,G2 | 3384h | 3384h | ANSS | Qualcomm | Rel-8 | Paolo |  |  |  |
| 988 | 304.1 | Stage 1 for ANSS for LCS | 1d? | 2008-12-11 A | 2008-12-11 A | 100% |  | 2008-12-11 | 2008-12-11 | 1d? |  | start no earlier than 2008-12-11 | S1 | 8h | 8h | ANSS |  | Rel-8 | Alain | PCG-22 | SP-42 |  |
| 989 | 304.2 | Support for Additional Navigation Satellite Systems (ANSS) for LCS | 136d? | 2008-05-16 A | 2008-11-21 A | 100% |  | 2008-05-16 | 2008-11-21 | 136d? |  | start no earlier than 2008-05-16 | G2 | 1088h | 1088h | ANSS | Qualcomm | Rel-8 | Paolo |  |  |  |
| 990 | 304.3 | Support for Additional Navigation Satellite Systems (ANSS) for LCS | 136d? | 2008-05-30 A | 2008-12-05 A | 100% |  | 2008-05-30 | 2008-12-05 | 136d? |  | finish no earlier than 2008-12-08 | R2 | 1088h | 1088h | RANimp-ANSS | Qualcomm | Rel-8 | Joern | PCG-21 | RP-40 | RP-080813 |
| 991 | 305 | **Conformance testing for the Latency Reductions feature** | 532d? | 2008-02-22 A | 2010-03-05 A | 100% |  | 2008-02-22 | 2010-03-05 | 532d? |  |  | G1, G3new | 10592h | 10592h | CTLATRED | Ericsson | Rel-8 | Paolo | PCG-21 |  |  |
| 992 | 305.1 | MS conformance testing for the Latency Reductions feature | 532d? | 2008-02-22 A | 2010-03-05 A | 100% |  | 2008-02-22 | 2010-03-05 | 532d? |  | finish no earlier than 2010-03-05 | G3new | 4248h | 4248h | CTLATRED-MStest | Ericsson | Rel-8 | Ingbert | PCG-21 |  |  |
| 993 | 305.2 | BTS conformance testing for the Latency Reductions feature | 261d? | 2008-02-22 A | 2009-02-20 A | 100% |  | 2008-02-22 | 2009-02-20 | 261d? |  | finish no earlier than 2009-02-20 | G1 | 2088h | 2088h | CTLATRED-BTStest | Ericsson | Rel-8 | Paolo | PCG-21 |  |  |
| 994 | 306 | MS conformance testing of changes introduced by WI "Support of Packet-switched Handover for GERAN A/Gb mode" | 196d? | 2008-02-22 A | 2008-11-21 A | 100% |  | 2008-02-22 | 2008-11-21 | 196d? |  | finish no earlier than 2008-11-21 | G3new | 1568h | 1568h | PSHCT-MStest | Rohde & Schwarz | Rel-8 | Ingbert | PCG-21 |  |  |
| 995 | 307 | (Small) Technical Enhancements and Improvements for Rel-8 | 509d? | 2007-01-01 A | 2008-12-11 A | 100% |  | 2007-01-01 | 2008-12-11 | 509d? |  | finish no earlier than 2008-12-11 | All | 4072h | 4072h | TEI8 |  | Rel-8 | All |  |  |  |
| 996 | 308 | Test - (Small) Technical Enhancements and Improvements for Rel-8 | 672d? | 2007-03-07 A | 2010-12-24 | 90% | 67.2d? | 2007-03-07 | 2010-12-24 | 672d? | 415.8d | finish no earlier than 2010-12-24 | R5,G3new | 5376h | 4838.4h | TEI8_Test |  | Rel-8 | Ingbert | PCG-21 | RP-40 |  |

Notes:
- 971: GP#41 completed (MS conformance testing open) / Text3: 44.018, 44.060, 45.002, 45.008, 45.010, 48.008, 48.018, 51.010 / Text5: sergio.parolari@nsn.com, vlora.rexhepi@nokia.com
- 972: GP#41 completed / Text3: 43.055, 43.129, 43.246, 45.002, 45.008, 45.010 / Text5: sergio.parolari@nsn.com, vlora.rexhepi@nokia.com
- 973: GP#41 completed / Text3: 44.018, 44.060, 48.008, 48.018 / Text5: sergio.parolari@nsn.com, vlora.rexhepi@nokia.com
- 974: - / Text3: 24.008 / Text5: sergio.parolari@nsn.com, vlora.rexhepi@nokia.com
- 975: - / Text3: 51.010 / Text5: sergio.parolari@nsn.com, vlora.rexhepi@nokia.com
- 976: GP#36 completed U-TDOA (Uplink Time Difference of Arrival) / Text3: 43.059, 45.008, 48.071 / Text5: Terry Brooks (terri.brooks@trueposition.com)
- 977: GP#37 completed. GP#43 completed Testing / Text5: mohammed.versi@t-mobile.com
- 978: GP#37 completed / Text3: 43.318, 44.318 / Text5: mohammed.versi@t-mobile.com
- 979: GP#43 completed / Text3: 51.010 / Text5: mohammed.versi@t-mobile.com
- 980: GP#40/TSG#42 completed . Triggered by TR 43.903 Study on A-interface over IP (AINTIP) UID_50589. / Text5: wangshuaiyu@chinamobile.com, paul.schliwa-bertling@ericsson.com
- 981: GP#40 completed. GP#39 updated WID GP-080901=>GP-081362. / Text3: 48.001, 48.002, 48.008, 48.020, 49.008, 48.103 / Text5: wangshuaiyu@chinamobile.com, paul.schliwa-bertling@ericsson.com
- 982: SP#42 completed / Text3: 26.102, 26.103, 26.202 / Text5: Karl.Hellwig@Ericsson.com
- 983: CP#42 completed. Updated WID CP-080278=>CP-080722 / Text3: 23.205, 23.153, 23.231, 29.232 / Text5: philip.hodges@ericsson.com
- 984: CP#42 completed. Updated WID CP-080278=>CP-080722 / Text3: 23.009 / Text5: philip.hodges@ericsson.com
- 985: CP#42 completed. Updated WID CP-080278=>CP-080722 / Text3: 29.007 / Text5: philip.hodges@ericsson.com
- 986: GP#39 completed / Text3: 45.005, 45.050, 51.021 / Text5: thomas.bitzer@alcatel-lucent.de
- 987: GP#40 completed. Align with RANimp-ANSS ongoing work item. GP#40 WID updated GP-080776=>GP-081784 (Conformance testing moved to A-GNSS WID) / Text5: Mungal Dhanda
- 988: SP#42 completed by 22.071 CR0077 / Text3: 22.071
- 989: GP#40 completed. Align with RANimp-ANSS ongoing work item. GP#40 WID updated GP-080776=>GP-081784 (Conformance testing moved to A-GNSS WID) / Text3: 43.059, 44.031, 49.031, 44.071, 48.031, 51.010 / Text5: Mungal Dhanda
- 990: SR in RP-080813. RP#42 WI closed at 95%. GERAN leading the work / considers performance requirements for Rel-9 / Text3: 25.305, 25.306, 25.331, 25.413, 25.423, 25.433, 25.453 / Text5: Etienne Chaponniere (echaponn@qualcomm.com)
- 991: GP#45 completed / Text5: mats.y.samuelsson@ericsson.com, hakan.e.grunditz@ericsson.com
- 992: GP#45 completed / Text3: 51.010 / Text5: hakan.e.grunditz@ericsson.com
- 993: GP#41 completed / Text3: 51.021 / Text5: mats.y.samuelsson@ericsson.com
- 994: GP#40 completed / Text3: 51.010 / Text5: Franz.Segerer@ROHDE-SCHWARZ.COM
- 995: SP#42 completed
- 996: -

| ID | WBS | Task | Type | Duration | Start | Finish | Complete | Baseline start | Baseline finish | Baseline duration | Constraint | Resources | Work | Actual work | Text1 | Text4 | Text5 | Text6 | Text8 | Text12 | Text3 | Text7 | Text2 | Text9 |
| --- | --- | --- | --- | --- | --- | --- | --- | --- | --- | --- | --- | --- | --- | --- | --- | --- | --- | --- | --- | --- | --- | --- | --- | --- |
| 997 | 309 | **Deleted - All-IP Network** |  | 448d? | 2004-06-28 A | 2006-03-15 A | 100% | 2004-06-28 | 2006-03-15 | 448d? |  | S1 | 7168h | 7168h | AIPN | NTT DoCoMo | c.masyu@nttdocomo.co.jp | Rel-8 | Alain | SP-38 |  |  |  |  |
| 998 | 309.1 | Deleted - Stage 1 |  | 448d? | 2004-06-28 A | 2006-03-15 A | 100% | 2004-06-28 | 2006-03-15 | 448d? | finish no earlier than 2006-03-15 | S1 | 3584h | 3584h | AIPN | NTT DoCoMo | c.masyu@nttdocomo.co.jp | Rel-8 | Alain | SP-38 | 22.258 |  |  |  |
| 999 | 310 | Deleted - was Rel7 - LCS for 3GPP Interworking WLAN | milestone | 0d? | 2007-09-28 A | 2007-09-28 A | 100% | 2007-09-28 | 2007-09-28 | 0d? | start no earlier than 2007-09-28 | S2 |  |  | LCS4_IWLAN | LG Electronics | dhshim@lge.com | Rel-8 | Maurice | SP-35 | 23.234, 23.271, 23.167 |  |  |  |
| 1000 | 311 | Deleted - never approved- FBI Phase 2 | milestone | 0d | 2007-09-28 A | 2007-09-28 A | 100% | 2007-09-28 | 2007-09-28 | 0d | start no earlier than 2007-09-28 | S2 |  |  | FBI2 | Nokia Siemens Networks |  | Rel-8 | Maurice | SP-38 |  |  |  |  |
| 1001 | 312 | Deleted -Enhancements to BS30 Bearer service for Videotelephony | milestone | 0d? | 2007-03-15 A | 2007-03-15 A | 100% | 2007-03-15 | 2007-03-15 | 0d? | finish no earlier than 2007-03-15 | S1 |  |  | BS30 |  | andre.jarvis@three.co.uk | Rel-8 | Alain | SP-38 | 22.002, 22.004, 22.101, 22.105, 24.008 |  |  |  |
| 1002 | 313 | Deleted - IMS Enhancements Rel-8 |  | 75d? | 2007-09-03 A | 2007-12-14 A | 100% | 2007-09-03 | 2007-12-14 | 75d? |  | S1 | 600h | 600h | IMS8 | Telecom Italia |  | Rel-8 | Alain | SP-38 |  | SP-37 |  |  |
| 1003 | 314 | **Deleted - Contact Manager Conformance Test specifications** |  | 471d? | 2008-06-02 A | 2010-03-19 A | 100% | 2008-06-02 | 2010-03-19 | 471d? |  | C6 | 11304h | 11304h | eUPHBOOK-Test | Comprion, Gemalto | Udo Willenbrink, Jacques Seif | Rel-8 | Xavier | CP-47 |  | CP-40 | PCG-21 | PCG-24 |
| 1004 | 314.1 | Deleted - Contact Manager for 3GPP UICC applications test specifications |  | 471d? | 2008-06-02 A | 2010-03-19 A | 100% | 2008-06-02 | 2010-03-19 | 471d? | finish no earlier than 2010-03-19 | C6 | 3768h | 3768h | eUPHBOOK-Test | Comprion | Udo Willenbrink (uwillenbrink@comprion.com ) | Rel-8 | Xavier | CP-47 | 31.320 (external interface for communication with the ME) | CP-40 | PCG-21 | PCG-24 |
| 1005 | 314.2 | Deleted - Contact Manager API for Java™ Card test specification |  | 471d? | 2008-06-02 A | 2010-03-19 A | 100% | 2008-06-02 | 2010-03-19 | 471d? | finish no earlier than 2010-03-19 | C6 | 3768h | 3768h | eUPHBOOK-Test | Gemalto | jacques.seif@gemalto.com | Rel-8 | Xavier | CP-47 | 31.321 (internal interface (API)) | CP-40 | PCG-21 | PCG-24 |
| 1006 | 315 | Deleted - MS conformance testing of Support of Conversational Services in A/Gb mode via the PS domain |  | 401d? | 2008-02-25 A | 2009-09-04 A | 100% | 2008-02-25 | 2009-09-04 | 401d? | finish no earlier than 2009-09-04 | G3new | 3208h | 3208h | SCSAGBCT-MStest | Nokia | arsi.heino@nokia.com | Rel-8 | Ingbert | GP-43 | 51.010 |  | PCG-21 | PCG-23 |
| 1007 | 316 | Release 8 Studies |  | 1332d? | 2005-10-07 A | 2010-11-12 A | 100% | 2005-10-07 | 2010-11-12 | 1332d? | start no earlier than 2000-01-03 | CP,GP,RP,SP | 10656h | 10656h |  |  |  | Rel-8 | All |  |  |  |  |  |
| 1008 | 317 | Study on Customised Alerting Tone (CAT) Requirements |  | 245d? | 2005-10-07 A | 2006-09-14 A | 100% | 2005-10-07 | 2006-09-14 | 245d? | start no earlier than 2005-10-07 | S1 | 1960h | 1960h | FS_CAT | China Mobile | Qing Huang (huangqing@chinamobile.com) | Rel-8 | Alain |  | 22.982 |  |  |  |
| 1009 | 318 | Study on Facilitating Machine to Machine Communication in GSM and UMTS (M2M) |  | 350d? | 2005-11-04 A | 2007-03-08 A | 100% | 2005-11-04 | 2007-03-08 | 350d? | finish no earlier than 2006-06-16 | S1 | 2800h | 2800h | FS_M2M | Siemens | Juergen Merkel | Rel-8 | Alain |  | 22.868 |  |  |  |
| 1010 | 319 | Study on Network Composition |  | 526d? | 2005-12-07 A | 2007-12-12 A | 100% | 2005-12-07 | 2007-12-12 | 526d? | finish no earlier than 2006-09-27 | S1 | 4208h | 4208h | FS_NetComp | Nokia Siemens Networks | Joerg Swetina (joerg.swetina@nw.neclab.eu) | Rel-8 | Alain |  | 22.980 |  |  |  |
| 1011 | 320 | Study on Requirements of IMS Multimedia Conferencing |  | 330d? | 2006-06-08 A | 2007-09-12 A | 100% | 2006-06-08 | 2007-09-12 | 330d? | finish no earlier than 2007-03-21 | S1 | 2640h | 2640h | FS_IMSconf | China Mobile | Qing Huang (huangqing@chinamobile.com) | Rel-8 | Alain |  | 22.948 |  |  |  |
| 1012 | 321 | Study on support of a Public Warning System |  | 140d? | 2007-09-03 A | 2008-03-14 A | 100% | 2007-09-03 | 2008-03-14 | 140d? |  | S1 | 1120h | 1120h | FS_PWS | T-Mobile | mark.younge@t-mobile.com | Rel-8 | Alain |  | 22.968 |  |  |  |
| 1013 | 322 | Study on Paging Permission with Access Control |  | 256d? | 2006-09-28 A | 2007-09-20 A | 100% | 2006-09-28 | 2007-09-20 | 256d? | finish no earlier than 2007-09-20 | S1 | 2048h | 2048h | FS_PPAC | NTT DoCoMo | Katsuhiro NOGUCHI (noguchi@nttdocomo.co.jp) | Rel-8 | Alain |  | 22.908 |  |  |  |
| 1014 | 323 | Study on Non-3GPP access Network Selection Principles (NSP) |  | 392d? | 2006-12-06 A | 2008-06-05 A | 100% | 2006-12-06 | 2008-06-05 | 392d? | finish no earlier than 2007-11-19 | S1 | 3136h | 3136h | FS_N3GtoNSP | Telefonica O2 | chris.friel@o2.com | Rel-8 | Alain |  | 22.912 |  |  |  |
| 1015 | 324 | Study on Value Added Services for Short Message Service |  | 263d? | 2006-12-06 A | 2007-12-07 A | 100% | 2006-12-06 | 2007-12-07 | 263d? | finish no earlier than 2007-12-07 | S1 | 2104h | 2104h | FS_VAS4SMS | China Mobile | Qing Huang (huangqing@chinamobile.com) | Rel-8 | Alain |  | 22.942 |  |  |  |
| 1016 | 325 | Study on Service continuity between mobile and WLAN networks |  | 262d? | 2006-12-06 A | 2007-12-06 A | 100% | 2006-12-06 | 2007-12-06 | 262d? | finish no earlier than 2008-12-25 | S1 | 2096h | 2096h | FS_SMLSWLAN | NEC | joerg.swetina@neclab.eu | Rel-8 | Alain |  | 22.937 |  |  |  |
| 1017 | 326 | Study on Services Alignment and Migration |  | 331d? | 2006-12-06 A | 2008-03-12 A | 100% | 2006-12-06 | 2008-03-12 | 331d? | finish no earlier than 2007-09-20 | S1 | 2648h | 2648h | FS_ServAl | Telefónica O2 Europe | chris.friel@o2.com | Rel-8 | Alain |  | 22.983 | SP-37 |  |  |
| 1018 | 327 | **Study on 3GPP System Architecture Evolution** |  | 1115d? | 2004-12-03 A | 2009-03-12 A | 100% | 2004-12-03 | 2009-03-12 | 1115d? |  | S2,S3 | 23456h | 23456h | FS_SAE | Vodafone | Chris Pudney | Rel-8 | Maurice |  |  |  |  |  |
| 1019 | 327.1 | Stage 2 Interim conclusion for RAN Work to start |  | 990d? | 2004-12-03 A | 2008-09-18 A | 100% | 2004-12-03 | 2008-09-18 | 990d? | finish no earlier than 2005-09-23 | S2 | 7920h | 7920h | FS_SAE | Vodafone | Chris Pudney | Rel-8 | Maurice |  | 23.882 |  |  |  |
| 1020 | 327.2 | Stage 2 study on 3GPP architectural development |  | 704d? | 2006-01-09 A | 2008-09-18 A | 100% | 2006-01-09 | 2008-09-18 | 704d? | finish no earlier than 2007-09-28 | S2 | 5632h | 5632h | FS_SAE | Vodafone | Chris Pudney | Rel-8 | Maurice |  | 23.882 |  |  |  |
| 1021 | 327.3 | Security study for Inter-access mobility between non-3GPP and 3GPP system |  | 334d? | 2007-09-03 A | 2009-03-12 A | 100% | 2007-09-03 | 2009-03-12 | 334d? | finish no earlier than 2009-03-12 | S3 | 2672h | 2672h | FS_SAE | Nokia | dajiang.zhang@nokia.com | Rel-8 | Dionisio |  | 33.821, 33.822 |  |  |  |
| 1022 | 328 | Study on Stage 2 aspects of IMS Service Brokering |  | 589d? | 2006-06-19 A | 2008-09-18 A | 100% | 2006-06-19 | 2008-09-18 | 589d? | finish no earlier than 2008-09-18 | S2 | 4712h | 4712h | FS_ISB_ST2 | Telcordia | raquel@research.telcordia.com | Rel-8 | Maurice |  | 23.810 |  |  |  |
| 1023 | 329 | Study on IMS utilizing multicast bearer services |  | 447d? | 2006-03-22 A | 2007-12-06 A | 100% | 2006-03-22 | 2007-12-06 | 447d? | finish no earlier than 2007-12-03 | S2 | 3576h | 3576h | FS_MLTICAST-IMS | Nokia Siemens Networks |  | Rel-8 | Maurice |  | 23.847 |  |  |  |
| 1024 | 330 | Study on Multimedia Session Continuity |  | 291d? | 2007-04-26 A | 2008-06-05 A | 100% | 2007-04-26 | 2008-06-05 | 291d? | finish no earlier than 2008-06-05 | S2 | 2328h | 2328h | FS_MMSC | LG Electronics |  | Rel-8 | Maurice |  | 23.893 |  |  |  |

Notes:
- 997: SP#38 stopped. 25/07/08 Moved UID_31059 Study on All-IP Network (FS_AIPN/was AIPFS ) to Rel-7 out of the stopped Rel-8 Feature UID_31067 Deleted - All-IP Network (AIPN)
- 998: 22.258 withdrawn, superseded by 22.278 (UID 320022). SP#38 stopped
- 999: SP-35 stopped
- 1000: SP#38 stopped
- 1001: SP#38 stopped (no support)
- 1002: SP#38 stopped
- 1003: CP#47 work stopped/abandoned
- 1004: CP#47 work stopped/abandoned
- 1005: CP#47 work stopped/abandoned
- 1006: GP#43 work stopped/abandoned (completion 0%)
- 1007: -
- 1008: Spin-off Rel-8 Feature Customized Alerting Tone (CAT) Service UID_340029
- 1009: SP#35 completed. Spin-off SA3 Study on Security Aspects of Remote Provisioning and Change of Subscription for M2M (UID_370053). SP#40 Spin-off new Feature UID_410030 (NIMTC)
- 1010: SP#38 completed
- 1011: SP#37 completed. Spin-off New Feature UID_370026 Value-Added Services for Short Message Service (VAS4SMS)
- 1012: SP#39 completed. Spin-off Rel-9 Feature UID_380057 (PWS)
- 1013: SP#37 completed. Spin-off new Feature UID_370084 (PPACR)
- 1014: SP#38 completed. Spin-off New Feature UID_380062 (N3GTONSP). SP#40 WID updated SP-060930=>SP-080318. TR re-approved with new # 22.812=>22.912
- 1015: SP#38 completed. Spin-off New Feature UID_370026 (VAS4SM)
- 1016: SP#38 completed
- 1017: SP#39 completed. Spin-off Rel-9 Feature UID_330017 Services Alignment and Migration (ServAl)
- 1018: SP#43 completed
- 1019: SP#41 completed
- 1020: SP#41 completed
- 1021: SP#43 completed
- 1022: SP#41 completed. No spin-off activity proposed. [Note: IMS Service Brokering enhancements UID_31088 moved back from R8 to R7 to give a home to 22228CR0036_(Rel-7)_S1-051232. Hence, Rel-7 ISB has Stage 1 only (and is misaligned with Rel-7 Stages 2/3.]
- 1023: SP#38 completed
- 1024: SP#40 completed

| ID | WBS | Task | Duration | Start | Finish | Complete | Baseline start | Baseline finish | Baseline duration | Constraint | Resources | Work | Actual work | Text1 | Text2 | Text4 | Text5 | Text6 | Text7 | Text8 | Text3 | Text11 | Text9 | Text12 |
| --- | --- | --- | --- | --- | --- | --- | --- | --- | --- | --- | --- | --- | --- | --- | --- | --- | --- | --- | --- | --- | --- | --- | --- | --- |
| 1025 | 331 | **Study on centralized IMS service control** | 363d? | 2006-10-23 A | 2008-03-12 A | 100% | 2006-10-23 | 2008-03-12 | 363d? |  | S2,S1 | 7952h | 7952h | FS_ICS | PCG-21 | Ericsson | peter.bleckert@ericsson.com | Rel-8 | SP-38 | Alain |  |  |  |  |
| 1026 | 331.1 | Study on centralized IMS services requirements | 268d? | 2007-03-05 A | 2008-03-12 A | 100% | 2007-03-05 | 2008-03-12 | 268d? | start no earlier than 2007-03-05 | S1 | 2144h | 2144h | FS_ICS-S1 |  | NEC | joerg.swetina@neclab.eu | Rel-8 | SP-37 | Alain | 22.892 |  |  |  |
| 1027 | 331.2 | Study on centralized IMS services control | 363d? | 2006-10-23 A | 2008-03-12 A | 100% | 2006-10-23 | 2008-03-12 | 363d? | finish no earlier than 2008-02-21 | S2 | 2904h | 2904h | FS_IMS_CSC |  | Alcatel-Lucent | Andy Bennett (andybennett@alcatel-lucent.com) | Rel-8 |  | Maurice | 23.892 |  |  |  |
| 1028 | 332 | Study on Architecture of IMS based Customized Alerting Tone (CAT) | 208d? | 2007-12-04 A | 2008-09-18 A | 100% | 2007-12-04 | 2008-09-18 | 208d? | finish no earlier than 2008-09-08 | S2 | 1664h | 1664h | FS_CAT-St2 | PCG-21 | China Mobile | WANG, Jing (wangjing@chinamobilecom) | Rel-8 | SP-38 | Maurice | 23.872 |  |  |  |
| 1029 | 333 | Study on Home (e)NodeB Security | 321d? | 2007-12-20 A | 2009-03-12 A | 100% | 2007-12-20 | 2009-03-12 | 321d? | finish no earlier than 2009-03-10 | S3 | 2568h | 2568h | FS_HNB_Sec | PCG-21 | Huawei | yangyanmei@huawei.com | Rel-8 | SP-38 | Dionisio | 33.820 |  |  |  |
| 1030 | 334 | Study on Transferring of emergency call data – in-band modem solution | 265d? | 2006-12-07 A | 2007-12-12 A | 100% | 2006-12-07 | 2007-12-12 | 265d? | finish no earlier than 2008-09-18 | S4 | 2120h | 2120h | eCALLIBMS |  | Airbiquity | lhong@airbiquity.com | Rel-8 |  | Paolo | 26.967 |  |  |  |
| 1031 | 335 | Study on Element Operations Systems Function (EOSF) definition | 266d? | 2007-06-07 A | 2008-06-12 A | 100% | 2007-06-07 | 2008-06-12 | 266d? | finish no earlier than 2008-12-11 | S5 | 2128h | 2128h | OAM7-NIM- EOSF |  | China Mobile | Li Jian (lijian@chinamobile.com) | Rel-8 |  | Dionisio | 32.819 |  |  |  |
| 1032 | 336 | Study on SA5 MTOSI XML Harmonization | 351d? | 2006-05-10 A | 2007-09-12 A | 100% | 2006-05-10 | 2007-09-12 | 351d? | finish no earlier than 2007-12-14 | S5 | 2808h | 2808h | OAM8-NIM-XML |  | Nortel | jduguay@nortel.com | Rel-8 |  | Dionisio | 32.818 |  |  |  |
| 1033 | 337 | Study on Common Profile Storage (CPS) Framework of User Data for network services and management | 244d? | 2006-07-03 A | 2007-06-07 A | 100% | 2006-07-03 | 2007-06-07 | 244d? | finish no earlier than 2007-06-07 | S5 | 1952h | 1952h | OAM7-CPS |  | T-Mobile | istvan.aba@t-mobile.at | Rel-8 |  | Dionisio | 32.808 |  |  |  |
| 1034 | 338 | Study on Management for LTE and SAE | 526d? | 2006-12-07 A | 2008-12-11 A | 100% | 2006-12-07 | 2008-12-11 | 526d? | finish no earlier than 2008-12-11 | S5 | 4208h | 4208h | FS_OAM_LTE_SAE |  | Ericsson | robert.petersen@ericsson.com | Rel-8 |  | Dionisio | 32.816 |  |  |  |
| 1035 | 339 | Study on Charging Aspects of 3GPP System Evolution | 179d? | 2007-04-02 A | 2007-12-06 A | 100% | 2007-04-02 | 2007-12-06 | 179d? | finish no earlier than 2007-12-06 | S5 | 1432h | 1432h | FS_SAEcharg |  | Nokia Siemens Networks | Gerald.Goermer@nsn.com | Rel-8 |  | Dionisio | 32.820 |  |  |  |
| 1036 | 340 | Study on AS-MRFC media server control protocol | 583d? | 2006-03-22 A | 2008-06-13 A | 100% | 2006-03-22 | 2008-06-13 | 583d? | finish no earlier than 2008-06-13 | C1 | 4664h | 4664h | MRFC |  | Hewlett-Packard | mark.syrett@hp.com | Rel-8 |  | Frederic | 24.880 |  |  |  |
| 1037 | 341 | Study on IMS Restoration Procedures | 310d? | 2007-03-26 A | 2008-05-30 A | 100% | 2007-03-26 | 2008-05-30 | 310d? | finish no earlier than 2008-05-30 | C4 | 2480h | 2480h | FS_IMS_RP |  | Ericsson | german.blanco@ericsson.com | Rel-8 |  | Kimmo | 23.820 |  |  |  |
| 1038 | 342 | Study on IMS Application Server Service Data Descriptions for AS interoperability | 261d? | 2007-09-14 A | 2008-09-12 A | 100% | 2007-09-14 | 2008-09-12 | 261d? | finish no earlier than 2008-09-12 | C4 | 2088h | 2088h | FS_IMS_ASIO |  | Alcatel-Lucent | Jean-Jacques Trottin | Rel-8 |  | Kimmo | 29.864 |  |  |  |
| 1039 | 343 | Study on Customized Alerting Tone (CAT) solution for voice and video call in CS domain | 261d? | 2007-09-14 A | 2008-09-12 A | 100% | 2007-09-14 | 2008-09-12 | 261d? |  | C4 | 626.4h | 626.4h | FS_CAT_VVC_CS |  | China Mobile | zhanghao@chinamobile.com | Rel-8 |  | Kimmo | 29.882 |  |  |  |
| 1040 | 344 | Study on InterWorking Function between MAP based and Diameter based interfaces | 266d? | 2007-11-30 A | 2008-12-05 A | 100% | 2007-11-30 | 2008-12-05 | 266d? | finish no earlier than 2008-12-05 | C4 | 2128h | 2128h | FS_MAP2Diam | PCG-21 | Huawei | liming49985@huawei.com | Rel-8 | CP-38 | Kimmo | 29.805 |  |  |  |
| 1041 | 345 | Study on Scope of future HSPA Evolution for 1.28 Mcps TDD | 186d? | 2007-09-14 A | 2008-05-30 A | 100% | 2007-09-14 | 2008-05-30 | 186d? | finish no earlier than 2008-05-30 | R1 | 1488h | 1488h | FS_RAN-LCRTDDHSPAEvo |  | RITT | Xu Fei | Rel-8 | RP-37 | Patrick | 25.824 | RP-080290 |  |  |
| 1042 | 346 | Study on Synchronized E-DCH for UTRA FDD | 126d? | 2007-09-14 A | 2008-03-07 A | 100% | 2007-09-14 | 2008-03-07 | 126d? | finish no earlier than 2008-03-14 | R1 | 1008h | 1008h | FS_RAN-UplinkSync |  | Nokia Siemens Networks | Karri.Ranta-aho@nsn.com | Rel-8 | RP-37 | Patrick | 25.823 | RP-080068 |  |  |
| 1043 | 347 | Study on Improved network controlled mobility between LTE and 3GPP2/mobile WiMAX radio technologies | 131d? | 2007-06-04 A | 2007-12-03 A | 100% | 2007-06-04 | 2007-12-03 | 131d? | finish no earlier than 2007-12-03 | R4 | 1048h | 1048h | FS_RAN-LTEmob |  | Motorola | hao.bi@Motorola.com | Rel-8 |  | Issam | 36.938 | RP-070827 |  |  |
| 1044 | 348 | Study on 3G Home NodeB/eNodeB | 325d? | 2007-03-05 A | 2008-05-30 A | 100% | 2007-03-05 | 2008-05-30 | 325d? | finish no earlier than 2008-05-30 | R4 | 2600h | 2600h | FS_RAN-HNBeNB |  | Motorola | howard.thomas@motorola.com | Rel-8 |  | Issam | 25.820 | RP-080289 |  |  |
| 1045 | 349 | Study on A-interface over IP | 126d? | 2007-08-31 A | 2008-02-22 A | 100% | 2007-08-31 | 2008-02-22 | 126d? | finish no earlier than 2008-02-22 | GP | 1008h | 1008h | AINTIP |  | China Mobile, Ericsson | paul.schliwa-bertling@ericsson.com | Rel-8 |  | Paolo | 43.903 |  |  |  |
| 1046 | 350 | Study on Optimized Transmit Pulse Shape for Downlink EGPRS2-B | 657d? | 2007-11-16 A | 2010-05-21 A | 100% | 2007-11-16 | 2010-05-21 | 657d? | finish no earlier than 2010-05-27 | G1 | 5248.44h | 5248.44h | WIDER |  | RIM, Nokia Siemens Networks | jdwyer@RIM.COM and eddie.riddington@nsn.com | Rel-8 |  | Paolo | 45.913 |  |  |  |
| 1047 | 351 | Deleted - Study on Mobility between 3GPP-WLAN Interworking and 3GPP Systems | 393d? | 2007-03-20 A | 2008-09-18 A | 100% | 2007-03-20 | 2008-09-18 | 393d? | finish no earlier than 2008-09-18 | S2 | 3144h | 3144h | FS_SM3GWLAN |  | Orange |  | Rel-8 |  | Maurice | withdrawn 23.827 |  | PCG-21 | SP-41 |
| 1048 | 352 | Deleted - equals 340035 -FS on Service continuity between mobile and WLAN networks | 75d? | 2007-09-03 A | 2007-12-14 A | 100% | 2007-09-03 | 2007-12-14 | 75d? | finish no earlier than 2007-12-14 | S1 | 600h | 600h | FSSCMobToW |  | BT | mike.meyerstein@bt.com | Rel-8 | SP-37 | Alain | 22.937 |  | PCG-21 | SP-39 |
| 1049 | 353 | Deleted - Study on Evaluation of LCS Control Plane Solution for EPS | 100d? | 2008-01-14 A | 2008-05-30 A | 100% | 2008-01-14 | 2008-05-30 | 100d? | finish no earlier than 2009-03-20 | S2 | 800h | 800h | FS_LCS_EPS |  | SiRF |  | Rel-8 | SP-38 | Maurice | 23.891 |  | PCG-21 | SP-40 |
| 1050 | 354 | Deleted - Study on HS-PDSCH serving cell change enhancements | 60d? | 2007-12-17 A | 2008-03-07 A | 100% | 2007-12-17 | 2008-03-07 | 60d? | finish no earlier than 2008-06-12 | R4 | 480h | 480h | FS_RAN-HSPDSCH | PCG-21 | Qualcomm |  | Rel-8 | RP-38 | Issam | none | RP-080070 | PCG-21 | RP-39 |
| 1051 | 355 | Deleted - Study on Dual-Cell HSDPA operation | 261d? | 2007-08-15 A | 2009-03-06 A | 100% | 2007-08-15 | 2009-03-06 | 261d? | finish no earlier than 2009-03-06 | R1 | 2088h | 2088h | FS_RAN-DCHS | PCG-21 | Qualcomm | Josef Blanz | Rel-8 | RP-39 | Patrick | withdrawn 25.825 v100 | RP-090066 | PCG-22 | RP-43 |
| 1052 | 356 | Release 7 Features | 679d? | 2005-05-02 A | 2007-12-06 A | 100% | 2005-05-02 | 2007-12-06 | 679d? | start no earlier than 2000-01-01 | CP,GP,RP,SP | 5432h | 5432h |  |  |  |  | Rel-7 |  | All |  |  |  |  |

Notes:
- 1025: SP#39 completed
- 1026: SP#39 completed
- 1027: SP#39 completed
- 1028: SP#41 completed as Rel-8
- 1029: SP#43 completed. Linked to RAN4 Study on 3G Home NodeB/eNodeB (UID_350039) and to SA5 Study on Self-Organizing Networks (SON) related OAM interfaces for Home NodeB (UID_360007)
- 1030: SP#38 completed. Spin-off WID UID_34042 (eCall_Phase2)
- 1031: SP#40 completed. SID updated SP-050608=>SP-070307
- 1032: SP#37 completed. SID updated SP-050295=>SP-070305
- 1033: SP#36 completed. Spin-off New Feature UID_400034 User Data Convergence (UDC)
- 1034: SP#42 completed
- 1035: SP#38 completed
- 1036: CP#40 completed. Spin-off New Feature UID_380035 (MRFC_TS)
- 1037: CP#40 completed. Spin-off WID UID_400012 (IMS_RP)
- 1038: CP#41 completed. Linked to SA5 Study on Common Profile Storage framework UID_320006. Spin-off WID UID_410003 (IMS_ASIO)
- 1039: CP#41 completed. Spin-off WID under Feature CAT UID_340029
- 1040: CP#42 completed. Spin-off implementation Building Block UID_410007 (MAP2Diam) under the SAES Feature UID_320005
- 1041: RP#40 completed
- 1042: RP#39 completed
- 1043: RP#38 completed
- 1044: RP#40 completed
- 1045: GP#37 completed. Spin-off implementation Feature AoIP (A-interface over IP) UID_50591
- 1046: GP#46 completed
- 1047: SP#41 stopped. Draft TR 23.827 content implemented in TS 23.327.
- 1048: SP#39 stopped
- 1049: SP#40 spin-off Feature UID_400038 (LCS_CPS_EPS). SP#40 FS stopped
- 1050: RP#39 stopped (no TR produced). Spin-off HS-DSCH Serving Cell Change Enhancements (UID_39003)
- 1051: RP#43 stopped (draft TR 25.825 v100 withdrawn). Conclusions in RP-090318 (RAN1 findings of the UTRA Multi-Carrier Evolution study). RP#42 New WI approved on Dual-Cell HSDPA operation on adjacent carriers (UID_400052)
- 1052: -

| ID | WBS | Task | Type | Duration | Start | Finish | Complete | Baseline start | Baseline finish | Baseline duration | Constraint | Resources | Work | Actual work | Text1 | Text4 | Text5 | Text6 | Text8 | Text12 | Text11 | Text7 | Text2 |
| --- | --- | --- | --- | --- | --- | --- | --- | --- | --- | --- | --- | --- | --- | --- | --- | --- | --- | --- | --- | --- | --- | --- | --- |
| 1053 | 357 | **Identification of Communication Services in IMS** |  | 620d? | 2005-05-02 A | 2007-09-14 A | 100% | 2005-05-02 | 2007-09-14 | 620d? |  | S2,S1,C1,S5 | 13016h | 13016h | ServID | Ericsson | stephen.terrill@ericsson.com | Rel-7 | Maurice |  |  |  |  |
| 1054 | 357.1 | TR on ServID |  | 232d? | 2005-05-02 A | 2006-03-21 A | 100% | 2005-05-02 | 2006-03-21 | 232d? | finish no earlier than 2006-03-20 | S2 | 1856h | 1856h | ServID | Ericsson | stephen.terrill@ericsson.com | Rel-7 | Maurice |  |  |  |  |
| 1055 | 357.2 | Stage 1,2 of ServID |  | 144d? | 2005-11-11 A | 2006-05-31 A | 100% | 2005-11-11 | 2006-05-31 | 144d? | start no earlier than 2005-11-11 | S1,S2 | 1152h | 1152h | ServID | Ericsson | stephen.terrill@ericsson.com | Rel-7 | Maurice |  |  |  |  |
| 1056 | 357.3 | Stage 3 of ServID |  | 250d? | 2006-03-31 A | 2007-03-15 A | 100% | 2006-03-31 | 2007-03-15 | 250d? | finish no earlier than 2007-03-15 | C1 | 2000h | 2000h | ServID | Ericsson | christer.holmberg@ericsson.com | Rel-7 | Frederic |  |  |  |  |
| 1057 | 357.4 | Charging of ServID |  | 381d? | 2006-03-31 A | 2007-09-14 A | 100% | 2006-03-31 | 2007-09-14 | 381d? | finish no earlier than 2007-09-14 | S5 | 3048h | 3048h | ServID | Orange | alain.bibas@orange-ft.com | Rel-7 | Dionisio |  |  |  |  |
| 1058 | 358 | **Supporting Globally Routable User Agent URIs in IMS** |  | 415d? | 2005-11-14 A | 2007-06-15 A | 100% | 2005-11-14 | 2007-06-15 | 415d? |  | S2,S1,C1 | 7760h | 7760h | GRUU | RIM | Adrian Buckley (abuckley@rim.com) | Rel-7 | Maurice |  |  |  |  |
| 1059 | 358.1 | Deleted - TR on GRUU |  | 219d? | 2005-11-14 A | 2006-09-14 A | 100% | 2005-11-14 | 2006-09-14 | 219d? | finish no earlier than 2006-09-14 | S2 | 1752h | 1752h | GRUU | RIM | Adrian Buckley (abuckley@rim.com) | Rel-7 | Maurice | SP-32 |  |  |  |
| 1060 | 358.2 | Stage 1,2 of GRUU |  | 65d? | 2006-07-03 A | 2006-09-29 A | 100% | 2006-07-03 | 2006-09-29 | 65d? | start no earlier than 2006-07-03 | S1,S2 | 520h | 520h | GRUU | RIM | Adrian Buckley (abuckley@rim.com) | Rel-7 | Maurice |  |  |  |  |
| 1061 | 358.3 | Stage 3 of GRUU |  | 271d? | 2006-06-02 A | 2007-06-15 A | 100% | 2006-06-02 | 2007-06-15 | 271d? | finish no earlier than 2007-06-15 | C1 | 2168h | 2168h | GRUU | CableLabs | Bernie McKibben | Rel-7 | Frederic |  |  |  |  |
| 1062 | 359 | **Multimedia Telephony Service for IMS** |  | 357d? | 2006-02-01 A | 2007-06-15 A | 100% | 2006-02-01 | 2007-06-15 | 357d? |  | S1,C1,S4 | 8976h | 8976h | MTSI | Ericsson | peter.bleckert@ericsson.com | Rel-7 | Alain |  |  |  |  |
| 1063 | 359.1 | Stage 1 of MTSI |  | 173d? | 2006-02-01 A | 2006-09-29 A | 100% | 2006-02-01 | 2006-09-29 | 173d? | start no earlier than 2006-02-01 | S1 | 1384h | 1384h | MTSI-REQ | Ericsson | peter.bleckert@ericsson.com | Rel-7 | Alain |  |  |  |  |
| 1064 | 359.2 | Stage 3 of MTSI |  | 330d? | 2006-03-10 A | 2007-06-14 A | 100% | 2006-03-10 | 2007-06-14 | 330d? | finish no earlier than 2007-06-15 | C1 | 2640h | 2640h | MTSI | Ericsson | christer.holmberg@ericsson.com | Rel-7 | Frederic |  |  |  |  |
| 1065 | 359.3 | Media handling and interaction in MTSI |  | 262d? | 2006-03-15 A | 2007-03-15 A | 100% | 2006-03-15 | 2007-03-15 | 262d? | finish no earlier than 2007-03-15 | S4 | 2096h | 2096h | MTSI-MHI | Ericsson | olle.franceschi@ericsson.com | Rel-7 | Paolo |  |  |  |  |
| 1066 | 359.4 | Deleted - duplicates UID7039 - IMS Multimedia Telephony Service | milestone | 0d? | 2007-06-15 A | 2007-06-15 A | 100% | 2007-06-15 | 2007-06-15 | 0d? | start no earlier than 2007-06-15 | S1 |  |  | MMTEL | Ericsson | peter.bleckert@ericsson.com | Rel-7 | Alain | SP-32 |  |  |  |
| 1067 | 360 | Multimedia Telephony Service for IMS (MTSI) - UE Conformance Testing |  | 387d | 2007-09-19 A | 2009-03-12 A | 100% | 2007-09-19 | 2009-03-12 | 387d | finish no earlier than 2009-03-13 | R5 | 1664h | 1664h | MTSI-UEConTest | Ericsson, Motorola | Leif.Mattisson@ericsson.com, Jacob.John@motorola.com | Rel-7 | Ingbert |  | RP-090056 |  |  |
| 1068 | 361 | TISPAN requirements for Multimedia Telephony with PSTN/ISDN simulation services |  | 58d? | 2007-09-18 A | 2007-12-06 A | 100% | 2007-09-18 | 2007-12-06 | 58d? | start no earlier than 2007-09-18 | S1 | 464h | 464h | TMMTEL7 |  |  | Rel-7 | Alain |  |  | SP-37 |  |
| 1069 | 362 | **Maintenance of TISPAN release 1 common IMS** |  | 58d? | 2007-09-18 A | 2007-12-06 A | 100% | 2007-09-18 | 2007-12-06 | 58d? |  | S2 | 1392h | 1392h | MCIMSTR1 | Ericsson | Raymond Forbes | Rel-7 | Maurice |  |  | SP-38 | PCG-21 |
| 1070 | 362.1 | SA1 aspects of MCIMSTR1 |  | 58d? | 2007-09-18 A | 2007-12-06 A | 100% | 2007-09-18 | 2007-12-06 | 58d? | finish no earlier than 2007-12-06 | S1 | 464h | 464h | MCIMSTR1-S1 | Telecom Italia | Marco.DeLuca1@telecomitalia.it | Rel-7 | Alain |  |  | SP-38 | PCG-21 |
| 1071 | 362.2 | SA2 aspects of MCIMSTR1 |  | 58d? | 2007-09-18 A | 2007-12-06 A | 100% | 2007-09-18 | 2007-12-06 | 58d? | finish no earlier than 2007-12-06 | S2 | 464h | 464h | MCIMSTR1-S2 | Ericsson | Raymond Forbes | Rel-7 | Maurice |  |  | SP-38 | PCG-21 |
| 1072 | 363 | **PS domain and IMS impacts for supporting IMS Emergency calls** |  | 1760d? | 2000-09-18 A | 2007-06-15 A | 100% | 2000-09-18 | 2007-06-15 | 1760d? |  | S2,S1 | 44157h | 44157h | EMC1 | Siemens | Rainer Liebhart | Rel-7 | Maurice |  |  |  |  |
| 1073 | 10.1.1 | Service Requirements for IP-based emergency calls |  | 985d | 2000-09-18 A | 2004-06-25 A | 100% | 2000-09-18 | 2004-06-25 | 985d | finish no earlier than 2004-06-25 | S1 | 7880h | 7880h | EMC1 | Siemens | Rainer Liebhart | Rel-7 | Alain |  |  |  |  |
| 1074 | 363.2 | Study on Stage 2 for IMS-level solution |  | 668d? | 2003-02-26 A | 2005-09-16 A | 100% | 2003-02-26 | 2005-09-16 | 668d? | finish no earlier than 2005-09-16 | S2 | 5344h | 5344h | EMC1 | Siemens | Rainer Liebhart | Rel-7 | Maurice |  |  |  |  |
| 1075 | 363.3 | Study on Stage 2 for GPRS-level solution |  | 301d? | 2004-10-14 A | 2005-12-08 A | 100% | 2004-10-14 | 2005-12-08 | 301d? | finish no earlier than 2005-12-08 | S2 | 2408h | 2408h | EMC1 | Siemens | Rainer Liebhart | Rel-7 | Maurice |  |  |  |  |
| 1076 | 363.4 | Stage 2 Specification Phase - IMS-level |  | 200d? | 2005-09-05 A | 2006-06-09 A | 100% | 2005-09-05 | 2006-06-09 | 200d? | finish no earlier than 2006-06-09 | S2 | 1600h | 1600h | EMC1 | Siemens | Rainer Liebhart | Rel-7 | Maurice |  |  |  |  |
| 1077 | 363.5 | Deleted - Stage 2 Specification Phase - GPRS-level | milestone | 0d? | 2007-03-02 A | 2007-03-02 A | 100% | 2007-03-02 | 2007-03-02 | 0d? | start no earlier than 2007-03-02 | S2 |  |  | EMC1 | Siemens | Rainer Liebhart | Rel-7 | Maurice | SP-32 |  |  |  |

Notes:
- 1053: WID approved SP#28. WID updated SP#32
- 1054: - / Text3: 23.816
- 1055: - / Text3: 22.228, 23.228, 23.203
- 1056: CP#32 approved WID / Text3: 23.218, 24.229
- 1057: - / Text3: 32.260, 32.298, 32.299
- 1058: SP#29 approved WID
- 1059: Abandoned
- 1060: SP#29 approved WID / Text3: 22.228, 23.228, 23.218, 24.229
- 1061: CP#32 approved WID / Text3: 24.229
- 1062: -
- 1063: - / Text3: 22.173
- 1064: - / Text3: 24.173
- 1065: - / Text3: 26.114
- 1066: - / Text3: 22.173
- 1067: RP#43 completed. Linked UID_7038 (MTSI) / Text3: 34.123-1, 34.123-2, 34.123-3, 34.229-1, 34.229-2
- 1068: - / Text3: 22.273 (EI 181 002 maintenance)
- 1069: - / Text3: http://www.3gpp.org/specs/TISPAN-IMS-ansfer.htm
- 1070: - / Text3: 22.173, 22.273
- 1071: - / Text3: 23.406, 23.417, 23.508,23.509, 23.511
- 1072: -
- 1073: - / Text3: 22.976 (DB shows 04/2003 withdrawn Study on PS domain services and capabilities (az: belongs this really here ?!)
- 1074: - / Text3: 23.867
- 1075: - / Text3: 23.867
- 1076: - / Text3: 23.167, 23.228, 23.060, 23.002, 23.271
- 1077: -

| ID | WBS | Task | Type | Duration | Start | Finish | Complete | Baseline start | Baseline finish | Baseline duration | Constraint | Resources | Work | Actual work | Text1 | Text4 | Text5 | Text6 | Text8 | Text3 | Text12 | Text10 | Text11 |
| --- | --- | --- | --- | --- | --- | --- | --- | --- | --- | --- | --- | --- | --- | --- | --- | --- | --- | --- | --- | --- | --- | --- | --- |
| 1078 | 10.1 | **Emergency Call Enhancements for IP& PS Based Calls – stage 3** |  | 375d | 2006-01-09 A | 2007-06-15 A | 100% | 2006-01-09 | 2007-06-15 | 375d |  | C1 | 12845h | 12845h | EMC1 | Ericsson | alf.heidermark@ericsson.com | Rel-7 | Frederic |  |  |  |  |
| 1079 | 10.1.2 | CT1 IMS aspects to support IMS Emergency sessions |  | 350.82d | 2006-01-09 A | 2007-06-15 A | 100% | 2006-01-09 | 2007-06-15 | 350.82d | finish no earlier than 2007-06-15 | C1 | 2806.57h | 2806.57h | EMC1 | Ericsson | alf.heidermark@ericsson.com | Rel-7 | Frederic | 24.229 |  |  |  |
| 1080 | 10.1.2 | Deleted - CT3 IMS aspects to support IMS Emergency sessions |  | 95d | 2006-05-08 A | 2006-09-15 A | 100% | 2006-05-08 | 2006-09-15 | 95d | finish no earlier than 2006-09-15 | C3 | 760h | 760h | EMC1 | Ericsson | alf.heidermark@ericsson.com | Rel-7 | Gwiho | 29.163 | CP-33 |  |  |
| 1081 | 10.1.5 | Deleted - CT3 PS domain aspects to support IMS Emergency sessions |  | 95d | 2006-05-08 A | 2006-09-15 A | 100% | 2006-05-08 | 2006-09-15 | 95d | start no earlier than 2006-05-08 | C3 | 760h | 760h | EMC1 | Ericsson | alf.heidermark@ericsson.com | Rel-7 | Gwiho | 29.061 | CP-33 |  |  |
| 1082 | 10.1.5 | CT1 PS domain aspects to support IMS Emergency sessions |  | 349.9d | 2006-01-09 A | 2007-06-15 A | 100% | 2006-01-09 | 2007-06-15 | 349.9d | finish no earlier than 2007-06-15 | C1 | 2799.2h | 2799.2h | EMC1 | Ericsson | alf.heidermark@ericsson.com | Rel-7 | Frederic | 24.008, 24.234 |  |  |  |
| 1083 | 10.1.5 | CT4 PS domain aspects to support IMS Emergency sessions |  | 365d | 2006-01-09 A | 2007-06-01 A | 100% | 2006-01-09 | 2007-06-01 | 365d | finish no earlier than 2007-06-01 | C4 | 2920h | 2920h | EMC1-GPRSc4 | Ericsson | alf.heidermark@ericsson.com | Rel-7 | Kimmo | 29.060 |  |  |  |
| 1084 | 364 | IMS Support of Conferencing |  | 355d? | 2005-11-04 A | 2007-03-15 A | 100% | 2005-11-04 | 2007-03-15 | 355d? | finish no earlier than 2007-03-15 | C1 | 2840h | 2840h | IMSconf | Alcatel-Lucent | Keith Drage (drage@alcatel-lucent.com) | Rel-7 | Frederic | 24.147, 24.229 |  |  |  |
| 1085 | 365 | Performance Characterization of VoIMS over HSDPA\EUL channels |  | 713d? | 2005-03-15 A | 2007-12-06 A | 100% | 2005-03-15 | 2007-12-06 | 713d? | finish no earlier than 2007-12-06 | S4 | 5704h | 5704h | VoIMS-PCVoIMS | Alcatel-Lucent | mcgowan@alcatel-lucent.com | Rel-7 | Paolo | 26.935 |  |  |  |
| 1086 | 366 | **WLAN-UMTS Interworking Phase 2** |  | 371d? | 2004-01-05 A | 2005-06-07 A | 100% | 2004-01-05 | 2005-06-07 | 371d? |  | S1 | 3888h | 3888h | WLAN2 | Telenor | frederic.paint@telenor.com | Rel-7 | Alain | 33.234 (SP-36 SA3 CRs approved) |  |  |  |
| 1087 | 366.1 | Stage 1 on Session Continuity |  | 115d? | 2004-01-05 A | 2004-06-11 A | 100% | 2004-01-05 | 2004-06-11 | 115d? | start no earlier than 2004-01-05 | S1 | 920h | 920h | WLAN-SC |  |  | Rel-7 | Alain | 22.234 |  | SP-24 |  |
| 1088 | 366.2 | Stage 2 on Session Continuity: covered by SAE | milestone | 0d? | 2005-06-07 A | 2005-06-07 A | 100% | 2005-06-07 | 2005-06-07 | 0d? | finish no earlier than 2005-06-07 | S2 |  |  | WLAN-SC |  |  | Rel-7 | Maurice |  |  |  |  |
| 1089 | 367 | **WLAN Interworking – Private Network access from WLAN 3GPP IP Access** |  | 252d? | 2005-10-10 A | 2006-09-26 A | 100% | 2005-10-10 | 2006-09-26 | 252d? |  | S2,C1,C3,C4 | 8936h | 8936h | WLANPNA | NEC | Toshiyuki Tamura (tamurato@aj.jp.nec.com) | Rel-7 | Maurice |  |  |  |  |
| 1090 | 367.1 | WLAN-PNA - Stage 2 |  | 185d? | 2005-10-10 A | 2006-06-23 A | 100% | 2005-10-10 | 2006-06-23 | 185d? | start no earlier than 2005-10-10 | S2 | 1480h | 1480h | WLANPNA-st2 | NEC | Toshiyuki Tamura (tamurato@aj.jp.nec.com) | Rel-7 | Maurice | 23.234, 33.234 |  |  |  |
| 1091 | 367.2 | **WLAN-PNA - Stage 3** |  | 170d? | 2006-02-01 A | 2006-09-26 A | 100% | 2006-02-01 | 2006-09-26 | 170d? |  | C1,C3,C4 | 5440h | 5440h | WLANPNA-st3 | NEC |  | Rel-7 | Frederic |  |  |  |  |
| 1092 | 367.2.1 | CT1 aspets for WLAN-PNA |  | 170d? | 2006-02-01 A | 2006-09-26 A | 100% | 2006-02-01 | 2006-09-26 | 170d? | start no earlier than 2006-02-01 | C1 | 1360h | 1360h | WLANPNA-st3 | NEC |  | Rel-7 | Frederic | 24.234 |  |  |  |
| 1093 | 367.2.2 | CT3 aspets for WLAN-PNA |  | 170d? | 2006-02-01 A | 2006-09-26 A | 100% | 2006-02-01 | 2006-09-26 | 170d? | start no earlier than 2006-02-01 | C3 | 1360h | 1360h | WLANPNA-st3 | NEC |  | Rel-7 | Gwiho | 29.161 |  |  |  |
| 1094 | 367.2.3 | Deleted - CT4 aspets for WLAN-PNA |  | 170d? | 2006-02-01 A | 2006-09-26 A | 100% | 2006-02-01 | 2006-09-26 | 170d? | start no earlier than 2006-02-01 | C4 | 1360h | 1360h | WLANPNA-st3 | NEC |  | Rel-7 | Kimmo | 29.234 | CP-32 |  |  |
| 1095 | 368 | **Enhancements to support QoS provisioning over 3GPP/WLAN Interworking** |  | 520d? | 2005-03-14 A | 2007-03-09 A | 100% | 2005-03-14 | 2007-03-09 | 520d? |  | S2,C4,C1 | 8360h | 8360h | WLANQOS | Samsung |  | Rel-7 | Maurice |  |  |  |  |
| 1096 | 368.1 | Deleted - TR on support of QoS on WLAN |  | 232d? | 2005-03-14 A | 2006-01-31 A | 100% | 2005-03-14 | 2006-01-31 | 232d? | start no earlier than 2005-03-14 | S2 | 1856h | 1856h | WLANQOS | Samsung |  | Rel-7 | Maurice | 23.836 | SP-32 |  |  |
| 1097 | 368.2 | Stage 2 on support of QoS over 3GPP/WLAN interworking |  | 108d? | 2006-02-01 A | 2006-06-30 A | 100% | 2006-02-01 | 2006-06-30 | 108d? | start no earlier than 2006-02-01 | S2 | 864h | 864h | WLANQOS | Samsung |  | Rel-7 | Maurice | 23.234 |  |  |  |
| 1098 | 368.3 | Stage 3 CT4 on support of QoS over 3GPP/WLAN Interworking |  | 121d? | 2006-09-22 A | 2007-03-09 A | 100% | 2006-09-22 | 2007-03-09 | 121d? | finish no earlier than 2007-03-09 | C4 | 968h | 968h | WLANQOS | Huawei | zhang.peng@huawei.com | Rel-7 | Kimmo | 29.234, 23.008 |  |  |  |
| 1099 | 368.4 | Stage 3 CT1 on support of QoS over 3GPP/WLAN Interworking |  | 64d? | 2006-09-04 A | 2006-11-30 A | 100% | 2006-09-04 | 2006-11-30 | 64d? | finish no earlier than 2006-11-30 | C1 | 512h | 512h | WLANQOS | Huawei | zhang.peng@huawei.com | Rel-7 | Frederic | 24.234 |  |  |  |
| 1100 | 369 | **Location Services enhancements** |  | 906d? | 2004-06-28 A | 2007-12-17 A | 100% | 2004-06-28 | 2007-12-17 | 906d? |  | S1,S2,GP,C4,R2 | 46933.6h | 46933.6h | LCS3 |  |  | Rel-7 | Alain |  |  |  |  |
| 1101 | 369.1 | Stage 2 for LCS3 (including IMS emergency location aspects) |  | 446d? | 2004-12-31 A | 2006-09-15 A | 100% | 2004-12-31 | 2006-09-15 | 446d? | finish no earlier than 2006-09-15 | S2 | 3568h | 3568h | LCS3 | SiRF | brodilitz@sirf.com | Rel-7 | Maurice | 23.271 |  |  |  |
| 1102 | 369.2 | LCS Enhancements related to Location-Based Services |  | 695d? | 2005-01-03 A | 2007-08-31 A | 100% | 2005-01-03 | 2007-08-31 | 695d? | finish no earlier than 2007-08-31 | GP | 5560h | 5560h | LCS3-LBS | SiRF | kjudge@sirf.com | Rel-7 | Paolo | 43.059, 44.031, 48.008, 49.031 |  |  |  |
| 1103 | 369.3 | CT4 aspects for LCS UEPos-LBS |  | 240d? | 2006-01-02 A | 2006-12-01 A | 100% | 2006-01-02 | 2006-12-01 | 240d? | finish no earlier than 2006-12-01 | C4 | 1920h | 1920h | LCS3-UEPos-LBS | SiRF | brodilitz@sirf.com | Rel-7 | Kimmo | 24.030, 24.080, 29.002 |  |  |  |
| 1104 | 369.4 | UE positioning - Velocity |  | 394d? | 2005-03-15 A | 2006-09-15 A | 100% | 2005-03-15 | 2006-09-15 | 394d? | finish no earlier than 2006-09-15 | R2 | 3152h | 3152h | LCS3-UEPos-Velocity | SiRF | BRodilitz@SiRF.com | Rel-7 | Joern | 25.305, 25.331, 25.410, 25.413, 25.453 |  |  | RP-060459 |
| 1105 | 369.5 | Inclusion of Uplink TDOA UE positioning method in the UTRAN specifications |  | 849d? | 2004-09-15 A | 2007-12-17 A | 100% | 2004-09-15 | 2007-12-17 | 849d? | finish no earlier than 2007-12-17 | R2 | 6792h | 6792h | LCS3-UEPos-UTDOA | TruePosition | Robert Gross | Rel-7 | Joern | 25.305, 25.453 |  |  | RP-070797 |

Notes:
- 1078: -
- 1079: -
- 1080: Cancelled for Rel-7 and there is now corresponding Rel-8 WI
- 1081: Cancelled for Rel-7 and there is now corresponding Rel-8 WI
- 1082: -
- 1083: -
- 1084: CP#35 revised WID
- 1085: -
- 1086: Created at TSG#27 because of WLAN items belonging to Rel-7
- 1087: -
- 1088: -
- 1089: -
- 1090: Approved at SP#29
- 1091: Approved at CP#29
- 1092: Approved at CP#29
- 1093: Approved at CP#29
- 1094: CT4#31; no impacts identified, therefore completed. CP-32 stopped
- 1095: Moved from FS section Feb 06. SP-30 updated WID
- 1096: SP-32 stopped
- 1097: SP-30 updated WID
- 1098: CP-32 approved WID
- 1099: CP-32 approved WID
- 1100: -
- 1101: SP#27 approved WID.
- 1102: -
- 1103: -
- 1104: Completed Sept 2006; SR in RP-060459
- 1105: Completed Nov 2007; SR in RP-070797

| ID | WBS | Task | Type | Duration | Start | Finish | Complete | Baseline start | Baseline finish | Baseline duration | Constraint | Resources | Work | Actual work | Text1 | Text4 | Text5 | Text6 | Text8 | Text12 | Text11 | Text2 | Text7 |
| --- | --- | --- | --- | --- | --- | --- | --- | --- | --- | --- | --- | --- | --- | --- | --- | --- | --- | --- | --- | --- | --- | --- | --- |
| 1106 | 369.6 | **LCS for 3GPP Interworking WLAN** |  | 700d? | 2004-06-28 A | 2007-03-02 A | 100% | 2004-06-28 | 2007-03-02 | 700d? |  | S1 | 11901.6h | 11901.6h | LCS3-IWLAN | Telcordia | Mike Loushine | Rel-7 | Alain |  |  |  |  |
| 1107 | 369.6.1 | FS on 3GPP system to WLAN Interworking with LCS |  | 512.7d? | 2004-06-28 A | 2006-06-30 A | 100% | 2004-06-28 | 2006-06-30 | 512.7d? | finish no earlier than 2005-09-29 | S1 | 4101.6h | 4101.6h | LCS3-IWLAN-FSs1 | Telcordia | Mike Loushine | Rel-7 | Alain |  |  |  |  |
| 1108 | 369.6.2 | Deleted - Study of work on an LCS architecture for I-WLAN. |  | 180d? | 2006-06-26 A | 2007-03-02 A | 100% | 2006-06-26 | 2007-03-02 | 180d? | finish no earlier than 2007-03-02 | S2 | 1440h | 1440h | LCS3-IWLAN-FSs2 | LG Electronics | dhshim@lge.com ; phede@lge.com | Rel-7 | Maurice | SP-35 |  |  |  |
| 1109 | 369.6.3 | Stage 2 for LCS architecture for I-WLAN |  | 95d? | 2006-10-23 A | 2007-03-02 A | 100% | 2006-10-23 | 2007-03-02 | 95d? | finish no earlier than 2007-03-02 | S2 | 760h | 760h | LCS3-IWLAN | LG Electronics | dhshim@lge.com ; phede@lge.com | Rel-7 | Maurice |  |  |  |  |
| 1110 | 369.7 | Deleted - UE positioning Rel-7 |  | 849d? | 2004-09-15 A | 2007-12-17 A | 100% | 2004-09-15 | 2007-12-17 | 849d? |  | RP | 6792h | 6792h | LCS3-UEpos |  |  | Rel-7 | Joern | RP-38 |  |  |  |
| 1111 | 369.8 | Deleted - RAN2 aspects for LBS | milestone | 0d? | 2005-06-15 A | 2005-06-15 A | 100% | 2005-06-15 | 2005-06-15 | 0d? | start no earlier than 2005-06-15 | R2 |  |  | LCS3-UEPos-LBS | SiRF | BRodilitz@SiRF.com | Rel-7 | Joern | RP-31 |  |  |  |
| 1112 | 370 | **MBMS Enhancements** |  | 625d? | 2005-07-11 A | 2007-11-30 A | 100% | 2005-07-11 | 2007-11-30 | 625d? |  | S1,R1,C3 | 10844.6h | 10844.6h | MBMSE | China Mobile | liuhongyfw@chinamobile.com | Rel-7 | Alain |  |  |  |  |
| 1113 | 370.1 | Stage 1 of MBMSE |  | 109d? | 2005-07-11 A | 2005-12-08 A | 100% | 2005-07-11 | 2005-12-08 | 109d? | finish no earlier than 2005-12-08 | S1 | 872h | 872h | MBMSE | China Mobile | liuhongyfw@chinamobile.com | Rel-7 | Alain |  |  |  |  |
| 1114 | 370.2 | MBMS FDD Physical layer Enhancements |  | 117.29d? | 2006-12-15 A | 2007-06-04 A | 100% | 2006-12-15 | 2007-06-04 | 117.29d? | finish no earlier than 2007-06-04 | R1 | 938.32h | 938.32h | MBMSE-RANPhysFDD | Ericsson | Lars.Lindbom@ericsson.com | Rel-7 | Patrick |  | RP-070290 |  |  |
| 1115 | 370.3 | MBMS TDD Physical layer Enhancements |  | 117.29d? | 2006-12-15 A | 2007-06-04 A | 100% | 2006-12-15 | 2007-06-04 | 117.29d? | finish no earlier than 2007-06-04 | R1 | 938.32h | 938.32h | MBMSE-RANPhysTDD | IPWireless | Nicholas Anderson | Rel-7 | Patrick |  | RP-070291 |  |  |
| 1116 | 370.4 | MBMS Low Chip Rate TDD Physical Layer Enhancement |  | 127d? | 2007-03-16 A | 2007-09-10 A | 100% | 2007-03-16 | 2007-09-10 | 127d? | finish no earlier than 2007-09-10 | R1 | 1016h | 1016h | MBMSE-RANPhysLCRTDD | RITT | Lin Hui | Rel-7 | Patrick |  | RP-070292 |  |  |
| 1117 | 370.5 | MBMS Mz interface |  | 260d? | 2006-12-04 A | 2007-11-30 A | 100% | 2006-12-04 | 2007-11-30 | 260d? | finish no earlier than 2007-05-11 | C3 | 2080h | 2080h | MBMSMz | Huawei | Deng Tingting (ttdeng@huawei.com) | Rel-7 | Gwiho |  |  |  |  |
| 1118 | 371 | **MBMS - UE Conformance Testing** |  | 657d? | 2007-06-01 A | 2009-12-04 A | 100% | 2007-06-01 | 2009-12-04 | 657d? |  | R5 | 13848h | 13848h | MBMSE_UEConTest |  |  | Rel-7 | Ingbert |  |  | PCG-21 | SP-40 |
| 1119 | 371.1 | Conformance Test Aspects – MBMS TDD Physical layer Enhancements – MBSFN for HCR and VHCR TDD |  | 336d? | 2007-06-01 A | 2008-09-12 A | 100% | 2007-06-01 | 2008-09-12 | 336d? | start no earlier than 2007-06-01 | R5 | 2688h | 2688h | MBMSE-RANPhysTDD_UEConTest | IPWireless | tspeight@ipwireless.com | Rel-7 | Ingbert |  | RP-080541 |  |  |
| 1120 | 371.2 | Conformance Test Aspects – MBMS LCR TDD Physical Layer Enhancement |  | 342d? | 2008-05-30 A | 2009-09-18 A | 100% | 2008-05-30 | 2009-09-18 | 342d? | finish no earlier than 2009-09-18 | R5 | 2728h | 2728h | MBMSE-RANPhysLCRTDD_UEConTest | CATT | chenxiaozhong@datangmobile.cn | Rel-7 | Ingbert |  | RP-090715 | PCG-21 | RP-40 |
| 1121 | 371.3 | Conformance Test Aspects – MBSFN for FDD |  | 397d? | 2008-05-30 A | 2009-12-04 A | 100% | 2008-05-30 | 2009-12-04 | 397d? | finish no earlier than 2009-12-04 | R5 | 3176h | 3176h | MBMSE-UEConTest_RANPhysFDD | Huawei | Xiang Li (trica_li@huawei.com) | Rel-7 | Ingbert |  | RP-091214 | PCG-21 | RP-40 |
| 1122 | 372 | MBMS User Service Extensions |  | 392d? | 2005-12-07 A | 2007-06-07 A | 100% | 2005-12-07 | 2007-06-07 | 392d? | finish no earlier than 2007-06-07 | S4 | 3136h | 3136h | MBMSUSE | Ericsson | Thorsten.Lohmar@ericsson.com | Rel-7 | Paolo |  |  |  |  |
| 1123 | 373 | **Advanced Global Navigation Satellite System (A-GNSS) concept** |  | 830d? | 2004-06-28 A | 2007-08-31 A | 100% | 2004-06-28 | 2007-08-31 | 830d? |  | S1,GP,R2 | 9553.6h | 9553.6h | LCS3-AGNSS | Alcatel | Michel.monnerat@thalesaleniaspace.com | Rel-7 | Alain |  |  |  |  |
| 1124 | 373.1 | Towards A-GNSS Concept |  | 811.2d? | 2004-06-28 A | 2007-08-31 A | 100% | 2004-06-28 | 2007-08-31 | 811.2d? | finish no earlier than 2007-08-31 | GP | 6489.6h | 6489.6h | AGNSS-GP | Alcatel | richard.couty@space.alcatel.fr | Rel-7 | Paolo |  |  |  |  |
| 1125 | 373.2 | Global Navigation Satellite System (GNSS) in UTRAN |  | 383d? | 2005-12-15 A | 2007-06-04 A | 100% | 2005-12-15 | 2007-06-04 | 383d? | finish no earlier than 2007-06-04 | R2 | 3064h | 3064h | LCS3-GNSS-UTRAN | France Telecom | alain.abinakhoul@francetelecom.com | Rel-7 | Joern |  | RP-070482 |  |  |
| 1126 | 373.3 | Deleted - Towards A-GNSS Concept | milestone | 0d? | 2007-02-16 A | 2007-02-16 A | 100% | 2007-02-16 | 2007-02-16 | 0d? | start no earlier than 2007-02-16 | S1 |  |  | GNSS | Alcatel | richard.couty@space.alcatel.fr | Rel-7 | Alain | SP-34 |  |  |  |
| 1127 | 374 | A-GPS Minimum Performance |  | 351d? | 2006-04-28 A | 2007-08-31 A | 100% | 2006-04-28 | 2007-08-31 | 351d? | finish no earlier than 2007-08-31 | GP | 2808h | 2808h | GAGR | Spirent | richard.catmur@spirentcom.com | Rel-7 | Paolo |  |  |  |  |
| 1128 | 375 | **USSD message delivery and transfer to USIM** |  | 376d? | 2004-03-05 A | 2005-08-12 A | 100% | 2004-03-05 | 2005-08-12 | 376d? |  | S1,C6 | 2762.4h | 2762.4h | USSD-USIM | Axalto | Christophe Dubois (cdubois@axalto.com) | Rel-7 | Alain |  |  |  |  |
| 1129 | 375.1 | Stage 1 |  | 152d? | 2004-03-18 A | 2004-10-15 A | 100% | 2004-03-18 | 2004-10-15 | 152d? | start no earlier than 2004-03-18 | S1 | 1216h | 1216h | USSD-USIM | Axalto | Christophe Dubois (cdubois@axalto.com) | Rel-7 | Alain |  |  |  |  |
| 1130 | 375.2 | Alignment with requirements regarding USSD usage |  | 193.3d? | 2004-03-05 A | 2005-08-12 A | 100% | 2004-03-05 | 2005-08-12 | 193.3d? | finish no earlier than 2005-08-12 | C6 | 1546.4h | 1546.4h | USSD-USIM | Axalto | Christophe Dubois (cdubois@axalto.com) | Rel-7 | Xavier |  |  |  |  |

Notes:
- 1106: -
- 1107: - / Text3: 22.935
- 1108: Updated WID at SP#32 to change "stage 2" to "study" , duplicated UID 320017 deleted. SP#33 TR for Information. Last mention SP-35 Mar 2007 (abandoned ?) / Text3: 23.837
- 1109: WID at SP#55 / Text3: 23.234, 23.271, 23.167
- 1110: -
- 1111: - / Text3: 25.305, 25.331, 25.410, 25.413, 25.453
- 1112: -
- 1113: Structure created by MCC to include RAN aspects under SA1 Feature / Text3: 22.146, 22.246, 22.228
- 1114: Completed May 2007; SR in RP-070290 / Text3: 25.211, 25.212, 25.213, 25.101, 25.104, 25.331, 25.433, 25.346, 25.306
- 1115: Completed May 2007; SR in RP-070291 / Text3: 25.346, 25.221, 25.222, 25.223, 25.224, 25.306, 25.331, 25.402, 25.433, 25.102, 25.105, 25.123
- 1116: Completed May 2007; SR in RP-070292 / Text3: 25.346, 25.221, 25.222, 25.223, 25.224, 25.306, 25.331, 25.402, 25.433, 25.102, 25.105, 25.123
- 1117: - / Text3: 29.061
- 1118: Linked to Rel-7 Feature UID_31084 (MBMSE)
- 1119: RP#41 completed / Text3: 34.108, 34.122, 34.123-1/2/3
- 1120: RP#45 completed / Text3: 34.108, 34.123-1
- 1121: RP#46 completed / Text3: 34.108, 34.109, 34.121-1, 34.121-2, 34.123-1, 34.123-2, 34.123-3
- 1122: - / Text3: 26.346, 26.946
- 1123: -
- 1124: GP#36 completed
- 1125: Completed Sept 2006; SR in RP-070482 / Text3: 25.305, 25.331, 25.306, 25.413, 25.423, 25.433, 25.453, 25.302, 25.215, 25.401, 25.402, 25.450, 25.452
- 1126: -
- 1127: - / Text3: 45.005, 51.010
- 1128: -
- 1129: - / Text3: 22.090
- 1130: -

| ID | WBS | Task | Type | Duration | Start | Finish | Complete | Baseline start | Baseline finish | Baseline duration | Constraint | Resources | Work | Actual work | Text1 | Text4 | Text5 | Text6 | Text8 | Text3 | Text12 |
| --- | --- | --- | --- | --- | --- | --- | --- | --- | --- | --- | --- | --- | --- | --- | --- | --- | --- | --- | --- | --- | --- |
| 1131 | 376 | **Combinational Services** |  | 296d? | 2005-01-17 A | 2006-03-06 A | 100% | 2005-01-17 | 2006-03-06 | 296d? |  | S1,S2,C1,S4 | 5176h | 5176h | CSICS | TeliaSonera | Robert.Frank@teliasonera.com | Rel-7 | Alain |  |  |
| 1132 | 376.1 | Stage 1 for CSICS |  | 104d? | 2005-01-17 A | 2005-06-09 A | 100% | 2005-01-17 | 2005-06-09 | 104d? | start no earlier than 2005-01-17 | S1 | 832h | 832h | CSICS | TeliaSonera | Robert.Frank@teliasonera.com | Rel-7 | Alain | 22.279 |  |
| 1133 | 376.2 | Stage 2 for CSICS |  | 130d? | 2005-01-17 A | 2005-07-15 A | 100% | 2005-01-17 | 2005-07-15 | 130d? | start no earlier than 2005-01-17 | S2 | 1040h | 1040h | CSICS | TeliaSonera | Robert.Frank@teliasonera.com | Rel-7 | Maurice | 23.279 |  |
| 1134 | 376.3 | Stage 3 for CSICS CN aspects |  | 221d? | 2005-05-02 A | 2006-03-06 A | 100% | 2005-05-02 | 2006-03-06 | 221d? | finish no earlier than 2006-03-06 | C1 | 1768h | 1768h | CSICS | Vodafone | Peter Dawes | Rel-7 | Frederic | 24.879, 24.279, 24.229, 24.008 |  |
| 1135 | 376.4 | Stage 3 for codec aspects |  | 192d? | 2005-03-15 A | 2005-12-07 A | 100% | 2005-03-15 | 2005-12-07 | 192d? | finish no earlier than 2005-12-07 | S4 | 1536h | 1536h | CSICS-Codec | Ericsson | Per.Frojdh@ericsson.com | Rel-7 | Paolo | 26.141, 26.235 |  |
| 1136 | 377 | **CAMEL Trunk Triggers** |  | 251d? | 2004-12-17 A | 2005-12-05 A | 100% | 2004-12-17 | 2005-12-05 | 251d? |  | S1,C4 | 6024h | 6024h | TTCAMEL | Nortel | Amar Deol (deola@nortelnetworks.com) | Rel-7 | Alain |  |  |
| 1137 | 377.1 | Stage 1 for CAMEL Trunk Triggers |  | 251d? | 2004-12-17 A | 2005-12-05 A | 100% | 2004-12-17 | 2005-12-05 | 251d? |  | S1 | 2008h | 2008h | TTCAMEL | Nortel | Amar Deol (deola@nortelnetworks.com) | Rel-7 | Alain | 22.078 |  |
| 1138 | 377.2 | CAMEL Trunk Originated Trigger Detection Points |  | 251d? | 2004-12-17 A | 2005-12-05 A | 100% | 2004-12-17 | 2005-12-05 | 251d? | start no earlier than 2004-12-17 | C4 | 2008h | 2008h | CamelR7 | Nortel | David Hutton (dhutton@nortel.com) | Rel-7 | Kimmo |  |  |
| 1139 | 378 | **IMS Service Brokering enhancements** |  | 69d? | 2005-12-07 A | 2006-03-13 A | 100% | 2005-12-07 | 2006-03-13 | 69d? |  | S1 | 1104h | 1104h | ISB | Telcordia | jbakker@telcordia.com | Rel-7 | Alain | 22.228 |  |
| 1140 | 378.1 | Stage 1 for ISB |  | 69d? | 2005-12-07 A | 2006-03-13 A | 100% | 2005-12-07 | 2006-03-13 | 69d? | finish no earlier than 2006-03-13 | S1 | 552h | 552h | ISB-s1 | Telcordia | jbakker@telcordia.com | Rel-7 | Alain | 22.228 |  |
| 1141 | 379 | **Enhancements of VGCS for public authority officials** |  | 731d? | 2004-08-27 A | 2007-06-15 A | 100% | 2004-08-27 | 2007-06-15 | 731d? |  | S1,C1,C4,G2 | 25920h | 25920h | EVGCS |  |  | Rel-7 | Alain | 43.068, 44.068, 24.008, 29.002 |  |
| 1142 | 379.1 | Stage 1 | milestone | 0d? | 2004-08-27 A | 2004-08-27 A | 100% | 2004-08-27 | 2004-08-27 | 0d? | finish no earlier than 2004-08-27 | S1 |  |  | EVGCS | Siemens | Joerg Swetina (joerg.swetina@nw.neclab.eu) | Rel-7 | Alain | 42.068, 43.068 |  |
| 1143 | 379.2 | **Architecture and protocol aspects** |  | 731d? | 2004-08-27 A | 2007-06-15 A | 100% | 2004-08-27 | 2007-06-15 | 731d? |  | C1,C4 | 14904h | 14904h | EVGCS | Siemens | robert.zaus@nsn.com | Rel-7 | Frederic | 43.068, 44.068 |  |
| 1144 | 379.2.1 | CT1 aspects of EVGCS |  | 731d? | 2004-08-27 A | 2007-06-15 A | 100% | 2004-08-27 | 2007-06-15 | 731d? | finish no earlier than 2006-09-15 | C1 | 5848h | 5848h | EVGCS | Siemens | robert.zaus@nsn.com | Rel-7 | Frederic | 43.068, 44.068, 24.008 |  |
| 1145 | 379.2.2 | CT4 aspects of EVGCS |  | 401d? | 2004-08-27 A | 2006-03-10 A | 100% | 2004-08-27 | 2006-03-10 | 401d? | finish no earlier than 2006-03-10 | C4 | 3208h | 3208h | EVGCS | Siemens | robert.zaus@nsn.com | Rel-7 | Kimmo | 29.002 |  |
| 1146 | 379.3 | GERAN2 aspects |  | 646d? | 2004-08-27 A | 2007-02-16 A | 100% | 2004-08-27 | 2007-02-16 | 646d? | finish no earlier than 2007-02-16 | G2 | 5168h | 5168h | EVGCS | Siemens | kenneth.isaacs@roke.co.uk | Rel-7 | Gert |  |  |
| 1147 | 380 | **Improvements of VGCS for parallel use of services** |  | 523d? | 2005-03-15 A | 2007-03-15 A | 100% | 2005-03-15 | 2007-03-15 | 523d? |  | S1 | 12230.2h | 12230.2h | IVGCS |  |  | Rel-7 | Alain |  |  |
| 1148 | 380.1 | Service Requirements for VGCS improvements |  | 62d? | 2005-03-15 A | 2005-06-08 A | 100% | 2005-03-15 | 2005-06-08 | 62d? | finish no earlier than 2005-06-08 | S1 | 496h | 496h | IVGCS | T-Mobile | kurt.bischinger@t-mobile.at | Rel-7 | Alain | 42.068 |  |
| 1149 | 380.2 | Stage 2 modifications for VGCS improvements |  | 335d? | 2005-12-01 A | 2007-03-14 A | 100% | 2005-12-01 | 2007-03-14 | 335d? | start no earlier than 2005-12-01 | C1 | 2680h | 2680h | IVGCS | T-Mobile | kurt.bischinger@t-mobile.at | Rel-7 | Frederic | 43.068 |  |
| 1150 | 380.3 | **Protocol aspects** |  | 336d? | 2005-12-01 A | 2007-03-15 A | 100% | 2005-12-01 | 2007-03-15 | 336d? |  | C1 | 5376h | 5376h | IVGCS | T-Mobile | Dieter Jacobsohn | Rel-7 | Frederic | 44.068 |  |
| 1151 | 380.3.1 | CT1 aspects of IVGCS |  | 336d? | 2005-12-01 A | 2007-03-15 A | 100% | 2005-12-01 | 2007-03-15 | 336d? | finish no earlier than 2007-03-15 | C1 | 2688h | 2688h | IVGCS | T-Mobile |  | Rel-7 | Frederic | 43.068, 44.068 |  |
| 1152 | 380.3.2 | Deleted - CT4 aspects of IVGCS | milestone | 0d? | 2007-03-09 A | 2007-03-09 A | 100% | 2007-03-09 | 2007-03-09 | 0d? | finish no earlier than 2007-03-09 | C4 |  |  | IVGCS-St3-c4 | T-mobile |  | Rel-7 | Kimmo | 29.002 | CP-35 |
| 1153 | 381 | **OSA Rel-7** |  | 584d? | 2005-03-15 A | 2007-06-08 A | 100% | 2005-03-15 | 2007-06-08 | 584d? |  | S1,C5 | 17920h | 17920h | OSA7 | AePONA | eamonn.murray@aepona.com | Rel-7 | Alain |  |  |
| 1154 | 381.1 | Service Requirements for OSA Service Broker |  | 62d? | 2005-03-15 A | 2005-06-08 A | 100% | 2005-03-15 | 2005-06-08 | 62d? | finish no earlier than 2005-06-08 | S1 | 496h | 496h | OSA7-SB | AePONA | eamonn.murray@aepona.com | Rel-7 | Alain | 22.127 |  |
| 1155 | 381.2 | Stage 2 OSA API Service Brokering |  | 156d? | 2006-04-28 A | 2006-12-01 A | 100% | 2006-04-28 | 2006-12-01 | 156d? |  | C5 | 1248h | 1248h | OSA7-SB | AePONA | damian.oneill@aepona.com | Rel-7 | Kimmo | 23.198 |  |
| 1156 | 381.3 | Stage 3 OSA API Service Brokering |  | 156d? | 2006-04-28 A | 2006-12-01 A | 100% | 2006-04-28 | 2006-12-01 | 156d? | finish no earlier than 2006-12-01 | C5 | 1248h | 1248h | OSA7-SB | AePONA | damian.oneill@aepona.com | Rel-7 | Kimmo | 29.198-16 |  |

Notes:
- 1131: -
- 1132: -
- 1133: -
- 1134: -
- 1135: -
- 1136: -
- 1137: -
- 1138: -
- 1139: No CR submitted in rel-8 (according to CR database).
- 1140: No Rel-8 changes
- 1141: Moved from Rel-6 UID_50563 Enhancements of VGCS in public networks for communication of public authority officials
- 1142: Voice Group Call Service
- 1143: -
- 1144: -
- 1145: -
- 1146: -
- 1147: Voice Group Call Service
- 1148: -
- 1149: -
- 1150: Previous name (before CT32) was Architecture and protocol aspects
- 1151: -
- 1152: CT4#33 stage 2 solution is still open. ...
- 1153: -
- 1154: az: WID URL corrected
- 1155: -
- 1156: -

| ID | WBS | Task | Type | Duration | Start | Finish | Complete | Baseline start | Baseline finish | Baseline duration | Constraint | Resources | Work | Actual work | Text1 | Text3 | Text4 | Text5 | Text6 | Text8 | Text12 | Text11 |
| --- | --- | --- | --- | --- | --- | --- | --- | --- | --- | --- | --- | --- | --- | --- | --- | --- | --- | --- | --- | --- | --- | --- |
| 1157 | 381.4 | **OSA Stage 2/3 enhancements** |  | 291d? | 2006-04-28 A | 2007-06-08 A | 100% | 2006-04-28 | 2007-06-08 | 291d? |  | C5 | 10256h | 10256h | OSA7 | 29.198/9, 23.198 | AePONA | damian.oneill@aepona.com | Rel-7 | Kimmo |  |  |
| 1158 | 381.4.1 | Parlay X Message Broadcast Web Service |  | 156d? | 2006-04-28 A | 2006-12-01 A | 100% | 2006-04-28 | 2006-12-01 | 156d? | finish no earlier than 2006-12-01 | C5 | 1248h | 1248h | OSA7 | 29.199-15, 23.198 | ETRI |  | Rel-7 | Kimmo |  |  |
| 1159 | 381.4.2 | Parlay X Geocoding Web Service |  | 156d? | 2006-04-28 A | 2006-12-01 A | 100% | 2006-04-28 | 2006-12-01 | 156d? | finish no earlier than 2006-12-01 | C5 | 1248h | 1248h | OSA7 | 29.199-16, 23.198 | ETRI |  | Rel-7 | Kimmo |  |  |
| 1160 | 381.4.3 | Parlay X Application driven QoS Web Service |  | 226d? | 2006-04-28 A | 2007-03-09 A | 100% | 2006-04-28 | 2007-03-09 | 226d? | finish no earlier than 2007-03-09 | C5 | 1808h | 1808h | OSA7 | 29.199-17, 23.198 | BT |  | Rel-7 | Kimmo |  |  |
| 1161 | 381.4.4 | Parlay-X Device Capabilities and Configuration |  | 162d? | 2006-10-26 A | 2007-06-08 A | 100% | 2006-10-26 | 2007-06-08 | 162d? | finish no earlier than 2007-06-09 | C5 | 1296h | 1296h | OSA7 | 29.199-18, 23.198 | Telenor |  | Rel-7 | Kimmo |  |  |
| 1162 | 381.4.5 | Parlay-X Multimedia Streaming Session Management Web Service |  | 97d? | 2006-10-26 A | 2007-03-09 A | 100% | 2006-10-26 | 2007-03-09 | 97d? | start no earlier than 2006-10-26 | C5 | 776h | 776h | OSA7 | 29.199-19, 23.198 | Telenor |  | Rel-7 | Kimmo |  |  |
| 1163 | 381.4.6 | Parlay-X Multimedia Multicast Control Web Service |  | 97d? | 2006-10-26 A | 2007-03-09 A | 100% | 2006-10-26 | 2007-03-09 | 97d? | start no earlier than 2006-10-26 | C5 | 776h | 776h | OSA7 | 29.199-20, 23.198 | ETRI |  | Rel-7 | Kimmo |  |  |
| 1164 | 381.4.7 | OSA API Conference Call Control SCF |  | 97d? | 2006-10-26 A | 2007-03-09 A | 100% | 2006-10-26 | 2007-03-09 | 97d? | start no earlier than 2006-10-26 | C5 | 776h | 776h | OSA7 | 29.198-04-5, 23.198 | Ericsson |  | Rel-7 | Kimmo |  |  |
| 1165 | 382 | **Selective Disabling of UE Capabilities** |  | 624.36d? | 2005-01-24 A | 2007-06-15 A | 100% | 2005-01-24 | 2007-06-15 | 624.36d? |  | S1,S2,C1 | 12351.7h | 12351.7h | SDoUE |  | Motorola |  | Rel-7 | Alain |  |  |
| 1166 | 382.1 | Stage 1 of SDoUE |  | 393.6d? | 2005-01-24 A | 2006-12-08 A | 100% | 2005-01-24 | 2006-12-08 | 393.6d? | finish no earlier than 2006-12-08 | S1 | 3148.8h | 3148.8h | SDoUE-CR | 22.011 | Motorola |  | Rel-7 | Alain |  |  |
| 1167 | 382.2 | Deleted - TR on different possible architectures |  | 195d? | 2005-03-21 A | 2005-12-16 A | 100% | 2005-03-21 | 2005-12-16 | 195d? | finish no earlier than 2005-12-16 | S2 | 1560h | 1560h | SDoUE-FS | 23.805 abandonned at SP-30; descendant C1 24.305 | Vodafone | Gavin.Wong@vodafone.com | Rel-7 | Maurice | SP-30 |  |
| 1168 | 382.3 | Stage 3 of SDoUE |  | 331d? | 2006-03-10 A | 2007-06-15 A | 100% | 2006-03-10 | 2007-06-15 | 331d? | finish no earlier than 2007-06-15 | C1 | 2648h | 2648h | SDoUE | 24.305 | Ericsson | christian.herrero@ericsson.com | Rel-7 | Frederic |  |  |
| 1169 | 383 | **Network selection enhancements (NSP)** |  | 328d? | 2006-03-15 A | 2007-06-15 A | 100% | 2006-03-15 | 2007-06-15 | 328d? |  | S1 | 6320h | 6320h | NSP-CR | 22.101, 22.011, 23.122, 24.008, 25.304, 31.102, 45.008 | O2 | chris.friel@o2.com | Rel-7 | Alain |  |  |
| 1170 | 383.1 | Stage 1 of NSP |  | 191d? | 2006-03-15 A | 2006-12-06 A | 100% | 2006-03-15 | 2006-12-06 | 191d? | start no earlier than 2006-03-15 | S1 | 1528h | 1528h | NSP-TS | 22.101, 22.011, 23.122, 24.008, 25.304, 31.102, 45.008 | O2 | chris.friel@o2.com | Rel-7 | Alain |  |  |
| 1171 | 383.2 | Procedural aspects of NSP |  | 271d? | 2006-06-02 A | 2007-06-15 A | 100% | 2006-06-02 | 2007-06-15 | 271d? | finish no earlier than 2007-06-15 | C1 | 2168h | 2168h | NSP-CR | 23.122, 24.008, 31.102 | Motorola | Andrew Howell | Rel-7 | Frederic |  |  |
| 1172 | 384 | Network selection enhancements (NSP) - UE Conformance Testing |  | 396d? | 2007-06-01 A | 2008-12-05 A | 100% | 2007-06-01 | 2008-12-05 | 396d? | finish no earlier than 2008-12-05 | R5 | 3168h | 3168h | NSP-CR_UEConTest | 34.108, 34.123-1, 34.123-2, 34.123-3 | Nokia | jarkko.hellsten@nokia.com | Rel-7 | Ingbert |  | RP-080819 |
| 1173 | 385 | **Access Class Barring and Overload Protection** |  | 650d? | 2004-03-15 A | 2006-09-08 A | 100% | 2004-03-15 | 2006-09-08 | 650d? |  | S2,C1 | 3568h | 3568h | ACBOP | 23.898 | Vodafone | Chris Pudney | Rel-7 | Maurice |  |  |
| 1174 | 385.1 | TR on Stage 2 |  | 274d? | 2004-03-15 A | 2005-03-31 A | 100% | 2004-03-15 | 2005-03-31 | 274d? | finish no earlier than 2005-03-31 | S2 | 2192h | 2192h | ACBOP | 23.898 | NTT DoCoMo | Jean-Jacques Davidian (davidian@docomo.fr) | Rel-7 | Maurice |  |  |
| 1175 | 385.2 | Stage 3 CN aspects of ACBOP |  | 172d? | 2005-06-06 A | 2006-01-31 A | 100% | 2005-06-06 | 2006-01-31 | 172d? | start no earlier than 2005-06-06 | C1 | 1376h | 1376h | ACBOP | 24.008 |  |  | Rel-7 | Frederic |  |  |
| 1176 | 385.3 | Deleted - Potential impact on Iu interface Overload functionality | milestone | 0d? | 2004-03-15 A | 2004-03-15 A | 100% | 2004-03-15 | 2004-03-15 | 0d? | finish no earlier than 2004-03-15 | RP |  |  | ACBOP | 25.413 |  |  | Rel-7 | Issam | RP-25 |  |
| 1177 | 385.4 | Deleted - Extra ACBOP information in RAN | milestone | 0d? | 2004-03-15 A | 2004-03-15 A | 100% | 2004-03-15 | 2004-03-15 | 0d? | finish no earlier than 2004-03-15 | RP |  |  | ACBOP | 25.331 |  |  | Rel-7 | Issam | RP-25 |  |
| 1178 | 385.5 | Deleted - Extra ACBOP information in GERAN | milestone | 0d? | 2006-09-08 A | 2006-09-08 A | 100% | 2006-09-08 | 2006-09-08 | 0d? | start no earlier than 2006-09-08 | GP |  |  | ACBOP | 44.018 |  |  | Rel-7 | Paolo | RP-33 |  |
| 1179 | 386 | **System enhancements for fixed broadband access to IMS** |  | 876d? | 2003-11-05 A | 2007-03-14 A | 100% | 2003-11-05 | 2007-03-14 | 876d? |  | S2,S3,S5,C1,C3,C4 | 36656h | 36656h | FBI |  |  |  | Rel-7 | Maurice |  |  |
| 1180 | 386.1 | **TISPAN Rel 1 related aspects** |  | 873d? | 2003-11-05 A | 2007-03-09 A | 100% | 2003-11-05 | 2007-03-09 | 873d? |  | S2 | 31568h | 31568h | FBI-TIS1 |  |  |  | Rel-7 | Maurice |  |  |
| 1181 | 386.1.1 | Stage 2 of FBI for TISPAN R1 |  | 365d? | 2004-10-14 A | 2006-03-08 A | 100% | 2004-10-14 | 2006-03-08 | 365d? | start no earlier than 2004-10-14 | S2 | 2920h | 2920h | FBI-TIS1 |  |  |  | Rel-7 | Maurice |  |  |

Notes:
- 1157: CP#34: WID updated. Completion 12/06 =>03/07
- 1158: -
- 1159: -
- 1160: -
- 1161: -
- 1162: -
- 1163: -
- 1164: -
- 1165: Moved from FS section Feb 06
- 1166: Moved from FS section Feb 06
- 1167: Moved from FS section Feb 06. Abandoned at SP-30
- 1168: -
- 1169: -
- 1170: -
- 1171: -
- 1172: RP#42 completed. Testing for Feature UID_7041 (NSP-CR)
- 1173: -
- 1174: -
- 1175: -
- 1176: -
- 1177: -
- 1178: -
- 1179: -
- 1180: -
- 1181: -

| ID | WBS | Task | Duration | Start | Finish | Complete | Baseline start | Baseline finish | Baseline duration | Constraint | Resources | Work | Actual work | Text1 | Text4 | Text5 | Text6 | Text8 | Text3 | Text12 |
| --- | --- | --- | --- | --- | --- | --- | --- | --- | --- | --- | --- | --- | --- | --- | --- | --- | --- | --- | --- | --- |
| 1182 | 386.1.2 | **Protocol impact of FBI for TISPAN R1** | 873d? | 2003-11-05 A | 2007-03-09 A | 100% | 2003-11-05 | 2007-03-09 | 873d? |  | C1 | 20720h | 20720h | FBI-TIS1 | Siemens | peter.leis@nsn.com | Rel-7 | Frederic |  |  |
| 1183 | 386.1.2.1 | CT1 aspects of FBI for TISPAN R1 | 802d? | 2003-11-05 A | 2006-11-30 A | 100% | 2003-11-05 | 2006-11-30 | 802d? | finish no earlier than 2006-11-30 | C1 | 6416h | 6416h | FBI-TIS1 | Siemens | peter.leis@nsn.com | Rel-7 | Frederic | 24.819, 24.229 |  |
| 1184 | 386.1.2.2 | CT3 aspects of FBI for TISPAN R1 | 808d? | 2003-11-05 A | 2006-12-08 A | 100% | 2003-11-05 | 2006-12-08 | 808d? | finish no earlier than 2006-12-08 | C3 | 6464h | 6464h | FBI-TIS1 | Siemens | peter.leis@nsn.com | Rel-7 | Gwiho | 29.163, 29.209 |  |
| 1185 | 386.1.2.3 | CT4 aspects of FBI for TISPAN R1 | 301d? | 2006-01-13 A | 2007-03-09 A | 100% | 2006-01-13 | 2007-03-09 | 301d? | finish no earlier than 2007-03-09 | C4 | 2408h | 2408h | FBI-TIS1-st3-c4 | Siemens | peter.leis@nsn.com | Rel-7 | Kimmo | 29.229 |  |
| 1186 | 386.1.3 | Security Enhancements for FBI | 118d? | 2005-06-28 A | 2005-12-08 A | 100% | 2005-06-28 | 2005-12-08 | 118d? | start no earlier than 2005-06-28 | S3 | 944h | 944h | FBI-ISE | Ericsson | Bengt.Sahlin@ericsson.com | Rel-7 | Dionisio | 33.203 |  |
| 1187 | 386.2 | **PacketCable Related aspects** | 291d? | 2006-02-01 A | 2007-03-14 A | 100% | 2006-02-01 | 2007-03-14 | 291d? |  | S2,S5,C1 | 5088h | 5088h | FBI-PCBL | CableLabs | Bernie McKibben | Rel-7 | Maurice |  |  |
| 1188 | 386.2.1 | Stage 1,2 of FBI for PacketCable | 228d? | 2006-02-01 A | 2006-12-15 A | 100% | 2006-02-01 | 2006-12-15 | 228d? | finish no earlier than 2006-12-15 | S2 | 1824h | 1824h | FBI-PCBL | CableLabs | Bernie McKibben | Rel-7 | Maurice | 22.228, 23.228 |  |
| 1189 | 386.2.2 | Protocol impact of FBI for PacketCable | 228d? | 2006-05-01 A | 2007-03-14 A | 100% | 2006-05-01 | 2007-03-14 | 228d? | finish no earlier than 2007-03-15 | C1 | 1824h | 1824h | FBI-PCBL |  |  | Rel-7 | Frederic |  |  |
| 1190 | 386.2.3 | SA5 Charging aspects of FBI for PacketCable | 180d? | 2006-03-31 A | 2006-12-07 A | 100% | 2006-03-31 | 2006-12-07 | 180d? | finish no earlier than 2006-12-07 | S5 | 1440h | 1440h | FBI-PCBL-CH | CableLabs | Bernie McKibben | Rel-7 | Dionisio | 32.240, 32.260, 32.298, 32.299 |  |
| 1191 | 387 | **Support of SMS over generic 3GPP IP access** | 696d? | 2004-10-14 A | 2007-06-14 A | 100% | 2004-10-14 | 2007-06-14 | 696d? |  | S2,C4,C1 | 12408h | 12408h | SMSIP | Huawei | zhangwenlin@huawei.com | Rel-7 | Maurice |  |  |
| 1192 | 387.1 | FS on SMSIP | 173d? | 2004-10-14 A | 2005-06-13 A | 100% | 2004-10-14 | 2005-06-13 | 173d? | start no earlier than 2004-10-14 | S2 | 1384h | 1384h | SMSIP | Huawei | zhangwenlin@huawei.com | Rel-7 | Maurice | 23.804 |  |
| 1193 | 387.2 | Stage 2 for SMSIP | 333d? | 2005-06-08 A | 2006-09-15 A | 100% | 2005-06-08 | 2006-09-15 | 333d? | finish no earlier than 2006-09-15 | S2 | 2664h | 2664h | SMSIP | Huawei | zhangwenlin@huawei.com | Rel-7 | Maurice | 23.204 |  |
| 1194 | 387.3 | **Stage 3 for SMSIP** | 527d? | 2005-06-08 A | 2007-06-14 A | 100% | 2005-06-08 | 2007-06-14 | 527d? |  | C4,C1 | 8360h | 8360h | SMSIP-St3 | Nokia | jari.jansson@nokia.com | Rel-7 | Kimmo |  |  |
| 1195 | 387.3.1 | CT1 aspects for SMSIP | 527d? | 2005-06-08 A | 2007-06-14 A | 100% | 2005-06-08 | 2007-06-14 | 527d? | finish no earlier than 2007-06-15 | C1 | 4216h | 4216h | SMSIP | Nokia | jari.jansson@nokia.com | Rel-7 | Frederic | 23.040, 24.229 |  |
| 1196 | 387.3.2 | CT4 aspects for SMSIP | 518d? | 2005-06-08 A | 2007-06-01 A | 100% | 2005-06-08 | 2007-06-01 | 518d? | finish no earlier than 2007-06-01 | C4 | 4144h | 4144h | SMSIP-St3-c4 | Nokia | jari.jansson@nokia.com | Rel-7 | Kimmo | 23.008, 29.002 |  |
| 1197 | 388 | **Evolution of Policy Control and Charging** | 817d? | 2004-10-14 A | 2007-11-30 A | 100% | 2004-10-14 | 2007-11-30 | 817d? |  | S2,S5,C3,C1 | 30336h | 30336h | PCC | Nokia | balazs.bertenyi@nsn.com | Rel-7 | Maurice |  |  |
| 1198 | 388.1 | Deleted - TR for PCC | 315d? | 2004-10-14 A | 2005-12-29 A | 100% | 2004-10-14 | 2005-12-29 | 315d? | finish no earlier than 2005-12-28 | S2 | 2520h | 2520h | PCC | Nokia | balazs.bertenyi@nsn.com | Rel-7 | Maurice | 23.803 | SP-33 |
| 1199 | 388.2 | Stage 2 for PCC | 315d? | 2005-07-04 A | 2006-09-15 A | 100% | 2005-07-04 | 2006-09-15 | 315d? | finish no earlier than 2006-09-15 | S2 | 2520h | 2520h | PCC | Nokia | balazs.bertenyi@nsn.com | Rel-7 | Maurice | 23.203 |  |
| 1200 | 388.3 | Evolution of policy control and flow based bearer level charging | 109d? | 2006-08-01 A | 2006-12-29 A | 100% | 2006-08-01 | 2006-12-29 | 109d? | start no earlier than 2006-08-01 | S2 | 872h | 872h | PCC | Nokia | balazs.bertenyi@nsn.com | Rel-7 | Maurice | 23.207, 23.002, 23.228 |  |
| 1201 | 388.4 | SA5 Charging aspects of PCC | 316d? | 2006-03-31 A | 2007-06-15 A | 100% | 2006-03-31 | 2007-06-15 | 316d? | finish no earlier than 2007-06-15 | S5 | 2528h | 2528h | PCC-CH | Orange | alain.bibas@orange-ft.com | Rel-7 | Dionisio | 32.250, 32.251, 32.298, 32.299 |  |
| 1202 | 388.5 | Gx reference point for Policy and Charging Control | 521d? | 2005-12-02 A | 2007-11-30 A | 100% | 2005-12-02 | 2007-11-30 | 521d? | finish no earlier than 2007-09-14 | C3 | 4168h | 4168h | PCC-Gx | Siemens | Thomas.Belling@nsn.com | Rel-7 | Gwiho | 29.212 (not progressed to Rel-7: 29.210, 29.207, 29.208) |  |
| 1203 | 388.6 | **Rx reference point for PCC CT3 aspects** | 521d? | 2005-12-02 A | 2007-11-30 A | 100% | 2005-12-02 | 2007-11-30 | 521d? |  | C3,C1 | 11192h | 11192h | PCC-Rx | Ericsson | j.javier.pastor@ericsson.com | Rel-7 | Gwiho |  |  |
| 1204 | 388.6.1 | PCC-Rx CT3 aspects | 521d? | 2005-12-02 A | 2007-11-30 A | 100% | 2005-12-02 | 2007-11-30 | 521d? | finish no earlier than 2007-09-14 | C3 | 4168h | 4168h | PCC-Rx-c3 | Ericsson | j.javier.pastor@ericsson.com | Rel-7 | Gwiho | 29.213, 29.214 (not progressed to Rel-7: 29.209, 29.211) |  |
| 1205 | 388.6.2 | PCC-Rx CT1 aspects | 357d? | 2005-12-02 A | 2007-06-15 A | 100% | 2005-12-02 | 2007-06-15 | 357d? | finish no earlier than 2007-06-15 | C1 | 2856h | 2856h | PCC-Rx-Gx-c1 | Ericsson | j.javier.pastor@ericsson.com | Rel-7 | Frederic | 24.229 |  |

Notes:
- 1182: -
- 1183: end date updated by CT1-chairman after CP#33
- 1184: -
- 1185: CT4#32: a set of CRs on FBI for cable labs
- 1186: Duplicated entry ("ACCSEC2", "Access Security Enhancements", SP-040865) deleted by A.Sultan
- 1187: -
- 1188: -
- 1189: -
- 1190: 03/2006 SP#31 WID approved
- 1191: SP#33 updated WID (removed MMS)
- 1192: SP#33 updated WID
- 1193: SP#33 updated WID
- 1194: CP#34 updated WID
- 1195: CP#34 updated WID
- 1196: CP#34 updated WID
- 1197: SP-29 approved WID. SP-31 updated WID adding SA5 charging. 23.125 will be discontinued from Rel-7.
- 1198: SP-30: S2 has no intention for TR completion
- 1199: SP-29 approved WID. SP-31 updated WID. 23.125 will be discontinued from Rel-7.
- 1200: SP-29 approved WID. SP-31 updated WID. 23.125 will be discontinued from Rel-7.
- 1201: SP-31 updated WID with SA5 charging.
- 1202: -
- 1203: WID approved at CP#30, Revised at CP#31, Revised at CP#33
- 1204: -
- 1205: -

| ID | WBS | Task | Type | Duration | Start | Finish | Complete | Baseline start | Baseline finish | Baseline duration | Constraint | Resources | Work | Actual work | Text1 | Text4 | Text5 | Text6 | Text8 | Text3 | Text12 |
| --- | --- | --- | --- | --- | --- | --- | --- | --- | --- | --- | --- | --- | --- | --- | --- | --- | --- | --- | --- | --- | --- |
| 1206 | 389 | **Voice call continuity between CS and IMS (incl. I-WLAN)** |  | 641d? | 2004-12-31 A | 2007-06-15 A | 100% | 2004-12-31 | 2007-06-15 | 641d? |  | S2,S1,S5,C1,C4 | 12224h | 12224h | VCC | Alcatel-Lucent | Keith Drage (drage@alcatel-lucent.com) | Rel-7 | Maurice |  |  |
| 1207 | 389.1 | TR for VCC |  | 245d? | 2004-12-31 A | 2005-12-08 A | 100% | 2004-12-31 | 2005-12-08 | 245d? | finish no earlier than 2005-12-08 | S2 | 1960h | 1960h | VCC | Alcatel-Lucent | Andy Bennett (andybennett@alcatel-lucent.com) | Rel-7 | Maurice | 23.806 |  |
| 1208 | 389.2 | Stage 1 for VCC |  | 140d? | 2005-03-17 A | 2005-09-28 A | 100% | 2005-03-17 | 2005-09-28 | 140d? | finish no earlier than 2005-09-28 | S1 | 1120h | 1120h | VCC | Alcatel-Lucent | Andy Bennett (andybennett@alcatel-lucent.com) | Rel-7 | Alain | 22.101 |  |
| 1209 | 389.3 | Stage 2 for VCC |  | 264d? | 2005-09-06 A | 2006-09-08 A | 100% | 2005-09-06 | 2006-09-08 | 264d? | finish no earlier than 2006-09-08 | S2 | 2112h | 2112h | VCC | Alcatel-Lucent | Andy Bennett (andybennett@alcatel-lucent.com) | Rel-7 | Maurice | 23.206 |  |
| 1210 | 389.4 | SA5 Charging aspects of VCC |  | 325d? | 2006-03-17 A | 2007-06-14 A | 100% | 2006-03-17 | 2007-06-14 | 325d? | finish no earlier than 2007-06-14 | S5 | 2600h | 2600h | VCC-CH | Orange | alain.bibas@orange-ft.com | Rel-7 | Dionisio | 32.250, 32.260 |  |
| 1211 | 389.5 | **Stage 3 for VCC** |  | 358d? | 2006-02-01 A | 2007-06-15 A | 100% | 2006-02-01 | 2007-06-15 | 358d? |  | C1,C4 | 4432h | 4432h | VCC | Alcatel-Lucent | Keith Drage (drage@alcatel-lucent.com) | Rel-7 | Frederic |  |  |
| 1212 | 389.5.1 | CT1 aspects of VCC |  | 358d? | 2006-02-01 A | 2007-06-15 A | 100% | 2006-02-01 | 2007-06-15 | 358d? | finish no earlier than 2007-06-15 | C1 | 2864h | 2864h | VCC | Alcatel-Lucent | Keith Drage (drage@alcatel-lucent.com) | Rel-7 | Frederic | 24.206, 24.216 |  |
| 1213 | 389.5.2 | CT4 aspects of VCC |  | 196d? | 2006-06-09 A | 2007-03-09 A | 100% | 2006-06-09 | 2007-03-09 | 196d? | start no earlier than 2006-06-09 | C4 | 1568h | 1568h | VCC-St3-c4 | Alcatel-Lucent | Keith Drage (drage@alcatel-lucent.com) | Rel-7 | Kimmo | 23.003 |  |
| 1214 | 389.5.3 | Deleted - CT3 aspects of VCC | milestone | 0d? | 2006-11-02 A | 2006-11-02 A | 100% | 2006-11-02 | 2006-11-02 | 0d? | finish no earlier than 2006-11-02 | C3 |  |  | VCC | Alcatel-Lucent | Keith Drage (drage@alcatel-lucent.com) | Rel-7 | Gwiho | 29.163 | CP-33 |
| 1215 | 390 | **One Tunnel solution for optimization of Packet Data Traffic** |  | 418d? | 2006-03-27 A | 2007-10-31 A | 100% | 2006-03-27 | 2007-10-31 | 418d? |  | S2 | 7048h | 7048h | OPTUNEL | Nokia | antti.j.pasanen@nokia.com | Rel-7 | Maurice |  |  |
| 1216 | 390.1 | Deleted - Study on Stage 2 for One Tunnel solution |  | 125d? | 2006-03-27 A | 2006-09-15 A | 100% | 2006-03-27 | 2006-09-15 | 125d? | finish no earlier than 2005-09-12 | S2 | 1000h | 1000h | OPTUNEL-Study | Nokia | antti.j.pasanen@nokia.com | Rel-7 | Maurice | 23.809 | SP-34 |
| 1217 | 390.2 | One Tunnel Deployment Guideline |  | 268d? | 2006-10-23 A | 2007-10-31 A | 100% | 2006-10-23 | 2007-10-31 | 268d? | finish no earlier than 2007-10-31 | S2 | 2144h | 2144h | OPTUNEL-Guide | Huawei | lan.liu@huawei.com | Rel-7 | Maurice | 23.919 |  |
| 1218 | 390.3 | Stage 2 specification for One Tunnel solution |  | 70d? | 2006-09-11 A | 2006-12-15 A | 100% | 2006-09-11 | 2006-12-15 | 70d? | finish no earlier than 2006-12-15 | S2 | 560h | 560h | OPTUNEL-Stage2 | Nokia | antti.j.pasanen@nokia.com | Rel-7 | Maurice | 23.060 |  |
| 1219 | 391 | **CSI Terminating Session handling** |  | 267d? | 2006-06-08 A | 2007-06-15 A | 100% | 2006-06-08 | 2007-06-15 | 267d? |  | S2,C1 | 4728h | 4728h | CSItermS | Samsung | Osok Song | Rel-7 | Maurice |  |  |
| 1220 | 391.1 | Stage 2 of CStermS |  | 192d? | 2006-06-08 A | 2007-03-02 A | 100% | 2006-06-08 | 2007-03-02 | 192d? | start no earlier than 2006-06-08 | S2 | 1536h | 1536h | CSItermS | Samsung | Osok Song | Rel-7 | Maurice | 23.279 |  |
| 1221 | 391.2 | Stage 3 of CStermS |  | 132d? | 2006-12-14 A | 2007-06-15 A | 100% | 2006-12-14 | 2007-06-15 | 132d? | finish no earlier than 2007-06-15 | C1 | 1056h | 1056h | CSItermS | Samsung | chenho.chin@samsung.com | Rel-7 | Frederic | 24.229, 24.279 |  |
| 1222 | 391.3 | Deleted - duplicated with UID 340015 -Stage 3 CSI Terminating Session handling | milestone | 0d? | 2007-03-09 A | 2007-03-09 A | 100% | 2007-03-09 | 2007-03-09 | 0d? | start no earlier than 2007-03-09 | C1 |  |  | CSItermS | Samsung | chenho.chin@samsung.com | Rel-7 | Frederic | 24.229, 24.179, 24.279 | CP-34 |
| 1223 | 392 | Liberty Alliance and 3GPP Security Interworking |  | 451d? | 2005-03-10 A | 2006-11-30 A | 100% | 2005-03-10 | 2006-11-30 | 451d? | finish no earlier than 2006-11-30 | S3 | 3608h | 3608h | LibSec | Nokia | Silke.Holtmanns@nokia.com | Rel-7 | Dionisio | 33.980 |  |
| 1224 | 393 | Trust Requirements for Open Platforms in 3GPP |  | 499d? | 2005-01-03 A | 2006-11-30 A | 100% | 2005-01-03 | 2006-11-30 | 499d? | finish no earlier than 2006-11-30 | S3 | 3992h | 3992h | TrustOP | Nokia | Silke.Holtmanns@nokia.com | Rel-7 | Dionisio | 33.905 |  |
| 1225 | 394 | Development of UEA2 and UIA2 |  | 268d? | 2004-12-01 A | 2005-12-09 A | 100% | 2004-12-01 | 2005-12-09 | 268d? | finish no earlier than 2005-12-09 | S3 | 2144h | 2144h | AlgUEA2 | TeliaSonera | per.christoffersson@teliasonera.com | Rel-7 | Dionisio | 35.919, 35.215, 35.216, 35.217, 35.218 |  |
| 1226 | 395 | Lawful Interception in the 3GPP Rel-7 architecture |  | 118d? | 2005-06-28 A | 2005-12-08 A | 100% | 2005-06-28 | 2005-12-08 | 118d? | start no earlier than 2005-06-28 | S3 | 944h | 944h | LI-7A | BMWI | berthold.wilhelm@regtp.de | Rel-7 | Dionisio | 33.106, 33.107, 33.108 |  |
| 1227 | 396 | Key establishment between a UICC and a terminal |  | 201.45d? | 2005-12-07 A | 2006-09-28 A | 100% | 2005-12-07 | 2006-09-28 | 201.45d? | finish no earlier than 2006-09-28 | S3 | 1611.6h | 1611.6h | KeyEstUTerm | Gemalto | mireille.pauliac@gemplus.com | Rel-7 | Dionisio | 33.110 |  |
| 1228 | 397 | NDS Authentication Framework Extension for Transport Layer Security |  | 50d? | 2006-09-28 A | 2006-12-06 A | 100% | 2006-09-28 | 2006-12-06 | 50d? | finish no earlier than 2006-09-28 | S3 | 400h | 400h | NDSAFTLS | Nokia | tiina.s.koskinen@nokia.com | Rel-7 | Dionisio | 33.310 |  |
| 1229 | 398 | **Security enhancements** |  | 319d? | 2005-09-12 A | 2006-11-30 A | 100% | 2005-09-12 | 2006-11-30 | 319d? |  | S3,C1,C4 | 4856h | 4856h | SEC7 |  |  | Rel-7 | Dionisio |  |  |
| 1230 | 398.1 | HTTPS connection between a UICC and a NAF |  | 1d? | 2005-09-12 A | 2005-09-12 A | 100% | 2005-09-12 | 2005-09-12 | 1d? | start no earlier than 2005-09-12 | S3,C1 | 8h | 8h | SEC7-HSUN | Gemalto | JSeif@axalto.com, mireille.pauliac@gemplus.com | Rel-7 | Dionisio | 33.918, 33.222, 24.109 |  |
| 1231 | 398.2 | 2G GBA: 2G SIM usage in 3GPP GAA framework |  | 61d? | 2005-09-12 A | 2005-12-05 A | 100% | 2005-09-12 | 2005-12-05 | 61d? | finish no earlier than 2005-12-05 | S3 | 488h | 488h | SEC7-2GGBA | Nokia | Silke.Holtmanns@nokia.com | Rel-7 | Dionisio | 33.920, 33.220 |  |
| 1232 | 398.3 | Generic Authentication Architecture usage extensions and optimizations |  | 319d? | 2005-09-12 A | 2006-11-30 A | 100% | 2005-09-12 | 2006-11-30 | 319d? | finish no earlier than 2006-11-30 | S3 | 2552h | 2552h | SEC7-GAA2 | Nokia | Silke.Holtmanns@nokia.com | Rel-7 | Dionisio | 33.220, 29.109, 24.109, (33.223 goes to R8) |  |

Notes:
- 1206: WID approved SP#27; updated SP#28; updated SP#32
- 1207: -
- 1208: -
- 1209: -
- 1210: 03/2006 SP#31 WID approved
- 1211: -
- 1212: -
- 1213: -
- 1214: -
- 1215: -
- 1216: S2#52 CREATED. TR for Info SP-33. SP-34: S2 Report intention to discontinue TR
- 1217: -
- 1218: S2#52 CREATED
- 1219: Triggered by the abandoned Study UID_32117
- 1220: -
- 1221: CP-34 approved WID. CP-35 updated WID
- 1222: CP-34 approved WID
- 1223: WID approved SP#27.
- 1224: WID approved SP#26.
- 1225: WID approved SP#26, Dependant on Funding Availability.
- 1226: -
- 1227: -
- 1228: TLS profile is moved to Rel-8
- 1229: -
- 1230: -
- 1231: -
- 1232: 33.223 goes to R8

| ID | WBS | Task | Duration | Start | Finish | Complete | Baseline start | Baseline finish | Baseline duration | Constraint | Resources | Work | Actual work | Text1 | Text4 | Text5 | Text6 | Text8 | Text3 | Text12 | Text2 | Text7 |
| --- | --- | --- | --- | --- | --- | --- | --- | --- | --- | --- | --- | --- | --- | --- | --- | --- | --- | --- | --- | --- | --- | --- |
| 1233 | 398.4 | **SS7 TCAP security Gateway** | 241d? | 2005-09-12 A | 2006-08-14 A | 100% | 2005-09-12 | 2006-08-14 | 241d? |  | S3,C4 | 1808h | 1808h | SEC7-NDS-TCAPsec | Siemens | marc.blommaert.ext@nsn.com | Rel-7 | Dionisio |  |  |  |  |
| 1234 | 398.4.1 | SA3 aspects of SEC7-NDS-TCAPsec | 130d? | 2005-09-12 A | 2006-03-10 A | 100% | 2005-09-12 | 2006-03-10 | 130d? | finish no earlier than 2006-03-10 | S3 | 1040h | 1040h | SEC7-NDS-TCAPsec-SA3 | Siemens | marc.blommaert.ext@nsn.com | Rel-7 | Dionisio | 33.204 |  |  |  |
| 1235 | 398.4.2 | TCAPsec Gateway | 96d? | 2006-04-03 A | 2006-08-14 A | 100% | 2006-04-03 | 2006-08-14 | 96d? | start no earlier than 2006-04-01 | C4 | 768h | 768h | SEC7-TCAP | Siemens | Ulrich.wiehe@gksag.de | Rel-7 | Kimmo | 29.204, 29.002 |  |  |  |
| 1236 | 399 | IMS Stage 3 IETF Protocol alignment | 589d? | 2004-12-10 A | 2007-03-14 A | 100% | 2004-12-10 | 2007-03-14 | 589d? | finish no earlier than 2007-03-15 | C1 | 4712h | 4712h | IMSProtoc |  |  | Rel-7 | Frederic | 24.930 |  |  |  |
| 1237 | 400 | **Interoperability between VGCS/VBS and A/Gb flexibility** | 253d? | 2006-03-22 A | 2007-03-09 A | 100% | 2006-03-22 | 2007-03-09 | 253d? |  | C1,C4 | 3296h | 3296h | VGCSFlex | Siemens | robert.zaus@nsn.com | Rel-7 | Frederic |  |  |  |  |
| 1238 | 400.1 | CT1 aspects of VGCSFlex | 159d? | 2006-03-22 A | 2006-10-30 A | 100% | 2006-03-22 | 2006-10-30 | 159d? | finish no earlier than 2006-10-30 | C1 | 1272h | 1272h | VGCSFlex | Siemens | robert.zaus@nsn.com | Rel-7 | Frederic | 43.068, 43.069 |  |  |  |
| 1239 | 400.2 | CT4 aspects of VGCSFlex | 253d? | 2006-03-22 A | 2007-03-09 A | 100% | 2006-03-22 | 2007-03-09 | 253d? | finish no earlier than 2007-03-09 | C4 | 2024h | 2024h | VGCSFlex-c4 | Siemens | robert.zaus@nsn.com | Rel-7 | Kimmo | 29.002 |  |  |  |
| 1240 | 401 | DIAMETER on the GGSN Gi interface | 586d? | 2004-09-10 A | 2006-12-08 A | 100% | 2004-09-10 | 2006-12-08 | 586d? | finish no earlier than 2006-12-08 | C3 | 4688h | 4688h | DIAMGi | Vodafone | Nico.Gabriele@vodafone.com | Rel-7 | Gwiho | 29.061 |  |  |  |
| 1241 | 402 | DIAMETER on the PDG Wi interface | 586d? | 2004-09-10 A | 2006-12-08 A | 100% | 2004-09-10 | 2006-12-08 | 586d? | finish no earlier than 2006-12-08 | C3 | 4688h | 4688h | DIAMWi | Vodafone | Nico.Gabriele@vodafone.com | Rel-7 | Gwiho | 29.161 |  |  |  |
| 1242 | 403 | Interworking between the 3GPP CS domain with BICC or ISUP as signalling protocol and external SIP-I networks | 478d? | 2006-09-22 A | 2008-07-22 A | 100% | 2006-09-22 | 2008-07-22 | 478d? | finish no earlier than 2007-09-14 | C3 | 3824h | 3824h | ExtSIPI | Siemens | Thomas.Belling@nsn.com | Rel-7 | Gwiho | 29.164 |  |  |  |
| 1243 | 404 | PDU multiplexing at Nb Interface with IP transport | 427d? | 2006-12-04 A | 2008-07-22 A | 100% | 2006-12-04 | 2008-07-22 | 427d? | start no earlier than 2006-12-04 | C3 | 3416h | 3416h | NbIPMux | Alcatel-Lucent | Jean.Rzeznik@alcatel-lucent.fr | Rel-7 | Gwiho | 29.414 |  |  |  |
| 1244 | 405 | **Mp (MRFC - MRFP) interface** | 345d? | 2006-02-13 A | 2007-06-08 A | 100% | 2006-02-13 | 2007-06-08 | 345d? |  | C4,C1 | 4384h | 4384h | Mp | Ericsson | philip.hodges@ericsson.com | Rel-7 | Kimmo |  |  |  |  |
| 1245 | 405.1 | CT1 aspects of Mp | 1d | 2006-02-13 A | 2006-02-13 A | 100% | 2006-02-13 | 2006-02-13 | 1d | finish no earlier than 2006-02-13 | C1 | 8h | 8h | Mp | Ericsson | philip.hodges@ericsson.com | Rel-7 | Frederic | 24.229 |  |  |  |
| 1246 | 405.2 | Deleted - CT3 aspects of Mp | 1d | 2006-09-22 A | 2006-09-22 A | 100% | 2006-09-22 | 2006-09-22 | 1d | start no earlier than 2006-09-22 | C3 | 8h | 8h | Mp | Ericsson | philip.hodges@ericsson.com | Rel-7 | Gwiho | 29.162 | CP-33 |  |  |
| 1247 | 405.3 | Procedures description | 201d? | 2006-06-02 A | 2007-03-09 A | 100% | 2006-06-02 | 2007-03-09 | 201d? | finish no earlier than 2007-03-09 | C4 | 1608h | 1608h | Mp-PROCc4 | Huawei | Chencheng@huawei.com | Rel-7 | Kimmo | 23.333 |  |  |  |
| 1248 | 405.4 | Stage 3 | 345d | 2006-02-13 A | 2007-06-08 A | 100% | 2006-02-13 | 2007-06-08 | 345d | finish no earlier than 2007-06-08 | C4 | 2760h | 2760h | Mp-St3c4 | Ericsson | philip.hodges@ericsson.com | Rel-7 | Kimmo | 29.333 |  |  |  |
| 1249 | 406 | Routeing of MT-SMS via the HPLMN | 71d? | 2006-12-01 A | 2007-03-09 A | 100% | 2006-12-01 | 2007-03-09 | 71d? | finish no earlier than 2007-03-09 | C4,C1 | 568h | 568h | SMSviaH | Vodafone | Nick.Russell@vodafone.com | Rel-7 | Kimmo | 23.040, 29.002 |  |  |  |
| 1250 | 407 | Mobile Termination whilst the MS is moving to another MSC | 60d? | 2007-03-09 A | 2007-05-31 A | 100% | 2007-03-09 | 2007-05-31 | 60d? | start no earlier than 2007-03-09 | C4 | 480h | 480h | MTmovMS | Alcatel-Lucent | bruno.landais@alcatel-lucent.fr | Rel-7 | Kimmo | 23.008, 23.012, 23.018, 23.078, 23.079, 29.002 |  |  |  |
| 1251 | 408 | ISIM API for Java Card | 620d? | 2005-03-14 A | 2007-07-27 A | 100% | 2005-03-14 | 2007-07-27 | 620d? | finish no earlier than 2007-07-27 | C6 | 4960h | 4960h | APIJAVA | Sun | Sebastian Hans | Rel-7 | Xavier | 31.103, 102 241 |  |  |  |
| 1252 | 409 | Rel-7 (U)SIM API Testing (TS 31.213) | 211d? | 2009-05-30 A | 2010-03-19 A | 100% | 2009-05-30 | 2010-03-19 | 211d? | finish no earlier than 2010-03-12 | C6 | 1688h | 1688h | USIM_API_test | Sagem Orga | gerrit.hartbrod@sagem-orga.com | Rel-7 | Xavier | 31.213 |  | PCG-23 | CP-44 |
| 1253 | 410 | High speed interface between the UICC and the ME | 311d? | 2006-09-22 A | 2007-11-30 A | 100% | 2006-09-22 | 2007-11-30 | 311d? | finish no earlier than 2007-11-30 | C6 | 2488h | 2488h | HSI | Gemalto | jacques.seif@GEMALTO.COM | Rel-7 | Xavier | 31.101 |  |  |  |
| 1254 | 411 | Video Codec Performance Requirements | 634d? | 2005-01-03 A | 2007-06-07 A | 100% | 2005-01-03 | 2007-06-07 | 634d? | finish no earlier than 2007-06-07 | S4 | 5072h | 5072h | VICPer | Siemens | juergen.pandel@siemens.com | Rel-7 | Paolo | 26.234, 26.235, 26.346, 26.140, 26.902 |  |  |  |
| 1255 | 412 | Dynamic and Interactive Multimedia Scenes | 583d? | 2005-03-15 A | 2007-06-07 A | 100% | 2005-03-15 | 2007-06-07 | 583d? | finish no earlier than 2007-06-07 | S4 | 4664h | 4664h | DIMS | Streamezzo | gaelle.martin-cocher@streamezzo.com | Rel-7 | Paolo | 26.140, 26.142, 26.234, 26.244, 23.346 |  |  |  |
| 1256 | 413 | 3G-324M Video Telephony Call Setup Times Improvements | 341d? | 2005-06-08 A | 2006-09-27 A | 100% | 2005-06-08 | 2006-09-27 | 341d? | finish no earlier than 2006-09-27 | S4 | 2728h | 2728h | VTCSTI | Vodafone | edward.hall@vodafone.co.uk | Rel-7 | Paolo | 26.911 |  |  |  |

Notes:
- 1233: -
- 1234: -
- 1235: -
- 1236: TR 24.930: Signalling flows for the session setup in the IM CN subsystem based on Session Initiation Protocol (SIP)
- 1237: Voice Group Call Service
- 1238: -
- 1239: -
- 1240: -
- 1241: -
- 1242: -
- 1243: -
- 1244: -
- 1245: -
- 1246: CP#34: CT3 not involved in Mp interface definition
- 1247: -
- 1248: -
- 1249: WID approved in CP#34
- 1250: -
- 1251: -
- 1252: CP#47 completed. Update of Rel-6 (U)SIM API for Java Card Testing UID_43007 under Rel-6 UICC/USIM enhancements and interworking UID_1800
- 1253: Following ETSI publication of TS 102 600, expected to be completed at CT6 meeting 45
- 1254: -
- 1255: -
- 1256: -

| ID | WBS | Task | Type | Duration | Start | Finish | Complete | Baseline start | Baseline finish | Baseline duration | Constraint | Resources | Work | Actual work | Text1 | Text4 | Text5 | Text6 | Text8 | Text12 |
| --- | --- | --- | --- | --- | --- | --- | --- | --- | --- | --- | --- | --- | --- | --- | --- | --- | --- | --- | --- | --- |
| 1257 | 414 | **Optimizations for Multimedia Telephony over IMS** |  | 0d? | 2005-09-28 A | 2005-09-28 A | 100% | 2005-09-28 | 2005-09-28 | 0d? |  | S4 |  |  | OMTIMS | Ericsson | olle.franceschi@ericsson.com | Rel-7 | Paolo |  |
| 1258 | 414.1 | Deleted - Characterisation of Adaptive Jitter Management Performance for VoIP Services | milestone | 0d? | 2005-09-28 A | 2005-09-28 A | 100% | 2005-09-28 | 2005-09-28 | 0d? | start no earlier than 2007-03-15 | S4 |  |  | OMTIMS-CAJMP | Lucent | dhuo@lucent.com | Rel-7 | Paolo | SP-35 |
| 1259 | 415 | End-to-End Multimedia Services Performance Metrics |  | 382d? | 2005-09-28 A | 2007-03-15 A | 100% | 2005-09-28 | 2007-03-15 | 382d? | finish no earlier than 2007-03-15 | S4 | 3056h | 3056h | E2EMSPM | China Mobile | zhangyanyf@chinamobile.com | Rel-7 | Paolo |  |
| 1260 | 416 | Packet Switched Streaming Enhancements |  | 261d? | 2006-06-08 A | 2007-06-07 A | 100% | 2006-06-08 | 2007-06-07 | 261d? | finish no earlier than 2007-06-07 | S4 | 2088h | 2088h | PSSe | Ericsson | olle.franceschi@ericsson.com | Rel-7 | Paolo |  |
| 1261 | 417 | **OAM&P Rel-7** |  | 472.86d? | 2005-09-02 A | 2007-06-26 A | 100% | 2005-09-02 | 2007-06-26 | 472.86d? |  | S5 | 82725.8h | 82725.8h | OAM7 | Huawei | Christian.Toche@huawei.com | Rel-7 | Dionisio |  |
| 1262 | 417.1 | **Network Infrastructure Management** |  | 465d? | 2005-09-02 A | 2007-06-14 A | 100% | 2005-09-02 | 2007-06-14 | 465d? |  | S5 | 41800h | 41800h | OAM7-NIM |  |  | Rel-7 | Dionisio |  |
| 1263 | 417.1.1 | Enhance NRM to accommodate NGN (IMS as basis of the Next Generation Network) |  | 465d? | 2005-09-02 A | 2007-06-14 A | 100% | 2005-09-02 | 2007-06-14 | 465d? | finish no earlier than 2007-06-14 | S5 | 3720h | 3720h | OAM7-NIM | Motorola |  | Rel-7 | Dionisio |  |
| 1264 | 417.1.2 | Co-operative Element Management interface (CO-OP) (Study + Implementation) |  | 400d? | 2005-09-02 A | 2007-03-15 A | 100% | 2005-09-02 | 2007-03-15 | 400d? | finish no earlier than 2007-03-15 | S5 | 3200h | 3200h | OAM7-NIM | Motorola |  | Rel-7 | Dionisio |  |
| 1265 | 417.1.3 | Network Management (NM) Itf-N performance criteria |  | 465d? | 2005-09-02 A | 2007-06-14 A | 100% | 2005-09-02 | 2007-06-14 | 465d? | finish no earlier than 2007-06-14 | S5 | 3720h | 3720h | OAM7-NIM | China Mobile |  | Rel-7 | Dionisio |  |
| 1266 | 417.1.4 | Delta synchronization between IRP Manager and IRP Agent (Study + Implementation) |  | 465d? | 2005-09-02 A | 2007-06-14 A | 100% | 2005-09-02 | 2007-06-14 | 465d? | finish no earlier than 2007-06-14 | S5 | 3720h | 3720h | OAM7-NIM | Siemens |  | Rel-7 | Dionisio |  |
| 1267 | 417.1.5 | Subscription Management (SuM) IRP Solution Sets |  | 330d? | 2005-09-02 A | 2006-12-07 A | 100% | 2005-09-02 | 2006-12-07 | 330d? | finish no earlier than 2006-12-07 | S5 | 2640h | 2640h | OAM7-NIM | Ericsson |  | Rel-7 | Dionisio |  |
| 1268 | 417.1.6 | Integration Reference Point (IRP) Security Management |  | 400d? | 2005-09-02 A | 2007-03-15 A | 100% | 2005-09-02 | 2007-03-15 | 400d? | finish no earlier than 2007-03-15 | S5 | 3200h | 3200h | OAM7-NIM | Huawei | Christian.Toche@huawei.com | Rel-7 | Dionisio |  |
| 1269 | 417.1.7 | Partial suspension of Itf-N during maintenance/testing (Study + Implementation) |  | 465d? | 2005-09-02 A | 2007-06-14 A | 100% | 2005-09-02 | 2007-06-14 | 465d? | finish no earlier than 2007-06-14 | S5 | 3720h | 3720h | OAM7-NIM | Siemens |  | Rel-7 | Dionisio |  |
| 1270 | 417.1.8 | Deleted - Management of Legacy Equipment |  | 336d? | 2005-09-02 A | 2006-12-15 A | 100% | 2005-09-02 | 2006-12-15 | 336d? | finish no earlier than 2006-12-15 | S5 | 2688h | 2688h | OAM7-NIM | Siemens |  | Rel-7 | Dionisio | SP-35 |
| 1271 | 417.1.9 | Deleted - Rules for Vendor Specific Extensions |  | 400d? | 2005-09-02 A | 2007-03-15 A | 100% | 2005-09-02 | 2007-03-15 | 400d? | finish no earlier than 2007-03-15 | S5 | 3200h | 3200h | OAM7-NIM | Siemens |  | Rel-7 | Dionisio | SP-35 |
| 1272 | 417.1.10 | Backward and Forward Compatibility of IRP systems |  | 465d? | 2005-09-02 A | 2007-06-14 A | 100% | 2005-09-02 | 2007-06-14 | 465d? | finish no earlier than 2007-06-14 | S5 | 3720h | 3720h | OAM7-NIM | Ericsson |  | Rel-7 | Dionisio |  |
| 1273 | 417.1.11 | Repeater Network Resource Model (NRM) definition |  | 214d? | 2006-02-13 A | 2006-12-07 A | 100% | 2006-02-13 | 2006-12-07 | 214d? | finish no earlier than 2006-12-07 | S5 | 1712h | 1712h | OAM7-NIM | China Mobile |  | Rel-7 | Dionisio |  |
| 1274 | 417.1.12 | UTRAN radio channel power monitoring |  | 284d? | 2006-02-13 A | 2007-03-15 A | 100% | 2006-02-13 | 2007-03-15 | 284d? | finish no earlier than 2007-03-15 | S5 | 2272h | 2272h | OAM7-NIM | China Mobile |  | Rel-7 | Dionisio |  |
| 1275 | 417.1.13 | Notification XML Schema |  | 71d? | 2006-12-07 A | 2007-03-15 A | 100% | 2006-12-07 | 2007-03-15 | 71d? | finish no earlier than 2007-03-15 | S5 | 568h | 568h | OAM7-NIM | Huawei | Christian.Toche@huawei.com | Rel-7 | Dionisio |  |
| 1276 | 417.2 | **Performance Management** |  | 465d? | 2005-09-02 A | 2007-06-14 A | 100% | 2005-09-02 | 2007-06-14 | 465d? |  | S5 | 22992h | 22992h | OAM7-PM |  |  | Rel-7 | Dionisio |  |
| 1277 | 417.2.1 | Performance measurements definition for CN CS |  | 400d? | 2005-09-02 A | 2007-03-15 A | 100% | 2005-09-02 | 2007-03-15 | 400d? | finish no earlier than 2007-03-15 | S5 | 3200h | 3200h | OAM7-PM | China Mobile |  | Rel-7 | Dionisio |  |
| 1278 | 417.2.2 | Enhancement UTRAN performance measurements definition |  | 465d? | 2005-09-02 A | 2007-06-14 A | 100% | 2005-09-02 | 2007-06-14 | 465d? | finish no earlier than 2007-06-14 | S5 | 3720h | 3720h | OAM7-PM | China Mobile |  | Rel-7 | Dionisio |  |
| 1279 | 417.2.3 | Add TDD specific counters in Performance measurement |  | 330d? | 2005-09-02 A | 2006-12-07 A | 100% | 2005-09-02 | 2006-12-07 | 330d? | finish no earlier than 2006-12-15 | S5 | 2640h | 2640h | OAM7-PM | CATT |  | Rel-7 | Dionisio |  |
| 1280 | 417.2.4 | ATM bearer network Performance measurements |  | 400d? | 2005-09-02 A | 2007-03-15 A | 100% | 2005-09-02 | 2007-03-15 | 400d? | finish no earlier than 2007-03-15 | S5 | 3200h | 3200h | OAM7-PM | ZTE |  | Rel-7 | Dionisio |  |
| 1281 | 417.2.5 | Performance measurements definition for IMS |  | 465d? | 2005-09-02 A | 2007-06-14 A | 100% | 2005-09-02 | 2007-06-14 | 465d? | finish no earlier than 2007-06-14 | S5 | 3720h | 3720h | OAM7-PM | China Mobile |  | Rel-7 | Dionisio |  |
| 1282 | 417.2.6 | HSDPA performance measurements |  | 349d? | 2006-02-13 A | 2007-06-14 A | 100% | 2006-02-13 | 2007-06-14 | 349d? | finish no earlier than 2007-06-14 | S5 | 2792h | 2792h | OAM7-PM | China Mobile |  | Rel-7 | Dionisio |  |

Notes:
- 1257: - / Text3: 26.235, 26.236
- 1258: SP-35 stopped
- 1259: - / Text3: 26.944
- 1260: - / Text3: 26.234, 26.244
- 1261: - / Text3: TR 30.817
- 1262: -
- 1263: - / Text3: 32.731/2/3/5, 32.631/2/3/5
- 1264: - / Text3: 32.806, 32.814, 32.101
- 1265: - / Text3: 32.811
- 1266: - / Text3: 32.391/2/3/5
- 1267: - / Text3: 32.307/317/607/667/665, 32.101, 32.175
- 1268: - / Text3: 32.372/3/5, 32.111,32.30x,32.32x,32.33x,32.34x,32.35x,32.36x,32.41x,32.60x,32.61x,32.66x
- 1269: - / Text3: 32.381/2/3/5
- 1270: Request to TSG#35 to STOP the WI / Text3: new 32.xxx
- 1271: Request to TSG#35 to STOP the WI / Text3: 32.62n; For n = 1 to 5
- 1272: - / Text3: 32.154
- 1273: - / Text3: 32.721/2/3/5
- 1274: - / Text3: 32.405, 32.64n; For n = 1 to 5
- 1275: 12/2006 SP#34 WID approved / Text3: New 32.325/345/365/415, CR to 32.335/615/665
- 1276: -
- 1277: - / Text3: 32.407, 32.408
- 1278: - / Text3: 32.405
- 1279: - / Text3: 32.405
- 1280: - / Text3: No impact on 32.404, 32.405, 32.406, 32.407
- 1281: - / Text3: 32.404,32.409,32.437, 32.632/3/4/5
- 1282: - / Text3: 32.405

| ID | WBS | Task | Type | Duration | Start | Finish | Complete | Baseline start | Baseline finish | Baseline duration | Constraint | Resources | Work | Actual work | Text1 | Text4 | Text6 | Text8 | Text12 | Text5 | Text11 |
| --- | --- | --- | --- | --- | --- | --- | --- | --- | --- | --- | --- | --- | --- | --- | --- | --- | --- | --- | --- | --- | --- |
| 1283 | 44.5 | **Trace Management** |  | 472.86d? | 2005-09-02 A | 2007-06-26 A | 100% | 2005-09-02 | 2007-06-26 | 472.86d? |  | S5 | 14150.9h | 14150.9h | OAM7-Trace | Vodafone | Rel-7 | Dionisio |  |  |  |
| 1284 | 417.3.1 | End-to-end Service Level tracing for IMS |  | 350d? | 2005-11-11 A | 2007-03-15 A | 100% | 2005-11-11 | 2007-03-15 | 350d? | finish no earlier than 2007-03-15 | S5 | 2800h | 2800h | OAM7-Trace | Vodafone | Rel-7 | Dionisio | SP-31 |  |  |
| 1285 | 417.3.2 | Trace record content for UTRAN TDD |  | 330d? | 2005-09-02 A | 2006-12-07 A | 100% | 2005-09-02 | 2006-12-07 | 330d? | finish no earlier than 2006-12-07 | S5 | 2640h | 2640h | OAM7-Trace | Nokia | Rel-7 | Dionisio |  |  |  |
| 1286 | 417.3.3 | IRP for Subscriber and Equipment Trace Management |  | 465d? | 2005-09-02 A | 2007-06-14 A | 100% | 2005-09-02 | 2007-06-14 | 465d? | finish no earlier than 2007-06-14 | S5 | 3720h | 3720h | OAM7-Trace | Nokia | Rel-7 | Dionisio |  |  |  |
| 1287 | 417.3.4 | Deleted - SIP enhancements for trace | milestone | 0d? | 2007-06-15 A | 2007-06-26 A | 100% | 2007-06-15 | 2007-06-26 | 0d? | start no earlier than 2007-06-15 | C1 |  |  | OAM7-Trace |  | Rel-7 | Frederic | CP-32 |  |  |
| 1288 | 417.3.5 | Deleted - duplicated with UID 35063 - IRP for Subscriber and Equipment Trace Management |  | 336d? | 2005-09-02 A | 2006-12-15 A | 100% | 2005-09-02 | 2006-12-15 | 336d? | finish no earlier than 2006-12-15 | S5 | 2688h | 2688h | OAM7-Trace | Nokia | Rel-7 | Dionisio | SP-33 |  |  |
| 1289 | 418 | **Charging Management small Enhancements Rel-7** |  | 279d? | 2006-05-22 A | 2007-06-14 A | 100% | 2006-05-22 | 2007-06-14 | 279d? |  | S5 | 5952h | 5952h | CH7 | Orange | Rel-7 | Dionisio |  | alain.bibas@orange-ft.com |  |
| 1290 | 418.1 | Alternate Charged Party (ACP) for IMS |  | 279d? | 2006-05-22 A | 2007-06-14 A | 100% | 2006-05-22 | 2007-06-14 | 279d? | finish no earlier than 2007-06-14 | S5 | 2232h | 2232h | CH7-IMS-ACP | Lucent | Rel-7 | Dionisio |  | njmazzarella@alcatel-lucent.com |  |
| 1291 | 418.2 | Align 3GPP Charging with OMA PoC Enabler Release 2.0 |  | 186d? | 2006-09-28 A | 2007-06-14 A | 100% | 2006-09-28 | 2007-06-14 | 186d? | finish no earlier than 2007-06-14 | S5 | 1488h | 1488h | CH7-PoC | Siemens | Rel-7 | Dionisio |  | Gerald.Goermer@nsn.com |  |
| 1292 | 8.5 | **Multiple-Input Multiple-Output (MIMO) antennas** |  | 1301d? | 2003-03-14 A | 2008-03-07 A | 100% | 2003-03-14 | 2008-03-07 | 1301d? |  | R1,R5 | 45440h | 45440h | MIMO | Alcatel-Lucent | Rel-7 | Patrick |  | hchuang@Alcatel-Lucent.com | RP-070037, RP-070531 |
| 1293 | 419.1 | MIMO - Physical layer |  | 915d? | 2003-09-12 A | 2007-03-15 A | 100% | 2003-09-12 | 2007-03-15 | 915d? | finish no earlier than 2007-03-15 | R1 | 7320h | 7320h | MIMO-Phys | Alcatel-Lucent | Rel-7 | Patrick |  | hchuang@Alcatel-Lucent.com | RP-070037 |
| 1294 | 419.2 | MIMO - Layer 2,3 aspects |  | 915d? | 2003-09-12 A | 2007-03-15 A | 100% | 2003-09-12 | 2007-03-15 | 915d? | finish no earlier than 2007-03-15 | R2 | 7320h | 7320h | MIMO-L23 | Alcatel-Lucent | Rel-7 | Joern |  | hchuang@Alcatel-Lucent.com | RP-070037 |
| 1295 | 419.3 | MIMO - Iub/Iur Protocol Aspects |  | 1045d? | 2003-03-14 A | 2007-03-15 A | 100% | 2003-03-14 | 2007-03-15 | 1045d? | finish no earlier than 2007-03-15 | R3 | 8360h | 8360h | MIMO-IurIub | Alcatel-Lucent | Rel-7 | Juha |  | hchuang@Alcatel-Lucent.com | RP-070037 |
| 1296 | 419.4 | MIMO - RF Radio Transmission/Reception, System Performance Requirements and Conformance Testing |  | 982d? | 2003-12-12 A | 2007-09-17 A | 100% | 2003-12-12 | 2007-09-17 | 982d? | finish no earlier than 2007-09-17 | R4 | 7856h | 7856h | MIMO-RF | Alcatel-Lucent | Rel-7 | Issam |  | ngm@Alcatel-Lucent.com | RP-070531 |
| 1297 | 419.5 | **UE Conformance Testing for Multiple Input Multiple Output antennas (MIMO)** |  | 261d? | 2007-03-09 A | 2008-03-07 A | 100% | 2007-03-09 | 2008-03-07 | 261d? |  | R5 | 4176h | 4176h | MIMO-UEConTest | Qualcomm | Rel-7 | Ingbert |  | svora@qualcomm.com |  |
| 1298 | 419.5.1 | Conformance Test Aspects – Multiple Input Multiple Output Antennas (MIMO) for FDD |  | 261d? | 2007-03-09 A | 2008-03-07 A | 100% | 2007-03-09 | 2008-03-07 | 261d? | finish no earlier than 2008-03-07 | R5 | 2088h | 2088h | MIMO-UEConTest_FDD | Qualcomm | Rel-7 | Ingbert |  | svora@qualcomm.com |  |
| 1299 | 420 | **Rel-7 Improvements of the Radio Interface** |  | 709d? | 2004-09-15 A | 2007-06-04 A | 100% | 2004-09-15 | 2007-06-04 | 709d? |  | RP | 29696h | 29696h | RInImp |  | Rel-7 | Issam |  |  |  |
| 1300 | 420.1 | Extended UMTS 1.7/2.1 GHz |  | 198d? | 2006-03-15 A | 2006-12-15 A | 100% | 2006-03-15 | 2006-12-15 | 198d? | finish no earlier than 2006-12-15 | R4 | 1584h | 1584h | RInImp-UMTS1721Ext | Ericsson | Rel-7 | Issam |  | Johan Sköld (johan.skold@ericsson.com) | RP-060681 |
| 1301 | 420.2 | UMTS 2.6 GHz 7.68 Mcps TDD |  | 67d? | 2006-06-15 A | 2006-09-15 A | 100% | 2006-06-15 | 2006-09-15 | 67d? | finish no earlier than 2006-09-15 | R4 | 536h | 536h | RInImp-UMTS26VHCRTDD | IPWireless | Rel-7 | Issam |  | Shin Horng Wong (shwong@ipwireless.com) | RP-060451 |
| 1302 | 420.3 | UMTS 2.6 GHz |  | 195d? | 2004-09-15 A | 2005-06-14 A | 100% | 2004-09-15 | 2005-06-14 | 195d? | finish no earlier than 2005-06-14 | R4 | 1560h | 1560h | RInImp-UMTS2600 | Nokia | Rel-7 | Issam |  | jussi.numminen@nokia.com | RP-050184 |
| 1303 | 420.4 | UMTS 2.6 GHz TDD |  | 261d? | 2004-12-15 A | 2005-12-14 A | 100% | 2004-12-15 | 2005-12-14 | 261d? | finish no earlier than 2005-12-15 | R4 | 2088h | 2088h | RInImp-UMTS2600TDD | IPWireless | Rel-7 | Issam |  | Shin Horng Wong (shwong@ipwireless.com) | RP-050661 |
| 1304 | 420.5 | UMTS 900 MHz |  | 261d? | 2004-12-15 A | 2005-12-14 A | 100% | 2004-12-15 | 2005-12-14 | 261d? | finish no earlier than 2005-12-15 | R4 | 2088h | 2088h | RInImp-UMTS900 | Nortel | Rel-7 | Issam |  | Yannick Li (yli@nortelnetworks.com) | RP-050662 |
| 1305 | 420.6 | UMTS 1700 MHz |  | 197d? | 2005-03-15 A | 2005-12-14 A | 100% | 2005-03-15 | 2005-12-14 | 197d? | finish no earlier than 2005-12-15 | R4 | 1576h | 1576h | RInImp-UMTS1700 | NTT DoCoMo | Rel-7 | Issam |  | Takehiro Nakamura (nakamurata@nttdocomo.co.jp) | RP-050824 |
| 1306 | 420.7 | UE Antenna Performance Evaluation Method and Requirements |  | 644d? | 2004-12-15 A | 2007-06-04 A | 100% | 2004-12-15 | 2007-06-04 | 644d? | finish no earlier than 2007-06-04 | R4 | 5152h | 5152h | RInImp-UEAnt | TeliaSonera | Rel-7 | Issam |  | Christian.Bergljung@TeliaSonera.com | RP-070281 |
| 1307 | 420.8 | Improved Performance Requirements for HSDPA UE based on Rx Diversity (type 1) & LMMSE equalizer (type 2) | milestone | 0d? | 2005-03-15 A | 2005-03-15 A | 100% | 2005-03-15 | 2005-03-15 | 0d? | finish no earlier than 2005-03-15 | R4 |  |  | RInImp-HSPerf-Type3 | Cingular | Rel-7 | Issam |  | Marc Grant | RP-060015 |

Notes:
- 1283: -
- 1284: 07/2005: OMA (Stage 1), Stage 2/3 SA5, CT1/3/4 / Text3: CR 32.101, 32.421/2/3.
- 1285: - / Text3: CR 32.421/2/3.
- 1286: - / Text3: 32.441/2/3/5, CRs 32.632/3/5
- 1287: combined with UID 11067
- 1288: - / Text3: 32.421,32.422,32.423. 3 new 32.4x1,2,3
- 1289: - / Text3: TR 30.817
- 1290: - / Text3: 32.240, 32.260, 32.298, 32.299
- 1291: 09/2006 SP#33 WID approved / Text3: 32.240, 32.272, 32.299, 32.298
- 1292: Completed Sep 2007; SR in RP-070037and RP-070531 / Text3: 25.876, 25.996
- 1293: Completed Sep 2007; SR in RP-070037 / Text3: 25.211, 25.212, 25.213, 25.214, 25.215, 25.221
- 1294: Completed Sep 2007; SR in RP-070037 / Text3: 25.876
- 1295: Completed Sep 2007; SR in RP-070037
- 1296: Completed Sep 2007; SR in RP-070531
- 1297: BB place holder for a number of RAN5 Tasks
- 1298: - / Text3: TS 34.108, TS 34.109, TS 34.121-1, TS 34.121-2, TS 34.123-1, TS 34.123-2, TS 34.123-3
- 1299: Generic feature
- 1300: RP#34 completed. Introduction of Band X (Extended UMTS 1.7/2.1 GHz) in 25.307 / Text3: 25.806, 25.101, 25.104, 25.133, 24.141, 25.331, 25.306, 25.307, 25.423, 25.461, 25.463, 34.121
- 1301: RP#33 completed / Text3: 25.102, 25.105, 25.123, 25.113, 25.142, 34.124
- 1302: RP#28 completed / Text3: 25.101, 25.104, 25.133, 25.141, 25.331, 25.942, 25.306, 25.307, 34.121
- 1303: RP#30 completed / Text3: 25.102, 25.105, 25.113, 25.123, 25.142, 25.331, 25.942, 25.306, 25.307, 34.122, 34.124
- 1304: RP#30 completed / Text3: 25.101, 25.104, 25.113, 25.133, 25.141, 25.331, 25.942, 25.306, 25.307, 34.121
- 1305: RP#30 completed / Text3: 25.101, 25.104, 25.113, 25.133, 25.141, 25.306, 25.307, 25.331, 34.121
- 1306: RP#36 completed / Text3: 25.101, 25.963
- 1307: RP#27 completed / Text3: 25.101

| ID | WBS | Task | Type | Duration | Start | Finish | Complete | Baseline start | Baseline finish | Baseline duration | Constraint | Deadline | Resources | Work | Actual work | Text1 | Text4 | Text5 | Text6 | Text8 | Text11 | Text12 | Text9 | Text10 |
| --- | --- | --- | --- | --- | --- | --- | --- | --- | --- | --- | --- | --- | --- | --- | --- | --- | --- | --- | --- | --- | --- | --- | --- | --- |
| 1308 | 420.9 | **Additional minimum UE performance requirement for non-HSDPA channels based on type 1 enhanced receiver (Rx Diversity)** |  | 327d? | 2005-09-15 A | 2006-12-15 A | 100% | 2005-09-15 | 2006-12-15 | 327d? |  |  | R4 | 7344h | 7344h | RInImp-RxDiv | Qualcomm | Serge Willenegger (sergew@qualcomm.com) | Rel-7 | Issam |  |  |  |  |
| 1309 | 420.9.1 | Additional minimum UE performance requirement for DL physical channels in support of DCH/HS-DSCH operation based on type 1 enhanced receiver (RX-Diversity) |  | 195d? | 2005-09-15 A | 2006-06-14 A | 100% | 2005-09-15 | 2006-06-14 | 195d? | finish no earlier than 2006-06-15 |  | R4 | 1560h | 1560h | RInImp-RxDiv-DCH | Cingular | Marc Grant | Rel-7 | Issam | RP-060235 |  |  |  |
| 1310 | 420.9.2 | Additional minimum UE performance requirement for downlink physical channels in support of MTCH and MCCH operation based on type 1 enhanced receiver (Rx-Diversity) |  | 198d? | 2006-03-15 A | 2006-12-15 A | 100% | 2006-03-15 | 2006-12-15 | 198d? | finish no earlier than 2006-12-15 |  | R4 | 1584h | 1584h | RInImp-RxDiv-MBMS | Qualcomm | Serge Willenegger (sergew@qualcomm.com) | Rel-7 | Issam | RP-060678 |  |  |  |
| 1311 | 420.9.3 | Additional minimum UE performance requirement for downlink physical channels in support of E-DCH operation based on type 1 enhanced receiver (Rx-Diversity) |  | 198d? | 2006-03-15 A | 2006-12-15 A | 100% | 2006-03-15 | 2006-12-15 | 198d? | finish no earlier than 2006-12-15 |  | R4 | 1584h | 1584h | RInImp-RxDiv-EDCH | Qualcomm | Serge Willenegger (sergew@qualcomm.com) | Rel-7 | Issam | RP-060679 |  |  |  |
| 1312 | 420.10 | Deleted Improved support of gaming over HSDPA/EDCH |  | 262d? | 2005-12-15 A | 2006-12-15 A | 100% | 2005-12-15 | 2006-12-15 | 262d? | finish no earlier than 2006-12-15 |  | R2 | 2096h | 2096h | RInImp-Gaming | Cingular | Don Zelmer (dz1069@att.com) | Rel-7 | Joern | RP-060680 | RP-34 |  |  |
| 1313 | 420.11 | Deleted (not approved at PCG) - UMTS 2.6 GHz FDD DL External | milestone | 0d? | 2005-09-15 A | 2005-09-15 A | 100% | 2005-09-15 | 2005-09-15 | 0d? | finish no earlier than 2005-09-15 |  | R4 |  |  | RInImp-UMTS2600Ext | T-mobile | han.van.bussel@t-mobile.de | Rel-7 | Issam |  | RP-31 | PCG-16 |  |
| 1314 | 421 | **Rel-7 Improvements of the Radio Interface - UE Conformance Testing** |  | 741d? | 2005-11-11 A | 2008-09-12 A | 100% | 2005-11-11 | 2008-09-12 | 741d? |  |  | R5 | 17568h | 17568h | RInImp-UEConTest |  |  | Rel-7 | Ingbert |  |  |  |  |
| 1315 | 16.5.1 | UE Conformance Test for UMTS 2600 MHz |  | 146d | 2005-11-11 A | 2006-06-02 A | 100% | 2005-11-11 | 2006-06-02 | 146d | finish no earlier than 2006-06-02 | 2006-06-02 | R5 | 1168h | 1168h | RInImp-UMTS2600_Test | Nokia | Aleksi.Heino@nokia.com | Rel-7 | Ingbert |  |  |  | Fri 7/11/05 |
| 1316 | 16.5.1 | UE Conformance Test for UMTS 900 MHz (band VIII) |  | 146d | 2005-11-11 A | 2006-06-02 A | 100% | 2005-11-11 | 2006-06-02 | 146d | finish no earlier than 2006-06-02 | 2006-06-02 | R5 | 1168h | 1168h | RInImp-UMTS900_Test | Qualcomm | hanye@qualcomm.com | Rel-7 | Ingbert |  |  |  | Fri 11/03/05 |
| 1317 | 421.3 | Conformance Test Aspects – Improved Performance of HSDPA Receiver type 3 |  | 191d? | 2006-03-10 A | 2006-12-01 A | 100% | 2006-03-10 | 2006-12-01 | 191d? | finish no earlier than 2006-12-01 |  | R5 | 1528h | 1528h | RInImp-HSPerf-Type3_Test | Motorola | carolyn.taylor@motorola.com | Rel-7 | Ingbert |  |  |  |  |
| 1318 | 421.4 | UE antenna Over The Air (OTA) conformance testing |  | 518d? | 2006-09-20 A | 2008-09-12 A | 100% | 2006-09-20 | 2008-09-12 | 518d? | finish no earlier than 2008-09-12 |  | R5 | 4144h | 4144h | RInImp-UEAnt_Test | Nokia | Aleksi.Heino@nokia.com | Rel-7 | Ingbert | RP-080535 |  |  |  |
| 1319 | 421.5 | UE conformance testing for FDD Inter-Band Operation |  | 131d? | 2006-06-02 A | 2006-12-01 A | 100% | 2006-06-02 | 2006-12-01 | 131d? | finish no earlier than 2006-12-01 |  | R5 | 1048h | 1048h | RInImp-InterBand_Test | NEC, Motorola | Jacob.John@motorola.com | Rel-7 | Ingbert |  |  |  |  |
| 1320 | 421.6 | Conformance Test Aspects – Extended UMTS 1.7/2.1 GHz |  | 131d? | 2006-12-01 A | 2007-06-01 A | 100% | 2006-12-01 | 2007-06-01 | 131d? | finish no earlier than 2007-06-01 |  | R5 | 1048h | 1048h | RInImp-UEConTest_UMTS1721Ext | Motorola | carolyn.taylor@motorola.com | Rel-7 | Ingbert | RP-070312 |  |  |  |
| 1321 | 421.7 | Conformance Test Aspects – Minimum UE performance requirement for downlink physical channels in support of E-DCH operation based on type 1 enhanced receiver (Rx-Diversity) |  | 136d? | 2007-06-01 A | 2007-12-07 A | 100% | 2007-06-01 | 2007-12-07 | 136d? | finish no earlier than 2007-12-07 |  | R5 | 1088h | 1088h | RInImp-UEConTest_RxDivEDCH | Motorola | carolyn.taylor@motorola.com | Rel-7 | Ingbert | RP-070810 |  |  |  |
| 1322 | 421.8 | Conformance Test Aspects – Minimum UE performance requirement for downlink physical channels in support of MTCGH and MCCH operation based on type 1 enhanced receiver (Rx-Diversity) |  | 201d? | 2007-06-01 A | 2008-03-07 A | 100% | 2007-06-01 | 2008-03-07 | 201d? | finish no earlier than 2008-03-07 |  | R5 | 1608h | 1608h | RInImp-UEConTest_RxDivMBMS | Ericsson | leif.mattisson@ericsson.com | Rel-7 | Ingbert | RP-080056 |  |  |  |
| 1323 | 422 | **Rel-7 RAN improvements** |  | 653d? | 2004-12-15 A | 2007-06-15 A | 100% | 2004-12-15 | 2007-06-15 | 653d? |  |  | RP | 29952h | 29952h | RANimp |  |  | Rel-7 |  |  |  |  |  |
| 1324 | 422.1 | Optimization of channelisation code utilisation for 1.28 Mcps TDD |  | 523d? | 2004-12-15 A | 2006-12-15 A | 100% | 2004-12-15 | 2006-12-15 | 523d? | finish no earlier than 2006-12-15 |  | R1 | 4184h | 4184h | RANimp-RABSE-CodOptLCRTDD | UTStarcom | Ka Leong Lo (kaleong.lo@UTSTAR.COM) | Rel-7 | Patrick | RP-060682 |  |  |  |
| 1325 | 422.2 | Delay optimization for procedures applicable to CS and PS Connections |  | 394d? | 2005-03-15 A | 2006-09-15 A | 100% | 2005-03-15 | 2006-09-15 | 394d? | finish no earlier than 2006-09-15 |  | R2 | 3152h | 3152h | RANimp-DelayOpt | Nokia | juho.pirskanen@nokia.com | Rel-7 | Joern | RP-060453 |  |  |  |
| 1326 | 422.3 | Improved support of IMS Realtime Services using HSDPA/HSUPA |  | 197d? | 2005-03-15 A | 2005-12-14 A | 100% | 2005-03-15 | 2005-12-14 | 197d? | start no earlier than 2005-03-15 |  | R2 | 1576h | 1576h | RANimp-IMSRealTime | Cingular | Don Zelmer (dz1069@att.com) | Rel-7 | Joern | RP-050667 |  |  |  |
| 1327 | 422.4 | UE Performance Requirements for MBMS (TDD) |  | 328d? | 2005-03-15 A | 2006-06-15 A | 100% | 2005-03-15 | 2006-06-15 | 328d? | finish no earlier than 2006-06-15 |  | R4 | 2624h | 2624h | MBMS-RAN-RF-TDD | IPwireless | shwong@ipwireless.com | Rel-7 | Issam | RP-060477 |  |  |  |
| 1328 | 422.5 | Continuous connectivity for packet data users |  | 524d? | 2005-03-14 A | 2007-03-15 A | 100% | 2005-03-14 | 2007-03-15 | 524d? | finish no earlier than 2007-03-15 |  | R1 | 4192h | 4192h | RANimp-CPC | Siemens | Joern.Krause@siemens.com | Rel-7 | Patrick | RP-070033 |  |  |  |
| 1329 | 422.6 | Extended WCDMA Cell Range |  | 198d? | 2006-03-15 A | 2006-12-15 A | 100% | 2006-03-15 | 2006-12-15 | 198d? | finish no earlier than 2006-12-15 |  | R3 | 1584h | 1584h | RANimp-ExtCell | Ericsson | Muhammad Kazmi | Rel-7 | Juha | RP-060685 |  |  |  |
| 1330 | 422.7 | 7.68 Mcps TDD Enhanced Uplink |  | 198d? | 2006-03-15 A | 2006-12-15 A | 100% | 2006-03-15 | 2006-12-15 | 198d? | finish no earlier than 2006-12-15 |  | R1 | 1584h | 1584h | RANimp-VHCRTDD-EDCH | IPwireless | nanderson@ipwireless.com | Rel-7 | Patrick | RP-060684 |  |  |  |
| 1331 | 422.8 | Enhanced CELL_FACH State in FDD |  | 181d? | 2006-09-25 A | 2007-06-04 A | 100% | 2006-09-25 | 2007-06-04 | 181d? | finish no earlier than 2007-06-04 |  | R2 | 1448h | 1448h | RANimp-EnhState | Nokia | juho.pirskanen@nokia.com | Rel-7 | Joern | RP-070286 |  |  |  |
| 1332 | 422.9 | 64QAM for HSDPA (FDD) |  | 110d? | 2006-12-15 A | 2007-06-04 A | 100% | 2006-12-15 | 2007-06-04 | 110d? | finish no earlier than 2007-06-04 |  | R1 | 880h | 880h | RANimp-64QamDownlink | Ericsson | Johan.Bergman@ericsson.com | Rel-7 | Patrick | RP-070287 |  |  |  |
| 1333 | 422.10 | Improved L2 support for high data rates |  | 122d? | 2006-12-15 A | 2007-06-04 A | 100% | 2006-12-15 | 2007-06-04 | 122d? | finish no earlier than 2007-06-04 |  | R2 | 976h | 976h | RANimp-L2DataRates | Ericsson | Janne.Peisa@ericsson.com | Rel-7 | Joern | RP-070289 |  |  |  |
| 1334 | 422.11 | Introduction of 16QAM in HSUPA (FDD) |  | 110d? | 2006-12-15 A | 2007-06-04 A | 100% | 2006-12-15 | 2007-06-04 | 110d? | finish no earlier than 2007-06-04 |  | R1 | 880h | 880h | RANimp-16QamUplink | Nokia | Karri.Ranta-aho@nsn.com | Rel-7 | Patrick | RP-070288 |  |  |  |

Notes:
- 1308: - / Text3: 25.101
- 1309: RP#32 completed / Text3: 25.101
- 1310: RP#34 completed / Text3: 25.101
- 1311: RP#34 completed / Text3: 25.101
- 1312: RP#34 stopped. SR in RP-060680
- 1313: This item was conditionnaly approved pending decision of PCG#16 who decided not to approve it / Text3: 25.101, 25.104, 25.133, 25.141, 25.331, 25.942, 25.306, 25.307, 34.121
- 1314: Linked to Feature UID_20028 (RInImp)
- 1315: RP#32 completed / Text3: 34.108, 34.121
- 1316: RP#32 completed / Text3: 34.108, 34.121
- 1317: RP#34 completed / Text3: 34.121, 34.108
- 1318: RP#41 completed (GERAN aspects might need to be included later) / Text3: 34.114
- 1319: RP#34 completed / Text3: 34.108, 34.123-1, 34.123-2, 34.123-3
- 1320: RP#36 completed / Text3: 34.108, 34.121-1, 34.121-2
- 1321: RP#38 completed
- 1322: RP#39 completed
- 1323: Generic feature
- 1324: RP#34 completed
- 1325: RP#33 completed / Text3: 25.815, 25.321, 25.322, 25.331
- 1326: RP#30 completed
- 1327: RP#32 completed / Text3: 25.102, 25.123
- 1328: RP#35 completed / Text3: 25.903, 25.201, 25.211, 25.212, 25.214, 25.308, 25.321, 25.331, 25.423, 25.433, 25.101, 25.133
- 1329: RP#34 completed / Text3: 25.133, 25.423, 25.425, 25.433, 25.435, 25.453, 25.331
- 1330: RP#34 completed / Text3: 25.201, 25.202, 25.221, 25.222, 25.223, 25.224, 25.225, 25.331, 23.321, 25.306, 25.302, 25.401, 25.420, 25.423, 25.427, 25.433, 25.102, 25.105, 25.142
- 1331: RP#36 completed / Text3: 25.308, 25.304, 25.306, 25.321, 25.331, 25.433, 25.435, 25.423, 25.425,
- 1332: RP#36 completed / Text3: 25.308, 25.211, 25.212, 25.213, 25.306, 25.331, 25.433, 25.435, 25.423, 25.425, 25.101, 25.104, 25.141
- 1333: RP#36 completed / Text3: 25.301, 25.308,25.306, 25.321, 25.322, 25.331, 25.433, 25.435, 25.423, 25.425, 25.999
- 1334: RP#36 completed / Text3: 25.319, 25.101, 25.104, 25.133, 25.141, 25.211, 25.212, 25.213, 25.214, 25.306, 25.321, 25.331, 25.423, 25.433

| ID | WBS | Task | Duration | Start | Finish | Complete | Baseline start | Baseline finish | Baseline duration | Total slack | Constraint | Resources | Work | Actual work | Text1 | Text4 | Text5 | Text6 | Text8 | Text11 | Text2 | Text7 |
| --- | --- | --- | --- | --- | --- | --- | --- | --- | --- | --- | --- | --- | --- | --- | --- | --- | --- | --- | --- | --- | --- | --- |
| 1335 | 422.12 | **Interface to control Tower Mounted Amplifiers (TMAs)** | 271d? | 2006-06-02 A | 2007-06-15 A | 100% | 2006-06-02 | 2007-06-15 | 271d? |  |  | R3,S5 | 1648h | 1648h | RANImp-TMA | Vodafone | alexej.kulakov@vodafone.com | Rel-7 | Juha | RP-070140 |  |  |
| 1336 | 422.12.1 | Interface to control Tower Mounted Amplifiers (TMAs) | 206d? | 2006-06-02 A | 2007-03-16 A | 100% | 2006-06-02 | 2007-03-16 | 206d? |  |  | R3 | 840h | 840h | RANImp-TMA | Vodafone | alexej.kulakov@vodafone.com | Rel-7 | Juha | RP-070140 |  |  |
| 1337 | 422.12.2 | OAM aspects to Interface to control TMAs | 101d? | 2007-01-26 A | 2007-06-15 A | 100% | 2007-01-26 | 2007-06-15 | 101d? |  | finish no earlier than 2007-06-15 | S5 | 808h | 808h | RANImp-TMA-OAM | Vodafone | Adrian.Neal@vodafone.com | Rel-7 | Dionisio |  |  |  |
| 1338 | 423 | **Rel-7 RAN improvements - UE Conformance Testing** | 784d? | 2006-09-20 A | 2009-09-18 A | 100% | 2006-09-20 | 2009-09-18 | 784d? |  |  | R5 | 25472h | 25472h | RANimp-UEConTest |  |  | Rel-7 | Ingbert |  |  |  |
| 1339 | 423.1 | Conformance Test Aspects - 3.84 Mcps and 7.68 Mcps TDD Enhanced Uplink | 518d? | 2006-09-20 A | 2008-09-12 A | 100% | 2006-09-20 | 2008-09-12 | 518d? |  | finish no earlier than 2008-09-12 | R5 | 4144h | 4144h | RANimp-UEConTest_EDCHTDH | IPWireless | tspeight@ipwireless.com | Rel-7 | Ingbert | RP-080536 |  |  |
| 1340 | 423.2 | Conformance Test Aspects – 64QAM for HSDPA (FDD) | 257d? | 2007-03-09 A | 2008-03-03 A | 100% | 2007-03-09 | 2008-03-03 | 257d? |  | finish no earlier than 2008-03-03 | R5 | 2056h | 2056h | RANimp-UEConTest_64QamDownlink | Ericsson | leif.mattisson@ericsson.com | Rel-7 | Ingbert | RP-080059 |  |  |
| 1341 | 423.3 | Conformance Test Aspects – 16QAM for HSUPA (FDD) | 321d? | 2007-03-09 A | 2008-05-30 A | 100% | 2007-03-09 | 2008-05-30 | 321d? |  | finish no earlier than 2008-05-30 | R5 | 2568h | 2568h | RANimp-UEConTest_16QamUplink | Motorola | carolyn.taylor@motorola.com | Rel-7 | Ingbert | RP-080281 |  |  |
| 1342 | 423.4 | Conformance Test Aspects – Improved L2 support for high data rates | 321d? | 2007-03-09 A | 2008-05-30 A | 100% | 2007-03-09 | 2008-05-30 | 321d? |  | finish no earlier than 2008-05-30 | R5 | 2568h | 2568h | RANimp-UEConTest_L2DataRates | Ericsson | leif.mattisson@ericsson.com | Rel-7 | Ingbert | RP-080256 |  |  |
| 1343 | 423.5 | Conformance Test Aspects – Continuous connectivity for packet data users | 321d? | 2007-03-09 A | 2008-05-30 A | 100% | 2007-03-09 | 2008-05-30 | 321d? |  | finish no earlier than 2008-05-30 | R5 | 2568h | 2568h | RANimp-UEConTest_CPC | Nokia | jarkko.hellsten@nokia.com | Rel-7 | Ingbert | RP-080282 |  |  |
| 1344 | 423.6 | Conformance Test Aspects – Enhanced CELL_FACH state in FDD | 662d? | 2007-03-09 A | 2009-09-18 A | 100% | 2007-03-09 | 2009-09-18 | 662d? |  | finish no earlier than 2009-09-18 | R5 | 5296h | 5296h | RANimp-UEConTest_EnhancedCellFACHState | Nokia | jarkko.hellsten@nokia.com | Rel-7 | Ingbert | RP-090711 |  |  |
| 1345 | 424 | **7.68 Mcps TDD option** | 783d? | 2004-09-15 A | 2007-09-14 A | 100% | 2004-09-15 | 2007-09-14 | 783d? |  |  | RP | 24496h | 24496h | VHCRTDD | IPwireless | Martin Beale (mbeale@ipwireless.com) | Rel-7 |  | RP-060684 |  |  |
| 1346 | 424.1 | VHCRTDD: Stage 2 | 391d? | 2004-09-15 A | 2006-03-15 A | 100% | 2004-09-15 | 2006-03-15 | 391d? |  | finish no earlier than 2006-03-15 | R1 | 3128h | 3128h | VHCRTDD-Stage2 | IPwireless | Martin Beale (mbeale@ipwireless.com) | Rel-7 | Patrick | RP-060684 |  |  |
| 1347 | 424.2 | VHCRTDD: Physical Layer | 391d? | 2004-09-15 A | 2006-03-15 A | 100% | 2004-09-15 | 2006-03-15 | 391d? |  | finish no earlier than 2006-03-15 | R1 | 3128h | 3128h | VHCRTDD-Phys | IPwireless | Martin Beale (mbeale@ipwireless.com) | Rel-7 | Patrick | RP-060684 |  |  |
| 1348 | 424.3 | VHCRTDD: Layer 2 and layer 3 protocol aspects | 391d? | 2004-09-15 A | 2006-03-15 A | 100% | 2004-09-15 | 2006-03-15 | 391d? |  | finish no earlier than 2006-03-15 | R2 | 3128h | 3128h | VHCRTDD-L23 | IPwireless | drichards@ipwireless.com | Rel-7 | Joern | RP-060684 |  |  |
| 1349 | 424.4 | VHCRTDD: UTRAN Iub/Iur Protocol Aspects | 391d? | 2004-09-15 A | 2006-03-15 A | 100% | 2004-09-15 | 2006-03-15 | 391d? |  | finish no earlier than 2006-03-15 | R3 | 3128h | 3128h | VHCRTDD-IurIub | IPwireless | Peter Legg (plegg@ipwireless.com) | Rel-7 | Juha | RP-060684 |  |  |
| 1350 | 424.5 | VHCRTDD: RF Radio Transmission/ Reception, System Performance Requirements and Conformance Testing | 457d? | 2004-09-15 A | 2006-06-15 A | 100% | 2004-09-15 | 2006-06-15 | 457d? |  | finish no earlier than 2006-06-15 | R4 | 3656h | 3656h | VHCRTDD-RF | IPwireless | Shin Horng Wong (shwong@ipwireless.com) | Rel-7 | Issam | RP-060684 |  |  |
| 1351 | 424.6 | Conformance Test Aspects - 7.68 Mcps TDD | 258d? | 2006-09-20 A | 2007-09-14 A | 100% | 2006-09-20 | 2007-09-14 | 258d? |  | finish no earlier than 2007-09-10 | R5 | 2064h | 2064h | VHCRTDD-UEConTest | IPWireless | tspeight@ipwireless.com | Rel-7 | Ingbert | RP-070307 |  |  |
| 1352 | 425 | **3.84 Mcps TDD Enhanced Uplink** | 394d? | 2005-03-15 A | 2006-09-15 A | 100% | 2005-03-15 | 2006-09-15 | 394d? |  |  | RP | 18384h | 18384h | EDCHTDD | IPwireless | nanderson@ipwireless.com | Rel-7 |  | RP-060462 |  |  |
| 1353 | 425.1 | EDCHTDD: Stage 2 | 328d? | 2005-03-15 A | 2006-06-15 A | 100% | 2005-03-15 | 2006-06-15 | 328d? |  | finish no earlier than 2006-06-15 | R2 | 2624h | 2624h | EDCHTDD-Stage2 | IPwireless | nanderson@ipwireless.com | Rel-7 | Joern | RP-060462 |  |  |
| 1354 | 425.2 | EDCHTDD: Physical Layer | 394d? | 2005-03-15 A | 2006-09-15 A | 100% | 2005-03-15 | 2006-09-15 | 394d? |  | finish no earlier than 2006-09-15 | R1 | 3152h | 3152h | EDCHTDD-Phys | IPwireless | nanderson@ipwireless.com | Rel-7 | Patrick | RP-060462 |  |  |
| 1355 | 425.3 | EDCHTDD: Layer 2 and 3 Protocol Aspects | 394d? | 2005-03-15 A | 2006-09-15 A | 100% | 2005-03-15 | 2006-09-15 | 394d? |  | finish no earlier than 2006-09-15 | R2 | 3152h | 3152h | EDCHTDD-L23 | IPwireless | drichards@ipwireless.com | Rel-7 | Joern | RP-060462 |  |  |
| 1356 | 425.4 | EDCHTDD: UTRAN Iub/Iur Protocol Aspects | 394d? | 2005-03-15 A | 2006-09-15 A | 100% | 2005-03-15 | 2006-09-15 | 394d? |  | finish no earlier than 2006-09-15 | R3 | 3152h | 3152h | EDCHTDD-IurIub | Interdigital | jim.miller@interdigital.com | Rel-7 | Juha | RP-060462 |  |  |
| 1357 | 425.5 | EDCHTDD: RF Radio Transmission/ Reception, System Performance Requirements and Conformance Testing | 394d? | 2005-03-15 A | 2006-09-15 A | 100% | 2005-03-15 | 2006-09-15 | 394d? |  | finish no earlier than 2006-09-15 | R4 | 3152h | 3152h | EDCHTDD-RF | IPwireless | Shin Horng Wong (shwong@ipwireless.com) | Rel-7 | Issam | RP-060462 |  |  |
| 1358 | 426 | **1.28 Mcps TDD Enhanced Uplink** | 653d? | 2006-03-15 A | 2008-09-12 A | 100% | 2006-03-15 | 2008-09-12 | 653d? |  |  | RP | 14760h | 14760h | LCRTDD-EDCH | CATT | Haijing Hu | Rel-7 |  | RP-070296 |  |  |
| 1359 | 426.1 | 1.28 Mcps TDD Enhanced Uplink: Physical Layer | 262d? | 2006-03-15 A | 2007-03-15 A | 100% | 2006-03-15 | 2007-03-15 | 262d? |  | finish no earlier than 2007-03-15 | R1 | 2096h | 2096h | LCRTDD-EDCH-Phys | CATT | Ke Wang | Rel-7 | Patrick | RP-070038 |  |  |
| 1360 | 426.2 | 1.28 Mcps TDD Enhanced Uplink: Layer 2 and 3 Protocol Aspects | 262d? | 2006-03-15 A | 2007-03-15 A | 100% | 2006-03-15 | 2007-03-15 | 262d? |  | finish no earlier than 2007-03-15 | R2 | 2096h | 2096h | LCRTDD-EDCH-L23 | CATT | Haiyang Quan | Rel-7 | Joern | RP-070038 |  |  |
| 1361 | 426.3 | 1.28 Mcps TDD Enhanced Uplink: UTRAN Iub/Iur Protocol Aspects | 262d? | 2006-03-15 A | 2007-03-15 A | 100% | 2006-03-15 | 2007-03-15 | 262d? |  | finish no earlier than 2007-03-15 | R3 | 2096h | 2096h | LCRTDD-EDCH-IubIur | CATT | Yincheng Zhang | Rel-7 | Juha | RP-070038 |  |  |
| 1362 | 426.4 | 1.28 Mcps TDD Enhanced Uplink: RF Radio Transmission/ Reception, System Performance Requirements and Conformance Testing | 328d? | 2006-03-15 A | 2007-06-15 A | 100% | 2006-03-15 | 2007-06-15 | 328d? |  | finish no earlier than 2007-06-15 | R4 | 2624h | 2624h | LCRTDD-EDCH-RF | CATT | Yuexia Song | Rel-7 | Issam | RP-070296 |  |  |
| 1363 | 426.5 | 1.28 Mcps TDD Enhanced Uplink - UE Conformance Testing | 257d? | 2007-09-20 A | 2008-09-12 A | 100% | 2007-09-20 | 2008-09-12 | 257d? |  | finish no earlier than 2008-09-11 | R5 | 624h | 624h | LCRTDD-EDCH-UEConTest | CATT | chenxiaozhong@datangmobile.cn | Rel-7 | Ingbert | RP-080539 |  |  |
| 1364 | 427 | Conformance Test Aspects – Multiple Band and Multiple Frequency operation for LCR TDD | 326d? | 2010-09-17 | 2011-12-16 |  | 2010-09-17 | 2011-12-16 | 326d? | 160.8d | finish no earlier than 2011-12-16 | R5 | 2608h |  | LCRTDD_MB_MF_UEConTest | CATR | Ms Jun Chen (chenjun@catr.cn) | Rel-7 | Ingbert |  | PCG-25 | RP-49 |
| 1365 | 428 | MS Antenna Performance Evaluation Method and Requirements | 731d? | 2005-01-28 A | 2007-11-16 A | 100% | 2005-01-28 | 2007-11-16 | 731d? |  | finish no earlier than 2007-11-16 | GP | 5848h | 5848h | APEMR | TeliaSonera | Ulf.Tegth@teliasonera.com | Rel-7 | Paolo |  |  |  |

Notes:
- 1335: RP#35 completed
- 1336: RP#35 completed
- 1337: SP#36 completed / Text3: 32.642, 32.643, 32.645 – Align with RAN 25.466
- 1338: Linked to Feature UID_20029 (RANimp)
- 1339: RP#41 completed / Text3: 34.108, 34.122, 34.123-1, 34.123-2, 34.123-3
- 1340: RP#39 completed / Text3: 34.108, 34.121-1, 34.121-2, 34.123-1, 34.123-2, 34.123-3
- 1341: RP#40 completed / Text3: 34.108, 34.121-1, 34.121-2, 34.123-1, 34.123-2, 34.123-3
- 1342: RP#40 completed / Text3: 34.108, 34.123-1, 34.123-2, 34.123-3
- 1343: RP#40 completed / Text3: 34.108, 34.121-1, 34.121-2, 34.123-1, 34.123-2, 34.123-3
- 1344: RP#45 completed / Text3: 34.108, 34.123-1, 34.123-2, 34.123-3
- 1345: RP#31 completed
- 1346: RP#31 completed / Text3: 25.202
- 1347: RP#31 completed / Text3: 25.221, 25.222, 25.223, 25.224,25.225
- 1348: RP#31 completed / Text3: 25.301, 25.302, 25.305, 25.306, 25.321, 25.331
- 1349: RP#31 completed / Text3: 25.401, 25.420, 25.423, 25.425, 25.427, 25.430, 25.433, 25.435
- 1350: RP#32 completed / Text3: 25.102, 25.105, 25.123, 25.133, 25.142
- 1351: RP#37 completed / Text3: 34.108, 34.122, 34.123-1, 34.123-2, 34.123-3
- 1352: RP#33 completed
- 1353: RP#33 completed
- 1354: RP#33 completed / Text3: 25.201, 25.221,25.222, 25.223, 25.224, 25.225
- 1355: RP#33 completed / Text3: 25.301, 25.302, 25.306, 25.321, 25.331
- 1356: RP#33 completed / Text3: 25.401, 25.420, 25.423, 25.427, 25.430, 25.433, 25.435
- 1357: RP#33 completed / Text3: 25.102, 25.105, 25.123, 25.142
- 1358: RP#35 completed
- 1359: RP#35 completed / Text3: 25.201, 25.221, 25.222, 25.223, 25.224, 25.225
- 1360: RP#35 completed / Text3: 25.301, 25.302, 25.306, 25.321, 25.331
- 1361: RP#35 completed / Text3: 25.401, 25.420, 25.423, 25.425, 25.427, 25.430, 25.433, 25.435
- 1362: RP#36 completed / Text3: 25.102, 25.105, 25.123, 25.142
- 1363: RP#41 completed / Text3: 34.108, 34.122, 34.123-1/2/3
- 1364: Core specification was introduced via Rel-7 CR under TEI7 (RP#37 RP-070650) and via 2 Rel-8 work items: RInImp9-UMTS1880TDD and RInImp8-UMTS2300TDD. / Text3: UTRA 34.108, 34.123-1, 34.123-2, 34.123-3
- 1365: GP#36 completed for R7 / Text3: 25.914, 25.144, 45.005

| ID | WBS | Task | Type | Duration | Start | Finish | Complete | Baseline start | Baseline finish | Baseline duration | Constraint | Resources | Work | Actual work | Text1 | Text4 | Text5 | Text6 | Text8 | Text12 |
| --- | --- | --- | --- | --- | --- | --- | --- | --- | --- | --- | --- | --- | --- | --- | --- | --- | --- | --- | --- | --- |
| 1366 | 429 | **Lower 700 MHz Inclusion in the GERAN Specifications** |  | 390d? | 2005-01-03 A | 2006-06-30 A | 100% | 2005-01-03 | 2006-06-30 | 390d? |  | GP | 7632h | 7632h | GSM710 | UTC | dcotton@mtview.union-tel.com | Rel-7 | Paolo |  |
| 1367 | 429.1 | Inclusion of the 698 – 746 MHz band into GERAN core specifications |  | 129d? | 2005-01-03 A | 2005-06-30 A | 100% | 2005-01-03 | 2005-06-30 | 129d? | finish no earlier than 2005-06-30 | G1 | 1032h | 1032h | GSM710-core |  |  | Rel-7 | Paolo |  |
| 1368 | 429.2 | G1 aspects of GSM710 |  | 217.5d? | 2005-08-31 A | 2006-06-30 A | 100% | 2005-08-31 | 2006-06-30 | 217.5d? | finish no earlier than 2006-06-30 | G1 | 1740h | 1740h | GSM-710-test |  |  | Rel-7 | Paolo |  |
| 1369 | 429.3 | G3 aspects of GSM710 |  | 217.5d? | 2005-08-31 A | 2006-06-30 A | 100% | 2005-08-31 | 2006-06-30 | 217.5d? | finish no earlier than 2006-06-30 | G3new | 1740h | 1740h | GSM-710-test |  |  | Rel-7 | Ingbert |  |
| 1370 | 430 | **Support of Conversational Services in A/Gb mode via the PS domain** |  | 626d? | 2005-04-08 A | 2007-08-31 A | 100% | 2005-04-08 | 2007-08-31 | 626d? |  | GP | 15442.8h | 15442.8h | SCSAGB | Ericsson | gunnar.hedby@ericsson.com | Rel-7 | Paolo |  |
| 1371 | 430.1 | Minimise the transfer delay between the SGSN and the MS |  | 604.95d? | 2005-04-08 A | 2007-08-31 A | 100% | 2005-04-08 | 2007-08-31 | 604.95d? | finish no earlier than 2007-08-31 | GP | 4839.6h | 4839.6h | SCSAGB-MTD | Ericsson | gunnar.hedby@ericsson.com | Rel-7 | Paolo |  |
| 1372 | 430.2 | Definition of radio resource management functionality |  | 626d? | 2005-04-08 A | 2007-08-31 A | 100% | 2005-04-08 | 2007-08-31 | 626d? | finish no earlier than 2007-08-31 | G1 | 5008h | 5008h | SCSAGB-RRM | Ericsson | gunnar.hedby@ericsson.com | Rel-7 | Paolo |  |
| 1373 | 430.3 | Support of Conversational Services in A/Gb mode via the PS domain – RLC Non-Persistent mode |  | 101d? | 2006-06-30 A | 2006-11-17 A | 100% | 2006-06-30 | 2006-11-17 | 101d? | finish no earlier than 2006-11-17 | G2 | 808h | 808h | SCSAGB-RLCNP | Ericsson | gunnar.hedby@ericsson.com | Rel-7 | Gert |  |
| 1374 | 430.4 | Deleted- Radio Channel Support | milestone | 0d? | 2006-07-17 A | 2006-07-17 A | 100% | 2006-07-17 | 2006-07-17 | 0d? | start no earlier than 2006-07-17 | G2 |  |  | SCSAGB-RCHS | Ericsson | gunnar.hedby@ericsson.com | Rel-7 | Gert | SP-32 |
| 1375 | 430.5 | Deleted- Modifications to FLO | milestone | 0d? | 2006-07-17 A | 2006-07-17 A | 100% | 2006-07-17 | 2006-07-17 | 0d? | start no earlier than 2006-07-17 | G2 |  |  | SCSAGB-FLO | Ericsson | gunnar.hedby@ericsson.com | Rel-7 | Gert | SP-32 |
| 1376 | 431 | **Addition of new frequency band to GSM (T-GSM810)** |  | 626d? | 2005-04-08 A | 2007-08-31 A | 100% | 2005-04-08 | 2007-08-31 | 626d? |  | GP | 12112h | 12112h | TGSM810 | Huawei | chende@huawei.com | Rel-7 | Paolo |  |
| 1377 | 431.1 | Changes to core specification |  | 106d? | 2005-04-08 A | 2005-09-02 A | 100% | 2005-04-08 | 2005-09-02 | 106d? | finish no earlier than 2005-09-02 | GP | 848h | 848h | TGSM810-Core | Huawei | chende@huawei.com | Rel-7 | Paolo |  |
| 1378 | 431.2 | Changes to MS testing specification |  | 626d? | 2005-04-08 A | 2007-08-31 A | 100% | 2005-04-08 | 2007-08-31 | 626d? | finish no earlier than 2007-08-31 | G3new | 5008h | 5008h | TGSM810-MStest | Huawei | chende@huawei.com | Rel-7 | Ingbert |  |
| 1379 | 431.3 | Changes to BTS testing specification |  | 156d? | 2005-04-08 A | 2005-11-11 A | 100% | 2005-04-08 | 2005-11-11 | 156d? | finish no earlier than 2005-11-11 | G1 | 1248h | 1248h | TGSM810-BTStest | Huawei | chende@huawei.com | Rel-7 | Paolo |  |
| 1380 | 432 | **Handover of dedicated and shared resources while in Dual Transfer Mode** |  | 421d? | 2005-04-08 A | 2006-11-17 A | 100% | 2005-04-08 | 2006-11-17 | 421d? |  | GP | 12672h | 12672h | HODSRDTM | Nokia | rami.vaittinen@nokia.com | Rel-7 | Paolo |  |
| 1381 | 432.1 | Handover of dedicated and shared resources while in Dual Transfer Mode |  | 321d? | 2005-04-08 A | 2006-06-30 A | 100% | 2005-04-08 | 2006-06-30 | 321d? | finish no earlier than 2006-06-30 | G2 | 2568h | 2568h | HODSRDTM-G2 | Nokia | rami.vaittinen@nokia.com | Rel-7 | Gert |  |
| 1382 | 432.2 | Deleted - MS Conformance Testing |  | 421d? | 2005-04-08 A | 2006-11-17 A | 100% | 2005-04-08 | 2006-11-17 | 421d? | finish no earlier than 2006-11-17 | G3new | 3368h | 3368h | HODSRDTM-Mstest | Nokia | rami.vaittinen@nokia.com | Rel-7 | Ingbert | GP-32 |
| 1383 | 432.3 | Deleted - BTS conformance testing |  | 421d? | 2005-04-08 A | 2006-11-17 A | 100% | 2005-04-08 | 2006-11-17 | 421d? | finish no earlier than 2006-11-17 | G1 | 3368h | 3368h | HODSRDTM-BTStest | Nokia | rami.vaittinen@nokia.com | Rel-7 | Paolo | GP-32 |
| 1384 | 433 | **Mobile Station Receive Diversity (DARP Phase II)** |  | 526d? | 2005-11-11 A | 2007-11-16 A | 100% | 2005-11-11 | 2007-11-16 | 526d? |  | GP | 16360h | 16360h | MSRD2 | Nokia | kent.pedersen@nokia.com | Rel-7 | Paolo |  |
| 1385 | 433.1 | Performance Requirements for Mobile Station Receive Diversity, DARP Phase II |  | 331d? | 2005-11-11 A | 2007-02-16 A | 100% | 2005-11-11 | 2007-02-16 | 331d? | finish no earlier than 2007-02-16 | GP | 2648h | 2648h | MSRD2-PerfReq | Nokia | kent.pedersen@nokia.com | Rel-7 | Paolo |  |
| 1386 | 433.2 | Capability signalling of Mobile Station Receive Diversity, DARP Phase II |  | 331d? | 2005-11-11 A | 2007-02-16 A | 100% | 2005-11-11 | 2007-02-16 | 331d? | finish no earlier than 2007-02-16 | GP | 2648h | 2648h | MSRD2-CapSig | Nokia | kent.pedersen@nokia.com | Rel-7 | Paolo |  |
| 1387 | 433.3 | Test Scenarios for Mobile Station Receive Diversity, DARP Phase II |  | 331d? | 2005-11-11 A | 2007-02-16 A | 100% | 2005-11-11 | 2007-02-16 | 331d? | finish no earlier than 2007-02-16 | GP | 2648h | 2648h | MSRD2-TestSc | Nokia | kent.pedersen@nokia.com | Rel-7 | Paolo |  |
| 1388 | 433.4 | MS conformance test of DARP Phase II (MSRD) |  | 526d? | 2005-11-11 A | 2007-11-16 A | 100% | 2005-11-11 | 2007-11-16 | 526d? | finish no earlier than 2007-11-16 | GP | 4208h | 4208h | MSRD2-Msconf | Nokia | kent.pedersen@nokia.com | Rel-7 | Ingbert |  |
| 1389 | 434 | **Downlink Dual Carrier** |  | 947d? | 2006-01-20 A | 2009-09-04 A | 100% | 2006-01-20 | 2009-09-04 | 947d? |  | GP | 15446.6h | 15446.6h | GDCDL | Nokia Siemens Networks | leonardo.provvedi@roke.co.uk | Rel-7 | Paolo |  |
| 1390 | 434.1 | Downlink Dual Carrier Stage 2 |  | 116d? | 2006-01-20 A | 2006-06-30 A | 100% | 2006-01-20 | 2006-06-30 | 116d? | finish no earlier than 2006-06-30 | G1 | 928h | 928h | GDCDL-Stage2 | Nokia Siemens Networks | leonardo.provvedi@roke.co.uk | Rel-7 | Paolo |  |
| 1391 | 434.2 | Downlink Dual Carrier Stage 3 |  | 421d? | 2006-01-20 A | 2007-08-31 A | 100% | 2006-01-20 | 2007-08-31 | 421d? | finish no earlier than 2007-08-31 | G1 | 3368h | 3368h | GDCDL-Stage2 | Nokia Siemens Networks | leonardo.provvedi@roke.co.uk | Rel-7 | Paolo |  |
| 1392 | 434.3 | Downlink Dual Carrier – MS Conformance Test |  | 446.82d? | 2006-01-20 A | 2009-09-04 A | 100% | 2006-01-20 | 2009-09-04 | 446.82d? | finish no earlier than 2009-09-04 | G3new | 3574.6h | 3574.6h | GDCDL-MStest | Nokia Siemens Networks | leonardo.provvedi@roke.co.uk | Rel-7 | Ingbert |  |
| 1393 | 435 | Support of SIGTRAN in GERAN |  | 116d? | 2006-01-20 A | 2006-06-30 A | 100% | 2006-01-20 | 2006-06-30 | 116d? | finish no earlier than 2006-06-30 | GP | 928h | 928h | GSIGT | Ericsson | peter.ostrup@ericsson.com | Rel-7 | Ingbert |  |

Notes:
- 1366: - / Text3: 24.008, 43.022, 44.018, 44.118, 45, 001, 45.005, 51.010, 51.021
- 1367: Completed / Text3: 24.008, 43.022, 44.018, 44.118, 45, 001, 45.005,
- 1368: - / Text3: 51.021
- 1369: - / Text3: 51.010
- 1370: Originally started Nov. 2003 as GP-030443
- 1371: -
- 1372: -
- 1373: - / Text3: 43.955, 43.064, 44.060, 45.001, 45.002, 45.003, 45.005, 45.010, 51.010, 51.021
- 1374: -
- 1375: -
- 1376: - / Text3: 45.005, 45.050, 24.008, 45.008, 45.001, 43.022, 43.030, 44.018, 44.060, 51.010-1, 51.021
- 1377: - / Text3: 45.005, 45.050, 24.008, 45.008, 45.001, 43.022, 43.030, 44.018, 44.060
- 1378: - / Text3: 51010-1
- 1379: - / Text3: 51021
- 1380: GP#30 completed. Started at GP#24
- 1381: GP#30 completed / Text3: 43.055, 44.018, 44.060
- 1382: Stopped, no work done. 12/2008 Marked as stopped ("deleted") / Text3: 51-010
- 1383: Stopped, no work done. 12/2008 Marked as stopped ("deleted") / Text3: 51.026
- 1384: GP#36 completed
- 1385: GP#33 completed / Text3: 45.005
- 1386: GP#33 completed / Text3: 24.008
- 1387: GP#33 completed / Text3: 45.005
- 1388: GP#36 completed / Text3: 51.010
- 1389: GP#35 completed
- 1390: GP#30 completed / Text3: 43.055, 43.064
- 1391: GP#35 completed / Text3: 24.008, 44.018, 44.060, 45.001, 45.002, 45.005, 45.008
- 1392: GP#43 completed / Text3: 51.010
- 1393: GP#30 completed / Text3: 48.001, 48.006, 43.059, 49.031

| ID | WBS | Task | Type | Duration | Start | Finish | Complete | Remaining | Baseline start | Baseline finish | Baseline duration | Total slack | Constraint | Resources | Work | Actual work | Text1 | Text4 | Text5 | Text6 | Text8 | Text12 |
| --- | --- | --- | --- | --- | --- | --- | --- | --- | --- | --- | --- | --- | --- | --- | --- | --- | --- | --- | --- | --- | --- | --- |
| 1394 | 436 | **Latency Reductions** |  | 306d? | 2006-06-30 A | 2007-08-31 A | 100% |  | 2006-06-30 | 2007-08-31 | 306d? |  |  | GP | 7344h | 7344h | LATRED | Ericsson | Hakan.Persson@Ericsson.com | Rel-7 | Paolo |  |
| 1395 | 436.1 | Improved Ack/Nack reporting |  | 306d? | 2006-06-30 A | 2007-08-31 A | 100% |  | 2006-06-30 | 2007-08-31 | 306d? |  | finish no earlier than 2007-08-31 | G2 | 2448h | 2448h | LATRED-ACKNAR | Ericsson | Hakan.Persson@Ericsson.com | Rel-7 | Gert |  |
| 1396 | 436.2 | Reduced TTI |  | 306d? | 2006-06-30 A | 2007-08-31 A | 100% |  | 2006-06-30 | 2007-08-31 | 306d? |  | finish no earlier than 2007-08-31 | G2 | 2448h | 2448h | LATRED-REDTTI | Ericsson | Hakan.Persson@Ericsson.com | Rel-7 | Gert |  |
| 1397 | 437 | PS Handover between GERAN/UTRAN mode and GAN Mode |  | 166d? | 2006-06-30 A | 2007-02-16 A | 100% |  | 2006-06-30 | 2007-02-16 | 166d? |  | finish no earlier than 2007-02-16 | G2 | 1328h | 1328h | GUGAN | Ericsson | John.Diachina@Ericsson.com | Rel-7 | Gert |  |
| 1398 | 438 | **Higher Uplink performance for GERAN Evolution** |  | 1172d? | 2006-09-08 A | 2011-03-04 | 69% | 366.85d? | 2006-09-08 | 2011-03-04 | 1172d? | 365.8d |  | GP | 36304h | 24938h | HUGE | Nokia Siemens Networks, Ericsson | eddie.riddington@nokia.com, stefan.g.eriksson@ericsson.com | Rel-7 | Paolo |  |
| 1399 | 438.1 | Stage 2 for HUGE |  | 261d? | 2006-09-08 A | 2007-09-07 A | 100% |  | 2006-09-08 | 2007-09-07 | 261d? |  | finish no earlier than 2007-09-07 | G1 | 2088h | 2088h | HUGE-Stage2 | Nokia Siemens Networks, Ericsson | eddie.riddington@nokia.com, stefan.g.eriksson@ericsson.com | Rel-7 | Paolo |  |
| 1400 | 438.2 | Layer 1 Support for HUGE |  | 381d? | 2006-09-08 A | 2008-02-22 A | 100% |  | 2006-09-08 | 2008-02-22 | 381d? |  | finish no earlier than 2008-02-22 | G1 | 3048h | 3048h | HUGE-Layer1 | Nokia Siemens Networks, Ericsson | eddie.riddington@nokia.com, stefan.g.eriksson@ericsson.com | Rel-7 | Paolo |  |
| 1401 | 438.3 | Layer 2/3 Support for HUGE |  | 256d? | 2006-09-08 A | 2007-08-31 A | 100% |  | 2006-09-08 | 2007-08-31 | 256d? |  | finish no earlier than 2007-08-31 | G2 | 2048h | 2048h | HUGE-Layer23 | Nokia Siemens Networks, Ericsson | eddie.riddington@nokia.com, stefan.g.eriksson@ericsson.com | Rel-7 | Gert |  |
| 1402 | 438.4 | Performance requirements for HUGE |  | 516d? | 2006-09-08 A | 2008-08-29 A | 100% |  | 2006-09-08 | 2008-08-29 | 516d? |  | finish no earlier than 2008-08-29 | G1 | 4128h | 4128h | HUGE-Perfreq | Nokia Siemens Networks, Ericsson | eddie.riddington@nokia.com, stefan.g.eriksson@ericsson.com | Rel-7 | Paolo |  |
| 1403 | 438.5 | BTS Conformance Test for HUGE |  | 782d? | 2006-09-08 A | 2009-09-04 A | 100% |  | 2006-09-08 | 2009-09-04 | 782d? |  | finish no earlier than 2009-09-04 | G1 | 6248h | 6248h | HUGE-BTStest | Nokia Siemens Networks, Ericsson | eddie.riddington@nokia.com, stefan.g.eriksson@ericsson.com | Rel-7 | Paolo |  |
| 1404 | 438.6 | MS Conformance Test for HUGE |  | 1171d? | 2006-09-08 A | 2011-03-04 | 10% | 1053.9d? | 2006-09-08 | 2011-03-04 | 1171d? | 365.8d | finish no earlier than 2011-03-04 | G3new | 9368h | 936.8h | HUGE-Mstest | Nokia Siemens Networks, Ericsson | eddie.riddington@nokia.com, stefan.g.eriksson@ericsson.com | Rel-7 | Ingbert |  |
| 1405 | 439 | **REduced symbol Duration, Higher Order modulation and Turbo coding (RED HOT) for downlink** |  | 1042d? | 2006-11-17 A | 2010-11-12 | 82% | 189.55d? | 2006-11-17 | 2010-11-12 | 1042d? | 445.8d |  | GP | 26648h | 21800.4h | REDHOT | Ericsson, Nokia Siemens Networks, Marvell | stefan.g.eriksson@ericsson.com | Rel-7 | Paolo |  |
| 1406 | 439.1 | Stage 2 for REDHOT |  | 206d? | 2006-11-17 A | 2007-08-31 A | 100% |  | 2006-11-17 | 2007-08-31 | 206d? |  | finish no earlier than 2007-08-31 | G1 | 1648h | 1648h | REDHOT-Stage2 | Ericsson, Nokia Siemens Networks, Marvell | stefan.g.eriksson@ericsson.com | Rel-7 | Paolo |  |
| 1407 | 439.2 | Stage 3 for REDHOT |  | 391d? | 2006-11-17 A | 2008-05-16 A | 100% |  | 2006-11-17 | 2008-05-16 | 391d? |  | finish no earlier than 2008-05-16 | G1 | 3128h | 3128h | REDHOT-Stage3 | Ericsson, Nokia Siemens Networks, Marvell | stefan.g.eriksson@ericsson.com | Rel-7 | Paolo |  |
| 1408 | 439.3 | BTS Conformance Tests for REDHOT |  | 651d? | 2006-11-17 A | 2009-05-15 A | 100% |  | 2006-11-17 | 2009-05-15 | 651d? |  | finish no earlier than 2009-05-15 | G1 | 5208h | 5208h | REDHOT-BTStest | Ericsson, Nokia Siemens Networks, Marvell | stefan.g.eriksson@ericsson.com | Rel-7 | Paolo |  |
| 1409 | 439.4 | MS Conformance Tests for REDHOT |  | 1041d? | 2006-11-17 A | 2010-11-12 | 60% | 416.4d? | 2006-11-17 | 2010-11-12 | 1041d? | 445.8d | finish no earlier than 2010-11-12 | G3new | 8328h | 4996.8h | REDHOT-Mstest | Ericsson | stefan.g.eriksson@ericsson.com | Rel-7 | Ingbert |  |
| 1410 | 440 | (Small) Technical Enhancements and Improvements for Rel-7 | milestone | 0d? | 2007-03-26 A | 2007-03-26 A | 100% |  | 2007-03-26 | 2007-03-26 | 0d? |  | start no earlier than 2007-03-26 | All |  |  | TEI7 |  |  | Rel-7 | All |  |
| 1411 | 441 | Test - (Small) Technical Enhancements and Improvements for Rel-7 |  | 389d? | 2006-06-02 A | 2007-11-28 A | 100% |  | 2006-06-02 | 2007-11-28 | 389d? |  | finish no earlier than 2010-06-04 | R5 | 3112h | 3112h | TEI7_Test | RP#48 created for submitted CRs |  | Rel-7 | Ingbert |  |
| 1412 | 442 | **Deleted - PS domain and IMS support for IMS Emergency sessions** |  | 63.69d? | 2006-06-23 A | 2006-09-21 A | 100% |  | 2006-06-23 | 2006-09-21 | 63.69d? |  |  | S2 |  |  | IMS-EMER | Nokia | curt.c.wong@nokia.com | Rel-7 | Maurice | SP-30 |
| 1413 | 442.1 | Deleted - IMS aspects to support IMS Emergency sessions | milestone | 0d? | 2006-06-23 A | 2006-09-21 A | 100% |  | 2006-06-23 | 2006-09-21 | 0d? |  | start no earlier than 2006-06-23 | S2 |  |  | IMS-EMER | Nokia | curt.c.wong@nokia.com | Rel-7 | Maurice | SP-30 |
| 1414 | 442.2 | Deleted - PS domain aspects to support IMS Emergency sessions | milestone | 0d? | 2006-06-23 A | 2006-09-21 A | 100% |  | 2006-06-23 | 2006-09-21 | 0d? |  | start no earlier than 2006-06-23 | S2 |  |  | IMS-EMER | Nokia | curt.c.wong@nokia.com | Rel-7 | Maurice | SP-30 |
| 1415 | 16.7 | **Deleted - IMS Local services** |  | 0d? | 2006-01-06 A | 2006-01-06 A | 100% |  | 2006-01-06 | 2006-01-06 | 0d? |  |  | S2 |  |  | IMSLocal |  |  | Rel-7 | Maurice | SP-28 |
| 1416 | 16.7.1 | Deleted - Stage 2 | milestone | 0d | 2006-01-06 A | 2006-01-06 A | 100% |  | 2006-01-06 | 2006-01-06 | 0d |  | start no earlier than 2006-01-06 | S2 |  |  | IMSLocal |  |  | Rel-7 | Maurice | SP-26 |
| 1417 | 443.2 | Deleted - Stage 3 for IMS Local services | milestone | 0d? | 2006-01-06 A | 2006-01-06 A | 100% |  | 2006-01-06 | 2006-01-06 | 0d? |  | finish no earlier than 2006-01-06 | C1 |  |  | IMSLocal | Lucent | Keith Drage (drage@alcatel-lucent.com) | Rel-7 | Frederic | SP-25 |
| 1418 | 444 | Deleted - IMS Phase 3 | milestone | 0d? | 2006-01-06 A | 2006-01-06 A | 100% |  | 2006-01-06 | 2006-01-06 | 0d? |  | start no earlier than 2006-01-06 | S2 |  |  |  |  |  | Rel-7 | Maurice | SP-25 |
| 1419 | 445 | Deleted - Improvements of Radio Interface | milestone | 0d? | 2004-09-15 A | 2004-09-15 A | 100% |  | 2004-09-15 | 2004-09-15 | 0d? |  | start no earlier than 2004-09-15 | RP |  |  | RInImp |  |  | Rel-7 | Issam | SP-24 |
| 1420 | 446 | Deleted: Generic User Profile Phase 2 | milestone | 0d | 2005-08-08 A | 2006-06-30 A | 100% |  | 2005-08-08 | 2006-06-30 | 0d |  |  | C4 |  |  |  |  |  | Rel-7 | Kimmo | SP-27 |
| 1421 | 30.4 | Deleted - Stage 3 - Common objects | milestone | 0d | 2005-08-08 A | 2006-06-30 A | 100% |  | 2005-08-08 | 2006-06-30 | 0d |  | finish no earlier than 2006-06-30 | C4 |  |  |  |  |  | Rel-7 | Kimmo | SP-27 |
| 1422 | 448 | Release 7 Studies |  | 841d? | 2004-06-28 A | 2007-09-17 A | 100% |  | 2004-06-28 | 2007-09-17 | 841d? |  |  | CP,GP,RP,SP | 6728h | 6728h |  |  |  | Rel-7 | All |  |
| 1423 | 449 | Study on Multimedia Telephony Capabilities for IMS |  | 276d? | 2005-07-11 A | 2006-07-31 A | 100% |  | 2005-07-11 | 2006-07-31 | 276d? |  |  | S1 | 2145.6h | 2145.6h | MITE | Ericsson | peter.bleckert@ericsson.com | Rel-7 | Alain |  |
| 1424 | 450 | Study on Behaviour of Multi system UEs |  | 384d? | 2004-06-28 A | 2005-12-15 A | 100% |  | 2004-06-28 | 2005-12-15 | 384d? |  | start no earlier than 2004-06-28 | S1 | 3072h | 3072h | BMSU | Qualcomm | dwilliams@qualcomm.com | Rel-7 | Alain |  |
| 1425 | 451 | Study on Combining CS calls and IMS sessions |  | 189d? | 2004-06-28 A | 2005-03-17 A | 100% |  | 2004-06-28 | 2005-03-17 | 189d? |  | start no earlier than 2004-06-28 | S1 | 1512h | 1512h | IRTSD-CS_IMS | TeliaSonera | robert.frank@teliasonera.com | Rel-7 | Alain |  |
| 1426 | 452 | Study on All-IP Network |  | 188d? | 2004-06-28 A | 2005-03-16 A | 100% |  | 2004-06-28 | 2005-03-16 | 188d? |  | start no earlier than 2004-06-28 | S1 | 1504h | 1504h | FS_AIPN | NTT DoCoMo | Shin-ichi Isobe (isobes@nttdocomo.co.jp) | Rel-7 | Alain |  |
| 1427 | 453 | Study on Videotelephony teleservice |  | 231d? | 2005-03-01 A | 2006-01-17 A | 100% |  | 2005-03-01 | 2006-01-17 | 231d? |  |  | S1 | 1848h | 1848h | VidTel | T-Mobile | michael.kurz@t-mobile.at | Rel-7 | Alain |  |
| 1428 | 454 | Study on Network Selection Principles |  | 193d? | 2005-03-15 A | 2005-12-08 A | 100% |  | 2005-03-15 | 2005-12-08 | 193d? |  |  | S1 | 1544h | 1544h | NetSel | O2 | chris.friel@o2.com | Rel-7 | Alain |  |
| 1429 | 455 | Study on Multimedia Priority Service |  | 851d? | 2003-03-28 A | 2006-06-30 A | 100% |  | 2003-03-28 | 2006-06-30 | 851d? |  | finish no earlier than 2005-12-16 | S1 | 6808h | 6808h | PRIOR-MM | Telcordia | James Garrahan (jgarraha@telcordia.com) | Rel-7 | Alain |  |
| 1430 | 456 | Study on Transferring of emergency Call data |  | 190d? | 2005-07-11 A | 2006-03-31 A | 100% |  | 2005-07-11 | 2006-03-31 | 190d? |  | finish no earlier than 2005-12-08 | S1 | 1520h | 1520h | eCALL | Motorola | jian.j.wu@motorola.com | Rel-7 | Alain |  |
| 1431 | 457 | Study on Enhancement of E2E QoS |  | 281.4d? | 2004-06-28 A | 2005-09-15 A | 100% |  | 2004-06-28 | 2005-09-15 | 281.4d? |  | finish no earlier than 2005-12-01 | S2 | 2251.2h | 2251.2h | QoS7 | Huawei | Robert Jaksa | Rel-7 | Maurice |  |
| 1432 | 458 | Study on SOAP/HTTP IRP Solution Sets |  | 330d? | 2005-09-02 A | 2006-12-07 A | 100% |  | 2005-09-02 | 2006-12-07 | 330d? |  | finish no earlier than 2006-12-07 | S5 | 2640h | 2640h | OAM7-NIM-XML | Nortel | Suzèle Lariven (lariven@nortel.com) | Rel-7 | Dionisio |  |
| 1433 | 459 | Study on Itf-N Implementation Conformance Statement (ICS) template |  | 400d? | 2005-09-02 A | 2007-03-15 A | 100% |  | 2005-09-02 | 2007-03-15 | 400d? |  | finish no earlier than 2007-03-15 | S5 | 3200h | 3200h | OAM7-NIM-ICS | China Mobile | Li Yewen (liyewen@chinamobile.com) | Rel-7 | Dionisio |  |
| 1434 | 460 | Study on IRP Information Model |  | 400d? | 2005-09-02 A | 2007-03-15 A | 100% |  | 2005-09-02 | 2007-03-15 | 400d? |  | finish no earlier than 2007-03-15 | S5 | 3200h | 3200h | OAM7-NIM-IM | Motorola | trevor.pirt@motorola.com | Rel-7 | Dionisio |  |
| 1435 | 461 | Study on Bandwidth Saving at Nb Interface with IP transport |  | 261d? | 2006-03-10 A | 2007-03-09 A | 100% |  | 2006-03-10 | 2007-03-09 | 261d? |  | finish no earlier than 2007-03-09 | C3 | 2088h | 2088h | BSNbIP | Siemens | Thomas.Belling@siemens.com | Rel-7 | Gwiho |  |
| 1436 | 462 | Study on Routeing of MT-SMS via the HPLMN |  | 301d? | 2005-10-07 A | 2006-12-01 A | 100% |  | 2005-10-07 | 2006-12-01 | 301d? |  | finish no earlier than 2006-12-01 | C4 | 2408h | 2408h | SMS7 | Vodafone | Nick.Russell@vodafone.com | Rel-7 | Kimmo |  |
| 1437 | 463 | Study on the TCAPsec Gateway concept |  | 96d? | 2005-10-28 A | 2006-03-10 A | 100% |  | 2005-10-28 | 2006-03-10 | 96d? |  | finish no earlier than 2006-03-10 | C4 | 768h | 768h | SEC7-TCAP | Siemens | Ulrich.wiehe@gksag.de | Rel-7 | Kimmo |  |
| 1438 | 464 | Study on using M2PA in 3GPP network |  | 318d? | 2006-03-22 A | 2007-06-08 A | 100% |  | 2006-03-22 | 2007-06-08 | 318d? |  | finish no earlier than 2007-06-08 | C4 | 2544h | 2544h | FS-M2PA | China Mobile | zhaoyuyi@chinamobile.com | Rel-7 | Kimmo |  |

Notes:
- 1394: GP#35 completed / Text3: 45.001, 45.002, 45.003, 45.005, 45.010, 43.055, 43.064, 44.060, 51.010-1, 51.021
- 1395: GP#35 completed / Text3: 45.001, 45.002, 45.003, 45.005, 45.010, 43.055, 43.064, 44.060, 51.010-1, 51.021
- 1396: GP#35 completed / Text3: 45.001, 45.002, 45.003, 45.005, 45.010, 43.055, 43.064, 44.060, 51.010-1, 51.021
- 1397: GP#33 completed / Text3: 43.318, 44.318, 43.129, 25.306, 24.008, 44.060, 25.331, 51.010
- 1398: -
- 1399: GP#35 completed / Text3: 43.055, 43.064
- 1400: GP#37 completed / Text3: 45.001, 45.002, 45.003, 45.004, 45.008
- 1401: GP#35 completed / Text3: 24.008, 44.018, 44.060
- 1402: GP#39 completed / Text3: 45.005
- 1403: GP#43 completed / Text3: 51.021
- 1404: GP#46 completion 09/10=>03/11 (was 02/10=>03/10=>09/10). No interest in HUGE TCs development among the participating companies / Text3: 51.010
- 1405: GP#38 completed. SP#42 split core from testing specification work.
- 1406: GP#35 completed / Text3: 43.055, 43.064
- 1407: GP#38 completed / Text3: 24.008, 44.018, 44.060, 45.001, 45.002, 45.003, 45.004, 45.005, 45.008
- 1408: GP#42 completed / Text3: 51.021
- 1409: GP#46 completion 09/10=>11/10 (was 02/10=>03/10=>09/10) / Text3: 51.010
- 1410: - / Text3: CP-070260
- 1411: -
- 1412: Approved at SP#29 / Text3: 23.867, 23.abc, 23.060, 23.002, 23.271
- 1413: Approved at SP#29 / Text3: 23.867, 23.abc, 23.060, 23.002, 23.271
- 1414: Approved at SP#29 / Text3: 23.867, 23.abc, 23.060, 23.002, 23.271
- 1415: - / Text3: 23.228
- 1416: DAB - Not yet required in SA2 as it exists in previous releases
- 1417: -
- 1418: -
- 1419: Stage 2 description of Interim conclusion
- 1420: Created at TSG#27 by A. Sultan because of the move to Rel-7 of "Common Objects".
- 1421: No progress in CN4#26. This have to be moved to Rel-7. It was deleted from WID / Text3: 24.241
- 1422: -
- 1423: Spin-off Feature UID_7038 (MTSI) / Text3: 22.973
- 1424: - / Text3: 22.936
- 1425: - / Text3: 22.979
- 1426: 07/08 Moved to Rel-7 as Study out of stopped Rel-8 Feature UID_31067 All-IP Network (AIPN) / Text3: 22.978
- 1427: - / Text3: 22.903
- 1428: Spin-off Feature Network selection enhancements (NSP-CR) UID_7041 / Text3: 22.811
- 1429: Spin-off Feature PRIOR UID_340044 / Text3: 22.953
- 1430: - / Text3: 22.967
- 1431: - / Text3: 23.802
- 1432: SP#34 completed / Text3: 32.809
- 1433: SP#35 completed / Text3: 32.812
- 1434: SP#35 completed / Text3: 32.810
- 1435: Moved to FS at CT32 (in line with slides) / Text3: 29.814
- 1436: Previously known as "Study of a SMS Centre for MT SMS" / Text3: 23.840
- 1437: TR 29.800 content moved to TS 29.204 under implementation WI UID_310005 TCAPsec Gateway / Text3: 29.800
- 1438: - / Text3: 29.801

| ID | WBS | Task | Type | Duration | Start | Finish | Complete | Baseline start | Baseline finish | Baseline duration | Constraint | Resources | Work | Actual work | Text1 | Text3 | Text4 | Text5 | Text6 | Text8 | Text11 | Text12 |
| --- | --- | --- | --- | --- | --- | --- | --- | --- | --- | --- | --- | --- | --- | --- | --- | --- | --- | --- | --- | --- | --- | --- |
| 1439 | 465 | **Study on Support of (G)MSC-S - (G)MSC-S Nc Interface based on the SIP-I protocol** |  | 350d? | 2006-05-15 A | 2007-09-14 A | 100% | 2006-05-15 | 2007-09-14 | 350d? |  | C4 | 7800h | 7800h | NcSIP | 29.802 | Vodafone | david.hutton@vodafone.com | Rel-7 | Kimmo |  |  |
| 1440 | 465.1 | CT4 aspects of NcSIP |  | 275d? | 2006-05-15 A | 2007-06-01 A | 100% | 2006-05-15 | 2007-06-01 | 275d? | finish no earlier than 2007-06-01 | C4 | 2200h | 2200h | NcSIP | 29.802 | Vodafone | david.hutton@vodafone.com | Rel-7 | Kimmo |  |  |
| 1441 | 465.2 | CT3 aspects of NcSIP |  | 350d? | 2006-05-15 A | 2007-09-14 A | 100% | 2006-05-15 | 2007-09-14 | 350d? | finish no earlier than 2007-09-14 | C3 | 2800h | 2800h | NcSIP | 29.802 | Ericsson | ragnar.huslende@ericsson.com | Rel-7 | Gwiho |  |  |
| 1442 | 466 | Study on Evolved UTRA and UTRAN |  | 458d? | 2004-12-15 A | 2006-09-15 A | 100% | 2004-12-15 | 2006-09-15 | 458d? | finish no earlier than 2006-09-15 | RP | 3664h | 3664h | RANFS-Evo | 25.912 | NTT DoCoMo | nakamurata@NTTDOCOMO.CO.JP | Rel-7 | Issam | RP-060472 |  |
| 1443 | 467 | Study on Performance Evaluation of the UE behaviour in high speed trains with speeds up to 350 kmph |  | 328d? | 2005-03-15 A | 2006-06-15 A | 100% | 2005-03-15 | 2006-06-15 | 328d? | finish no earlier than 2006-06-15 | R4 | 2624h | 2624h | RANFS-HSTrains | none | Vodafone | Mike.vogel@vodafone.com,tim.frost@vodafone.com | Rel-7 | Issam | RP-060412 |  |
| 1444 | 468 | Study on UTRA Tower Mounted Amplifier (FDD) |  | 195d? | 2005-06-15 A | 2006-03-14 A | 100% | 2005-06-15 | 2006-03-14 | 195d? | finish no earlier than 2006-03-15 | R4 | 1560h | 1560h | RANFS-TMA | 25.818 | Ericsson | Klas.Sjerling@ericsson.com | Rel-7 | Issam | RP-060035 |  |
| 1445 | 469 | Study on Continuous connectivity for packet data users |  | 132d? | 2005-03-15 A | 2005-09-14 A | 100% | 2005-03-15 | 2005-09-14 | 132d? | finish no earlier than 2005-09-15 | R1 | 1056h | 1056h | RANFS-cont-packet | none | Siemens | joerg.gustrau@siemens.com | Rel-7 | Patrick | RP-050427 |  |
| 1446 | 470 | Study on Improvement of the Multimedia Broadcast Multicast Service (MBMS) in UTRAN |  | 262d? | 2005-12-15 A | 2006-12-15 A | 100% | 2005-12-15 | 2006-12-15 | 262d? | finish no earlier than 2006-12-15 | R2 | 2096h | 2096h | RANFS-MBMSImp | 25.905 | LG Electronics | leego@lge.com | Rel-7 | Joern | RP-060692 |  |
| 1447 | 471 | Study on Performance Improvements in Small Cells using HSDPA/EDCH |  | 131d? | 2005-12-15 A | 2006-06-15 A | 100% | 2005-12-15 | 2006-06-15 | 131d? | finish no earlier than 2006-06-15 | R4 | 1048h | 1048h | SMALLCELLS | none | Cingular | Marc Grant | Rel-7 | Issam | RP-060263 |  |
| 1448 | 472 | Study on Further Improved Performance Requirements for UMTS/HSDPA UE (FDD) |  | 383d? | 2005-12-15 A | 2007-06-04 A | 100% | 2005-12-15 | 2007-06-04 | 383d? | finish no earlier than 2007-06-04 | R4 | 3064h | 3064h | RANFS-IC | 25.963 | Cingular | Marc Grant | Rel-7 | Issam | RP-070499 |  |
| 1449 | 473 | Study on Scope of future FDD HSPA Evolution |  | 394d? | 2006-03-15 A | 2007-09-17 A | 100% | 2006-03-15 | 2007-09-17 | 394d? | finish no earlier than 2007-09-17 | RP | 3152h | 3152h | RANFS-HSPAEvo | 25.999 | Cingular | Don Zelmer (dz1069@att.com) | Rel-7 | Issam | RP-070533 |  |
| 1450 | 474 | Study on Dynamically reconfiguring a FDD UE receiver to reduce power consumption when desired Quality of Service is met | milestone | 0d? | 2007-06-22 A | 2007-06-22 A | 100% | 2007-06-22 | 2007-06-22 | 0d? |  | R4 |  |  | FSUEPow | 25.906 | Nokia | Chris.callender@nokia.com, tiina.s.koskinen@nokia.com | Rel-7 | Issam | RP-070534 |  |
| 1451 | 475 | Study on Future GERAN Evolution |  | 486d? | 2005-04-08 A | 2007-02-16 A | 100% | 2005-04-08 | 2007-02-16 | 486d? | finish no earlier than 2007-02-16 | GP | 3888h | 3888h | FGE | 45.912 | Nokia | eddie.riddington@nokia.com | Rel-7 | Paolo |  |  |
| 1452 | 476 | Study on GAN Enhancements | milestone | 0d? | 2007-08-31 A | 2007-08-31 A | 100% | 2007-08-31 | 2007-08-31 | 0d? | start no earlier than 2007-08-31 | GP |  |  | EGAN | 43.902 | T-Mobile | janne.linkola@t-mobile.com | Rel-7 | Paolo |  |  |
| 1453 | 477 | Deleted - Study on IMS with real time services deployment |  | 316d? | 2004-06-28 A | 2005-09-12 A | 100% | 2004-06-28 | 2005-09-12 | 316d? |  | S1 | 2528h | 2528h | IRTSD |  |  |  | Rel-7 | Alain |  | SP-30 |
| 1454 | 478 | Deleted - Covered by SI - Personal Network (PN) and Personal Area Network (PAN) | milestone | 0d? | 2005-12-08 A | 2005-12-20 A | 100% | 2005-12-08 | 2005-12-20 | 0d? | start no earlier than 2005-12-08 | S1 |  |  | PNPAN |  | Vodafone | armin.toepfer@vodafone.com | Rel-7 | Alain |  | SP-30 |
| 1455 | 479 | Deleted - Study on Personal Network and Personal Area Network | milestone | 0d? | 2006-10-20 A | 2006-10-20 A | 100% | 2006-10-20 | 2006-10-20 | 0d? | finish no earlier than 2006-10-20 | S1 |  |  | PNPAN |  |  |  | Rel-7 | Alain |  | SP-31 |
| 1456 | 480 | Deleted - Covered by SI - Multimedia Telephony Capabilities for IMS | milestone | 0d? | 2005-12-08 A | 2005-12-20 A | 100% | 2005-12-08 | 2005-12-20 | 0d? | start no earlier than 2005-12-08 | S1 |  |  | MITE |  | Ericsson | peter.bleckert@ericsson.com | Rel-7 | Alain |  | SP-30 |
| 1457 | 481 | Deleted - Covered by SI - Transferring of emergency Call data | milestone | 0d? | 2005-12-08 A | 2005-12-08 A | 100% | 2005-12-08 | 2005-12-08 | 0d? | start no earlier than 2005-12-08 | S1 |  |  | eCALL |  | Motorola | steven.vardy@motorola.com | Rel-7 | Alain |  | SP-30 |
| 1458 | 482 | Deleted - Covered by SI - MBMS Enhancements | milestone | 0d? | 2005-12-08 A | 2005-12-08 A | 100% | 2005-12-08 | 2005-12-08 | 0d? | start no earlier than 2005-12-08 | S1 |  |  | MBMSE |  | China Mobile | liuhongyfw@chinamobile.com | Rel-7 | Alain |  | SP-30 |
| 1459 | 483 | Deleted - Study on Customised Alerting Tone (CAT) Requirements (was duplicated) | milestone | 0d? | 2006-06-30 A | 2006-06-30 A | 100% | 2006-06-30 | 2006-06-30 | 0d? | start no earlier than 2006-06-30 | S1 |  |  | CAT |  |  |  | Rel-7 | Alain |  | SP-31 |
| 1460 | 484 | Deleted - Study on LCS architecture for I-WLAN (covered by 32108) | milestone | 0d? | 2006-12-08 A | 2006-12-08 A | 100% | 2006-12-08 | 2006-12-08 | 0d? | start no earlier than 2006-12-08 | S2 |  |  | IMS-SE |  | LG Electronics | Donghee Shim dhshim@lge.com ; phede@lge.com | Rel-7 | Maurice |  | SP-33 |
| 1461 | 485 | Deleted - IMS security extensions (covered by UID33027) | milestone | 0d? | 2005-12-08 A | 2005-12-08 A | 100% | 2005-12-08 | 2005-12-08 | 0d? | start no earlier than 2005-12-08 | S3 |  |  | IMS-SE |  | Ericsson | Bengt.Sahlin@ericsson.com | Rel-7 | Dionisio |  | SP-30 |
| 1462 | 486 | **Deleted - Study on applicability of GALILEO for LCS** |  | 0d? | 2005-06-30 A | 2005-06-30 A | 100% | 2005-06-30 | 2005-06-30 | 0d? |  | S2 |  |  | Galileo |  |  |  | Rel-7 | Maurice |  | SP-25 |
| 1463 | 486.1 | Deleted - TR on Stage 2 | milestone | 0d? | 2005-06-30 A | 2005-06-30 A | 100% | 2005-06-30 | 2005-06-30 | 0d? | finish no earlier than 2005-06-30 | S2 |  |  | Galileo |  |  |  | Rel-7 | Maurice |  | SP-25 |
| 1464 | 486.2 | Deleted - GERAN review of the TR | milestone | 0d? | 2005-06-30 A | 2005-06-30 A | 100% | 2005-06-30 | 2005-06-30 | 0d? | start no earlier than 2005-06-30 | GP |  |  | Galileo |  |  |  | Rel-7 | Paolo |  | SP-26 |
| 1465 | 487 | Deleted - Study on Stage 2 (IMS services using CS bearers) |  | 316d? | 2004-06-28 A | 2005-09-12 A | 100% | 2004-06-28 | 2005-09-12 | 316d? | finish no earlier than 2005-09-12 | S2 | 2528h | 2528h | IRTSD-IMSCS | 23.899 | Nortel | Mark Watson | Rel-7 | Maurice |  | SP-30 |

Notes:
- 1439: -
- 1440: -
- 1441: -
- 1442: RP#33 (Sep 2006) completed. SR in RP-060472
- 1443: RP#32 (Jun 2006) completed. SR in RP-060412
- 1444: RP#31 (Mar 2006) completed. SR in RP-060035
- 1445: RP#29 (Sep 2006) completed. SR in RP-050427
- 1446: RP#34 (Dec 2006) completed. SR in RP-060692
- 1447: RP#32 (Jun 2006) closed (no progress). SR in RP-060263
- 1448: RP#36 (May 2007) completed. SR in RP-070499
- 1449: RP#37 (Sep 2007) completed. SR in RP-070533
- 1450: RP#37 (Sep 2007) completed. SR in RP-070534
- 1451: GP#33 completed
- 1452: GP#35 completed
- 1453: -
- 1454: -
- 1455: Moved from FS section Feb 06
- 1456: -
- 1457: -
- 1458: -
- 1459: Awaiting MCC SA3 input
- 1460: S2#52: Entry created
- 1461: -
- 1462: -
- 1463: -
- 1464: -
- 1465: SP-30: S2 has no intention for TR completion

| ID | WBS | Task | Type | Duration | Start | Finish | Complete | Baseline start | Baseline finish | Baseline duration | Constraint | Resources | Work | Actual work | Text1 | Text6 | Text8 | Text12 | Text3 | Text4 | Text5 | Text7 | Text10 |
| --- | --- | --- | --- | --- | --- | --- | --- | --- | --- | --- | --- | --- | --- | --- | --- | --- | --- | --- | --- | --- | --- | --- | --- |
| 1466 | 488 | **Deleted - VoIMS bearer related enhancements** |  | 0d? | 2006-07-21 A | 2006-07-21 A | 100% | 2006-07-21 | 2006-07-21 | 0d? |  | S2 |  |  | VoIMS | Rel-7 | Maurice | SP-32 |  |  |  |  |  |
| 1467 | 488.1 | Deleted - Study on enhancement of radio performance for VoIMS | milestone | 0d? | 2006-07-21 A | 2006-07-21 A | 100% | 2006-07-21 | 2006-07-21 | 0d? | start no earlier than 2006-07-21 | S2 |  |  | VoIMS | Rel-7 | Maurice | SP-32 | 23.807 | Nortel | Laurence Lautier (lautierl@nortel.com) |  |  |
| 1468 | 489 | Deleted - Study on IMS enhancements and optimizations for real time communication. |  | 430d? | 2005-10-10 A | 2007-06-01 A | 100% | 2005-10-10 | 2007-06-01 | 430d? | finish no earlier than 2007-06-01 | S2 | 3440h | 3440h | IMS-RT | Rel-7 | Maurice | SP-35 | 23.818 | Ericsson | stephen.terrill@ericsson.com |  |  |
| 1469 | 490 | Deleted - Study on Terminating Session handling |  | 255d? | 2006-01-09 A | 2006-12-29 A | 100% | 2006-01-09 | 2006-12-29 | 255d? | finish no earlier than 2006-12-29 | S2 | 2040h | 2040h | CSIterm | Rel-7 | Maurice | SP-32 | 23.819 | Samsung |  |  |  |
| 1470 | 491 | Deleted - Study on Transferring of emergency call data – in-band modem solution (moved to Rel-8) | milestone | 0d? | 2007-06-22 A | 2007-06-22 A | 100% | 2007-06-22 | 2007-06-22 | 0d? | start no earlier than 2007-06-22 | S4 |  |  | eCALLIBMS | Rel-7 | Paolo | SP-38 | 26.967 | Airbiquity | lhong@airbiquity.com |  |  |
| 1471 | 492 | Deleted - Study on IRP usage scenarios |  | 330d? | 2005-09-02 A | 2006-12-07 A | 100% | 2005-09-02 | 2006-12-07 | 330d? | finish no earlier than 2006-12-07 | S5 | 2640h | 2640h | OAM-Study | Rel-7 | Dionisio | SP-32 | 32.8xy | Lucent |  |  |  |
| 1472 | 493 | Deleted - Study on Interference Cancellation for UTRA FDD UE (covered by UID 20053) |  | 1d? | 2007-03-28 A | 2007-03-28 A | 100% | 2007-03-28 | 2007-03-28 | 1d? | start no earlier than 2007-03-28 | R4 | 8h | 8h | RANFS-InterfCanc | Rel-7 | Issam | SP-38 |  |  |  |  |  |
| 1473 | 494 | Deleted - Study on enhanced support of Video Telephony | milestone | 0d? | 2006-06-30 A | 2006-06-30 A | 100% | 2006-06-30 | 2006-06-30 | 0d? | start no earlier than 2006-06-30 | GP |  |  | VIDGER | Rel-7 | Paolo | SP-32 |  | Ericsson | stefan.g.eriksson@ericsson.com |  |  |
| 1474 | 495 | Release 6 Features |  | 915d? | 2002-06-28 A | 2005-12-30 A | 100% | 2002-06-28 | 2005-12-30 | 915d? |  | NP,GP, RP,SP,TP | 7320h | 7320h |  | Rel-6 | All |  |  |  |  |  |  |
| 1475 | 8 | **Rel-6 Improvements of Radio Interface** |  | 1717d? | 2000-08-14 A | 2007-03-13 A | 100% | 2000-08-14 | 2007-03-13 | 1717d? |  | RP | 57776h | 57776h | RInImp | Rel-6 |  |  |  |  |  |  |  |
| 1476 | 496.1 | Improved support of IMS Realtime Services using HSDPA/EDCH |  | 197d? | 2005-03-15 A | 2005-12-14 A | 100% | 2005-03-15 | 2005-12-14 | 197d? | finish no earlier than 2005-12-14 | R2 | 1576h | 1576h | RInImp-IMSRealTime | Rel-6 | Joern |  |  | Cingular | Don Zelmer (dz1069@att.com) |  |  |
| 1477 | 496.2 | Improving Receiver Performance Requirements for the FDD UE |  | 401d | 2002-03-08 A | 2003-09-19 A | 100% | 2002-03-08 | 2003-09-19 | 401d | start no earlier than 2002-03-08 | R4 | 3208h | 3208h | RInImp-UERecPerf | Rel-6 | Issam |  | 25.101 | Intel | shimon.moshavi@INTEL.COM |  |  |
| 1478 | 8.2 | **Base station classification** |  | 603d | 2000-08-14 A | 2002-12-04 A | 100% | 2000-08-14 | 2002-12-04 | 603d |  | R4 | 9648h | 9648h | RInImp-BSClass | Rel-6 | Issam |  |  |  |  |  |  |
| 1479 | 8.2.1 | FDD Base station classification |  | 603d | 2000-08-14 A | 2002-12-04 A | 100% | 2000-08-14 | 2002-12-04 | 603d | finish no earlier than 2002-12-04 | R4 | 4824h | 4824h | RInImp-BSClass-FDD | Rel-6 | Issam |  | 25.104, 25.141 | Nokia | antti.toskala@nokia.com |  |  |
| 1480 | 496.4 | UMTS-850 |  | 266d | 2002-12-06 A | 2003-12-12 A | 100% | 2002-12-06 | 2003-12-12 | 266d | finish no earlier than 2003-12-15 | R4 | 2128h | 2128h | RInImp-UMTS850 | Rel-6 | Issam |  | 25.101, 25.104, 25.133, 25.141, 25.307, 25.331, 25.942 | Cingular | Don Zelmer (dz1069@att.com) |  |  |
| 1481 | 496.5 | DS-CDMA introduction in the 800 MHz band |  | 196d | 2003-03-14 A | 2003-12-12 A | 100% | 2003-03-14 | 2003-12-12 | 196d | finish no earlier than 2003-12-15 | R4 | 1568h | 1568h | RInImp-UMTS800 | Rel-6 | Issam |  | 25.101, 25.104, 25.133, 25.141, 25.307, 25.331 | NTT DoCoMo | Takehiro Nakamura (nakamurata@nttdocomo.co.jp) |  |  |
| 1482 | 496.6 | UMTS 1.7/2.1 GHz | milestone | 0d? | 2003-03-14 A | 2003-03-14 A | 100% | 2003-03-14 | 2003-03-14 | 0d? |  | R4 |  |  | RInImp-UMTS1721 | Rel-6 | Issam |  | 25.101, 25.104, 25.133, 25.141, 25.307, 25.331 | Nokia | jussi.numminen@NOKIA.COM |  |  |
| 1483 | 496.7 | Conformance Test Aspects – UMTS 1.7/2.1 GHz Band |  | 191d? | 2006-03-10 A | 2006-12-01 A | 100% | 2006-03-10 | 2006-12-01 | 191d? | finish no earlier than 2006-12-01 | R5 | 1528h | 1528h | RInImp-UMTS1721_Test | Rel-6 | Ingbert |  | TS34.121, TS34.108 | Motorola | carolyn.taylor@motorola.com |  |  |
| 1484 | 496.8 | **Improved Receiver Performance Requirements for HSDPA** |  | 908d | 2003-09-19 A | 2007-03-13 A | 100% | 2003-09-19 | 2007-03-13 | 908d |  | R4,R5 | 24384h | 24384h | RInImp-HSPerf | Rel-6 | Issam |  |  | Nokia | jussi.numminen@NOKIA.COM |  |  |
| 1485 | 496.8.1 | Improved Minimum Performance Requirements for HSDPA UE categories 7 and 8 |  | 650d | 2004-09-15 A | 2007-03-13 A | 100% | 2004-09-15 | 2007-03-13 | 650d |  | R4 | 3624h | 3624h | RInImp-HSPerf-10code | Rel-6 | Issam |  | 25.101 | Nokia | jussi.numminen@nokia.com |  |  |
| 1486 | 496.8.2 | Testing of Improved Minimum Performance for HSDPA |  | 650d | 2003-09-19 A | 2006-03-16 A | 100% | 2003-09-19 | 2006-03-16 | 650d | finish no earlier than 2006-03-16 | R5 | 5200h | 5200h | RInImp-HSPerf-10Code_Test | Rel-6 | Ingbert |  | 34.108, 34.121, 34.122, 34.123-1, 34.123-2, 34.123-3 | Motorola | carolyn.taylor@motorola.com | TSG | 19/9/2003 |
| 1487 | 496.8.3 | Performance Requirements of Receive Diversity for HSDPA |  | 387d | 2003-12-15 A | 2005-06-07 A | 100% | 2003-12-15 | 2005-06-07 | 387d |  | R4 | 3096h | 3096h | RInImp-HSPerf-RxDiv | Rel-6 | Issam |  | 25.101 | NTT DoCoMo | Takehiro Nakamura (nakamurata@nttdocomo.co.jp) |  |  |
| 1488 | 496.8.4 | Testing of Performance of Receiver diversity for HSDPA |  | 650d | 2003-09-19 A | 2006-03-16 A | 100% | 2003-09-19 | 2006-03-16 | 650d | finish no earlier than 2006-03-16 | R5 | 5200h | 5200h | RInImp-HSPerf-RxDiv_Test | Rel-6 | Ingbert |  | 34.108, 34.121, 34.122, 34.123-1, 34.123-2, 34.123-3 | Motorola | carolyn.taylor@motorola.com | TSG | 19/9/2003 |
| 1489 | 497 | **Rel-6 RAN Feasibility Studies** |  | 1196d? | 2000-08-14 A | 2005-03-14 A | 100% | 2000-08-14 | 2005-03-14 | 1196d? |  | RP | 43048h | 43048h |  | Rel-6 |  |  |  |  |  |  |  |
| 1490 | 497.1 | FS of the improved access to UE measurement data for CRNC to support TDD RRM |  | 270d? | 2002-12-06 A | 2003-12-18 A | 100% | 2002-12-06 | 2003-12-18 | 270d? | finish no earlier than 2003-09-19 | R3 | 2160h | 2160h | RANimp-RRMopt-FSUEMsD | Rel-6 | Juha |  | 25.801, 25.423 | Interdigital | jim.miller@interdigital.com |  | SP-24 |
| 1491 | 497.2 | FS on Radio link performance enhancements |  | 1067d | 2000-08-14 A | 2004-09-14 A | 100% | 2000-08-14 | 2004-09-14 | 1067d | finish no earlier than 2004-09-14 | R1 | 8536h | 8536h | RInImp-Rlperf | Rel-6 | Patrick |  | 25.899 | Nokia | antti.toskala@nokia.com |  |  |
| 1492 | 497.3 | FS on Improvement of inter-frequency and inter-system measurements for 1.28 Mcps TDD |  | 461d | 2001-12-14 A | 2003-09-19 A | 100% | 2001-12-14 | 2003-09-19 | 461d | start no earlier than 2001-12-14 | R1 | 3688h | 3688h | RInImp-IfIsMLCR | Rel-6 | Patrick |  | 25.888 | Samsung | Li Xiao Qiang (xqli@samsung.co.kr) |  |  |
| 1493 | 497.4 | FS for the analysis of OFDM for UTRAN enhancement |  | 526d | 2002-06-10 A | 2004-06-14 A | 100% | 2002-06-10 | 2004-06-14 | 526d | start no earlier than 2002-06-10 | R1 | 4208h | 4208h | RInImp-FSOFDM | Rel-6 | Patrick |  | 25.892 | Nortel | Sarah Boumendil |  |  |
| 1494 | 497.5 | FS on Uplink Enhancements for Dedicated Transport Channels |  | 396d | 2002-09-06 A | 2004-03-12 A | 100% | 2002-09-06 | 2004-03-12 | 396d | finish no earlier than 2004-03-12 | R1 | 3168h | 3168h | RInImp-FSUpDTrCh | Rel-6 | Patrick |  | 25.896 | Nokia | Karri.Ranta-aho@nsn.com |  |  |
| 1495 | 497.6 | FS on Analysis on Higher Chip Rates for UTRA TDD evolutions |  | 528d | 2002-09-06 A | 2004-09-14 A | 100% | 2002-09-06 | 2004-09-14 | 528d | finish no earlier than 2004-09-14 | R1 | 4224h | 4224h | RInImp-FSVHCRTDD | Rel-6 | Patrick |  | 25.895 | IPWireless | mbeale@ipwireless.com |  |  |
| 1496 | 497.7 | FS on Low Output Powers for general purpose FDD BSs |  | 128d | 2003-06-13 A | 2004-03-12 A | 100% | 2003-06-13 | 2004-03-12 | 128d | finish no earlier than 2004-03-12 | R3 | 1024h | 1024h | RInImp-FSLoPw | Rel-6 | Juha |  | 25.807 | Telefonica | Ana Burgos (burgos_a@tsm.es) |  |  |
| 1497 | 497.8 | FS on Uplink enhancements for UTRA TDD |  | 462d | 2003-06-06 A | 2005-03-14 A | 100% | 2003-06-06 | 2005-03-14 | 462d | finish no earlier than 2005-03-14 | R1 | 3696h | 3696h | RInImp-FSUpEnhTDD | Rel-6 | Patrick |  | 25.804 | Interdigital | Marian.Rudolf@InterDigital.com |  |  |
| 1498 | 8.8 | FS on UE antenna efficiency test methods performance requirements (2) |  | 131d | 2002-03-08 A | 2002-09-06 A | 100% | 2002-03-08 | 2002-09-06 | 131d | finish no earlier than 2002-09-06 | R4 | 1048h | 1048h | RInImp-UEAnTM2 | Rel-6 | Issam |  |  | Allgon | Alf Ahlström |  |  |
| 1499 | 9.4 | Deleted - FS on the evolution of the UTRAN architecture |  | 592d | 2002-09-09 A | 2004-12-14 A | 100% | 2002-09-09 | 2004-12-14 | 592d | finish no earlier than 2004-12-15 | R3 | 4736h | 4736h | RANimp-FSEvo | Rel-6 | Juha | RP-26 |  | Nokia | woonhee.hwang@nsn.com, Antti.Toskala@nokia.com |  |  |

Notes:
- 1466: Created by MCC to group all VoIMS related items, after consultation of chairs
- 1467: WID approved SP#28: SA2#52: CLOSED - To be removed from the work plan
- 1468: abandoned at 65%
- 1469: SP#32 Jun 2006 Study abandoned => spin-off Implementation work UID_320029
- 1470: SP-38 stopped
- 1471: -
- 1472: Deleted. Same as FS on Further Improved Performance Requirements for UMTS/HSDPA UE (FDD)
- 1473: FS CLOSED at G#28 (no input)
- 1474: -
- 1475: -
- 1476: -
- 1477: -
- 1478: -
- 1479: -
- 1480: Introduction of UMTS850 (Band V) in 25.307
- 1481: Introduction of UMTS800 in 25.307
- 1482: Introduction of UMTS1700/2100 (Band IV)
- 1483: -
- 1484: -
- 1485: Approved at RP#25 as RP-040375
- 1486: -
- 1487: -
- 1488: -
- 1489: -
- 1490: -
- 1491: Study finished at RP#25
- 1492: -
- 1493: -
- 1494: -
- 1495: Study finished at RP#25
- 1496: -
- 1497: -
- 1498: The RInImp-UEAnTM FS was re-opened at TSG RP#15 upon request from WG4
- 1499: Study Closed, work will continue within the FS on evolved UTRA and UTRAN

| ID | WBS | Task | Type | Duration | Start | Finish | Complete | Baseline start | Baseline finish | Baseline duration | Constraint | Deadline | Resources | Work | Actual work | Text1 | Text4 | Text5 | Text6 | Text3 | Text8 | Text7 | Text9 | Text10 | Text12 |
| --- | --- | --- | --- | --- | --- | --- | --- | --- | --- | --- | --- | --- | --- | --- | --- | --- | --- | --- | --- | --- | --- | --- | --- | --- | --- |
| 1500 | 498 | **FDD Enhanced Uplink** |  | 915d | 2004-03-15 A | 2007-09-14 A | 100% | 2004-03-15 | 2007-09-14 | 915d |  |  | RP | 23664h | 23664h | EDCH | Ericsson | Joakim Bergström | Rel-6 |  |  |  |  |  |  |
| 1501 | 498.1 | FDD Enhanced Uplink - Stage 2 |  | 197d | 2004-03-15 A | 2004-12-14 A | 100% | 2004-03-15 | 2004-12-14 | 197d | finish no earlier than 2004-12-14 |  | R2 | 1576h | 1576h | EDCH-Stage2 |  |  | Rel-6 | 25.309 | Joern |  |  |  |  |
| 1502 | 498.2 | FDD Enhanced Uplink - Physical Layer |  | 261d | 2004-03-15 A | 2005-03-14 A | 100% | 2004-03-15 | 2005-03-14 | 261d | finish no earlier than 2005-03-14 |  | R1 | 2088h | 2088h | EDCH-Phys | Nokia | Karri.Ranta-aho@nsn.com | Rel-6 | 25.211, 25.212, 25.213, 25.214, 25.215 | Patrick |  |  |  |  |
| 1503 | 498.3 | FDD Enhanced Uplink - Layer 2 and 3 Protocol Aspects |  | 261d | 2004-03-15 A | 2005-03-14 A | 100% | 2004-03-15 | 2005-03-14 | 261d | finish no earlier than 2005-03-14 |  | R2 | 2088h | 2088h | EDCH-L23 | Ericsson | Joakim Bergström | Rel-6 | 25.301, 25.302, 25.306, 25.321, 25.331 | Joern |  |  |  |  |
| 1504 | 498.4 | FDD Enhanced Uplink - UTRAN Iub/Iur Protocol Aspects |  | 261d | 2004-03-15 A | 2005-03-14 A | 100% | 2004-03-15 | 2005-03-14 | 261d | finish no earlier than 2005-03-14 |  | R3 | 2088h | 2088h | EDCH-IurIub | Nortel | Saso Stojanovski | Rel-6 | 25.401, 25.420, 25.423, 25.430, 25.433 | Juha |  |  |  |  |
| 1505 | 498.5 | FDD Enhanced Uplink - RF Radio Transmission/ Reception, System Performance Requirements and Conformance Testing |  | 74d | 2004-03-15 A | 2004-06-24 A | 100% | 2004-03-15 | 2004-06-24 | 74d |  |  | R4 | 592h | 592h | EDCH-RF | Ericsson | thomas.unshelm@ERICSSON.COM | Rel-6 | 25.101, 25.104, 25.133, 25.141 | Issam |  |  |  |  |
| 1506 | 498.6 | Conformance Test Aspects – FDD Enhanced Uplink |  | 596d | 2005-06-03 A | 2007-09-14 A | 100% | 2005-06-03 | 2007-09-14 | 596d | finish no earlier than 2007-09-14 | 2006-06-02 | R5 | 4768h | 4768h | EDCH_Test | Ericsson | Leif.Mattisson@ericsson.com | Rel-6 | 34.108, 34.109, 34.121, 34.123-1, 34.123-2, 34.123-3 | Ingbert | TSG | BB | Fri 03/06/05 |  |
| 1507 | 498.7 | FDD Enhanced Uplink - RF Radio Transmission/ Reception, System Performance Requirements and Conformance Testing |  | 393d | 2004-03-15 A | 2005-09-14 A | 100% | 2004-03-15 | 2005-09-14 | 393d | finish no earlier than 2005-09-15 |  | R4 | 3144h | 3144h | EDCH-RF | Ericsson | thomas.unshelm@ERICSSON.COM | Rel-6 | 25.101, 25.104, 25.133, 25.141 | Issam |  |  |  |  |
| 1508 | 499 | **Rel-6 RAN improvements** |  | 656d? | 2002-09-09 A | 2005-03-14 A | 100% | 2002-09-09 | 2005-03-14 | 656d? |  |  | RP | 28312h | 28312h | RANimp |  |  | Rel-6 |  |  |  |  |  |  |
| 1509 | 9.2 | **RAB support enhancement** |  | 522d? | 2003-03-14 A | 2005-03-14 A | 100% | 2003-03-14 | 2005-03-14 | 522d? |  |  | R2 | 9360h | 9360h | RANimp-RABSE | Nokia | Jussi Kähtävä (juha.mikola@nokia.com) | Rel-6 | 25.862 | Joern |  |  |  |  |
| 1510 | 499.1.1 | Optimization of downlink channelisation code utilisation |  | 262d | 2004-03-12 A | 2005-03-14 A | 100% | 2004-03-12 | 2005-03-14 | 262d | finish no earlier than 2005-03-14 |  | R1 | 2096h | 2096h | RANimp-RABSE-CodeOptFDD | Nortel | Sarah Boumendil | Rel-6 |  | Patrick |  |  |  |  |
| 1511 | 499.1.2 | optimization of channelisation code utilisation for 3.84 Mcps TDD |  | 261d | 2004-03-15 A | 2005-03-14 A | 100% | 2004-03-15 | 2005-03-14 | 261d | finish no earlier than 2005-03-15 |  | R1 | 2088h | 2088h | RANimp-RABSE-CodOptTDD | IPWireless | Nicholas Anderson | Rel-6 |  | Patrick |  |  |  |  |
| 1512 | 499.1.3 | HS-DPCCH ACK/NACK Enhancement |  | 65d? | 2004-09-15 A | 2004-12-14 A | 100% | 2004-09-15 | 2004-12-14 | 65d? | finish no earlier than 2004-12-15 |  | R1 | 520h | 520h | RANimp-RABSE-ACKNACK | Nokia | Jussi Kähtävä (juha.mikola@nokia.com) | Rel-6 | 25.212, 25.214, 24.331, 25.433 | Patrick |  |  |  |  |
| 1513 | 499.1.4 | Deleted - Iu enhancements for IMS support in RAN |  | 320d? | 2003-03-14 A | 2004-06-03 A | 100% | 2003-03-14 | 2004-06-03 | 320d? | start no earlier than 2003-03-14 |  | R3 | 2560h | 2560h | RANimp-RABSE-IuEnhIMS | Nortel | Philippe.Godin@nortelnetworks.com | Rel-6 |  | Juha |  |  |  | RP-24 |
| 1514 | 499.1.5 | Deleted - Improvement of RRM across RNS and RNS/BSS | milestone | 0d? | 2003-12-05 A | 2003-12-05 A | 100% | 2003-12-05 | 2003-12-05 | 0d? | finish no earlier than 2003-12-05 |  | R3 |  |  | RANimp-RRM1 | Nokia | antti.toskala@nokia.com | Rel-6 |  | Juha |  |  |  | RP-23 |
| 1515 | 9.1 | Beamforming Enhancements |  | 66d | 2003-09-19 A | 2003-12-19 A | 100% | 2003-09-19 | 2003-12-19 | 66d | finish no earlier than 2004-03-12 |  | R1 | 528h | 528h | RANimp-BFE | Nokia | Jussi Kähtävä (juha.mikola@nokia.com) | Rel-6 | 24.215, 25.423, 25.425, 25.433, 25.435 | Patrick |  |  |  |  |
| 1516 | 499.3 | **Rel6 RRM optimization for Iur and Iub** |  | 126d | 2003-09-19 A | 2004-03-12 A | 100% | 2003-09-19 | 2004-03-12 | 126d |  |  | R3 | 2016h | 2016h | RANimp-RRMopt | Ericsson | Gert-Jan.van.Lieshout@eln.ericsson.se | Rel-6 |  | Juha |  |  |  |  |
| 1517 | 499.3.1 | Improved access to UE measurement data for CRNC to support TDD RRM |  | 126d | 2003-09-19 A | 2004-03-12 A | 100% | 2003-09-19 | 2004-03-12 | 126d | finish no earlier than 2004-03-15 |  | R3 | 1008h | 1008h | RANimp-RRMopt-UEMsD | Interdigital | jim.miller@interdigital.com | Rel-6 | 25.423 | Juha |  |  |  | RP-22 |
| 1518 | 499.4 | **Remote Control of Electrical Tilting Antennas** |  | 395d? | 2003-03-14 A | 2004-09-16 A | 100% | 2003-03-14 | 2004-09-16 | 395d? |  |  | R3 | 7464h | 7464h | RANimp-TiltAnt | Vodafone | Andreas.Hauser@vodafone.com | Rel-6 |  | Juha |  |  |  |  |
| 1519 | 499.4.1 | Tilting Antenna - RAN aspects |  | 393d? | 2003-03-14 A | 2004-09-14 A | 100% | 2003-03-14 | 2004-09-14 | 393d? | finish no earlier than 2004-09-14 |  | R3 | 3144h | 3144h | RANimp-TiltAnt | Vodafone | Andreas.Hauser@vodafone.com | Rel-6 | 25.460, 25.461, 25.462, 25.463 | Juha |  |  |  |  |
| 1520 | 499.4.2 | OAM&P impacts |  | 145d | 2004-02-27 A | 2004-09-16 A | 100% | 2004-02-27 | 2004-09-16 | 145d | finish no earlier than 2004-09-16 |  | S5 | 1160h | 1160h | RANimp-TiltAnt-OAM | Vodafone | Adrian.Neal@vodafone.com | Rel-6 | 32.804, 32.64x | Dionisio |  |  | SP-24 |  |
| 1521 | 499.5 | Network Assisted Cell Change (NACC) from UTRAN to GERAN - network-side aspects |  | 462d? | 2002-09-09 A | 2004-06-15 A | 100% | 2002-09-09 | 2004-06-15 | 462d? | finish no earlier than 2004-06-15 |  | R3 | 3696h | 3696h | RANimp-NACC | Vodafone | Brendan.McWilliams@gb.vodafone.co.uk | Rel-6 |  | Juha |  |  |  |  |
| 1522 | 12 | **Location Services enhancements 2** |  | 1024d? | 2001-01-15 A | 2004-12-16 A | 100% | 2001-01-15 | 2004-12-16 | 1024d? |  |  | S2,S5,N4,RP | 78152h | 78152h | LCS2 |  |  | Rel-6 | 23.271 | Maurice |  |  |  |  |
| 1523 | 12.1 | **Improvement on Le interface** |  | 653d? | 2002-06-17 A | 2004-12-15 A | 100% | 2002-06-17 | 2004-12-15 | 653d? |  |  | S2 | 9872h | 9872h | LCS2 |  |  | Rel-6 |  | Maurice |  |  |  |  |
| 1524 | 500.1.1 | Stage 2 |  | 331d? | 2002-06-17 A | 2003-09-22 A | 100% | 2002-06-17 | 2003-09-22 | 331d? | start no earlier than 2002-06-17 |  | S2 | 2648h | 2648h | LCS2 |  |  | Rel-6 |  | Maurice |  |  |  |  |
| 1525 | 500.1.2 | Stage 3 - impacts MLP (Mobile Location Protocol) |  | 250d? | 2004-01-01 A | 2004-12-15 A | 100% | 2004-01-01 | 2004-12-15 | 250d? | finish no earlier than 2004-12-15 |  | OMA | 2000h | 2000h | LCS2 |  | OMA-LIAISON@mail.openmobilealliance.org | Rel-6 |  |  |  |  |  |  |

Notes:
- 1500: -
- 1501: -
- 1502: -
- 1503: -
- 1504: -
- 1505: -
- 1506: -
- 1507: -
- 1508: Generic feature
- 1509: building block without particular end date
- 1510: -
- 1511: WIDS modified in RP#26, RP-040551
- 1512: Approved at RP#25 as RP-040390
- 1513: Closed RP#24 due to the lack of progress
- 1514: abandoned RP-23
- 1515: -
- 1516: -
- 1517: -
- 1518: -
- 1519: Finished at RP#25
- 1520: SP#25 09/2004 completed
- 1521: -
- 1522: -
- 1523: -
- 1524: -
- 1525: Updated according to SP-040232

| ID | WBS | Task | Type | Duration | Start | Finish | Complete | Baseline start | Baseline finish | Baseline duration | Constraint | Resources | Work | Actual work | Text1 | Text6 | Text8 | Text5 | Text4 | Text12 |
| --- | --- | --- | --- | --- | --- | --- | --- | --- | --- | --- | --- | --- | --- | --- | --- | --- | --- | --- | --- | --- |
| 1526 | 12.2 | **Enhanced support for anonymity and user privacy** |  | 638d? | 2002-07-08 A | 2004-12-15 A | 100% | 2002-07-08 | 2004-12-15 | 638d? |  | S2 | 9144h | 9144h | LCS2 | Rel-6 | Maurice |  |  |  |
| 1527 | 500.2.1 | Stage 2 |  | 255d? | 2002-07-08 A | 2003-06-27 A | 100% | 2002-07-08 | 2003-06-27 | 255d? | finish no earlier than 2003-06-27 | S2 | 2040h | 2040h | LCS2 | Rel-6 | Maurice |  |  |  |
| 1528 | 500.2.2 | Stage 3 - impacts MLP and RLP |  | 250d? | 2004-01-01 A | 2004-12-15 A | 100% | 2004-01-01 | 2004-12-15 | 250d? | finish no earlier than 2004-12-15 | OMA | 2000h | 2000h | LCS2 | Rel-6 |  | OMA-LIAISON@mail.openmobilealliance.org |  |  |
| 1529 | 12.3 | **Enhanced inter-GMLC interface** |  | 648d? | 2002-06-24 A | 2004-12-15 A | 100% | 2002-06-24 | 2004-12-15 | 648d? |  | S2 | 9704h | 9704h | LCS2 | Rel-6 | Maurice |  |  |  |
| 1530 | 500.3.1 | Stage 2 |  | 315d? | 2002-06-24 A | 2003-09-05 A | 100% | 2002-06-24 | 2003-09-05 | 315d? | finish no earlier than 2003-09-05 | S2 | 2520h | 2520h | LCS2 | Rel-6 | Maurice |  |  |  |
| 1531 | 500.3.2 | Stage 3 - definition of RLP and PCP |  | 250d? | 2004-01-01 A | 2004-12-15 A | 100% | 2004-01-01 | 2004-12-15 | 250d? | finish no earlier than 2004-12-15 | OMA | 2000h | 2000h | LCS2 | Rel-6 |  | OMA-LIAISON@mail.openmobilealliance.org |  |  |
| 1532 | 12.4 | **Location Services support for IMS public identities** |  | 473d? | 2003-02-24 A | 2004-12-15 A | 100% | 2003-02-24 | 2004-12-15 | 473d? |  | S2 | 7704h | 7704h | LCS2 | Rel-6 | Maurice |  |  |  |
| 1533 | 500.4.1 | Stage 2 |  | 240d? | 2003-02-24 A | 2004-01-23 A | 100% | 2003-02-24 | 2004-01-23 | 240d? | finish no earlier than 2004-01-23 | S2 | 1920h | 1920h | LCS2 | Rel-6 | Maurice |  |  |  |
| 1534 | 500.4.2 | Stage 3 - impacts MLP, RLP and PCP |  | 250d? | 2004-01-01 A | 2004-12-15 A | 100% | 2004-01-01 | 2004-12-15 | 250d? | finish no earlier than 2004-12-15 | OMA | 2000h | 2000h | LCS2 | Rel-6 |  | OMA-LIAISON@mail.openmobilealliance.org |  |  |
| 1535 | 12.5 | **New area event for location service triggering reports** |  | 663d? | 2002-06-03 A | 2004-12-15 A | 100% | 2002-06-03 | 2004-12-15 | 663d? |  | S2 | 11416h | 11416h | LCS2 | Rel-6 | Maurice |  |  |  |
| 1536 | 500.5.1 | Stage 2 |  | 280d? | 2002-06-03 A | 2003-06-27 A | 100% | 2002-06-03 | 2003-06-27 | 280d? | finish no earlier than 2003-06-27 | S2 | 2240h | 2240h | LCS2 | Rel-6 | Maurice |  |  |  |
| 1537 | 500.5.2 | Stage 3 for UE-CN signalling |  | 234d? | 2003-10-09 A | 2004-08-31 A | 100% | 2003-10-09 | 2004-08-31 | 234d? | start no earlier than 2003-10-09 | N4 | 1872h | 1872h | LCS2 | Rel-6 | Kimmo |  |  |  |
| 1538 | 500.5.3 | Stage 3 - impacts MLP, RLP and PCP |  | 250d? | 2004-01-01 A | 2004-12-15 A | 100% | 2004-01-01 | 2004-12-15 | 250d? | finish no earlier than 2004-12-15 | OMA | 2000h | 2000h | LCS2 | Rel-6 |  | OMA-LIAISON@mail.openmobilealliance.org |  |  |
| 1539 | 12.7 | **UE positioning** |  | 957d? | 2001-01-15 A | 2004-09-14 A | 100% | 2001-01-15 | 2004-09-14 | 957d? |  | RP | 18480h | 18480h | LCS2-UEpos | Rel-6 | Issam |  |  |  |
| 1540 | 12.8 | Open SMLC-SRNC Interface within the UTRAN to support UTRAN Rel4 positioning methods |  | 700d? | 2001-01-15 A | 2003-09-19 A | 100% | 2001-01-15 | 2003-09-19 | 700d? | finish no earlier than 2003-09-19 | R2 | 5600h | 5600h | LCS-Rel4Pos | Rel-6 | Joern | Meik.Kottkamp@siemens.com | Siemens |  |
| 1541 | 500.6.2 | A-GPS minimum performance specification |  | 333d? | 2003-06-06 A | 2004-09-14 A | 100% | 2003-06-06 | 2004-09-14 | 333d? | finish no earlier than 2004-09-14 | R4 | 2664h | 2664h | LCS-UEPos-AGPSPerf | Rel-6 | Issam | donglin.shen@attws.com | AT&T Wireless |  |
| 1542 | 12.7.2 | FS on Enhancements to OTDOA Positioning using advanced blanking methods |  | 320d | 2002-07-01 A | 2003-09-19 A | 100% | 2002-07-01 | 2003-09-19 | 320d | finish no earlier than 2003-09-19 | R2 | 2560h | 2560h | LCS2-UEpos-FSBlank | Rel-6 | Joern | david.bartlett@cursor-system.com | Cambridge Positioning Systems |  |
| 1543 | 500.6.4 | Deleted - UE positioning enhancements - other methods | milestone | 0d? | 2003-09-26 A | 2003-09-26 A | 100% | 2003-09-26 | 2003-09-26 | 0d? | finish no earlier than 2003-09-26 | R2 |  |  | LCS2-UEpos-enh | Rel-6 | Joern | Meik.Kottkamp@siemens.com | Siemens | RP-24 |
| 1544 | 500.7 | LCS charging |  | 455d? | 2003-03-21 A | 2004-12-16 A | 100% | 2003-03-21 | 2004-12-16 | 455d? | start no earlier than 2003-03-21 | S5 | 3640h | 3640h | LCS2-CH | Rel-6 | Dionisio | alain.bibas@orange-ft.com | France Telecom |  |
| 1545 | 14 | **Rel-6 Security enhancements** |  | 1018d? | 2001-01-03 A | 2004-11-26 A | 100% | 2001-01-03 | 2004-11-26 | 1018d? |  | S3 | 28824h | 28824h | SEC1 | Rel-6 | Dionisio | Peter.Howard@vodafone.com | Vodafone |  |
| 1546 | 14.1 | **Enhanced HE control of security (including positive authentication reporting)** |  | 712d | 2001-01-03 A | 2003-09-25 A | 100% | 2001-01-03 | 2003-09-25 | 712d |  | S3 | 14064h | 14064h | SEC1 | Rel-6 | Dionisio | Peter.Howard@vodafone.com | Vodafone |  |
| 1547 | 14.1.1 | Deleted - SEC1 Stage 2 (Enhanced HE control of security) |  | 378d | 2001-01-03 A | 2002-06-14 A | 100% | 2001-01-03 | 2002-06-14 | 378d | finish no earlier than 2002-06-14 | S3 | 3024h | 3024h | SEC1 | Rel-6 | Dionisio |  |  | SP-16 |
| 1548 | 14.1.3 | **Network domain security** |  | 334d | 2002-06-17 A | 2003-09-25 A | 100% | 2002-06-17 | 2003-09-25 | 334d |  | S3 | 5344h | 5344h | SEC1-NDS | Rel-6 | Dionisio | Geir-myrdahl.koien@telenor.com | Telenor |  |
| 1549 | 14.1.3.1 | IP network layer security (NDS/IP) |  | 334d | 2002-06-17 A | 2003-09-25 A | 100% | 2002-06-17 | 2003-09-25 | 334d | finish no earlier than 2003-09-25 | S3 | 2672h | 2672h | SEC1-NDS-IP | Rel-6 | Dionisio |  |  |  |
| 1550 | 501.2 | Network Domain Security; Authentication Framework (NDS/AF) |  | 521d? | 2002-02-15 A | 2004-02-13 A | 100% | 2002-02-15 | 2004-02-13 | 521d? | finish no earlier than 2004-02-13 | S3 | 4168h | 4168h | SEC1-NDS-AF | Rel-6 | Dionisio | tommi.viitanen@nokia.com | Nokia |  |
| 1551 | 501.3 | Key Management of group keys for Voice Group Call Services |  | 306d | 2003-09-26 A | 2004-11-26 A | 100% | 2003-09-26 | 2004-11-26 | 306d | finish no earlier than 2004-11-26 | S3 | 2448h | 2448h | SECGKYV | Rel-6 | Dionisio | benno.tietz@vodafone.com | Vodafone |  |

Notes:
- 1526: -
- 1527: -
- 1528: Updated according to SP-040232
- 1529: -
- 1530: -
- 1531: Updated according to SP-040232
- 1532: -
- 1533: -
- 1534: Updated according to SP-040232
- 1535: -
- 1536: -
- 1537: 31/10/2003 work has started. Current stage 3 fullfills the requirements of stage 2. ......
- 1538: Updated according to SP-040232
- 1539: -
- 1540: - / Text3: 25.305, 25.401, 25.450, 25.452, 25.453
- 1541: Finished at RP#25 / Text3: 25.171
- 1542: -
- 1543: building block without particular end date
- 1544: SP#26 12/2004 completed / Text3: 32.271
- 1545: Added BB UE authentication and rapporteur added.
- 1546: Added by SP-000575 without any dates. 18/10/00: Change of WI title, added hyperlink rapporteur new end date 03/01. New end date and correct Release to be decided S3#18
- 1547: New end date and correct Release to be decided S3#18. Marked as stopped 12/2008
- 1548: WID approved for Rel-6 at SP#17. Completed 2004-12
- 1549: Should be complete after SA3#27. Completed 2004-12 / Text3: 33.210
- 1550: WID approved SP#19. Work started after FS approved SP#18
- 1551: Approved TSG#21. Completed 2004-12 / Text3: 42.068, 43.068, 44.068, 42.069, 43.069, 44.069, 31.102, 24.008, 48.008, 42.009, 43.020

| ID | WBS | Task | Type | Duration | Start | Finish | Complete | Baseline start | Baseline finish | Baseline duration | Constraint | Resources | Work | Actual work | Text1 | Text3 | Text6 | Text8 | Text4 | Text5 | Text12 |
| --- | --- | --- | --- | --- | --- | --- | --- | --- | --- | --- | --- | --- | --- | --- | --- | --- | --- | --- | --- | --- | --- |
| 1552 | 16 | **IMS Phase 2** |  | 1840d? | 2000-08-28 A | 2007-09-14 A | 100% | 2000-08-28 | 2007-09-14 | 1840d? |  | S1,S2,S3,S5,NP,R5 | 136976h | 136976h | IMS2 | 23.228 | Rel-6 | Alain |  |  |  |
| 1553 | 502.1 | Enhancements to the Cx and Sh interfaces |  | 323d? | 2003-06-06 A | 2004-08-31 A | 100% | 2003-06-06 | 2004-08-31 | 323d? | finish no earlier than 2004-08-31 | N4 | 2584h | 2584h | IMS2-CCR |  | Rel-6 | Kimmo |  |  |  |
| 1554 | 502.2 | Conformance Test Aspects – IMS Call Control Rel-6 enhancements |  | 396d? | 2006-03-10 A | 2007-09-14 A | 100% | 2006-03-10 | 2007-09-14 | 396d? | finish no earlier than 2007-09-14 | R5 | 3168h | 3168h | IMS2_CCR_Test | 34.229-1, 34.229-2, 34.229-3, 34.108 | Rel-6 | Ingbert | Ericsson | Jacob.John@motorola.com, Leif.Mattisson@ericsson.com |  |
| 1555 | 16.12 | **IMS Group Management** |  | 715d? | 2002-03-14 A | 2004-12-08 A | 100% | 2002-03-14 | 2004-12-08 | 715d? |  | S1 | 12680h | 12680h | IMSGM |  | Rel-6 | Alain | Nokia | juha.kalliokulju@nokia.com |  |
| 1556 | 16.12.1 | Stage 1 - TS on IMS group management |  | 193d | 2002-03-14 A | 2002-12-09 A | 100% | 2002-03-14 | 2002-12-09 | 193d | finish no earlier than 2002-12-09 | S1 | 1544h | 1544h | IMSGM |  | Rel-6 | Alain | Nokia | juha.kalliokulju@nokia.com |  |
| 1557 | 502.3.2 | Stage 2 |  | 158d? | 2003-05-26 A | 2003-12-31 A | 100% | 2003-05-26 | 2003-12-31 | 158d? | finish no earlier than 2003-12-31 | S2 | 1264h | 1264h | IMSGM |  | Rel-6 | Maurice |  |  |  |
| 1558 | 502.3.3 | Stage 3 for IMS Group management (e.g. chat) |  | 519d? | 2002-12-13 A | 2004-12-08 A | 100% | 2002-12-13 | 2004-12-08 | 519d? | finish no earlier than 2004-12-08 | N1 | 4152h | 4152h | IMSGM |  | Rel-6 | Frederic | Lucent | Keith Drage (drage@alcatel-lucent.com) |  |
| 1559 | 502.4 | **IMS Conferencing** |  | 548d? | 2002-11-04 A | 2004-12-08 A | 100% | 2002-11-04 | 2004-12-08 | 548d? |  | N1 | 10960h | 10960h |  |  | Rel-6 | Frederic |  |  |  |
| 1560 | 502.4.1 | Stage 2 |  | 303d? | 2002-11-04 A | 2003-12-31 A | 100% | 2002-11-04 | 2003-12-31 | 303d? | finish no earlier than 2003-12-31 | S2 | 2424h | 2424h |  |  | Rel-6 | Maurice |  |  |  |
| 1561 | 502.4.2 | Stage 3 |  | 519d? | 2002-12-13 A | 2004-12-08 A | 100% | 2002-12-13 | 2004-12-08 | 519d? | finish no earlier than 2004-12-08 | N1 | 4152h | 4152h |  |  | Rel-6 | Frederic | Lucent | Keith Drage (drage@alcatel-lucent.com) |  |
| 1562 | 16.11 | **IMS Messaging** |  | 992d? | 2002-03-14 A | 2005-12-30 A | 100% | 2002-03-14 | 2005-12-30 | 992d? |  | S1 | 23912h | 23912h | IMSM |  | Rel-6 | Alain | Nokia | juha.kalliokulju@nokia.com |  |
| 1563 | 16.11.1 | TR on support of messaging in the IMS |  | 193d | 2002-03-14 A | 2002-12-09 A | 100% | 2002-03-14 | 2002-12-09 | 193d | finish no earlier than 2002-12-09 | S1 | 1544h | 1544h | IMSM-TR | new 22.940 | Rel-6 | Alain | Nokia | juha.kalliokulju@nokia.com |  |
| 1564 | 502.5.2 | Stage 1 22.340 |  | 23d? | 2002-11-11 A | 2002-12-11 A | 100% | 2002-11-11 | 2002-12-11 | 23d? | finish no earlier than 2002-12-11 | S1 | 184h | 184h | IMSM-TS | 22.340 | Rel-6 | Alain | Nokia | juha.kalliokulju@nokia.com |  |
| 1565 | 502.5.3 | CRs to 22.140 & 22.228 |  | 263d? | 2002-03-14 A | 2003-03-17 A | 100% | 2002-03-14 | 2003-03-17 | 263d? | finish no earlier than 2003-03-17 | S1 | 2104h | 2104h | IMSM-CR | 22.140,22.228 | Rel-6 | Alain | Nokia | juha.kalliokulju@nokia.com |  |
| 1566 | 16.11.3 | Stage 2 |  | 477d | 2002-11-04 A | 2004-08-31 A | 100% | 2002-11-04 | 2004-08-31 | 477d | finish no earlier than 2004-08-31 | S2 | 3816h | 3816h | IMSM |  | Rel-6 | Maurice |  |  |  |
| 1567 | 502.5.5 | Stage 3 for IMS Messaging |  | 519d? | 2002-12-13 A | 2004-12-08 A | 100% | 2002-12-13 | 2004-12-08 | 519d? | finish no earlier than 2004-12-08 | N1 | 4152h | 4152h | IMSM |  | Rel-6 | Frederic | Lucent | Keith Drage (drage@alcatel-lucent.com) |  |
| 1568 | 502.5.6 | SIP/SIMPLE Instant messaging |  | 522d? | 2004-01-01 A | 2005-12-30 A | 100% | 2004-01-01 | 2005-12-30 | 522d? | finish no earlier than 2005-06-30 | OMA | 4176h | 4176h |  |  | Rel-6 |  |  | OMA-LIAISON@mail.openmobilealliance.org |  |
| 1569 | 502.6 | **Additional SIP Capabilities support not covered by Rel-5** |  | 680d? | 2002-11-11 A | 2005-06-17 A | 100% | 2002-11-11 | 2005-06-17 | 680d? |  | N1 | 13392h | 13392h |  |  | Rel-6 | Frederic |  |  |  |
| 1570 | 502.6.1 | Stage 2 for add SIP cap (e.g. forking) |  | 335d? | 2002-11-11 A | 2004-02-20 A | 100% | 2002-11-11 | 2004-02-20 | 335d? | finish no earlier than 2004-02-20 | S2 | 2680h | 2680h |  |  | Rel-6 | Maurice |  |  |  |
| 1571 | 502.6.2 | Stage 3 for Additional SIP Capabilities |  | 454d? | 2002-12-13 A | 2004-09-08 A | 100% | 2002-12-13 | 2004-09-08 | 454d? | finish no earlier than 2004-09-08 | N1 | 3632h | 3632h |  |  | Rel-6 | Frederic | Lucent | Keith Drage (drage@alcatel-lucent.com) |  |
| 1572 | 502.6.3 | Procedured associated with IMS-ALG |  | 205d? | 2004-09-06 A | 2005-06-17 A | 100% | 2004-09-06 | 2005-06-17 | 205d? | start no earlier than 2004-09-06 | N1 | 1640h | 1640h |  |  | Rel-6 | Frederic |  |  |  |
| 1573 | 502.7 | Review additional SIP Capabilities against IMS |  | 454d? | 2002-12-13 A | 2004-09-08 A | 100% | 2002-12-13 | 2004-09-08 | 454d? | finish no earlier than 2004-09-08 | N1 | 3632h | 3632h |  |  | Rel-6 | Frederic | Lucent | Keith Drage (drage@alcatel-lucent.com) |  |
| 1574 | 16.5 | **Interworking between IMS and IP networks** |  | 1118d? | 2000-08-28 A | 2004-12-08 A | 100% | 2000-08-28 | 2004-12-08 | 1118d? |  | N3 | 31712h | 31712h | IMS-CCR-IWIP | 23.821, 29.061, 29.162 | Rel-6 | Gwiho | BT | nigel.holland@bt.com |  |
| 1575 | 16.5.1 | Interworking for 3GPP_SIP and IETF_SIP |  | 730d | 2000-08-28 A | 2003-06-13 A | 100% | 2000-08-28 | 2003-06-13 | 730d | finish no earlier than 2003-06-13 | N3 | 5840h | 5840h |  | New 29.962 | Rel-6 | Gwiho | Siemens | Thomas.Belling@nsn.com |  |
| 1576 | 16.5.2 | Interworking for IPv6 to IPv4 |  | 1118d | 2000-08-28 A | 2004-12-08 A | 100% | 2000-08-28 | 2004-12-08 | 1118d | finish no earlier than 2004-12-08 | N3 | 8944h | 8944h |  | 29.163 | Rel-6 | Gwiho |  |  |  |
| 1577 | 502.8.3 | Interworking for IPv6 to IPv4 (SIP / SDP aspects) |  | 87d? | 2004-05-11 A | 2004-09-08 A | 100% | 2004-05-11 | 2004-09-08 | 87d? | finish no earlier than 2004-09-08 | N1 | 696h | 696h |  |  | Rel-6 | Frederic |  |  |  |
| 1578 | 16.8.1 | stage 3 of interworking with non-IMS IP networks |  | 911d | 2001-03-14 A | 2004-09-08 A | 100% | 2001-03-14 | 2004-09-08 | 911d | finish no earlier than 2004-09-08 | N1 | 7288h | 7288h |  |  | Rel-6 | Frederic |  |  |  |
| 1579 | 16.6.1 | Interworking between IMS and CS networks |  | 929d? | 2000-08-28 A | 2004-03-18 A | 100% | 2000-08-28 | 2004-03-18 | 929d? | finish no earlier than 2004-03-18 | N3 | 7432h | 7432h | IMS-CCR-IWCS | 29.163, 29.061, 24.228, and new CN4 specification | Rel-6 | Gwiho | Vodafone | Brendan.McWilliams@gb.vodafone.co.uk |  |
| 1580 | 16.10 | Mn interface (IM-MGW to MGCF) enhancements (CN4 Part) |  | 418d | 2001-08-07 A | 2004-09-01 A | 100% | 2001-08-07 | 2004-09-01 | 418d | finish no earlier than 2004-09-01 | N4 | 3344h | 3344h | IMS-CCR-Mn |  | Rel-6 | Kimmo |  |  |  |
| 1581 | 502.11 | Study of subscriber and operators relationship in IMS and related ISIM requirements for Rel 6” |  | 20d? | 2002-11-15 A | 2002-12-12 A | 100% | 2002-11-15 | 2002-12-12 | 20d? | finish no earlier than 2002-12-12 | S1 | 160h | 160h |  |  | Rel-6 | Alain | Nokia | juha.kalliokulju@nokia.com |  |
| 1582 | 502.12 | Lawful Interception in the 3GPP Rel-6 architecture |  | 269d? | 2002-12-09 A | 2003-12-18 A | 100% | 2002-12-09 | 2003-12-18 | 269d? | finish no earlier than 2003-12-18 | S3 | 2152h | 2152h | SEC1-LI | 33.106, 33.107, 33.108 | Rel-6 | Dionisio | Reg TP | berthold.wilhelm@regtp.de |  |
| 1583 | 502.13 | IMS Subscription and access scenarios |  | 130d? | 2002-12-16 A | 2003-06-13 A | 100% | 2002-12-16 | 2003-06-13 | 130d? | start no earlier than 2002-12-16 | S1 | 1040h | 1040h |  | 22.800 | Rel-6 | Alain | TeliaSonera | FRANK, Robert |  |
| 1584 | 502.14 | IMS charging |  | 455d? | 2003-03-21 A | 2004-12-16 A | 100% | 2003-03-21 | 2004-12-16 | 455d? | finish no earlier than 2004-12-16 | S5 | 3640h | 3640h | IMS2-CH | 32.260 | Rel-6 | Dionisio | Ericsson | Patrik TEPPO |  |
| 1585 | 502.15 | IMS Management objects |  | 306d? | 2004-09-03 A | 2005-11-04 A | 100% | 2004-09-03 | 2005-11-04 | 306d? | finish no earlier than 2005-03-04 | N1 | 2448h | 2448h |  | 24.167 | Rel-6 | Frederic |  |  |  |
| 1586 | 502.16 | Deleted - Stage 2 of IMS Phase 2 | milestone | 0d? | 2003-09-19 A | 2003-09-19 A | 100% | 2003-09-19 | 2003-09-19 | 0d? | finish no earlier than 2003-09-19 | S2 |  |  | IMS2 |  | Rel-6 | Maurice |  |  | SP-21 |

Notes:
- 1552: Not yet available: verbally approved at SA15, actual WID to be provided at SA16 by Lucent
- 1553: Shared public user identities need to be solved. If email approval CR is accepted. Work 100% done....
- 1554: -
- 1555: -
- 1556: -
- 1557: -
- 1558: Depends on CN decision on CPCP in Rel-6. Complete, if unresolved IETF dependencies are dropped (-> LS to CN plenary)
- 1559: -
- 1560: -
- 1561: Depends on CN decision on IETF dependencies in Rel-6. Higher figure if CPCP is dropped (-> LS to CN plenary)
- 1562: -
- 1563: -
- 1564: -
- 1565: -
- 1566: -
- 1567: -
- 1568: Updated according to SP-040232
- 1569: -
- 1570: -
- 1571: -
- 1572: -
- 1573: -
- 1574: [DAB 14.02.02] - end date pushed back to March 2003
- 1575: [DAB - 20.08.03] - CN Part of TR Complete @ CN#20
- 1576: -
- 1577: -
- 1578: -
- 1579: [DAB - 25.05.04] - CN3 consider this work to be complete
- 1580: TISPAN issue is open
- 1581: -
- 1582: -
- 1583: -
- 1584: SP#26 12/2004 completed
- 1585: -
- 1586: -

| ID | WBS | Task | Type | Duration | Start | Finish | Complete | Baseline start | Baseline finish | Baseline duration | Constraint | Resources | Work | Actual work | Text1 | Text4 | Text5 | Text6 | Text8 | Text3 | Text10 | Text12 |
| --- | --- | --- | --- | --- | --- | --- | --- | --- | --- | --- | --- | --- | --- | --- | --- | --- | --- | --- | --- | --- | --- | --- |
| 1587 | 503 | **3GPP Enablers for services like Push to Talk over Cellular (PoC)** |  | 459d? | 2003-09-08 A | 2005-06-09 A | 100% | 2003-09-08 | 2005-06-09 | 459d? |  | S2,S4,S5 | 10696h | 10696h | PoC | Ericsson | Shabnam Sultana | Rel-6 | Maurice |  |  |  |
| 1588 | 503.1 | Feasibility Study |  | 322d? | 2003-09-08 A | 2004-11-30 A | 100% | 2003-09-08 | 2004-11-30 | 322d? | finish no earlier than 2004-11-30 | S2 | 2576h | 2576h | PoC | Ericsson | Shabnam Sultana | Rel-6 | Maurice | 23.979 | SP-24 |  |
| 1589 | 503.2 | Dependencies on OMA PoC |  | 303d? | 2004-01-01 A | 2005-02-28 A | 100% | 2004-01-01 | 2005-02-28 | 303d? | finish no earlier than 2004-12-30 | OMA | 2424h | 2424h | PoC |  | OMA-LIAISON@mail.openmobilealliance.org | Rel-6 |  |  | SP-24 |  |
| 1590 | 503.3 | Selection of one or more PoC codec(s) for PoC |  | 69d? | 2004-09-13 A | 2004-12-16 A | 100% | 2004-09-13 | 2004-12-16 | 69d? | start no earlier than 2004-09-13 | S4 | 552h | 552h | PoC |  |  | Rel-6 | Paolo | 26.235, 26.236 | SP-25 |  |
| 1591 | 503.4 | PoC charging |  | 184d? | 2004-09-27 A | 2005-06-09 A | 100% | 2004-09-27 | 2005-06-09 | 184d? | finish no earlier than 2005-06-09 | S5 | 1472h | 1472h | PoC-CH | Siemens | Gerald.Goermer@nsn.com | Rel-6 | Dionisio | 32.272 |  |  |
| 1592 | 504 | Study on Interworking aspects and migration scenarios for IPv4 based IMS Implementations |  | 210d? | 2003-09-08 A | 2004-06-25 A | 100% | 2003-09-08 | 2004-06-25 | 210d? | finish no earlier than 2004-06-25 | S2 | 1680h | 1680h | IPv4IMS | Siemens | Alexander Milinski | Rel-6 | Maurice | 23.981 |  |  |
| 1593 | 16.3 | **Interoperability and Commonality between IMS using different IP-connectivity Networks** |  | 325d? | 2002-09-16 A | 2003-12-12 A | 100% | 2002-09-16 | 2003-12-12 | 325d? |  | S2 | 9176h | 9176h | IMSCOOP |  |  | Rel-6 | Maurice | 23.864 |  |  |
| 1594 | 16.3.1 | Stage 2 for Interoperability |  | 272d | 2002-09-16 A | 2003-09-30 A | 100% | 2002-09-16 | 2003-09-30 | 272d | finish no earlier than 2003-09-30 | S2 | 2176h | 2176h | IMSCOOP | Nokia | balazs.bertenyi@nsn.com | Rel-6 | Maurice | 23.864 |  |  |
| 1595 | 505.2 | Stage 2 for commonality |  | 265d? | 2002-09-16 A | 2003-09-19 A | 100% | 2002-09-16 | 2003-09-19 | 265d? | start no earlier than 2002-09-16 | S2 | 2120h | 2120h | IMSCOOP | Nokia | balazs.bertenyi@nsn.com | Rel-6 | Maurice | 23.864 |  |  |
| 1596 | 16.3.2 | Stage 3 |  | 305d | 2002-10-14 A | 2003-12-12 A | 100% | 2002-10-14 | 2003-12-12 | 305d | finish no earlier than 2003-12-12 | N1 | 2440h | 2440h | IMSCOOP | Lucent | Keith Drage (drage@alcatel-lucent.com) | Rel-6 | Frederic |  |  |  |
| 1597 | 17 | **Support of Push Services** |  | 823d | 2001-01-03 A | 2004-02-27 A | 100% | 2001-01-03 | 2004-02-27 | 823d |  | S1 | 11390.6h | 11390.6h | PUSH | NTT Comware | Yoshinori Kitada | Rel-6 | Alain | 23.976 |  |  |
| 1598 | 17.1 | Stage 1 |  | 378d | 2001-01-03 A | 2002-06-14 A | 100% | 2001-01-03 | 2002-06-14 | 378d | finish no earlier than 2002-06-14 | S1 | 3024h | 3024h | PUSH |  |  | Rel-6 | Alain |  |  |  |
| 1599 | 17.3 | TR 23.976 on Push Architecture |  | 340d | 2002-11-11 A | 2004-02-27 A | 100% | 2002-11-11 | 2004-02-27 | 340d | finish no earlier than 2004-02-27 | S2 | 2720h | 2720h | PUSH | RIM | Nick Alfano | Rel-6 | Maurice | 23.976 |  |  |
| 1600 | 18 | **Multimedia Messaging (MMS) enhancements** |  | 865d? | 2002-08-15 A | 2005-12-07 A | 100% | 2002-08-15 | 2005-12-07 | 865d? |  | T2,S1,S4,S5,OMA | 31936h | 31936h | MMS6 | Siemens | Josef.Laumen@SAL.SIEMENS.DE | Rel-6 | Kimmo |  |  |  |
| 1601 | 18.1 | **Definition of service requirements** |  | 286d? | 2002-11-15 A | 2003-12-19 A | 100% | 2002-11-15 | 2003-12-19 | 286d? |  | S1 | 4576h | 4576h | MMS6-SR |  |  | Rel-6 | Alain | 22.140 |  |  |
| 1602 | 507.1.1 | Definition of service requirements charging |  | 286d? | 2002-11-15 A | 2003-12-19 A | 100% | 2002-11-15 | 2003-12-19 | 286d? | finish no earlier than 2003-12-20 | S1 | 2288h | 2288h | MMS6-SR | Siemens | Josef.Laumen@SAL.SIEMENS.DE | Rel-6 | Alain | 22.140 |  |  |
| 1603 | 18.2 | Technical realization |  | 591d | 2002-09-06 A | 2004-12-10 A | 100% | 2002-09-06 | 2004-12-10 | 591d | finish no earlier than 2004-12-10 | T2 | 4728h | 4728h | MMS6 | Siemens | Josef.Laumen@SAL.SIEMENS.DE | Rel-6 | Kimmo | 23.140 |  |  |
| 1604 | 18.3 | OMA dependencies |  | 446d | 2003-08-15 A | 2005-04-29 A | 100% | 2003-08-15 | 2005-04-29 | 446d | finish no earlier than 2004-12-10 | OMA | 3568h | 3568h | MMS6 |  |  | Rel-6 | Kimmo | OMA specs |  |  |
| 1605 | 18.4 | MMS formats and codecs |  | 865d | 2002-08-15 A | 2005-12-07 A | 100% | 2002-08-15 | 2005-12-07 | 865d | finish no earlier than 2005-12-07 | S4 | 6920h | 6920h | MMS6-Codec | Nokia | roberto.castagno@nokia.com | Rel-6 | Paolo | 26.140, 26.936 |  |  |
| 1606 | 507.5 | Handling of private addressing schemes in MMS |  | 263d | 2003-12-10 A | 2004-12-10 A | 100% | 2003-12-10 | 2004-12-10 | 263d | finish no earlier than 2004-12-10 | T2 | 2104h | 2104h | MMS6 | T-Mobile | Steffen.Habermann@T-MOBILE.DE | Rel-6 | Kimmo | 23.140 |  |  |
| 1607 | 507.6 | MMS charging |  | 390d? | 2003-03-21 A | 2004-09-16 A | 100% | 2003-03-21 | 2004-09-16 | 390d? | start no earlier than 2003-03-21 | S5 | 3120h | 3120h | MMS6-CH |  |  | Rel-6 | Dionisio | 32.270 |  |  |
| 1608 | 507.7 | Deleted - FS Multiple MMS Relay/Server Architecture | milestone | 0d | 2004-12-10 A | 2004-12-10 A | 100% | 2004-12-10 | 2004-12-10 | 0d | finish no earlier than 2004-12-10 | T2 |  |  | MMS6 | Telefónica Móviles | Juan Gorospe (gorospe_j@tsm.es) | Rel-6 | Kimmo | probably Annex to 23.140 |  | TP-26 |
| 1609 | 19 | **Rel-6 MExE enhancements** |  | 326d | 2002-03-08 A | 2003-06-06 A | 100% | 2002-03-08 | 2003-06-06 | 326d |  | T2 | 7328h | 7328h | MEXE6 |  |  | Rel-6 | Kimmo |  |  |  |
| 1610 | 19.1 | MExE Rel-6 Improvements and Investigations |  | 264d | 2002-03-08 A | 2003-03-12 A | 100% | 2002-03-08 | 2003-03-12 | 264d | finish no earlier than 2003-03-12 | T2 | 2112h | 2112h | MEXE6-ENHANC | TTPCom | Lars Brenk ( (lsb_ttpcom@HOTMAIL.COM) | Rel-6 | Kimmo |  |  |  |
| 1611 | 19.2 | MExE Run-Time Independent Framework Feasibility Study |  | 326d | 2002-03-08 A | 2003-06-06 A | 100% | 2002-03-08 | 2003-06-06 | 326d | finish no earlier than 2003-06-06 | T2 | 2608h | 2608h | MEXE6-RTIF | Nokia Siemens Networks | BERTENYI, Balazs | Rel-6 | Kimmo | 22.857 |  |  |
| 1612 | 21 | Subscription Management |  | 650d | 2002-09-20 A | 2005-03-17 A | 100% | 2002-09-20 | 2005-03-17 | 650d | finish no earlier than 2005-03-17 | S5 | 5200h | 5200h | SuM | T-Mobile | istvan.aba@t-mobile.at | Rel-6 | Dionisio | 32.140/1, 32.171/2/5, 32.803 |  |  |

Notes:
- 1587: -
- 1588: -
- 1589: Updated according to SP-040232
- 1590: Completed
- 1591: SP#28 06/2005 completed
- 1592: -
- 1593: -
- 1594: No contributions assumed that no more will be done in 3GPP hence work may need to be done in 3GPP2
- 1595: -
- 1596: -
- 1597: Changed from FS to actual support of Push
- 1598: -
- 1599: -
- 1600: -
- 1601: -
- 1602: -
- 1603: -
- 1604: -
- 1605: -
- 1606: -
- 1607: SP#25 09/2004 completed
- 1608: originally it was intended to create a FS TR but most likely the work will become an Annex of 23.140
- 1609: -
- 1610: -
- 1611: -
- 1612: SP#27 03/2005 completed

| ID | WBS | Task | Duration | Start | Finish | Complete | Baseline start | Baseline finish | Baseline duration | Constraint | Resources | Work | Actual work | Text1 | Text4 | Text5 | Text6 | Text8 | Text3 |
| --- | --- | --- | --- | --- | --- | --- | --- | --- | --- | --- | --- | --- | --- | --- | --- | --- | --- | --- | --- |
| 1613 | 22 | **Presence Capability** | 1233d? | 2001-03-19 A | 2005-12-07 A | 100% | 2001-03-19 | 2005-12-07 | 1233d? |  | S1 | 37112h | 37112h | PRESNC | Motorola | Mark Cataldo | Rel-6 | Alain |  |
| 1614 | 22.1 | Stage 1 | 610d | 2001-03-19 A | 2003-07-18 A | 100% | 2001-03-19 | 2003-07-18 | 610d | finish no earlier than 2003-07-18 | S1 | 4880h | 4880h | PRESNC |  |  | Rel-6 | Alain | 22.141 |
| 1615 | 22.2 | Stage 2 | 268d | 2001-09-12 A | 2002-09-20 A | 100% | 2001-09-12 | 2002-09-20 | 268d | finish no earlier than 2002-09-20 | S2 | 2144h | 2144h | PRESNC | Nokia | balazs.bertenyi@nsn.com | Rel-6 | Maurice |  |
| 1616 | 22.3 | Stage 3 | 703d | 2002-04-01 A | 2004-12-08 A | 100% | 2002-04-01 | 2004-12-08 | 703d | finish no earlier than 2004-12-08 | N1 | 5624h | 5624h | PRESNC | Lucent | Keith Drage (drage@alcatel-lucent.com) | Rel-6 | Frederic |  |
| 1617 | 510.4 | Stage 3 (CN3 Part Pk interface) | 770d? | 2002-04-01 A | 2005-03-11 A | 100% | 2002-04-01 | 2005-03-11 | 770d? | finish no earlier than 2005-03-11 | N3 | 6160h | 6160h | PRESNC |  |  | Rel-6 | Gwiho |  |
| 1618 | 510.5 | Media Codecs and Formats for IMS Messaging and Presence | 650d? | 2003-06-12 A | 2005-12-07 A | 100% | 2003-06-12 | 2005-12-07 | 650d? | finish no earlier than 2005-12-07 | S4 | 5200h | 5200h | PRESNC-COFIMP | Nokia | harri.honko@nokia.com | Rel-6 | Paolo | 26.141, 26.936 |
| 1619 | 22.4 | Security issues | 79d | 2002-08-26 A | 2002-12-12 A | 100% | 2002-08-26 | 2002-12-12 | 79d | finish no earlier than 2002-12-12 | S3 | 632h | 632h | PRESNC |  |  | Rel-6 | Dionisio |  |
| 1620 | 510.7 | SIMPLE Presence | 326d? | 2004-01-01 A | 2005-03-31 A | 100% | 2004-01-01 | 2005-03-31 | 326d? | finish no earlier than 2004-12-30 | OMA | 2608h | 2608h | PRESNC |  | OMA-LIAISON@mail.openmobilealliance.org | Rel-6 |  |  |
| 1621 | 25 | **Enhanced A/Gb feasibility study** | 51d? | 2002-08-30 A | 2002-11-08 A | 100% | 2002-08-30 | 2002-11-08 | 51d? |  | GP | 3264h | 3264h | AGbEnFS | Vodafone | jose-luis.carrizo@vodafone.co.uk | Rel-6 | Paolo | None |
| 1622 | 25.1 | **Feasibility study on A/Gb enhancements** | 51d? | 2002-08-30 A | 2002-11-08 A | 100% | 2002-08-30 | 2002-11-08 | 51d? |  | G2 | 2856h | 2856h | AGbEnFS-FS | Vodafone | jose-luis.carrizo@vodafone.co.uk | Rel-6 | Gert | None |
| 1623 | 25.1.1 | Requirements for the support of conversational services | 51d | 2002-08-30 A | 2002-11-08 A | 100% | 2002-08-30 | 2002-11-08 | 51d | finish no earlier than 2002-11-08 | GP | 408h | 408h | AGbEnFS-FS |  |  | Rel-6 | Paolo | None |
| 1624 | 511.1.2 | Identification of the different building blocks for the provision of conversational services on the existing A/Gb protocol stack | 51d? | 2002-08-30 A | 2002-11-08 A | 100% | 2002-08-30 | 2002-11-08 | 51d? | finish no earlier than 2002-11-08 | GP | 408h | 408h | AGbEnFS-FS |  |  | Rel-6 | Paolo | None |
| 1625 | 511.1.3 | Outline of impact and feasibility of these building blocks and their different solutions | 51d? | 2002-08-30 A | 2002-11-08 A | 100% | 2002-08-30 | 2002-11-08 | 51d? | finish no earlier than 2002-11-08 | GP | 408h | 408h | AGbEnFS-FS |  |  | Rel-6 | Paolo | None |
| 1626 | 25.1.4 | Impact on 3GPP architecture and requirement to co-ordinatge with other TSGs (CN, SA) | 51d | 2002-08-30 A | 2002-11-08 A | 100% | 2002-08-30 | 2002-11-08 | 51d | finish no earlier than 2002-11-08 | GP | 408h | 408h | AGbEnFS-FS |  |  | Rel-6 | Paolo | None |
| 1627 | 25.1.5 | Standardisation effort | 51d | 2002-08-30 A | 2002-11-08 A | 100% | 2002-08-30 | 2002-11-08 | 51d | finish no earlier than 2002-11-08 | GP | 408h | 408h | AGbEnFS-FS |  |  | Rel-6 | Paolo | None |
| 1628 | 25.1.6 | Dependency to other features | 51d | 2002-08-30 A | 2002-11-08 A | 100% | 2002-08-30 | 2002-11-08 | 51d | finish no earlier than 2002-11-08 | GP | 408h | 408h | AGbEnFS-FS |  |  | Rel-6 | Paolo | None |
| 1629 | 26 | **Flexible Layer One for GERAN** | 1171d | 2000-01-03 A | 2004-06-25 A | 100% | 2000-01-03 | 2004-06-25 | 1171d |  | GP | 71551h | 71551h | FLOGER | Nokia | benoist.sebire@nokia.com | Rel-6 | Paolo |  |
| 1630 | 26.1 | **Realisation of a Flexible Layer One** | 1126d | 2000-01-03 A | 2004-04-23 A | 100% | 2000-01-03 | 2004-04-23 | 1126d |  | GP | 42816h | 42816h | FLOGER-Real | Nokia | benoist.sebire@nokia.com | Rel-6 | Paolo |  |
| 1631 | 26.1.1 | Technical Report | 471d | 2002-04-19 A | 2004-02-06 A | 100% | 2002-04-19 | 2004-02-06 | 471d | finish no earlier than 2004-02-06 | GP | 3768h | 3768h | FLOGER-Real |  |  | Rel-6 | Paolo |  |
| 1632 | 26.1.2 | Architecture in 45.001 and 43.051 | 526d | 2002-04-19 A | 2004-04-23 A | 100% | 2002-04-19 | 2004-04-23 | 526d | finish no earlier than 2004-04-23 | G1 | 4208h | 4208h | FLOGER-Real |  |  | Rel-6 | Paolo |  |
| 1633 | 26.1.3 | Multiplexing in 45.002 | 526d | 2002-04-19 A | 2004-04-23 A | 100% | 2002-04-19 | 2004-04-23 | 526d | finish no earlier than 2004-04-23 | G1 | 4208h | 4208h | FLOGER-Real |  |  | Rel-6 | Paolo |  |
| 1634 | 26.1.4 | Channel Coding in 45.003 | 526d | 2002-04-19 A | 2004-04-23 A | 100% | 2002-04-19 | 2004-04-23 | 526d | finish no earlier than 2004-04-23 | G1 | 4208h | 4208h | FLOGER-Real |  |  | Rel-6 | Paolo |  |
| 1635 | 26.1.5 | Performance Requirements in 45.005 | 1126d | 2000-01-03 A | 2004-04-23 A | 100% | 2000-01-03 | 2004-04-23 | 1126d | finish no earlier than 2004-04-23 | G1 | 9000h | 9000h | FLOGER-Real |  |  | Rel-6 | Paolo |  |
| 1636 | 26.1.6 | Radio subsystem link control in 45.008 | 526d | 2002-04-19 A | 2004-04-23 A | 100% | 2002-04-19 | 2004-04-23 | 526d | finish no earlier than 2004-04-23 | G1 | 4208h | 4208h | FLOGER-Real |  |  | Rel-6 | Paolo |  |
| 1637 | 26.1.7 | Requirements in 44.004 | 526d | 2002-04-19 A | 2004-04-23 A | 100% | 2002-04-19 | 2004-04-23 | 526d | finish no earlier than 2004-04-23 | G2 | 4208h | 4208h | FLOGER-Real |  |  | Rel-6 | Gert |  |

Notes:
- 1613: merged "Presence Service Enhancements" (UID31028, PRES1) to this feature as no answer was provided on why Presence and Presence Encmts had same target completion date
- 1614: -
- 1615: -
- 1616: Dependency to 2 IETF drafts, no known work at the moment
- 1617: No Contributions so far - only requires a little work
- 1618: -
- 1619: LSs handled in SA3. WID approved SP#17 Contribution at S3#25 & following e-mail discussion. Marked as closed 12/2008 (was marked 90% complete)
- 1620: Updated according to SP-040232
- 1621: -
- 1622: -
- 1623: -
- 1624: -
- 1625: -
- 1626: -
- 1627: -
- 1628: -
- 1629: -
- 1630: -
- 1631: -
- 1632: -
- 1633: -
- 1634: -
- 1635: -
- 1636: -
- 1637: -

| ID | WBS | Task | Type | Duration | Start | Finish | Complete | Baseline start | Baseline finish | Baseline duration | Constraint | Resources | Work | Actual work | Text1 | Text4 | Text5 | Text6 | Text8 | Text12 | Text3 |
| --- | --- | --- | --- | --- | --- | --- | --- | --- | --- | --- | --- | --- | --- | --- | --- | --- | --- | --- | --- | --- | --- |
| 1638 | 26.2 | **Signalling and protocol support for a Flexible Layer One** |  | 571d | 2002-04-19 A | 2004-06-25 A | 100% | 2002-04-19 | 2004-06-25 | 571d |  | G2 | 13704h | 13704h | FLOGER-SigPro | Nokia | benoist.sebire@nokia.com | Rel-6 | Gert |  |  |
| 1639 | 26.2.1 | Modifications to RLC/MAC in 44.060 and 44.160 |  | 571d | 2002-04-19 A | 2004-06-25 A | 100% | 2002-04-19 | 2004-06-25 | 571d | finish no earlier than 2004-06-25 | G2 | 4568h | 4568h | FLOGER-SigPro |  |  | Rel-6 | Gert |  |  |
| 1640 | 26.2.2 | Modifications to RRC in 44.118 and 44.018 |  | 571d | 2002-04-19 A | 2004-06-25 A | 100% | 2002-04-19 | 2004-06-25 | 571d | finish no earlier than 2004-06-25 | G2 | 4568h | 4568h | FLOGER-SigPro |  |  | Rel-6 | Gert |  |  |
| 1641 | 26.3 | **Security for a Flexible Layer One** |  | 356d | 2002-04-19 A | 2003-08-29 A | 100% | 2002-04-19 | 2003-08-29 | 356d |  | S3, G2 | 5663.03h | 5663.03h | FLOGER-SecFLO | Nokia | benoist.sebire@nokia.com | Rel-6 | Dionisio |  |  |
| 1642 | 26.3.1 | Ciphering in 44.160,44.118, 44.060 and 44.018 |  | 356d | 2002-04-19 A | 2003-08-29 A | 100% | 2002-04-19 | 2003-08-29 | 356d | finish no earlier than 2003-08-29 | S3, G2 | 2848h | 2848h | FLOGER-SecFLO |  |  | Rel-6 | Dionisio |  |  |
| 1643 | 26.4 | **Deleted - GERAN MS Conformance test for the Flexible Layer One - DELETE** |  | 0d | 2004-02-06 A | 2004-02-06 A | 100% | 2004-02-06 | 2004-02-06 | 0d |  | G4,G5 |  |  | FLOGER-Msconf | Nokia | benoist.sebire@nokia.com | Rel-6 | Paolo | GP-27 |  |
| 1644 | 26.4.1 | Deleted at TSG #27 - MS Test in 51.010 | milestone | 0d | 2004-02-06 A | 2004-02-06 A | 100% | 2004-02-06 | 2004-02-06 | 0d | finish no earlier than 2004-02-06 | G4,G5 |  |  | FLOGER-Msconf |  |  | Rel-6 | Paolo | GP-22 |  |
| 1645 | 26.5 | **Deleted - GERAN BTS Conformance test for the Flexible Layer One - DELETE** |  | 0d | 2004-02-06 A | 2004-02-06 A | 100% | 2004-02-06 | 2004-02-06 | 0d |  | G3new |  |  | FLOGER-BTSconf | Nokia | benoist.sebire@nokia.com | Rel-6 | Ingbert | GP-27 |  |
| 1646 | 26.5.1 | Deleted at TGS #27 - BTS Test in 51.021 - DELETE | milestone | 0d | 2004-02-06 A | 2004-02-06 A | 100% | 2004-02-06 | 2004-02-06 | 0d | finish no earlier than 2004-02-06 | G3new |  |  | FLOGER-BTSconf |  |  | Rel-6 | Ingbert | GP-22 |  |
| 1647 | 27 | Uplink TDOA feasibility study |  | 151d | 2001-11-30 A | 2002-06-28 A | 100% | 2001-11-30 | 2002-06-28 | 151d | finish no earlier than 2002-06-28 | GP | 1208h | 1208h | TDOAF | TruePosition | Bob Gross (rlgross@trueposition.com) | Rel-6 | Paolo |  | 45.811 |
| 1648 | 28 | **Multimedia Broadcast and Multicast Service** |  | 1781d? | 2001-05-11 A | 2008-03-07 A | 100% | 2001-05-11 | 2008-03-07 | 1781d? |  | S1,S2,S4,S5,RP,R5,GP | 158712h | 158712h | MBMS |  |  | Rel-6 | Alain |  |  |
| 1649 | 28.1 | Stage 1 |  | 232d | 2001-05-11 A | 2002-04-01 A | 100% | 2001-05-11 | 2002-04-01 | 232d | finish no earlier than 2002-04-01 | S1 | 1856h | 1856h | MBMS |  |  | Rel-6 | Alain |  | 22.146, 22.101 |
| 1650 | 28.2 | **Stage 2** |  | 648d | 2001-09-24 A | 2004-03-17 A | 100% | 2001-09-24 | 2004-03-17 | 648d |  | S2 | 10408h | 10408h | MBMS |  |  | Rel-6 | Maurice |  |  |
| 1651 | 28.2.1 | TR on Architectural Study |  | 240d | 2001-09-24 A | 2002-08-23 A | 100% | 2001-09-24 | 2002-08-23 | 240d | finish no earlier than 2002-08-23 | S2 | 1920h | 1920h | MBMS |  |  | Rel-6 | Maurice |  | 23.846 |
| 1652 | 28.2.2 | Stage 2 Specification Work |  | 413d | 2002-08-19 A | 2004-03-17 A | 100% | 2002-08-19 | 2004-03-17 | 413d | finish no earlier than 2004-03-17 | S2 | 3304h | 3304h | MBMS |  |  | Rel-6 | Maurice |  | 23.246 |
| 1653 | 28.3 | **Introduction of MBMS in RAN** |  | 967d? | 2002-01-01 A | 2005-09-14 A | 100% | 2002-01-01 | 2005-09-14 | 967d? |  | R2 | 15992h | 15992h | MBMS-RAN | Nokia | juho.pirskanen@nokia.com | Rel-6 | Joern |  | 25.346, 25.304, 25.321, 25.322, 25.323, 25.331 |
| 1654 | 514.3.1 | Introduction of MBMS in RAN (physical & upper layers, access network interfaces) |  | 771d? | 2002-01-01 A | 2004-12-14 A | 100% | 2002-01-01 | 2004-12-14 | 771d? | finish no earlier than 2004-12-14 | R2 | 6168h | 6168h | MBMS-RAN | Nokia | juho.pirskanen@nokia.com | Rel-6 | Joern |  | 25.346, 25.304, 25.321, 25.322, 25.323 |
| 1655 | 514.3.2 | UE Performance Requirements for MBMS |  | 261d? | 2004-09-15 A | 2005-09-14 A | 100% | 2004-09-15 | 2005-09-14 | 261d? | finish no earlier than 2005-09-15 | R4 | 2088h | 2088h | MBMS-RAN-RF | Ericsson | Torgny.Palenius@ericsson.com | Rel-6 | Issam |  | 25.101, 25.133 |
| 1656 | 28.4 | Support of the MBMS in CN protocols |  | 647d | 2002-06-18 A | 2004-12-08 A | 100% | 2002-06-18 | 2004-12-08 | 647d | finish no earlier than 2004-12-08 | N1 | 5176h | 5176h | MBMS |  |  | Rel-6 | Frederic |  |  |
| 1657 | 514.5 | Gmb interface for MBMS (CN3 part) |  | 334d | 2003-08-29 A | 2004-12-08 A | 100% | 2003-08-29 | 2004-12-08 | 334d | finish no earlier than 2004-12-08 | N3 | 2672h | 2672h | MBMS |  |  | Rel-6 | Gwiho |  | 29.061 |
| 1658 | 28.5 | Security Aspects of MBMS |  | 710d | 2002-07-01 A | 2005-03-18 A | 100% | 2002-07-01 | 2005-03-18 | 710d | finish no earlier than 2005-03-18 | S3 | 5680h | 5680h | MBMS |  | adrian.escott@three.co.uk | Rel-6 | Dionisio |  |  |
| 1659 | 28.6 | **Support of MBMS in GERAN** |  | 892d? | 2001-08-30 A | 2005-01-28 A | 100% | 2001-08-30 | 2005-01-28 | 892d? |  | GP | 71040h | 71040h | MBMS-GERAN |  |  | Rel-6 | Paolo |  |  |
| 1660 | 28.6.1 | Impact on the logical and physical channels |  | 631d | 2002-08-30 A | 2005-01-28 A | 100% | 2002-08-30 | 2005-01-28 | 631d | finish no earlier than 2005-01-28 | GP | 5048h | 5048h | MBMS-GERAN |  |  | Rel-6 | Paolo |  |  |
| 1661 | 28.6.4 | Re-synchronisation at cell change |  | 631d | 2002-08-30 A | 2005-01-28 A | 100% | 2002-08-30 | 2005-01-28 | 631d | finish no earlier than 2005-01-28 | G2 | 5048h | 5048h | MBMS-GERAN |  |  | Rel-6 | Gert |  |  |
| 1662 | 514.7.3 | Simultaneous support of MBMS services |  | 631d? | 2002-08-30 A | 2005-01-28 A | 100% | 2002-08-30 | 2005-01-28 | 631d? | finish no earlier than 2005-01-28 | GP | 5048h | 5048h | MBMS-GERAN |  |  | Rel-6 | Paolo |  |  |
| 1663 | 514.7.4 | Simultaneous support of MBMS and non-MBMS services |  | 892d? | 2001-08-30 A | 2005-01-28 A | 100% | 2001-08-30 | 2005-01-28 | 892d? | finish no earlier than 2005-01-28 | GP | 7136h | 7136h | MBMS-GERAN |  |  | Rel-6 | Paolo |  |  |
| 1664 | 514.7.5 | Resynchronisation at cell change |  | 892d? | 2001-08-30 A | 2005-01-28 A | 100% | 2001-08-30 | 2005-01-28 | 892d? | finish no earlier than 2005-01-28 | GP | 7136h | 7136h | MBMS-GERAN |  |  | Rel-6 | Paolo |  |  |
| 1665 | 28.6.5 | Decision making process between point-to-point or pont-to-multipoint configurations |  | 631d | 2002-08-30 A | 2005-01-28 A | 100% | 2002-08-30 | 2005-01-28 | 631d | finish no earlier than 2005-01-28 | GP | 5048h | 5048h | MBMS-GERAN |  |  | Rel-6 | Paolo |  |  |
| 1666 | 28.6.6 | MBMS channel allocations procedures to multiple MSs |  | 631d | 2002-08-30 A | 2005-01-28 A | 100% | 2002-08-30 | 2005-01-28 | 631d | finish no earlier than 2005-01-28 | GP | 5048h | 5048h | MBMS-GERAN |  |  | Rel-6 | Paolo |  |  |
| 1667 | 28.6.7 | Changes to the Gb interface |  | 631d | 2002-08-30 A | 2005-01-28 A | 100% | 2002-08-30 | 2005-01-28 | 631d | finish no earlier than 2005-01-28 | GP | 5048h | 5048h | MBMS-GERAN |  |  | Rel-6 | Paolo |  |  |
| 1668 | 28.6.8 | GERAN specific changes to the Iu-ps interface |  | 631d | 2002-08-30 A | 2005-01-28 A | 100% | 2002-08-30 | 2005-01-28 | 631d | finish no earlier than 2005-01-28 | GP | 5048h | 5048h | MBMS-GERAN |  |  | Rel-6 | Paolo |  |  |
| 1669 | 28.6.9 | Interaction between MBMS and Iu-flex |  | 631d | 2002-08-30 A | 2005-01-28 A | 100% | 2002-08-30 | 2005-01-28 | 631d | finish no earlier than 2005-01-28 | GP | 5048h | 5048h | MBMS-GERAN |  |  | Rel-6 | Paolo |  |  |
| 1670 | 28.6.10 | Security aspects |  | 631d | 2002-08-30 A | 2005-01-28 A | 100% | 2002-08-30 | 2005-01-28 | 631d | finish no earlier than 2005-01-28 | GP | 5048h | 5048h | MBMS-GERAN |  |  | Rel-6 | Paolo |  |  |
| 1671 | 514.7.12 | MBMS-GERAN - MS conformance tests |  | 786d? | 2002-01-25 A | 2005-01-28 A | 100% | 2002-01-25 | 2005-01-28 | 786d? | finish no earlier than 2005-01-28 | G3new | 6288h | 6288h | MBMS-GERAN |  |  | Rel-6 | Ingbert |  |  |
| 1672 | 514.7.13 | Deleted - MS conformance tests - G5 | milestone | 0d? | 2003-06-27 A | 2003-06-27 A | 100% | 2003-06-27 | 2003-06-27 | 0d? | start no earlier than 2003-06-27 | G5 |  |  | MBMS-GERAN |  |  | Rel-6 | Paolo | GP-19 |  |

Notes:
- 1638: -
- 1639: -
- 1640: -
- 1641: -
- 1642: -
- 1643: -
- 1644: -
- 1645: -
- 1646: -
- 1647: -
- 1648: Title renamed at SP#13
- 1649: This may or may not be a separate stage 1. In the meantime, CRs are proposed for 22.101
- 1650: -
- 1651: -
- 1652: -
- 1653: -
- 1654: Was "Introduction of MBMS in RAN" before RP#25. Created w/o WIDS after RAN approved the WT for RF aspects.Take WIDS from the parent BB
- 1655: Approved at RP#25 as RP-040370
- 1656: -
- 1657: -
- 1658: WID approved SP#17. 2004-12: Expected completion March 2005
- 1659: -
- 1660: -
- 1661: -
- 1662: -
- 1663: -
- 1664: -
- 1665: -
- 1666: -
- 1667: -
- 1668: -
- 1669: -
- 1670: -
- 1671: -
- 1672: -

| ID | WBS | Task | Type | Duration | Start | Finish | Complete | Baseline start | Baseline finish | Baseline duration | Constraint | Deadline | Resources | Work | Actual work | Text1 | Text6 | Text8 | Text4 | Text5 | Text10 | Text12 |
| --- | --- | --- | --- | --- | --- | --- | --- | --- | --- | --- | --- | --- | --- | --- | --- | --- | --- | --- | --- | --- | --- | --- |
| 1673 | 28.1 | **MBMS User Services** |  | 743d? | 2003-05-13 A | 2006-03-16 A | 100% | 2003-05-13 | 2006-03-16 | 743d? |  |  | S1 | 13576h | 13576h | MBMS | Rel-6 | Alain |  |  |  |  |
| 1674 | 28.1 | MBMS User Services Stage 1 |  | 233d | 2003-05-13 A | 2004-04-01 A | 100% | 2003-05-13 | 2004-04-01 | 233d | start no earlier than 2003-05-13 |  | S1 | 1864h | 1864h | MBMS | Rel-6 | Alain |  |  |  |  |
| 1675 | 514.8.2 | Definition of MBMS user services, media codecs, formats and transport/application protocols using MBMS |  | 721d? | 2003-06-12 A | 2006-03-16 A | 100% | 2003-06-12 | 2006-03-16 | 721d? | finish no earlier than 2006-03-16 |  | S4 | 5768h | 5768h | MBMS-TSMBMS | Rel-6 | Paolo | Nokia | igor.curcio@nokia.com |  |  |
| 1676 | 514.9 | MBMS charging |  | 108d? | 2005-01-11 A | 2005-06-09 A | 100% | 2005-01-11 | 2005-06-09 | 108d? | start no earlier than 2005-01-11 |  | S5 | 864h | 864h | MBMS-CH | Rel-6 | Dionisio |  |  |  |  |
| 1677 | 514.10 | **MBMS UE Conformance Testing** |  | 521d? | 2006-03-10 A | 2008-03-07 A | 100% | 2006-03-10 | 2008-03-07 | 521d? |  |  | R5,T1 | 17200h | 17200h | MBMS-UEConTest | Rel-6 | Ingbert |  |  |  |  |
| 1678 | 16.5.1 | RF/RRM Conformance Test Aspects – MBMS (FDD) |  | 461d | 2006-06-02 A | 2008-03-07 A | 100% | 2006-06-02 | 2008-03-07 | 461d | finish no earlier than 2008-03-07 | 2006-06-02 | R5,T1 | 3688h | 3688h | MBMS-RAN-RF_Test | Rel-6 | Ingbert | Ericsson | leif.mattisson@ericsson.com | Fri 11/03/05 |  |
| 1679 | 514.10.2 | Conformance Test Aspects - MBMS for 3.84 Mcps and 7.68 Mcps TDD |  | 318d? | 2006-09-20 A | 2007-12-07 A | 100% | 2006-09-20 | 2007-12-07 | 318d? | finish no earlier than 2007-12-07 |  | R5,T1 | 2544h | 2544h | MBMS-UEConTest_TDH | Rel-6 | Ingbert | IPWireless | Timothy Speight (tspeight@ipwireless.com) |  |  |
| 1680 | 514.10.3 | Signalling Conformance Test Aspects – MBMS for LCR TDD |  | 318d? | 2006-09-20 A | 2007-12-07 A | 100% | 2006-09-20 | 2007-12-07 | 318d? | finish no earlier than 2007-12-07 |  | R5,T1 | 2544h | 2544h | MBMS-UEConTest_SIGTDL | Rel-6 | Ingbert | DATANG | zhaojian@datangmobile.cn |  |  |
| 1681 | 514.10.4 | Conformance Test Aspects – MBMS |  | 396d? | 2006-03-10 A | 2007-09-14 A | 100% | 2006-03-10 | 2007-09-14 | 396d? | finish no earlier than 2007-09-14 |  | R5,T1 | 3168h | 3168h | MBMS_Test | Rel-6 | Ingbert | Qualcomm | Shubhang Vora (svora@qualcomm.com) |  |  |
| 1682 | 16.5.1 | Conformance Test Aspects - 1.28 Mcps TDD MBMS RF/RRM |  | 136d | 2007-06-01 A | 2007-12-07 A | 100% | 2007-06-01 | 2007-12-07 | 136d | finish no earlier than 2007-12-07 | 2006-06-02 | R5,T1 | 1088h | 1088h | MBMS-UEConTest_RFTDL | Rel-6 | Ingbert | Datang Mobile | chenxiaozhong@datangmobile.cn | Fri 11/03/05 |  |
| 1683 | 29 | **Speech Recognition and Speech Enabled Services** |  | 1105d? | 2001-10-08 A | 2005-12-30 A | 100% | 2001-10-08 | 2005-12-30 | 1105d? |  |  | S1 | 20176h | 20176h | SRSES | Rel-6 | Alain |  |  |  |  |
| 1684 | 29.1 | Speech Enabled Services Based on Distributed Speech Recognition (DSR) |  | 115d | 2001-10-08 A | 2002-03-15 A | 100% | 2001-10-08 | 2002-03-15 | 115d | finish no earlier than 2002-03-15 |  | S1 | 920h | 920h | DSR | Rel-6 | Alain | Qualcomm | Dwilliams@qualcomm.com |  |  |
| 1685 | 29.2 | TR on Architectural impacts |  | 212d | 2003-05-12 A | 2004-03-02 A | 100% | 2003-05-12 | 2004-03-02 | 212d | finish no earlier than 2004-03-02 |  | S2 | 1696h | 1696h | SRSES | Rel-6 | Maurice |  |  |  |  |
| 1686 | 515.3 | Codec Work to Support Speech Recognition Framework for Automated Voice Services |  | 568d? | 2002-10-15 A | 2004-12-16 A | 100% | 2002-10-15 | 2004-12-16 | 568d? | finish no earlier than 2004-12-16 |  | S4 | 4544h | 4544h | SRSES-Codec | Rel-6 | Paolo | Motorola | David Pearce (bdp003@motorola.com) |  |  |
| 1687 | 515.4 | Multimodal support |  | 522d? | 2004-01-01 A | 2005-12-30 A | 100% | 2004-01-01 | 2005-12-30 | 522d? | finish no earlier than 2005-06-30 |  | OMA | 4176h | 4176h | SRSES | Rel-6 | Paolo |  | OMA-LIAISON@mail.openmobilealliance.org | SP-24 |  |
| 1688 | 515.5 | Deleted - SES codec negotiation at Session Description Protocol (SDP) | milestone | 0d? | 2003-06-04 A | 2003-06-04 A | 100% | 2003-06-04 | 2003-06-04 | 0d? | start no earlier than 2003-06-04 |  | N1 |  |  | SRSES | Rel-6 | Frederic |  |  |  | NP-23 |
| 1689 | 30 | **Generic User Profile Rel-6** |  | 889d | 2001-10-08 A | 2005-03-03 A | 100% | 2001-10-08 | 2005-03-03 | 889d |  |  | S1 | 24295.8h | 24295.8h | GUP | Rel-6 | Alain |  |  |  |  |
| 1690 | 30.1 | Stage 1 - Requirements |  | 430d | 2001-10-08 A | 2003-05-30 A | 100% | 2001-10-08 | 2003-05-30 | 430d | finish no earlier than 2002-12-09 |  | S1 | 3440h | 3440h | GUP | Rel-6 | Alain | T-Mobile | kurt.bischinger@t-mobile.at |  |  |
| 1691 | 30.3 | Stage 2 - Architecture |  | 355d | 2002-01-28 A | 2003-06-06 A | 100% | 2002-01-28 | 2003-06-06 | 355d | finish no earlier than 2003-06-06 |  | S2 | 2840h | 2840h | GUP | Rel-6 | Maurice | Nokia | harri.o.koskinen@nokia.com |  |  |
| 1692 | 30.2 | Stage 2 - Data Description Method |  | 586d | 2002-12-05 A | 2005-03-03 A | 100% | 2002-12-05 | 2005-03-03 | 586d | finish no earlier than 2005-03-03 |  | N4 | 4688h | 4688h | GUP | Rel-6 | Kimmo | T-Mobile | kurt.bischinger@t-mobile.at |  |  |
| 1693 | 30.5 | Stage 3 - Network |  | 468.98d | 2003-05-19 A | 2005-03-03 A | 100% | 2003-05-19 | 2005-03-03 | 468.98d | finish no earlier than 2005-03-03 |  | N4 | 3751.83h | 3751.83h | GUP | Rel-6 | Kimmo |  |  |  |  |
| 1694 | 30.6 | Security Aspects |  | 308d | 2002-07-16 A | 2003-09-18 A | 100% | 2002-07-16 | 2003-09-18 | 308d | finish no earlier than 2003-09-18 |  | S3 | 2464h | 2464h | GUP | Rel-6 | Dionisio | Lucent | Owen, Bradley (bvowen@lucent.com) |  |  |
| 1695 | 31 | **Digital Rights Management** |  | 690d? | 2001-10-08 A | 2004-05-28 A | 100% | 2001-10-08 | 2004-05-28 | 690d? |  |  | S1 | 10152h | 10152h | DRM | Rel-6 | Alain |  |  |  |  |
| 1696 | 31.1 | Requirements |  | 179d | 2001-10-08 A | 2002-06-13 A | 100% | 2001-10-08 | 2002-06-13 | 179d | finish no earlier than 2002-06-13 |  | S1 | 1432h | 1432h | DRM | Rel-6 | Alain | Openwave | nicholas.wood@openwave.com |  |  |
| 1697 | 517.2 | Stage 2 |  | 107d? | 2004-01-01 A | 2004-05-28 A | 100% | 2004-01-01 | 2004-05-28 | 107d? | finish no earlier than 2004-05-28 |  | OMA | 856h | 856h | DRM | Rel-6 |  |  | OMA-LIAISON@mail.openmobilealliance.org | SP-24 |  |
| 1698 | 517.3 | Stage 3 |  | 107d? | 2004-01-01 A | 2004-05-28 A | 100% | 2004-01-01 | 2004-05-28 | 107d? | finish no earlier than 2004-05-28 |  | OMA | 856h | 856h | DRM | Rel-6 |  |  | OMA-LIAISON@mail.openmobilealliance.org | SP-24 |  |
| 1699 | 31.3 | Security |  | 186d | 2002-06-17 A | 2003-03-03 A | 100% | 2002-06-17 | 2003-03-03 | 186d | finish no earlier than 2003-03-03 |  | OMA | 1488h | 1488h | DRM | Rel-6 |  |  |  |  |  |
| 1700 | 517.5 | Deleted - Monitoring of Stages 2 and 3 progress (actual work to be done by OMA) | milestone | 0d? | 2003-03-21 A | 2003-03-21 A | 100% | 2003-03-21 | 2003-03-21 | 0d? | start no earlier than 2002-08-19 |  | S1 |  |  | DRM | Rel-6 | Alain |  |  |  | SP-19 |

Notes:
- 1673: - / Text3: 22.246
- 1674: - / Text3: 22.246
- 1675: TR26.946 tbc by March 06 / Text3: 26.346, 26.936, 26.946
- 1676: SP#28 06/2005 completed / Text3: 32.273
- 1677: BB place holder for a number of RAN5 Tasks. Moved in from the Stoyan/Testing WP / Text3: 34.108, 34.109, 34.121-1, 34.121-2, 34.122, 34.123-1, 34.123-2, 34.123-3
- 1678: TS 34.109 is under RAN2; RAN5 need to identify possible new requirements on UE test loop functionality to enable testing / Text3: 34.108, 34.109, 34.121-1, 34.121-2
- 1679: - / Text3: 34.108, 34.122, 34.123-1, 34.123-2, 34.123-3
- 1680: - / Text3: 34.108, 34.123-1, 34.123-2, 34.123-3
- 1681: - / Text3: 34.108, 34.123-1, 34.123-2, 34.123-3
- 1682: - / Text3: 34.108, 34.109, 34.122
- 1683: -
- 1684: - / Text3: 22.977, 22.941, 23.207, 22.243
- 1685: - / Text3: 23.877
- 1686: - / Text3: 26.235, 26.236, 26.243, 26.177, 26.943
- 1687: -
- 1688: Abandoned NP-23
- 1689: -
- 1690: - / Text3: 22.240, 22.228
- 1691: - / Text3: 23.240
- 1692: TR approved in CN#26 / Text3: 23.241
- 1693: - / Text3: 29.240
- 1694: WID approved SP#17. SA WG3 progress slow, depends on progress in other groups. / Text3: 33.102, 33.203, 33.210
- 1695: Foreseen start and completion dates introduced by MCC (no indication at all on the WID)
- 1696: -
- 1697: -
- 1698: -
- 1699: SA3 acknowledge role in WI at SA3#20. Active contribution S3#24, S3#25. S3 WID approved SP#17
- 1700: Replaced by UID 60005 and 60006

| ID | WBS | Task | Type | Duration | Start | Finish | Complete | Baseline start | Baseline finish | Baseline duration | Constraint | Deadline | Resources | Work | Actual work | Text1 | Text4 | Text5 | Text6 | Text8 | Text3 | Text10 |
| --- | --- | --- | --- | --- | --- | --- | --- | --- | --- | --- | --- | --- | --- | --- | --- | --- | --- | --- | --- | --- | --- | --- |
| 1701 | 32 | **WLAN-UMTS Interworking Rel-6** |  | 1495d? | 2000-01-03 A | 2005-09-22 A | 100% | 2000-01-03 | 2005-09-22 | 1495d? |  |  | S1 | 45472h | 45472h | WLAN | Telenor | frederic.paint@telenor.com | Rel-6 | Alain |  |  |
| 1702 | 32.1 | Technical Report |  | 901d? | 2000-01-03 A | 2003-06-13 A | 100% | 2000-01-03 | 2003-06-13 | 901d? | finish no earlier than 2003-06-13 |  | S1 | 7200h | 7200h | WLAN-TR | T-mobile | Mark.Younge@t-mobile.com | Rel-6 | Alain | 22.934 |  |
| 1703 | 518.2 | Stage 1 |  | 375d? | 2003-01-06 A | 2004-06-11 A | 100% | 2003-01-06 | 2004-06-11 | 375d? |  |  | S1 | 920h | 920h | WLAN-TS | Telenor | frederic.paint@telenor.com | Rel-6 | Alain | 22.101, 22.105 | SP-24 |
| 1704 | 32.2 | Architecture Definition for scenarii 2 and 3 |  | 571d | 2002-03-25 A | 2004-05-31 A | 100% | 2002-03-25 | 2004-05-31 | 571d | finish no earlier than 2004-05-31 |  | S2 | 4568h | 4568h | WLAN |  |  | Rel-6 | Maurice | 23.234 |  |
| 1705 | 32.3 | Security |  | 125d | 2002-09-30 A | 2003-03-21 A | 100% | 2002-09-30 | 2003-03-21 | 125d | finish no earlier than 2003-03-21 |  | S3 | 1000h | 1000h | WLAN | Ericsson | luis.lopez-soria@ece.ericsson.se | Rel-6 | Dionisio | 21.133, 33.106, 33.107, 33.108, 33.200, 33.203, 33.210 |  |
| 1706 | 518.5 | Stage 3 - CN4 aspects |  | 334d? | 2003-05-23 A | 2004-09-01 A | 100% | 2003-05-23 | 2004-09-01 | 334d? | finish no earlier than 2004-09-01 |  | N4 | 2672h | 2672h | WLAN-IW | Nokia | raquel.rodriguez@nokia.com | Rel-6 | Kimmo | 29.234, 29.061 |  |
| 1707 | 518.6 | Stage 3 - CN3 aspects (Wi Interface for Scenario 3) |  | 355d? | 2003-05-23 A | 2004-09-30 A | 100% | 2003-05-23 | 2004-09-30 | 355d? | start no earlier than 2003-05-23 |  | N3 | 2840h | 2840h | WLAN |  |  | Rel-6 | Gwiho | 29.161 | SP-24 |
| 1708 | 518.7 | Stage 3 for scenario 2 |  | 339d? | 2003-05-23 A | 2004-09-08 A | 100% | 2003-05-23 | 2004-09-08 | 339d? | finish no earlier than 2004-09-08 |  | N1 | 2712h | 2712h | WLAN |  |  | Rel-6 | Frederic |  |  |
| 1709 | 518.8 | Stage 3 for scenario 3 |  | 404d? | 2003-05-23 A | 2004-12-08 A | 100% | 2003-05-23 | 2004-12-08 | 404d? | finish no earlier than 2004-12-08 |  | N1 | 3232h | 3232h | WLAN |  |  | Rel-6 | Frederic |  | SP-24 |
| 1710 | 518.9 | WLAN charging |  | 655d? | 2003-03-21 A | 2005-09-22 A | 100% | 2003-03-21 | 2005-09-22 | 655d? | finish no earlier than 2005-09-22 |  | S5 | 5240h | 5240h | WLAN-CH | Nokia | Benni ALEXANDER | Rel-6 | Dionisio | 32.252 |  |
| 1711 | 518.10 | USIM enhancements for WLAN Interworking |  | 391d? | 2003-09-05 A | 2005-03-04 A | 100% | 2003-09-05 | 2005-03-04 | 391d? | finish no earlier than 2005-03-04 |  | T3 | 3128h | 3128h | WLAN | Axalto | Jabellan@axalto.com | Rel-6 | Xavier |  |  |
| 1712 | 33 | **Priority Service** |  | 347d? | 2002-05-30 A | 2003-09-26 A | 100% | 2002-05-30 | 2003-09-26 | 347d? |  |  | S1 | 6464h | 6464h | PRIOR1 | Telcordia | James Garrahan (jgarraha@telcordia.com) | Rel-6 | Alain |  |  |
| 1713 | 33.1 | Feasibility Study |  | 1d | 2002-06-14 A | 2002-06-14 A | 100% | 2002-06-14 | 2002-06-14 | 1d | finish no earlier than 2002-06-14 |  | S1 | 8h | 8h | PRIOR-FS | Telcordia | James Garrahan (jgarraha@telcordia.com) | Rel-6 | Alain | 22.950 |  |
| 1714 | 33.2 | Stage 1 - Requirements |  | 340d | 2002-05-30 A | 2003-09-17 A | 100% | 2002-05-30 | 2003-09-17 | 340d | finish no earlier than 2003-09-17 |  | S1 | 2720h | 2720h | PRIOR-SR | Telcordia | James Garrahan (jgarraha@telcordia.com) | Rel-6 | Alain |  |  |
| 1715 | 519.3 | Priority service implementation guide |  | 131d? | 2003-03-28 A | 2003-09-26 A | 100% | 2003-03-28 | 2003-09-26 | 131d? | finish no earlier than 2003-09-26 |  | S1 | 1048h | 1048h | PRIOR1 | Telcordia | James Garrahan (jgarraha@telcordia.com) | Rel-6 | Alain | 22.952 |  |
| 1716 | 34 | **Network Sharing** |  | 820d? | 2003-01-20 A | 2006-03-10 A | 100% | 2003-01-20 | 2006-03-10 | 820d? |  |  | S1,S2,N1,R2,R5 | 18696h | 18696h | NTShar | T-Mobile | michele.zarri@t-mobile.co.uk | Rel-6 | Alain |  |  |
| 1717 | 34.1 | Technical Report |  | 240d? | 2003-01-20 A | 2003-12-19 A | 100% | 2003-01-20 | 2003-12-19 | 240d? |  |  | S1 | 1920h | 1920h | NTShar-TR | T-Mobile | michele.zarri@t-mobile.co.uk | Rel-6 | Alain | 22.951 |  |
| 1718 | 520.2 | Stage 1 - CRs to implement Network Sharing |  | 240d? | 2003-01-20 A | 2003-12-19 A | 100% | 2003-01-20 | 2003-12-19 | 240d? | finish no earlier than 2003-12-19 |  | S1 | 1920h | 1920h | NTSharCR | T-Mobile | michele.zarri@t-mobile.co.uk | Rel-6 | Alain | 22.011, 22.101, 22.115, 22.129 |  |
| 1719 | 520.3 | Stage 2 |  | 372d? | 2003-02-27 A | 2004-07-30 A | 100% | 2003-02-27 | 2004-07-30 | 372d? | finish no earlier than 2004-07-30 |  | S2 | 2976h | 2976h | NTShar | T-Mobile | michele.zarri@t-mobile.co.uk | Rel-6 | Maurice | 23.002, 23.060, 23.221, 23.236, new 23.251 |  |
| 1720 | 520.4 | Network sharing - stage 3 |  | 404d? | 2003-05-23 A | 2004-12-08 A | 100% | 2003-05-23 | 2004-12-08 | 404d? | finish no earlier than 2004-12-08 |  | N1 | 3232h | 3232h | NTShar | T-Mobile | michele.zarri@t-mobile.co.uk | Rel-6 | Frederic | 23.008, 23.122, 24.007, 24.008, 29.018 |  |
| 1721 | 520.5 | Enhancement of the support of network sharing in the UTRAN | milestone | 0d | 2003-09-19 A | 2003-09-19 A | 100% | 2003-09-19 | 2003-09-19 | 0d |  |  | R2 |  |  | NTShar-UTRANEnh | TeliaSonera | Anders.Dahlen@TeliaSonera.com | Rel-6 | Joern | 25.401, 25.413, 25.331, 25.304 |  |
| 1722 | 16.5.1 | Conformance Test Aspects – Network Sharing |  | 261d | 2005-03-11 A | 2006-03-10 A | 100% | 2005-03-11 | 2006-03-10 | 261d | finish no earlier than 2006-03-10 | 2006-03-10 | R5 | 2088h | 2088h | NTShar-UTRANEnh_Test | TeliaSonera | Niklas.Wiren@TeliaSonera.com | Rel-6 | Ingbert | 34.108, 34.123-1, 34.123-2, 34.123-3 | Fri 11/03/05 |
| 1723 | 35 | **QoS Improvements** |  | 628d? | 2002-07-15 A | 2004-12-08 A | 100% | 2002-07-15 | 2004-12-08 | 628d? |  |  | S2,N3 | 13128h | 13128h | QoS1 | Nokia |  | Rel-6 | Maurice | 23.107, 23.207, 23.221 |  |
| 1724 | 35.1 | FS on Dynamic Policy control enhancements for end-to-end QoS |  | 465d | 2002-07-15 A | 2004-04-23 A | 100% | 2002-07-15 | 2004-04-23 | 465d | finish no earlier than 2004-04-23 |  | S2 | 3720h | 3720h | QoS1 | Nortel | Claire Mousset | Rel-6 | Maurice | 23.917 withdrawn (Contents all in 23.207) |  |
| 1725 | 521.2 | Definition of the Gq interface |  | 214d? | 2003-07-01 A | 2004-04-23 A | 100% | 2003-07-01 | 2004-04-23 | 214d? | finish no earlier than 2004-04-23 |  | S2 | 1712h | 1712h | QoS1 |  | Janne Rinne | Rel-6 | Maurice | 23.207 |  |
| 1726 | 521.3 | Gq interface specification for Dynamic Policy control enhancements – Stage 3 |  | 334d | 2003-08-29 A | 2004-12-08 A | 100% | 2003-08-29 | 2004-12-08 | 334d | finish no earlier than 2004-12-08 |  | N3 | 2672h | 2672h | QoS1 | Nokia | Anna.Sillanpaai@nokia.com | Rel-6 | Gwiho | 29.207, 29.208, 29.209 |  |

Notes:
- 1701: -
- 1702: -
- 1703: -
- 1704: -
- 1705: Active contribution S3#24, S3#25. WID approved SP#17
- 1706: WID approved at CN#19
- 1707: -
- 1708: -
- 1709: -
- 1710: SP#28: delayed 09/2005. WT also under SA5 BB 35017 Charging Management for Bearer level
- 1711: -
- 1712: -
- 1713: -
- 1714: -
- 1715: -
- 1716: -
- 1717: -
- 1718: -
- 1719: -
- 1720: -
- 1721: -
- 1722: -
- 1723: -
- 1724: -
- 1725: -
- 1726: [DAB - 25.05.04] - Delayed to Sept - possibly Dec 2004

| ID | WBS | Task | Type | Duration | Start | Finish | Complete | Baseline start | Baseline finish | Baseline duration | Constraint | Resources | Work | Actual work | Text1 | Text4 | Text5 | Text6 | Text8 | Text10 | Text12 |
| --- | --- | --- | --- | --- | --- | --- | --- | --- | --- | --- | --- | --- | --- | --- | --- | --- | --- | --- | --- | --- | --- |
| 1727 | 36 | **Subscriber certificates** |  | 728d? | 2002-02-25 A | 2004-12-08 A | 100% | 2002-02-25 | 2004-12-08 | 728d? |  | S3,S2,N1,N4,T3,OMA | 12888h | 12888h | SEC1-SC | Nokia | valtteri.niemi@nokia.com | Rel-6 | Dionisio |  |  |
| 1728 | 36.1 | Stage 1 |  | 144d | 2002-02-25 A | 2002-09-12 A | 100% | 2002-02-25 | 2002-09-12 | 144d | finish no earlier than 2002-09-12 | S3 | 1152h | 1152h | SEC1-SC | Nokia | valtteri.niemi@nokia.com | Rel-6 | Dionisio |  |  |
| 1729 | 36.2 | Architecture review |  | 24d | 2002-10-14 A | 2002-11-14 A | 100% | 2002-10-14 | 2002-11-14 | 24d | finish no earlier than 2002-11-14 | S2 | 192h | 192h | SEC1-SC | Nokia |  | Rel-6 | Maurice |  |  |
| 1730 | 522.3 | Stage 3 |  | 313d? | 2003-09-19 A | 2004-11-30 A | 100% | 2003-09-19 | 2004-11-30 | 313d? | finish no earlier than 2004-11-30 | N4,T3 | 2504h | 2504h | SEC1-SC | Nokia | Lauri Laitinen | Rel-6 | Kimmo |  |  |
| 1731 | 522.4 | Stage 3 Ua & Ub interfaces |  | 288d? | 2003-11-03 A | 2004-12-08 A | 100% | 2003-11-03 | 2004-12-08 | 288d? | finish no earlier than 2004-12-08 | N1 | 2304h | 2304h | SEC1-SC | Nokia |  | Rel-6 | Frederic |  |  |
| 1732 | 522.5 | OMA dependencies on Subscriber certificates |  | 114d? | 2004-01-01 A | 2004-06-08 A | 100% | 2004-01-01 | 2004-06-08 | 114d? | finish no earlier than 2004-06-08 | OMA | 912h | 912h | SEC1-SC | Nokia | OMA-LIAISON@mail.openmobilealliance.org | Rel-6 |  | SP-24 |  |
| 1733 | 523 | **Rel-6 OSA enhancements** |  | 616d? | 2002-10-31 A | 2005-03-10 A | 100% | 2002-10-31 | 2005-03-10 | 616d? |  | N5 | 22576h | 22576h | OSA3 | Alcatel | Chelo.Abarca@alcatel.fr | Rel-6 | Kimmo |  |  |
| 1734 | 523.1 | Scope of the Open Service Access Release 6 |  | 66d? | 2003-03-28 A | 2003-06-27 A | 100% | 2003-03-28 | 2003-06-27 | 66d? | finish no earlier than 2003-06-27 | S1 | 528h | 528h | OSA3 |  |  | Rel-6 | Alain |  |  |
| 1735 | 523.2 | OSA Stage 2 |  | 150d? | 2004-08-13 A | 2005-03-10 A | 100% | 2004-08-13 | 2005-03-10 | 150d? | finish no earlier than 2005-03-10 | N5 | 1200h | 1200h | OSA3 |  |  | Rel-6 | Kimmo |  |  |
| 1736 | 523.3 | Multi Media Messaging function |  | 487d? | 2002-10-31 A | 2004-09-10 A | 100% | 2002-10-31 | 2004-09-10 | 487d? | finish no earlier than 2004-09-10 | N5 | 3896h | 3896h | OSA3 |  |  | Rel-6 | Kimmo |  |  |
| 1737 | 523.4 | Policy management extensions |  | 292d? | 2002-10-31 A | 2003-12-12 A | 100% | 2002-10-31 | 2003-12-12 | 292d? | finish no earlier than 2003-12-12 | N5 | 2336h | 2336h | OSA3 |  |  | Rel-6 | Kimmo |  |  |
| 1738 | 523.5 | TS on Presence and Availability Management (from the PRESNC WI) |  | 367d? | 2002-10-31 A | 2004-03-26 A | 100% | 2002-10-31 | 2004-03-26 | 367d? | finish no earlier than 2004-03-26 | N5 | 2936h | 2936h | OSA3 |  |  | Rel-6 | Kimmo |  |  |
| 1739 | 523.6 | OSA interfaces at different levels of abstractions (Parlay X, Web services) |  | 305d? | 2003-07-14 A | 2004-09-10 A | 100% | 2003-07-14 | 2004-09-10 | 305d? | finish no earlier than 2004-09-10 | N5 | 2440h | 2440h | OSA3 |  |  | Rel-6 | Kimmo |  |  |
| 1740 | 523.7 | Introduction of migration support mechanism |  | 290d? | 2002-10-31 A | 2003-12-10 A | 100% | 2002-10-31 | 2003-12-10 | 290d? | finish no earlier than 2003-12-12 | N5 | 2320h | 2320h | OSA3 |  |  | Rel-6 | Kimmo |  |  |
| 1741 | 523.8 | Framework Function for Federation |  | 225d? | 2003-02-03 A | 2003-12-12 A | 100% | 2003-02-03 | 2003-12-12 | 225d? | finish no earlier than 2003-12-12 | N5 | 1800h | 1800h | OSA3 |  |  | Rel-6 | Kimmo |  |  |
| 1742 | 523.9 | OMA potential overlaps with 3GPP OSA Stage 3 (Web services) |  | 196d? | 2003-12-18 A | 2004-09-16 A | 100% | 2003-12-18 | 2004-09-16 | 196d? | start no earlier than 2003-12-18 | OMA | 1568h | 1568h | OSA3 |  |  | Rel-6 |  | SP-24 |  |
| 1743 | 523.10 | Deleted - TR on Presence and Availability Management (from the PRESNC WI) | milestone | 0d? | 2004-09-17 A | 2004-09-17 A | 100% | 2004-09-17 | 2004-09-17 | 0d? | start no earlier than 2004-09-17 | N5 |  |  | OSA3 |  |  | Rel-6 | Kimmo |  | NP-24 |
| 1744 | 39 | **Addition of frequency bands to GSM (TAPS)** |  | 676d | 2002-06-28 A | 2005-01-28 A | 100% | 2002-06-28 | 2005-01-28 | 676d |  | GP | 16640h | 16640h | TAPS | Nokia | Torben Themsen | Rel-6 | Paolo |  |  |
| 1745 | 39.1 | **Addition of frequency bands to GSM – Changes to core specs** |  | 26d | 2002-11-15 A | 2002-12-20 A | 100% | 2002-11-15 | 2002-12-20 | 26d |  | G1 | 416h | 416h | TAPS-Specs | Nokia | Torben Themsen | Rel-6 | Paolo |  |  |
| 1746 | 39.1.1 | Changes to core specs |  | 26d | 2002-11-15 A | 2002-12-20 A | 100% | 2002-11-15 | 2002-12-20 | 26d | finish no earlier than 2002-12-20 | G1 | 208h | 208h | TAPS-Specs | Nokia | Torben Themsen | Rel-6 | Paolo |  |  |
| 1747 | 39.2 | **Deleted - Addition of frequency bands to GSM – Changes for conformance tests** |  | 676d | 2002-06-28 A | 2005-01-28 A | 100% | 2002-06-28 | 2005-01-28 | 676d |  | G4 | 10816h | 10816h | TAPS-Conf | Nokia | Torben Themsen | Rel-6 | Paolo |  | GP-23 |
| 1748 | 39.2.1 | Deleted - 51.010-1 Add testing |  | 676d | 2002-06-28 A | 2005-01-28 A | 100% | 2002-06-28 | 2005-01-28 | 676d | finish no earlier than 2005-01-28 | G4 | 5408h | 5408h | TAPS-Conf | Nokia | Torben Themsen | Rel-6 | Paolo |  | GP-23 |
| 1749 | 40 | **Seamless support of streaming services in A/Gb mode** |  | 1426d? | 2000-01-03 A | 2005-06-17 A | 100% | 2000-01-03 | 2005-06-17 | 1426d? |  | GP | 53096h | 53096h | SSStrea | Vodafone | José Luis Carrizo Martínez | Rel-6 | Paolo |  |  |
| 1750 | 40.1 | **Identification of requirements for streaming** |  | 46d? | 2003-06-27 A | 2003-08-29 A | 100% | 2003-06-27 | 2003-08-29 | 46d? |  | G1 | 736h | 736h | SSStrea | Vodafone | José Luis Carrizo Martínez | Rel-6 | Paolo |  |  |
| 1751 | 525.1.1 | Requirements |  | 46d? | 2003-06-27 A | 2003-08-29 A | 100% | 2003-06-27 | 2003-08-29 | 46d? | finish no earlier than 2003-08-29 | G1 | 368h | 368h | SSStrea | Vodafone | José Luis Carrizo Martínez | Rel-6 | Paolo |  |  |

Notes:
- 1727: Approved at SP#14. May require BBs from CN1, CN4, SA5 and T3
- 1728: Contribution received S3#24, S3#25 / Text3: 33.220, 33.221, 33.222, 33.246, new TR 33.919
- 1729: -
- 1730: Finished in CN4#26 / Text3: 23.003, 23.008, 29.109, 29.230, T3 31.102, 31.103, 31.111
- 1731: - / Text3: 24.109
- 1732: Updated according to SP-040420
- 1733: CN#25: Updated WID NP-040351 replaces NP-040144. / Text3: 22.127, 23.198, 29.198, 29.199, 29.998
- 1734: -
- 1735: Inherited by CN5 from SA2 at TSG#25 Sep 2004. SA2's 23.127 (OSA/VHE Stage 2) replaced from Rel-6 onwards by a new CN5 TS 23.198 (Stage 2 OSA-only). / Text3: 23.198 OSA Stage 2-ONLY replaces 23.127 (OSA/VHE) from Rel-6 onwards
- 1736: - / Text3: 29.198-15
- 1737: - / Text3: 29.198, 29.998
- 1738: N5#26: Split WI into TS & TR. / Text3: 29.198-14
- 1739: - / Text3: 29.199
- 1740: - / Text3: 29.198, 29.998
- 1741: - / Text3: 29.198, 29.998
- 1742: TSG#25 Approved CN5 29.199 Parlay X Web services. Ongoing 3GPP/OMA co-ordination to avoid OMA producing conflicting/OVERLAPING specs (NP-040283/SP-040493).
- 1743: N5#26:TR Completion 09/04; consistent with CN1 delayed Rel-6 completion.
- 1744: -
- 1745: -
- 1746: -
- 1747: -
- 1748: -
- 1749: -
- 1750: -
- 1751: -

| ID | WBS | Task | Duration | Start | Finish | Complete | Baseline start | Baseline finish | Baseline duration | Constraint | Resources | Work | Actual work | Text1 | Text4 | Text5 | Text6 | Text8 | Text12 | Text3 |
| --- | --- | --- | --- | --- | --- | --- | --- | --- | --- | --- | --- | --- | --- | --- | --- | --- | --- | --- | --- | --- |
| 1752 | 40.2 | **Performance study of cell change mechanisms** | 956d? | 2000-01-03 A | 2003-08-29 A | 100% | 2000-01-03 | 2003-08-29 | 956d? |  | G1 | 30568h | 30568h | SSStrea | Vodafone | José Luis Carrizo Martínez | Rel-6 | Paolo |  |  |
| 1753 | 525.2.1 | Performance of NACC | 956d? | 2000-01-03 A | 2003-08-29 A | 100% | 2000-01-03 | 2003-08-29 | 956d? | finish no earlier than 2003-08-29 | G1 | 7640h | 7640h | SSStrea | Vodafone | José Luis Carrizo Martínez | Rel-6 | Paolo |  |  |
| 1754 | 525.2.2 | Performance of cell change in DTM for the PS domain | 956d? | 2000-01-03 A | 2003-08-29 A | 100% | 2000-01-03 | 2003-08-29 | 956d? | finish no earlier than 2003-08-29 | G1 | 7640h | 7640h | SSStrea | Vodafone | José Luis Carrizo Martínez | Rel-6 | Paolo |  |  |
| 1755 | 525.2.3 | Handover | 956d? | 2000-01-03 A | 2003-08-29 A | 100% | 2000-01-03 | 2003-08-29 | 956d? | finish no earlier than 2003-08-29 | G1 | 7640h | 7640h | SSStrea | Vodafone | José Luis Carrizo Martínez | Rel-6 | Paolo |  |  |
| 1756 | 40.3 | **Reduction of service interruption times and packet loss during mobility procedures** | 516d? | 2003-06-27 A | 2005-06-17 A | 100% | 2003-06-27 | 2005-06-17 | 516d? |  | G2 | 10800h | 10800h | SSStrea | Vodafone | José Luis Carrizo Martínez | Rel-6 | Gert |  |  |
| 1757 | 525.3.1 | optimizations of existing mechanisms/procedures | 106d? | 2003-06-27 A | 2003-11-21 A | 100% | 2003-06-27 | 2003-11-21 | 106d? | finish no earlier than 2003-11-21 | G2 | 848h | 848h | SSStrea | Vodafone | José Luis Carrizo Martínez | Rel-6 | Gert |  |  |
| 1758 | 525.3.2 | Inter-system NACC | 106d? | 2003-06-27 A | 2003-11-21 A | 100% | 2003-06-27 | 2003-11-21 | 106d? | finish no earlier than 2003-11-21 | G2 | 848h | 848h | SSStrea | Vodafone | José Luis Carrizo Martínez | Rel-6 | Gert |  |  |
| 1759 | 525.3.3 | PS Handover (within GERAN and between GERAN and UTRAN) | 516d? | 2003-06-27 A | 2005-06-17 A | 100% | 2003-06-27 | 2005-06-17 | 516d? | finish no earlier than 2003-11-21 | G2 | 4128h | 4128h | SSStrea | Vodafone | José Luis Carrizo Martínez | Rel-6 | Gert |  |  |
| 1760 | 525.3.4 | Dependency to other features | 106d? | 2003-06-27 A | 2003-11-21 A | 100% | 2003-06-27 | 2003-11-21 | 106d? | finish no earlier than 2003-11-21 | G2 | 848h | 848h | SSStrea | Vodafone | José Luis Carrizo Martínez | Rel-6 | Gert |  |  |
| 1761 | 40.5 | **Deleted - MS conformance testing** | 31d? | 2003-12-19 A | 2004-01-30 A | 100% | 2003-12-19 | 2004-01-30 | 31d? |  | G3new | 248h | 248h | SSStrea | Vodafone | José Luis Carrizo Martínez | Rel-6 | Ingbert | GP-27 |  |
| 1762 | 525.4.1 | Deleted - MS conformance tests | 31d? | 2003-12-19 A | 2004-01-30 A | 100% | 2003-12-19 | 2004-01-30 | 31d? | finish no earlier than 2004-01-30 | G4,G5 | 248h | 248h | SSStrea | Vodafone | José Luis Carrizo Martínez | Rel-6 | Ingbert | GP-27 |  |
| 1763 | 525.5 | GERAN A/Gb mode security enhancements | 612d? | 2002-09-26 A | 2005-01-28 A | 100% | 2002-09-26 | 2005-01-28 | 612d? | finish no earlier than 2005-01-28 | S3 | 4896h | 4896h | SSStrea | Vodafone | peter.howard@vodafone.com | Rel-6 | Dionisio |  | 33.102 |
| 1764 | 41 | Performance characterisation of default codecs for PS conversational multimedia application | 455d | 2002-09-13 A | 2004-06-10 A | 100% | 2002-09-13 | 2004-06-10 | 455d | finish no earlier than 2004-06-10 | S4 | 3640h | 3640h | CODCAR | Nokia | pasi.s.ojala@nokia.com | Rel-6 | Paolo |  | 26.935 |
| 1765 | 43 | Study on Privacy Capability | 83d | 2003-11-10 A | 2004-03-03 A | 100% | 2003-11-10 | 2004-03-03 | 83d | start no earlier than 2003-11-10 | S1 | 664h | 664h | PrivCap | Lucent | Michael Boote (mboote@alcatel-lucent.com) | Rel-6 | Alain |  | 22.949 |
| 1766 | 44 | **OAM&P Rel-6** | 652d? | 2002-09-12 A | 2005-03-11 A | 100% | 2002-09-12 | 2005-03-11 | 652d? |  | S5 | 30819.5h | 30819.5h | OAM | Motorola |  | Rel-6 | Dionisio |  |  |
| 1767 | 44.1 | Principles, high level Requirements and Architecture | 526d | 2002-09-12 A | 2004-09-16 A | 100% | 2002-09-12 | 2004-09-16 | 526d | finish no earlier than 2004-09-16 | S5 | 4208h | 4208h | OAM-AR | Motorola |  | Rel-6 | Dionisio |  | 32.101, 32.102 |
| 1768 | 44.2 | Performance Management | 591d | 2002-09-12 A | 2004-12-16 A | 100% | 2002-09-12 | 2004-12-16 | 591d | finish no earlier than 2004-12-16 | S5 | 4728h | 4728h | OAM-PM | Nortel |  | Rel-6 | Dionisio |  | 32.401/3, 52.402, 32.411/2/3, 32.432/5/6 |
| 1769 | 44.4 | Network Infrastructure Management | 591d | 2002-09-12 A | 2004-12-16 A | 100% | 2002-09-12 | 2004-12-16 | 591d | finish no earlier than 2004-12-16 | S5 | 4728h | 4728h | OAM-NIM | Ericsson | thomas.tovinger@ericsson.com | Rel-6 | Dionisio |  | 32.15x, 32.3/6/7xy |
| 1770 | 44.5 | **Trace Management Rel-6** | 646d? | 2002-09-20 A | 2005-03-11 A | 100% | 2002-09-20 | 2005-03-11 | 646d? |  | S5 | 12061.9h | 12061.9h | OAM-Trace | Nokia | kari.t.ronka@nokia.com | Rel-6 | Dionisio |  | 32.42x, 52.008 |
| 1771 | 528.4.1 | Subscriber and UE trace management | 585d | 2002-09-20 A | 2004-12-16 A | 100% | 2002-09-20 | 2004-12-16 | 585d | finish no earlier than 2004-12-16 | S5 | 4680h | 4680h | OAM-Trace | Nokia | kari.t.ronka@nokia.com | Rel-6 | Dionisio |  | 32.421/2/3, 52.008 |
| 1772 | 528.4.2 | Subscriber and equipment trace in UTRAN | 268d? | 2003-06-06 A | 2004-06-15 A | 100% | 2003-06-06 | 2004-06-15 | 268d? | finish no earlier than 2004-06-15 | R3 | 2144h | 2144h | OAM-Trace-RAN | Nortel | Yann Sehedi (sehedic@nortelnetworks.com) | Rel-6 | Juha |  | 25.413, 25.420, 25.423 |
| 1773 | 528.4.3 | Trace Management, Stage3 | 193.74d? | 2004-06-09 A | 2005-03-11 A | 100% | 2004-06-09 | 2005-03-11 | 193.74d? | finish no earlier than 2005-03-11 | N4 | 1549.92h | 1549.92h | OAM-Trace | Nokia | seppo.kauntola@nokia.com | Rel-6 | Kimmo |  | 23.205, 29.232, 29.060, 29.002, 29.228 |
| 1774 | 529 | **Charging Management** | 666d? | 2002-11-21 A | 2005-06-09 A | 100% | 2002-11-21 | 2005-06-09 | 666d? |  | S5 | 55320h | 55320h | CH | T-Mobile | karl-heinz.nenner@t-mobile.de | Rel-6 | Dionisio |  | 32.2xy |
| 1775 | 529.1 | Charging architecture and principles | 390d? | 2003-03-21 A | 2004-09-16 A | 100% | 2003-03-21 | 2004-09-16 | 390d? | start no earlier than 2003-03-21 | S5 | 3120h | 3120h | CH |  |  | Rel-6 | Dionisio |  | 32.240 |
| 1776 | 529.2 | Charging Data Record (CDR) file format and transfer | 260d? | 2003-03-21 A | 2004-03-18 A | 100% | 2003-03-21 | 2004-03-18 | 260d? | start no earlier than 2003-03-21 | S5 | 2080h | 2080h | CH |  |  | Rel-6 | Dionisio |  | 32.297 |
| 1777 | 529.3 | CDR parameter description | 580d? | 2003-03-21 A | 2005-06-09 A | 100% | 2003-03-21 | 2005-06-09 | 580d? | finish no earlier than 2005-06-09 | S5 | 4640h | 4640h | CH |  |  | Rel-6 | Dionisio |  | 32.298 |
| 1778 | 529.4 | Diameter charging applications | 390d? | 2003-03-21 A | 2004-09-16 A | 100% | 2003-03-21 | 2004-09-16 | 390d? | start no earlier than 2003-03-21 | S5 | 3120h | 3120h | CH |  |  | Rel-6 | Dionisio |  | 32.299 |
| 1779 | 529.5 | Online Charging System (OCS) architecture study | 130d? | 2003-03-21 A | 2003-09-18 A | 100% | 2003-03-21 | 2003-09-18 | 130d? | start no earlier than 2003-03-21 | S5 | 1040h | 1040h | CH |  |  | Rel-6 | Dionisio |  | 32.815 |
| 1780 | 529.6 | OCS: Applications and interfaces | 455d? | 2003-03-21 A | 2004-12-16 A | 100% | 2003-03-21 | 2004-12-16 | 455d? | start no earlier than 2003-03-21 | S5 | 3640h | 3640h | CH |  |  | Rel-6 | Dionisio |  | 32.296 |

Notes:
- 1752: -
- 1753: -
- 1754: -
- 1755: -
- 1756: Completed at GERP#17
- 1757: -
- 1758: -
- 1759: -
- 1760: -
- 1761: Marked as stopped 10/2009
- 1762: Marked as stopped 10/2009
- 1763: Possible changes to 33.102 or new specification needed
- 1764: -
- 1765: -
- 1766: SP#26: Updated WID SP-040766 was SP-020445. Completion delayed 12/04->03/05 due to OAM-Trace in CN1/4.
- 1767: SP#25 09/2004 completed
- 1768: SP#26 12/2004 completed
- 1769: SP#26 12/2004 completed
- 1770: SP#26 12/2004 SA5 completed 12/04. Signalling Based Trace Activation for IMS (SIP) moved to Rel-7. Reason: CN1 cannot complete 24.229 trace without IETF dependency => estimate 05/2005.
- 1771: SP#26 12/2004 completed
- 1772: -
- 1773: -
- 1774: SP#28 Target 09/2005 for WLAN Charging 32.252
- 1775: SP#25 09/2004 completed
- 1776: SP#23 03/2004 completed
- 1777: SP#28 06/2005 completed
- 1778: SP#25 09/2004 completed
- 1779: SP#21 09/2003 completed
- 1780: SP#26 12/2004 completed

| ID | WBS | Task | Duration | Start | Finish | Complete | Baseline start | Baseline finish | Baseline duration | Constraint | Resources | Work | Actual work | Text1 | Text4 | Text5 | Text6 | Text8 | Text10 | Text12 |
| --- | --- | --- | --- | --- | --- | --- | --- | --- | --- | --- | --- | --- | --- | --- | --- | --- | --- | --- | --- | --- |
| 1781 | 529.7 | **Charging Management for Bearer level** | 390d? | 2003-03-21 A | 2004-09-16 A | 100% | 2003-03-21 | 2004-09-16 | 390d? |  | S5 | 11440h | 11440h | CH-BC | Nokia | Benni ALEXANDER | Rel-6 | Dionisio |  |  |
| 1782 | 529.7.1 | CS domain charging | 260d? | 2003-03-21 A | 2004-03-18 A | 100% | 2003-03-21 | 2004-03-18 | 260d? | start no earlier than 2003-03-21 | S5 | 2080h | 2080h | CH |  |  | Rel-6 | Dionisio |  |  |
| 1783 | 529.7.2 | PS domain charging | 390d? | 2003-03-21 A | 2004-09-16 A | 100% | 2003-03-21 | 2004-09-16 | 390d? | start no earlier than 2003-03-21 | S5 | 3120h | 3120h | CH |  |  | Rel-6 | Dionisio |  |  |
| 1784 | 529.7.3 | CDR transfer | 390d? | 2003-03-21 A | 2004-09-16 A | 100% | 2003-03-21 | 2004-09-16 | 390d? | start no earlier than 2003-03-21 | S5 | 3120h | 3120h | CH |  |  | Rel-6 | Dionisio |  |  |
| 1785 | 529.8 | Charging Management for the IMS | 455d? | 2003-03-21 A | 2004-12-16 A | 100% | 2003-03-21 | 2004-12-16 | 455d? | finish no earlier than 2004-12-16 | S5 | 3640h | 3640h | IMS2-CH | Ericsson | Patrik TEPPO | Rel-6 | Dionisio |  |  |
| 1786 | 529.9 | Charging Management for the Service domain | 580d? | 2003-03-21 A | 2005-06-09 A | 100% | 2003-03-21 | 2005-06-09 | 580d? | finish no earlier than 2005-06-09 | S5 | 4640h | 4640h | CH | Siemens | Gerald.Goermer@nsn.com | Rel-6 | Dionisio |  |  |
| 1787 | 529.10 | **Overall architectural aspects of IP flow based bearer level charging** | 602d? | 2002-11-21 A | 2005-03-11 A | 100% | 2002-11-21 | 2005-03-11 | 602d? |  | S2 | 12632h | 12632h | CH-FBC |  |  | Rel-6 | Maurice |  |  |
| 1788 | 529.10.1 | Overall definition of FBC architecture | 334d? | 2002-11-21 A | 2004-03-02 A | 100% | 2002-11-21 | 2004-03-02 | 334d? | start no earlier than 2002-11-21 | S2 | 2672h | 2672h | CH-FBC |  |  | Rel-6 | Maurice | SP-24 |  |
| 1789 | 529.10.2 | Study on providing policy control with FBC | 130d? | 2004-02-02 A | 2004-07-30 A | 100% | 2004-02-02 | 2004-07-30 | 130d? | start no earlier than 2004-02-01 | S2 | 1040h | 1040h | CH-FBC |  |  | Rel-6 | Maurice | SP-24 |  |
| 1790 | 529.10.3 | Gx interface for flow based charging | 223d? | 2004-02-02 A | 2004-12-08 A | 100% | 2004-02-02 | 2004-12-08 | 223d? | start no earlier than 2004-02-01 | N3 | 1784h | 1784h | CH-FBC | Nokia | juha.a.rasanen@nokia.com | Rel-6 | Gwiho | SP-25 |  |
| 1791 | 529.10.4 | Rx interface for flow based charging | 290d? | 2004-02-02 A | 2005-03-11 A | 100% | 2004-02-02 | 2005-03-11 | 290d? | finish no earlier than 2005-03-11 | N3 | 2320h | 2320h | CH-FBC | Nortel | Javier Gonzalez Gallego | Rel-6 | Gwiho | SP-25 |  |
| 1792 | 13 | **Rel-6 UICC/USIM enhancements and interworking** | 1164d? | 2000-09-25 A | 2005-03-10 A | 100% | 2000-09-25 | 2005-03-10 | 1164d? |  | T3 | 43088h | 43088h | USAT1 |  |  | Rel-6 | Xavier |  |  |
| 1793 | 13.1 | **UICC API** | 777d | 2002-03-20 A | 2005-03-10 A | 100% | 2002-03-20 | 2005-03-10 | 777d |  | T3 | 15024h | 15024h | USAT1-API |  |  | Rel-6 | Xavier |  |  |
| 1794 | 13.1.1 | Java API Test specification | 59d | 2002-03-20 A | 2002-06-10 A | 100% | 2002-03-20 | 2002-06-10 | 59d | finish no earlier than 2002-09-20 | T3 | 472h | 472h | USAT1-API | Microelectrónica Española | Mario Pérez | Rel-6 | Xavier |  |  |
| 1795 | 530.1.2 | 2G/3G Java Card™ API based applet interworking | 255d | 2003-03-17 A | 2004-03-05 A | 100% | 2003-03-17 | 2004-03-05 | 255d | finish no earlier than 2004-02-19 | T3 | 2040h | 2040h | USAT1-API | Oberthur Card Systems | Stéphane Andrau | Rel-6 | Xavier |  |  |
| 1796 | 530.1.3 | (U)SIM API for Java Card Testing | 519d | 2003-03-17 A | 2005-03-10 A | 100% | 2003-03-17 | 2005-03-10 | 519d | finish no earlier than 2005-03-10 | T3 | 4152h | 4152h | USAT1-API | Axalto | Christophe Begassat (cbegassat@axalto.com) | Rel-6 | Xavier |  |  |
| 1797 | 13.1.2 | Deleted - Java API Test specification (TS 43.019 Rel-5) | 268d | 2002-05-30 A | 2003-06-09 A | 100% | 2002-05-30 | 2003-06-09 | 268d | finish no earlier than 2003-09-17 | T3 | 2144h | 2144h | USAT1-API | Microelectrónica Española | Mario Pérez | Rel-6 | Xavier |  | TP-20 |
| 1798 | 530.2 | **Rel-6 USIM toolkit enhancements** | 1160d? | 2000-09-25 A | 2005-03-04 A | 100% | 2000-09-25 | 2005-03-04 | 1160d? |  | T3 | 21848h | 21848h | USAT1-API-MULTOS | Aspects Software | Neil Livingston | Rel-6 | Xavier |  |  |
| 1799 | 530.2.1 | **C SIM API** | 525d | 2000-09-25 A | 2002-09-27 A | 100% | 2000-09-25 | 2002-09-27 | 525d |  | T3 | 9960h | 9960h | USAT1-API-MULTOS | Aspects Software | Neil Livingston | Rel-6 | Xavier |  |  |
| 1800 | 530.2.1.1 | Specification | 525d | 2000-09-25 A | 2002-09-27 A | 100% | 2000-09-25 | 2002-09-27 | 525d | finish no earlier than 2002-09-27 | T3 | 4200h | 4200h | USAT1-API-MULTOS | Aspects Software | Neil Livingston | Rel-6 | Xavier |  |  |
| 1801 | 530.2.1.2 | Test specification | 195d | 2001-01-01 A | 2001-09-28 A | 100% | 2001-01-01 | 2001-09-28 | 195d | finish no earlier than 2001-09-28 | T3 | 1560h | 1560h | USAT1-API-MULTOS | Aspects Software | Neil Livingston | Rel-6 | Xavier |  |  |
| 1802 | 530.2.2 | USIM application toolkit Conformance Test Specification for Mobile Equipments | 326d? | 2003-12-05 A | 2005-03-04 A | 100% | 2003-12-05 | 2005-03-04 | 326d? | start no earlier than 2003-12-05 | T3 | 2608h | 2608h | USAT1-API-MULTOS | Gemplus | Eric.laffont@gemplus.com | Rel-6 | Xavier |  |  |
| 1803 | 531 | **Packet Switched Streaming Services Rel-6** | 798d? | 2002-11-18 A | 2005-12-07 A | 100% | 2002-11-18 | 2005-12-07 | 798d? |  | S4,S1 | 13304h | 13304h | PSSrel6 | Ericsson | olle.franceschi@ericsson.com | Rel-6 | Paolo |  |  |
| 1804 | 531.1 | Stage 1 | 86d? | 2002-11-18 A | 2003-03-17 A | 100% | 2002-11-18 | 2003-03-17 | 86d? | finish no earlier than 2003-03-17 | S1 | 688h | 688h | PSSrel6 | Ericsson |  | Rel-6 | Alain |  |  |
| 1805 | 531.2 | Stage 3 | 779d? | 2002-12-13 A | 2005-12-07 A | 100% | 2002-12-13 | 2005-12-07 | 779d? | finish no earlier than 2005-12-07 | S4 | 6232h | 6232h | PSSrel6-Stage3 | Ericsson | olle.franceschi@ericsson.com | Rel-6 | Paolo |  |  |
| 1806 | 532 | AMR-WB extension for high audio quality | 779d | 2002-12-13 A | 2005-12-07 A | 100% | 2002-12-13 | 2005-12-07 | 779d | finish no earlier than 2005-12-07 | S4 | 6232h | 6232h | AMRWB+ | Nokia | janne.m.vainio@nokia.com | Rel-6 | Paolo |  |  |
| 1807 | 533 | Codec Enhancements for Packet Switched Conversational Multimedia Applications | 198d? | 2004-03-16 A | 2004-12-16 A | 100% | 2004-03-16 | 2004-12-16 | 198d? | finish no earlier than 2004-12-16 | S4 | 1584h | 1584h | CEPSCM | Nokia | miska.hannuksela@nokia.com | Rel-6 | Paolo |  |  |
| 1808 | 534 | 3G-324M Improvements | 198d? | 2004-03-16 A | 2004-12-16 A | 100% | 2004-03-16 | 2004-12-16 | 198d? | finish no earlier than 2004-12-16 | S4 | 1584h | 1584h | 3G-324MI | Ericsson | bo.burman@ericsson.com | Rel-6 | Paolo |  |  |
| 1809 | 535 | Single Antenna Receiver Interference Cancellation (SAIC) | 420.92d? | 2002-11-15 A | 2004-06-25 A | 100% | 2002-11-15 | 2004-06-25 | 420.92d? | finish no earlier than 2004-08-27 | GP,G1 | 3367.36h | 3367.36h | SAIC | Cingular | Marc Grant | Rel-6 | Paolo |  |  |

Notes:
- 1781: SP#28 Target 09/2005 for WLAN Charging 32.252
- 1782: SP#23 03/2004 completed / Text3: 32.250
- 1783: SP#25 09/2004 completed / Text3: 32.251
- 1784: SP#25 09/2004 completed / Text3: 32.295
- 1785: SP#26 12/2004 completed / Text3: 32.260
- 1786: SP#26: Updated WID SP-040778 was SP-030050. Target completion 06/2005. Consisting of MMS-CH, LCS-CH, WLAN-CH, POC-CH, MBMS-CH / Text3: 32.252, 32.270, 32.271, 32.272
- 1787: - / Text3: 23.125
- 1788: -
- 1789: -
- 1790: - / Text3: 29.210
- 1791: - / Text3: 29.209
- 1792: -
- 1793: 8/3/2001: test spec is based on R99 core spec, so deleted from Workplan
- 1794: -
- 1795: -
- 1796: - / Text3: 31.213
- 1797: MOVED to Rel-5 WP
- 1798: -
- 1799: - / Text3: 31.101, 31.102, 31.103, 31.111, 31.113, new 31.115, 31.116
- 1800: -
- 1801: -
- 1802: - / Text3: 31.124
- 1803: -
- 1804: 2nd resp SA4 / Text3: 22.233
- 1805: TR tbc by Sept. 05 / Text3: 26.233, 26.234, 26.244, 26.245, 26.246, 26.401, 26.402, 26.403, 26.404, 26.405, 26.406, 26.410, 26.411, 26.412, 26.273, 26.290, 26.304, 26.412, 26.274, 26.936
- 1806: TR tbc by Sept. 05 / Text3: 26.290, 26.304, 26.273, 26.274, 26.412, 26.936
- 1807: - / Text3: 26.235, 26.236
- 1808: - / Text3: 26.111, 26.911
- 1809: - / Text3: 45.903

| ID | WBS | Task | Type | Duration | Start | Finish | Complete | Baseline start | Baseline finish | Baseline duration | Constraint | Resources | Work | Actual work | Text1 | Text3 | Text4 | Text5 | Text6 | Text8 | Text12 |
| --- | --- | --- | --- | --- | --- | --- | --- | --- | --- | --- | --- | --- | --- | --- | --- | --- | --- | --- | --- | --- | --- |
| 1810 | 536 | **Enhancement of dialled service for CAMEL** |  | 199d | 2003-03-28 A | 2003-12-31 A | 100% | 2003-03-28 | 2003-12-31 | 199d |  | S1,N2,N4 | 3184h | 3184h | EDCAMEL | 22.078 | Samsung | Craig Bishop | Rel-6 | Alain |  |
| 1811 | 536.1 | Stages 2 and 3 |  | 199d | 2003-03-28 A | 2003-12-31 A | 100% | 2003-03-28 | 2003-12-31 | 199d | finish no earlier than 2003-09-19 | N2,N4 | 1592h | 1592h | EDCAMEL | 23.008, 23.016, 23.018, 23.078, 29.002, 29.078 | Samsung | Richard Brook | Rel-6 | Kimmo |  |
| 1812 | 537 | Study on Bandwidth and resource savings in CS networks |  | 273d? | 2003-06-01 A | 2004-06-16 A | 100% | 2003-06-01 | 2004-06-16 | 273d? | finish no earlier than 2004-06-16 | S2 | 2184h | 2184h | BARS | 23.977 |  |  | Rel-6 | Maurice |  |
| 1813 | 538 | FS on (U)SIM Security Reuse by Peripheral Devices on Local Interfaces |  | 127d? | 2003-07-03 A | 2003-12-26 A | 100% | 2003-07-03 | 2003-12-26 | 127d? | finish no earlier than 2003-12-26 | S3 | 1016h | 1016h |  | 33.817 | Toshiba | Raziq Yaqub (ryaqub@tari.toshiba.com) | Rel-6 | Dionisio |  |
| 1814 | 539 | **Multiple TBF in A/Gb mode** |  | 736d? | 2002-04-05 A | 2005-01-28 A | 100% | 2002-04-05 | 2005-01-28 | 736d? |  | GP,G2 | 17600h | 17600h | MULTBF |  | Ericsson | gunnar.mildh@era.ericsson.se | Rel-6 | Paolo |  |
| 1815 | 539.1 | **Multiple TBF in A/Gb mode** |  | 366d? | 2002-04-05 A | 2003-08-29 A | 100% | 2002-04-05 | 2003-08-29 | 366d? |  | GP,G2 | 11712h | 11712h | MULTBF-Agbmode |  | Ericsson | gunnar.mildh@era.ericsson.se | Rel-6 | Paolo |  |
| 1816 | 539.1.1 | Multiple TBF Concept paper |  | 366d? | 2002-04-05 A | 2003-08-29 A | 100% | 2002-04-05 | 2003-08-29 | 366d? | finish no earlier than 2003-08-29 | GP,G2 | 2928h | 2928h | MULTBF-Agbmode |  |  |  | Rel-6 | Paolo |  |
| 1817 | 539.1.2 | Multiple TBF Stage 2 (43.064) CRs |  | 366d? | 2002-04-05 A | 2003-08-29 A | 100% | 2002-04-05 | 2003-08-29 | 366d? | finish no earlier than 2003-08-29 | GP,G2 | 2928h | 2928h | MULTBF-Agbmode |  |  |  | Rel-6 | Paolo |  |
| 1818 | 539.1.3 | Multiple TBF Stage 3 (44.060) CRs |  | 366d? | 2002-04-05 A | 2003-08-29 A | 100% | 2002-04-05 | 2003-08-29 | 366d? | finish no earlier than 2003-08-29 | GP,G2 | 2928h | 2928h | MULTBF-Agbmode |  |  |  | Rel-6 | Paolo |  |
| 1819 | 539.2 | Deleted - Multiple TBF in A/Gb mode – MS testing | milestone | 0d? | 2005-01-28 A | 2005-01-28 A | 100% | 2005-01-28 | 2005-01-28 | 0d? | start no earlier than 2005-01-28 | G3new |  |  | MULTBF-Testing |  | Ericsson | gunnar.mildh@era.ericsson.se | Rel-6 | Paolo | GP-27 |
| 1820 | 540 | **Alignment between the test-regimes for GERAN capable MS** |  | 526d? | 2003-08-29 A | 2005-09-02 A | 100% | 2003-08-29 | 2005-09-02 | 526d? |  | G3new | 4208h | 4208h | ALTERE |  | Ericsson | Toubassi | Rel-6 | Ingbert |  |
| 1821 | 540.1 | Determine the controversial test cases in the different test regimes and align them with 3GPP GERAN test specifications. Such test cases to be added to TS 51.010. |  | 526d? | 2003-08-29 A | 2005-09-02 A | 100% | 2003-08-29 | 2005-09-02 | 526d? | finish no earlier than 2005-09-02 | G3new | 4208h | 4208h | ALTERE-TC |  |  |  | Rel-6 | Ingbert |  |
| 1822 | 541 | Addition of U-TDOA in the CS domain |  | 111d? | 2003-11-21 A | 2004-04-23 A | 100% | 2003-11-21 | 2004-04-23 | 111d? | finish no earlier than 2004-04-23 | GP | 888h | 888h | UTDOACS |  | TruePosition | Bob Gross, Rhys Robinson (rlgross@trueposition.com) | Rel-6 | Paolo |  |
| 1823 | 542 | Addition of U-TDOA in the PS domain |  | 361d? | 2003-06-27 A | 2004-11-12 A | 100% | 2003-06-27 | 2004-11-12 | 361d? | finish no earlier than 2004-11-12 | GP | 2888h | 2888h | UTDOAPS |  | TruePosition | Bob Gross, Rhys Robinson (rlgross@trueposition.com) | Rel-6 | Paolo |  |
| 1824 | 543 | **Downlink Advanced Receiver Performance** |  | 466d? | 2003-11-21 A | 2005-09-02 A | 100% | 2003-11-21 | 2005-09-02 | 466d? |  | GP | 19160h | 19160h | DARP |  | Nokia | tommy.bysted@nokia.com | Rel-6 | Paolo |  |
| 1825 | 543.1 | DARP test scenarios |  | 201d? | 2003-11-21 A | 2004-08-27 A | 100% | 2003-11-21 | 2004-08-27 | 201d? | finish no earlier than 2004-08-27 | GP | 1608h | 1608h | DARP-TS |  | Nokia | tommy.bysted@nokia.com | Rel-6 | Paolo |  |
| 1826 | 543.2 | **DARP for GMSK modulated voice services** |  | 201d? | 2004-02-06 A | 2004-11-12 A | 100% | 2004-02-06 | 2004-11-12 | 201d? |  | GP | 4824h | 4824h | DARP-GMSK |  | Nokia | tommy.bysted@nokia.com | Rel-6 | Paolo |  |
| 1827 | 543.2.1 | Performance requirements in 45.005 |  | 201d? | 2004-02-06 A | 2004-11-12 A | 100% | 2004-02-06 | 2004-11-12 | 201d? | finish no earlier than 2004-11-12 | GP | 1608h | 1608h | DARP-GMSK-Perf |  |  |  | Rel-6 | Paolo |  |
| 1828 | 543.2.2 | Radio subsystem link control in 45.008 |  | 201d? | 2004-02-06 A | 2004-11-12 A | 100% | 2004-02-06 | 2004-11-12 | 201d? | finish no earlier than 2004-11-12 | GP | 1608h | 1608h | DARP-GMSK-LC |  |  |  | Rel-6 | Paolo |  |
| 1829 | 543.3 | **DARP for GPRS and EGPRS MCS1-MCS4** |  | 201d? | 2004-02-06 A | 2004-11-12 A | 100% | 2004-02-06 | 2004-11-12 | 201d? |  | GP | 4824h | 4824h | DARP-GPRSE |  | Nokia | tommy.bysted@nokia.com | Rel-6 | Paolo |  |
| 1830 | 543.3.1 | Performance requirements in 45.005 |  | 201d? | 2004-02-06 A | 2004-11-12 A | 100% | 2004-02-06 | 2004-11-12 | 201d? | finish no earlier than 2004-11-12 | GP | 1608h | 1608h | DARP-GPRSE-Perf |  |  |  | Rel-6 | Paolo |  |
| 1831 | 543.3.2 | Radio subsystem link control in 45.008 |  | 201d? | 2004-02-06 A | 2004-11-12 A | 100% | 2004-02-06 | 2004-11-12 | 201d? | finish no earlier than 2004-11-12 | GP | 1608h | 1608h | DARP-GPRSE-LC |  |  |  | Rel-6 | Paolo |  |
| 1832 | 543.4 | DARP Capability signalling |  | 256d? | 2003-11-21 A | 2004-11-12 A | 100% | 2003-11-21 | 2004-11-12 | 256d? | finish no earlier than 2004-11-12 | GP | 2048h | 2048h | DARP-CAPSIG |  | Nokia | tommy.bysted@nokia.com | Rel-6 | Paolo |  |
| 1833 | 543.5 | GERAN MS Conformance test for DARP |  | 266d? | 2004-08-27 A | 2005-09-02 A | 100% | 2004-08-27 | 2005-09-02 | 266d? | finish no earlier than 2005-06-24 | G3new | 2128h | 2128h | ARP-ConfTest |  | Nokia | tommy.bysted@nokia.com | Rel-6 | Ingbert |  |

Notes:
- 1810: -
- 1811: -
- 1812: -
- 1813: Approved TSG#20
- 1814: GP#17 Nov 2003 Moved from Rel-5 UID_50058 MULTBF (Only Multiple TBF Concept paper produced in Rel-5)
- 1815: -
- 1816: -
- 1817: -
- 1818: -
- 1819: -
- 1820: -
- 1821: -
- 1822: Completed, except for potential LMU performance specs
- 1823: -
- 1824: -
- 1825: -
- 1826: -
- 1827: -
- 1828: -
- 1829: -
- 1830: -
- 1831: -
- 1832: -
- 1833: -

| ID | WBS | Task | Type | Duration | Start | Finish | Complete | Baseline start | Baseline finish | Baseline duration | Constraint | Resources | Work | Actual work | Text1 | Text4 | Text5 | Text6 | Text8 | Text12 | Text3 | Text10 |
| --- | --- | --- | --- | --- | --- | --- | --- | --- | --- | --- | --- | --- | --- | --- | --- | --- | --- | --- | --- | --- | --- | --- |
| 1834 | 544 | **Reduction of PS service interruption in Dual Transfer Mode** |  | 416d? | 2003-11-21 A | 2005-06-24 A | 100% | 2003-11-21 | 2005-06-24 | 416d? |  | G2 | 8360h | 8360h | PSintDTM | Siemens | toby.proctor@roke.co.uk | Rel-6 | Gert |  |  |  |
| 1835 | 544.1 | Use case and requirement definition |  | 111d? | 2003-11-21 A | 2004-04-23 A | 100% | 2003-11-21 | 2004-04-23 | 111d? | finish no earlier than 2004-04-23 | G2 | 888h | 888h | PSintDTM-Req | Siemens | toby.proctor@roke.co.uk | Rel-6 | Gert |  |  |  |
| 1836 | 544.2 | Performance Study of Current Procedures |  | 111d? | 2003-11-21 A | 2004-04-23 A | 100% | 2003-11-21 | 2004-04-23 | 111d? | start no earlier than 2003-11-21 | G2 | 888h | 888h | PSintDTM-Perf | Siemens | toby.proctor@roke.co.uk | Rel-6 | Gert |  |  |  |
| 1837 | 544.3 | Reduction of service interruption times and packet loss during Dual Transfer Mode and mobility procedures |  | 146d? | 2004-04-23 A | 2004-11-12 A | 100% | 2004-04-23 | 2004-11-12 | 146d? | finish no earlier than 2004-11-12 | G2 | 1168h | 1168h | PSintDTM-Reduct | Siemens | toby.proctor@roke.co.uk | Rel-6 | Gert |  |  |  |
| 1838 | 544.4 | Deleted - MS Conformance testing - Reduction of PS service interruption in DTM |  | 261d? | 2004-06-25 A | 2005-06-24 A | 100% | 2004-06-25 | 2005-06-24 | 261d? | finish no earlier than 2005-06-24 | G3new | 2088h | 2088h | PSintDTM-ConfMS |  |  | Rel-6 | Ingbert | GP-25 |  |  |
| 1839 | 544.5 | Deleted - BTS Conformance testing - Reduction of PS service interruption in DTM | milestone | 0d? | 2005-06-24 A | 2005-06-24 A | 100% | 2005-06-24 | 2005-06-24 | 0d? | finish no earlier than 2005-06-24 | G3new |  |  | PSintDTM-ConfBTS |  |  | Rel-6 | Ingbert | GP-25 |  |  |
| 1840 | 545 | CAMEL prepay interworking with SCUDIF |  | 216.3d | 2003-12-08 A | 2004-10-05 A | 100% | 2003-12-08 | 2004-10-05 | 216.3d |  | N4,N3,S1 | 1730.4h | 1730.4h | SCCAMEL | Nokia | Keijo.Palviainen@Nokia.Com | Rel-6 | Kimmo |  | 22.078, 23.078, 29.078, 29.002, 23.172 |  |
| 1841 | 546 | **Circuit Switched Video and Voice Service Improvements** |  | 430d? | 2004-01-12 A | 2005-09-02 A | 100% | 2004-01-12 | 2005-09-02 | 430d? |  | S2,C1 | 9256h | 9256h | CS_VSS | Vodafone | John Watson | Rel-6 | Alain |  |  |  |
| 1842 | 546.1 | Deleted - Stage 1 - Requirements |  | 199d | 2004-01-12 A | 2004-10-14 A | 100% | 2004-01-12 | 2004-10-14 | 199d | finish no earlier than 2004-10-14 | S1 | 1592h | 1592h | CS_VSS | Vodafone | John Watson | Rel-6 | Alain | SP-26 | 22.101 |  |
| 1843 | 546.2 | Stage 2 Study on architecture alternatives |  | 244d? | 2004-01-12 A | 2004-12-16 A | 100% | 2004-01-12 | 2004-12-16 | 244d? | finish no earlier than 2004-08-13 | S2 | 1952h | 1952h | CS_VSS | Vodafone | Chris Pudney | Rel-6 | Maurice |  | 23.903 | SP-24 |
| 1844 | 546.3 | Deleted - Stage 2 description on Redial |  | 164d? | 2004-05-03 A | 2004-12-16 A | 100% | 2004-05-03 | 2004-12-16 | 164d? | finish no earlier than 2004-12-16 | S2 | 1312h | 1312h | CS_VSS | Vodafone | Chris Pudney | Rel-6 | Maurice | SP-26 |  | SP-24 |
| 1845 | 546.4 | Switching between voice and video call - Redial solution |  | 120d? | 2005-01-03 A | 2005-06-17 A | 100% | 2005-01-03 | 2005-06-17 | 120d? | start no earlier than 2005-01-03 | C1 | 960h | 960h | CS_VSS | Vodafone |  | Rel-6 | Frederic |  | 23.009, 24.008 |  |
| 1846 | 546.5 | Deleted - CS_VSS - GERAN2 Part | milestone | 0d | 2005-09-02 A | 2005-09-02 A | 100% | 2005-09-02 | 2005-09-02 | 0d | start no earlier than 2005-09-02 | G2 |  |  | CS_VSS | Vodafone |  | Rel-6 | Gert | GP-26 |  |  |
| 1847 | 546.6 | Deleted - CS_VSS - CN3 Part | milestone | 0d? | 2004-10-14 A | 2004-10-14 A | 100% | 2004-10-14 | 2004-10-14 | 0d? | start no earlier than 2004-10-14 | N3 |  |  | CS_VSS | Vodafone |  | Rel-6 | Gwiho | TP-26 |  |  |
| 1848 | 547 | Network Domain Security; MAP application layer security (NDS/MAPsec) |  | 127d? | 2004-07-06 A | 2004-12-29 A | 100% | 2004-07-06 | 2004-12-29 | 127d? | finish no earlier than 2003-12-26 | S3 | 1016h | 1016h | MAPSEC | Vodafone | Peter.Howard@vodafone.com | Rel-6 | Dionisio |  |  |  |
| 1849 | 548 | FS on Security for early IMS |  | 127d? | 2004-10-01 A | 2005-03-28 A | 100% | 2004-10-01 | 2005-03-28 | 127d? | finish no earlier than 2003-12-26 | S3 | 1016h | 1016h | SEC-IMS | Vodafone | Peter.Howard@vodafone.com | Rel-6 | Dionisio |  | 33.978 |  |
| 1850 | 549 | Reorganisation of CS Data Specifications |  | 14d? | 2004-11-19 A | 2004-12-08 A | 100% | 2004-11-19 | 2004-12-08 | 14d? | finish no earlier than 2004-12-24 | N3 | 112h | 112h | CS Data | Siemens | Thomas.Belling@nsn.com | Rel-6 | Gwiho |  | 23.910, 29.007, new 23.202 |  |
| 1851 | 550 | **Generic Access to A/Gb Interface (GAAI)** |  | 411d? | 2004-06-25 A | 2006-01-20 A | 100% | 2004-06-25 | 2006-01-20 | 411d? |  | GP | 9160h | 9160h | GAAI | Motorola |  | Rel-6 | Paolo |  |  |  |
| 1852 | 550.1 | FS on GAAI |  | 46d? | 2004-06-25 A | 2004-08-27 A | 100% | 2004-06-25 | 2004-08-27 | 46d? | finish no earlier than 2004-08-27 | GP | 368h | 368h | GAAG | Motorola |  | Rel-6 | Paolo |  | 43.901 |  |
| 1853 | 550.2 | GAAI – Stage 2 |  | 161d? | 2004-08-27 A | 2005-04-08 A | 100% | 2004-08-27 | 2005-04-08 | 161d? | finish no earlier than 2005-04-08 | GP | 1288h | 1288h | GAAI-Stage2 | Ericsson | jari.vikberg@ericsson.com | Rel-6 | Paolo |  | 43.318 |  |
| 1854 | 550.3 | GAAI – Stage 3 |  | 161d? | 2004-08-27 A | 2005-04-08 A | 100% | 2004-08-27 | 2005-04-08 | 161d? | finish no earlier than 2005-04-08 | GP | 1288h | 1288h | GAAI-Stage3 |  |  | Rel-6 | Paolo |  | 44.318 |  |
| 1855 | 550.4 | MS Conformance Test for GAAI |  | 366d? | 2004-08-27 A | 2006-01-20 A | 100% | 2004-08-27 | 2006-01-20 | 366d? | finish no earlier than 2006-01-20 | GP | 2928h | 2928h | GAAI-CT |  |  | Rel-6 | Ingbert |  |  |  |
| 1856 | 551 | **Support of PS Handover for GERAN A/Gb mode** |  | 473d? | 2003-11-03 A | 2005-08-24 A | 100% | 2003-11-03 | 2005-08-24 | 473d? |  | GP,G2 | 11352h | 11352h | SPSHAGB | Ericsson | gunnar.hedby@ericsson.com | Rel-6 | Paolo |  |  |  |
| 1857 | 551.1 | Stage 2 |  | 473d? | 2003-11-03 A | 2005-08-24 A | 100% | 2003-11-03 | 2005-08-24 | 473d? | finish no earlier than 2005-09-02 | GP,G2 | 3784h | 3784h | SPSHAGB-Stage2 | Ericsson | gunnar.hedby@ericsson.com | Rel-6 | Paolo |  | 43.129 |  |
| 1858 | 551.2 | PS handover |  | 473d? | 2003-11-03 A | 2005-08-24 A | 100% | 2003-11-03 | 2005-08-24 | 473d? | finish no earlier than 2005-09-02 | GP,G2 | 3784h | 3784h | SPSHAGB-PSHO | Ericsson | gunnar.hedby@ericsson.com | Rel-6 | Paolo |  |  |  |
| 1859 | 551.3 | Definition of radio resource management functionality |  | 473d? | 2003-11-03 A | 2005-08-24 A | 100% | 2003-11-03 | 2005-08-24 | 473d? | finish no earlier than 2005-09-02 | GP,G2 | 3784h | 3784h | SPSHAGB-RRM | Ericsson | gunnar.hedby@ericsson.com | Rel-6 | Paolo |  |  |  |
| 1860 | 552 | (Small) Technical Enhancements and Improvements for Rel-6 |  | 503d? | 2006-06-02 A | 2008-05-06 A | 100% | 2006-06-02 | 2008-05-06 | 503d? |  | All |  |  | TEI6 |  |  | Rel-6 | all |  |  |  |
| 1861 | 553 | Test - (Small) Technical Enhancements and Improvements for Rel-6 |  | 503d? | 2006-06-02 A | 2008-05-06 A | 100% | 2006-06-02 | 2008-05-06 | 503d? | start no earlier than 2006-06-02 | R5,T1 | 4024h | 4024h | TEI6_Test |  |  | Rel-6 | Ingbert |  | 34.108,34.121-1/2,34.122,34.123-1/2/3 |  |
| 1862 | 554 | Deleted - Study of Feature Interactions Requirements | milestone | 0d? | 2004-09-16 A | 2004-09-16 A | 100% | 2004-09-16 | 2004-09-16 | 0d? | finish no earlier than 2004-10-01 | S1 |  |  | FINTER |  |  | Rel-6 | Alain | SP-25 |  |  |
| 1863 | 555 | Deleted - Enhancements of VGCS in public networks for communication of public authority officials |  | 7d? | 2005-08-24 A | 2005-09-02 A | 100% | 2005-08-24 | 2005-09-02 | 7d? | start no earlier than 2005-08-24 | GP,G2 | 56h | 56h | EVGCS | Siemens | kenneth.isaacs@roke.co.uk | Rel-6 | Paolo | GP-26 | 44.018, 44.068, 48.008 |  |

Notes:
- 1834: -
- 1835: -
- 1836: -
- 1837: -
- 1838: -
- 1839: -
- 1840: -
- 1841: -
- 1842: -
- 1843: -
- 1844: -
- 1845: -
- 1846: -
- 1847: -
- 1848: Approved TSG#24. Marked as closed 12/2008 (was marked 20% complete)
- 1849: SP#24 approved WID. SP#27 completed. SP#46 TR 33.978 withdrawn from Rel-8 onwards
- 1850: Created at TSG#27 as 100 % complete
- 1851: -
- 1852: Feasibility Study
- 1853: -
- 1854: -
- 1855: Marked as closed 12/2008 (was marked 90% complete)
- 1856: Replaces SCSAGB- Originally Started Nov 2003 as GP-030443
- 1857: Replaces SCSAGB-Stage2
- 1858: Replaces SCSAGB-PSH
- 1859: Replaces SCSAGB-RRM
- 1860: "Joker" WI, to be used for a Rel 6 CR not related to any feature and with very limited impact on the system. Moved in from Stoyan/Testing WP
- 1861: "Joker" WI, to be used for small modifications applicable to Rel 4 conformance testing
- 1862: SP#25 stopped
- 1863: GP#26 moved to Rel-7 as UID_11045 Enhancements of VGCS in public networks for communication of public authority officials

| ID | WBS | Task | Type | Duration | Start | Finish | Complete | Baseline start | Baseline finish | Baseline duration | Constraint | Resources | Work | Actual work | Text1 | Text4 | Text5 | Text6 | Text8 | Text12 | Text3 | Text7 | Text10 |
| --- | --- | --- | --- | --- | --- | --- | --- | --- | --- | --- | --- | --- | --- | --- | --- | --- | --- | --- | --- | --- | --- | --- | --- |
| 1864 | 556 | **Deleted - Support of Conversational Services in A/Gb mode via the PS domain** |  | 64d? | 2003-11-21 A | 2004-02-19 A | 100% | 2003-11-21 | 2004-02-19 | 64d? |  | GP,N1 | 1024h | 1024h | SCSAGB | Ericsson | David Bladsjö (david.bladsjo@ericsson.com) | Rel-6 | Paolo | GP-18 |  |  |  |
| 1865 | 556.1 | Deleted - Creation of a TR | milestone | 0d? | 2003-11-21 A | 2003-11-21 A | 100% | 2003-11-21 | 2003-11-21 | 0d? | start no earlier than 2003-11-21 | GP |  |  | SCSAGB-TR | Ericsson | David Bladsjö (david.bladsjo@ericsson.com) | Rel-6 | Paolo | GP-17 |  |  |  |
| 1866 | 556.2 | Deleted - Stage 2 | milestone | 0d? | 2003-11-21 A | 2003-11-21 A | 100% | 2003-11-21 | 2003-11-21 | 0d? | finish no earlier than 2003-11-21 | GP |  |  | SCSAGB-Stage2 | Ericsson | David Bladsjö (david.bladsjo@ericsson.com) | Rel-6 | Paolo | GP-17 |  |  |  |
| 1867 | 556.3 | Deleted - Radio Channel Support | milestone | 0d? | 2003-11-21 A | 2003-11-21 A | 100% | 2003-11-21 | 2003-11-21 | 0d? | finish no earlier than 2003-11-21 | GP |  |  | SCSAGB-RCS | Ericsson | David Bladsjö (david.bladsjo@ericsson.com) | Rel-6 | Paolo | GP-17 |  |  |  |
| 1868 | 556.4 | Deleted - Definition of radio resource management functionality | milestone | 0d? | 2003-11-21 A | 2003-11-21 A | 100% | 2003-11-21 | 2003-11-21 | 0d? | finish no earlier than 2003-11-21 | GP |  |  | SCSAGB-RRM | Ericsson | David Bladsjö (david.bladsjo@ericsson.com) | Rel-6 | Paolo | GP-17 |  |  |  |
| 1869 | 556.5 | Deleted - replaced by 50561 - PS Handover |  | 64d | 2003-11-21 A | 2004-02-19 A | 100% | 2003-11-21 | 2004-02-19 | 64d | start no earlier than 2003-11-21 | GP,N1 | 512h | 512h | SCSAGB-PSH | Ericsson | David Bladsjö (david.bladsjo@ericsson.com) | Rel-6 | Paolo | GP-18 |  |  |  |
| 1870 | 556.6 | Deleted - Modifications to FLO | milestone | 0d? | 2003-11-21 A | 2003-11-21 A | 100% | 2003-11-21 | 2003-11-21 | 0d? | finish no earlier than 2003-11-21 | GP |  |  | SCSAGB-FLO | Ericsson | David Bladsjö (david.bladsjo@ericsson.com) | Rel-6 | Paolo | RP-29 |  |  |  |
| 1871 | 557 | Deleted - Rel-6 Evolutions of the transport in the UTRAN | milestone | 0d | 2003-12-31 A | 2003-12-31 A | 100% | 2003-12-31 | 2003-12-31 | 0d | start no earlier than 2003-12-31 | RP |  |  | ETRAN | Alcatel | Francois Courau | Rel-6 | Issam | RP-22 |  |  |  |
| 1872 | 558 | Release 5 Features |  | 325d? | 2001-03-30 A | 2002-06-28 A | 100% | 2001-03-30 | 2002-06-28 | 325d? |  | NP,GP, RP,SP,TP | 2600h | 2600h |  |  |  | Rel-5 | All |  |  |  |  |
| 1873 | 75 | IP transport in the UTRAN |  | 445d | 2000-07-17 A | 2002-03-29 A | 100% | 2000-07-17 | 2002-03-29 | 445d | finish no earlier than 2002-03-29 | R3 | 3560h | 3560h | ETRAN-IPtrans | Alcatel | Nicolas Drevon | Rel-5 | Juha |  |  |  |  |
| 1874 | 76 | FS on Usage of SUA |  | 205d | 2001-03-12 A | 2001-12-21 A | 100% | 2001-03-12 | 2001-12-21 | 205d | finish no earlier than 2001-12-21 | N4 | 1640h | 1640h | SS7IP |  |  | Rel-5 | Kimmo |  |  |  |  |
| 1875 | 77 | **High Speed Downlink Packet Access** |  | 1550d? | 2001-04-02 A | 2007-03-09 A | 100% | 2001-04-02 | 2007-03-09 | 1550d? |  | R2,R5 | 31488h | 31488h | HSDPA | Motorola | Ravi Kuchibhotla | Rel-5 | Joern |  |  |  |  |
| 1876 | 77.1 | Physical Layer |  | 257d | 2001-04-05 A | 2002-03-29 A | 100% | 2001-04-05 | 2002-03-29 | 257d | finish no earlier than 2002-03-29 | R1 | 2056h | 2056h | HSDPA-Phys | Motorola | Amitava Ghosh | Rel-5 | Patrick |  |  |  |  |
| 1877 | 77.2 | Layer 2 and 3 aspects |  | 257d | 2001-04-05 A | 2002-03-29 A | 100% | 2001-04-05 | 2002-03-29 | 257d | finish no earlier than 2002-03-29 | R2 | 2056h | 2056h | HSDPA-L23 | Motorola | Ravi Kuchibhotla | Rel-5 | Joern |  |  |  |  |
| 1878 | 77.3 | Iub/Iur protocol aspects |  | 260d | 2001-04-02 A | 2002-03-29 A | 100% | 2001-04-02 | 2002-03-29 | 260d | finish no earlier than 2002-03-29 | R3 | 2080h | 2080h | HSDPA-IubIur | Motorola | Mike Diesen | Rel-5 | Juha |  |  |  |  |
| 1879 | 77.4 | RF Radio Transmission/ Reception, System Performance Requirements and Conformance Testing |  | 565d | 2001-04-09 A | 2003-06-06 A | 100% | 2001-04-09 | 2003-06-06 | 565d | finish no earlier than 2003-06-06 | R4 | 4520h | 4520h | HSDPA-RF | Motorola | Howard Benn | Rel-5 | Issam |  |  |  |  |
| 1880 | 561.5 | Conformance Testing of HSDPA |  | 786d | 2003-09-19 A | 2006-09-22 A | 100% | 2003-09-19 | 2006-09-22 | 786d | finish no earlier than 2006-09-22 | R5 | 6288h | 6288h | HSDPA_Test | Motorola | carolyn.taylor@motorola.com | Rel-5 | Ingbert |  | 34.108, 34.121, 34.122, 34.123-1, 34.123-2, 34.123-3 | TSG | 19/9/2003 |
| 1881 | 561.6 | Conformance Testing of HCR TDD HSDPA |  | 261d? | 2006-03-10 A | 2007-03-09 A | 100% | 2006-03-10 | 2007-03-09 | 261d? | finish no earlier than 2007-03-09 | R5 | 2088h | 2088h | HSDPA_HCRTDD_Test | IPWireless | drichards@ipwireless.com | Rel-5 | Ingbert |  | 34.108, 34.122, 34.123-1, 34.123-2, 34.123-3 |  |  |
| 1882 | 78 | **Rel-5 Improvements of Radio Interface** |  | 535d | 2000-08-14 A | 2002-08-30 A | 100% | 2000-08-14 | 2002-08-30 | 535d |  | RP | 30376h | 30376h | RInImp |  |  | Rel-5 |  |  |  |  |  |
| 1883 | 78.1 | **Base station classification** |  | 480d | 2000-08-14 A | 2002-06-14 A | 100% | 2000-08-14 | 2002-06-14 | 480d |  | R4 | 9208h | 9208h | RInImp-BSClass | Nokia | antti.toskala@nokia.com | Rel-5 | Issam |  |  |  |  |
| 1884 | 78.1.1 | TDD Base station classification |  | 410d | 2000-08-14 A | 2002-03-08 A | 100% | 2000-08-14 | 2002-03-08 | 410d | finish no earlier than 2002-03-08 | R4 | 3280h | 3280h | RInImp-BSClass-TDD | Nokia | antti.toskala@nokia.com | Rel-5 | Issam |  |  |  |  |
| 1885 | 78.1.2 | Base Station Classification for 1.28 Mcps TDD option |  | 261d | 2001-06-15 A | 2002-06-14 A | 100% | 2001-06-15 | 2002-06-14 | 261d | finish no earlier than 2002-06-14 | R4 | 2088h | 2088h | RInImp-BSClass-LCRTDD | Siemens | Meik.Kottkamp@siemens.com | Rel-5 | Issam |  |  |  |  |
| 1886 | 78.2 | Enhancement on the DSCH hard split mode |  | 271d | 2001-03-16 A | 2002-03-29 A | 100% | 2001-03-16 | 2002-03-29 | 271d | finish no earlier than 2002-03-29 | R1 | 2168h | 2168h | RInImp-DSCHhsp | Samsung | Jaeyoel KIM | Rel-5 | Patrick |  |  |  |  |
| 1887 | 78.3 | Hybrid ARQ II/III |  | 355d | 2000-08-21 A | 2001-12-28 A | 100% | 2000-08-21 | 2001-12-28 | 355d | finish no earlier than 2001-12-28 | R2 | 2840h | 2840h | RInImp-HARQ | Siemens | A. Sitte | Rel-5 | Joern | RP-14 |  |  |  |
| 1888 | 78.4 | FS on USTS |  | 355d | 2000-08-14 A | 2001-12-21 A | 100% | 2000-08-14 | 2001-12-21 | 355d | finish no earlier than 2001-12-21 | R1 | 2840h | 2840h | RInImp-USTS | SK Telecom | D. Kim | Rel-5 | Patrick |  |  |  |  |
| 1889 | 78.5 | FS on UE antenna efficiency test method performance requirements |  | 255d | 2000-09-25 A | 2001-09-14 A | 100% | 2000-09-25 | 2001-09-14 | 255d | finish no earlier than 2001-09-14 | R4 | 2040h | 2040h | RInImp-UEAnTM | Allgon | O. Edvardsson | Rel-5 | Issam |  |  |  |  |
| 1890 | 78.6 | FS on the re-introduction of the downlink SIR measurement |  | 200d | 2001-03-12 A | 2001-12-14 A | 100% | 2001-03-12 | 2001-12-14 | 200d | finish no earlier than 2001-12-14 | R4 | 1600h | 1600h | RInImp-SIR | Ericsson | Torgny.Palenius@ericsson.com | Rel-5 | Issam |  |  |  |  |
| 1891 | 78.7 | FS on mitigating the effect of CPICH interference at the UE |  | 255d | 2001-03-19 A | 2002-03-08 A | 100% | 2001-03-19 | 2002-03-08 | 255d | finish no earlier than 2002-03-08 | R4 | 2040h | 2040h | RInImp-CPICH_Intf | Intel | shimon.moshavi@INTEL.COM | Rel-5 | Issam |  |  |  |  |

Notes:
- 1864: -
- 1865: -
- 1866: Started
- 1867: Not started
- 1868: Not started
- 1869: Started
- 1870: Not started
- 1871: Generic feature
- 1872: -
- 1873: -
- 1874: -
- 1875: -
- 1876: -
- 1877: -
- 1878: -
- 1879: -
- 1880: -
- 1881: -
- 1882: -
- 1883: -
- 1884: -
- 1885: -
- 1886: -
- 1887: Stopped at RP#14; work on this task was performed as part of High Speed Downlink Packet Access feature
- 1888: -
- 1889: -
- 1890: -
- 1891: -

| ID | WBS | Task | Duration | Start | Finish | Complete | Baseline start | Baseline finish | Baseline duration | Constraint | Deadline | Resources | Work | Actual work | Text6 | Text8 | Text12 | Text1 | Text4 | Text5 | Text3 | Text10 |
| --- | --- | --- | --- | --- | --- | --- | --- | --- | --- | --- | --- | --- | --- | --- | --- | --- | --- | --- | --- | --- | --- | --- |
| 1892 | 78.8 | **Deleted - Conformance Test Spec. improvements in Radio Interface** | 140d | 2002-02-18 A | 2002-08-30 A | 100% | 2002-02-18 | 2002-08-30 | 140d |  |  | T1 | 3360h | 3360h | Rel-5 | Ingbert | TP-17 |  |  |  |  |  |
| 1893 | 78.8.1 | Deleted - Testing improvement of inter-frequency and inter-system measurement | 140d | 2002-02-18 A | 2002-08-30 A | 100% | 2002-02-18 | 2002-08-30 | 140d | finish no earlier than 2002-08-30 |  | T1 | 1120h | 1120h | Rel-5 | Ingbert | TP-17 |  |  |  |  |  |
| 1894 | 78.8.2 | Deleted - Testing Hybrid ARQ II/III | 140d | 2002-02-18 A | 2002-08-30 A | 100% | 2002-02-18 | 2002-08-30 | 140d | finish no earlier than 2002-08-30 |  | T1 | 1120h | 1120h | Rel-5 | Ingbert | TP-17 |  |  |  |  |  |
| 1895 | 79 | **Rel-5 RAN improvements** | 1561d? | 2001-03-16 A | 2007-03-09 A | 100% | 2001-03-16 | 2007-03-09 | 1561d? |  |  | RP | 49424h | 49424h | Rel-5 |  |  | RANimp |  |  |  |  |
| 1896 | 79.1 | **RRM optimization for Iur and Iub** | 318d | 2001-03-16 A | 2002-06-04 A | 100% | 2001-03-16 | 2002-06-04 | 318d |  |  | R3 | 8904h | 8904h | Rel-5 | Juha |  | RANimp-RRMopt | Ericsson | Gert-Jan.van.Lieshout@eln.ericsson.se |  |  |
| 1897 | 79.1.1 | Iur common transport channel efficiency optimization | 271d | 2001-03-16 A | 2002-03-29 A | 100% | 2001-03-16 | 2002-03-29 | 271d | finish no earlier than 2002-03-29 |  | R3 | 2168h | 2168h | Rel-5 | Juha |  | RANimp-RRMopt-ctc | Ericsson | Shahrokh Amirijoo |  |  |
| 1898 | 79.1.2 | Iur neighbouring cell reporting efficiency optimization | 271d | 2001-03-16 A | 2002-03-29 A | 100% | 2001-03-16 | 2002-03-29 | 271d | finish no earlier than 2002-03-29 |  | R3 | 2168h | 2168h | Rel-5 | Juha |  | RANimp-RRMopt-ncr | Ericsson | Shahrokh Amirijoo |  |  |
| 1899 | 79.1.3 | FS Introduction of direct transport bearers between SRNC and Node-B | 253d | 2001-06-15 A | 2002-06-04 A | 100% | 2001-06-15 | 2002-06-04 | 253d | finish no earlier than 2002-06-28 |  | R3 | 2024h | 2024h | Rel-5 | Juha |  | RAN-imp-RRMopt-DTB | Ericsson | Risto Sepponen |  |  |
| 1900 | 79.2 | RL Timing Adjustment | 271d | 2001-03-16 A | 2002-03-29 A | 100% | 2001-03-16 | 2002-03-29 | 271d | finish no earlier than 2002-03-29 |  | R3 | 2168h | 2168h | Rel-5 | Juha |  | RANimp-RLTA | Ericsson | Elena Voltolina |  |  |
| 1901 | 79.3 | Separation of resource reservation and radio link activation | 271d | 2001-03-16 A | 2002-03-29 A | 100% | 2001-03-16 | 2002-03-29 | 271d | finish no earlier than 2002-03-29 |  | R3 | 2168h | 2168h | Rel-5 | Juha |  | RANimp-SepRR | Ericsson | Gert-Jan.van.Lieshout@eln.ericsson.se |  |  |
| 1902 | 79.4 | FS SRNS Relocation Procedure Enhancement | 318d | 2001-06-15 A | 2002-09-03 A | 100% | 2001-06-15 | 2002-09-03 | 318d | finish no earlier than 2002-09-06 |  | R3 | 2544h | 2544h | Rel-5 | Juha |  | RANimp-SRNS | Nokia | Olivier Guyot |  |  |
| 1903 | 79.5 | FS Improvement of Radio Resource Management across RNS and RNS/PSS | 201d | 2001-03-16 A | 2001-12-21 A | 100% | 2001-03-16 | 2001-12-21 | 201d | finish no earlier than 2001-12-21 |  | R3 | 1608h | 1608h | Rel-5 | Juha |  | RANimp-ImpRRM | Nokia | antti.toskala@nokia.com |  |  |
| 1904 | 79.6 | Re-arrangements of Iub transport bearers | 271d | 2001-03-16 A | 2002-03-29 A | 100% | 2001-03-16 | 2002-03-29 | 271d | finish no earlier than 2002-03-29 |  | R3 | 2168h | 2168h | Rel-5 | Juha |  | RANimp-TTPS | Nokia | antti.toskala@nokia.com |  |  |
| 1905 | 79.7 | RAB support enhancement for Rel-5 | 325d | 2001-04-02 A | 2002-06-28 A | 100% | 2001-04-02 | 2002-06-28 | 325d |  |  | R2 | 2600h | 2600h | Rel-5 | Joern |  | RANimp-RABSE5 | Nokia | Juha Mikola |  |  |
| 1906 | 16.5.1 | Testing of ROHC performance | 391d | 2005-09-09 A | 2007-03-09 A | 100% | 2005-09-09 | 2007-03-09 | 391d | finish no earlier than 2007-03-09 | 2006-06-02 | R5 | 3128h | 3128h | Rel-5 | Ingbert |  | RANimp-RABSE5_Test | Nokia | jarkko.hellsten@nokia.com | 34.108, 34.123-1, 34.123-2, 34.123-3 | Fri 11/03/05 |
| 1907 | 79.8 | Beamforming requirements for UE | 61d | 2001-09-21 A | 2001-12-14 A | 100% | 2001-09-21 | 2001-12-14 | 61d | finish no earlier than 2001-12-14 |  | R1 | 488h | 488h | Rel-5 | Patrick |  | RANimp-BFR-UE | Nokia | Jussi Kähtävä (juha.mikola@nokia.com) |  |  |
| 1908 | 79.9 | Support of Site Selection Diversity Transmission in UTRAN | 123d | 2001-12-14 A | 2002-06-04 A | 100% | 2001-12-14 | 2002-06-04 | 123d | finish no earlier than 2002-06-04 |  | R1 | 984h | 984h | Rel-5 | Patrick |  | RANimp-SSDT | NEC |  |  |  |
| 1909 | 79.10 | Node B Synchronisation for 1.28 Mcps TDD | 271d | 2001-03-16 A | 2002-03-29 A | 100% | 2001-03-16 | 2002-03-29 | 271d | finish no earlier than 2002-03-29 |  | R1 | 2168h | 2168h | Rel-5 | Patrick |  | RANimp-NBSLCR | CATT | Jinling HU |  |  |
| 1910 | 79.12 | **Deleted - Conformance Test Aspects - RAN Improvements** | 565d? | 2002-01-01 A | 2004-03-01 A | 100% | 2002-01-01 | 2004-03-01 | 565d? |  |  | T1 | 8008h | 8008h | Rel-5 | Ingbert | TP-23 |  |  |  | 0% |  |
| 1911 | 79.12.1 | Deleted - Testing Radio access bearer support enhancements | 175d | 2002-01-01 A | 2002-09-02 A | 100% | 2002-01-01 | 2002-09-02 | 175d | finish no earlier than 2002-09-02 |  | T1 | 1400h | 1400h | Rel-5 | Ingbert | TP-17 |  |  |  |  |  |
| 1912 | 563.12.2 | Deleted - General changes to TS34.121 and TS34.122 corresponding to release 5 | 261d? | 2003-03-03 A | 2004-03-01 A | 100% | 2003-03-03 | 2004-03-01 | 261d? | finish no earlier than 2004-03-01 |  | T1 | 2088h | 2088h | Rel-5 | Ingbert | TP-23 | RANimp-test |  |  | 34.108, 34.121, 34.122 |  |
| 1913 | 80 | UTRAN Sharing in Connected Mode | 197d | 2001-12-03 A | 2002-09-03 A | 100% | 2001-12-03 | 2002-09-03 | 197d | finish no earlier than 2002-09-06 |  | R3 | 1576h | 1576h | Rel-5 | Juha |  | NETSHARE | Ericsson | Martin Israelsson |  |  |
| 1914 | 81 | **Provisioning of IP-based multimedia services** | 1806d | 2000-01-03 A | 2006-12-01 A | 100% | 2000-01-03 | 2006-12-01 | 1806d |  |  | S1,S2,S5,R5 | 205676h | 205676h | Rel-5 | Alain |  | IMS | Openwave | Mark Cataldo |  |  |
| 1915 | 81.1 | **Call control and roaming to support IMS in UMTS** | 1806d | 2000-01-03 A | 2006-12-01 A | 100% | 2000-01-03 | 2006-12-01 | 1806d |  |  | S2,R5 | 95312h | 95312h | Rel-5 | Maurice |  | IMS-CCR | Lucent | Liz Daniel |  |  |
| 1916 | 81.1.1 | Stage 1 | 215d | 2000-02-21 A | 2000-12-15 A | 100% | 2000-02-21 | 2000-12-15 | 215d | finish no earlier than 2000-09-21 |  | S1 | 1720h | 1720h | Rel-5 | Alain |  | IMS-CCR | Motorola | Mark Cataldo | 22.228 |  |
| 1917 | 81.1.2 | Stage 2 (Architecture and Main flows) | 246d | 2000-04-14 A | 2001-03-23 A | 100% | 2000-04-14 | 2001-03-23 | 246d | finish no earlier than 2001-03-23 |  | S2 | 1968h | 1968h | Rel-5 | Maurice |  | IMS-CCR | Lucent | Liz Daniel | 23.228 |  |
| 1918 | 81.1.3 | Impact on MM/CC/SM | 400d | 2000-08-28 A | 2002-03-08 A | 100% | 2000-08-28 | 2002-03-08 | 400d | finish no earlier than 2002-03-08 |  | N1 | 3200h | 3200h | Rel-5 | Frederic |  | IMS-CCR-IWMM | Lucent | Keith Drage (drage@alcatel-lucent.com) |  |  |

Notes:
- 1892: Marked as stopped 12/2008
- 1893: Marked as stopped 12/2008
- 1894: Marked as stopped 12/2008
- 1895: -
- 1896: -
- 1897: -
- 1898: -
- 1899: FS was closed and introduction of WI not agreed at RAN #16
- 1900: -
- 1901: -
- 1902: -
- 1903: FS was closed and WI was introduced at RAN #14
- 1904: -
- 1905: RFC 3095 context relocation
- 1906: -
- 1907: -
- 1908: RP-020356
- 1909: -
- 1910: Marked as stopped 12/2008
- 1911: Marked as stopped 12/2008
- 1912: Marked as stopped 12/2008
- 1913: Formerly 'Shared Network support in connected mode', renamed at RAN #16.
- 1914: -
- 1915: -
- 1916: Issues include e.g.: Roaming requirements, Requirements on supplementary services, Interworking requirements
- 1917: Issues include e.g.: Mobile IP, RAB selection principles, Optimized VoIP bearer mechanisms, SIP multimedia protocol
- 1918: Per 26/2-02: This is understood to be the PCO & TFT CRs which CN1 provides to TSGN #15 for approval. If this is correct understanding, then the task is 100 % complete.

| ID | WBS | Task | Duration | Start | Finish | Complete | Baseline start | Baseline finish | Baseline duration | Constraint | Deadline | Resources | Work | Actual work | Text1 | Text3 | Text4 | Text5 | Text6 | Text8 | Text10 |
| --- | --- | --- | --- | --- | --- | --- | --- | --- | --- | --- | --- | --- | --- | --- | --- | --- | --- | --- | --- | --- | --- |
| 1919 | 81.1.4 | **SIP Call Control protocol for the IMS** | 385d | 2000-10-02 A | 2002-03-22 A | 100% | 2000-10-02 | 2002-03-22 | 385d |  |  | N1 | 12320h | 12320h | IMS-CCR | 24.228, 24.229, 23.218 | Lucent | Keith Drage (drage@alcatel-lucent.com) | Rel-5 | Frederic |  |
| 1920 | 81.1.4.1 | IMS signalling flows | 385d | 2000-10-02 A | 2002-03-22 A | 100% | 2000-10-02 | 2002-03-22 | 385d | finish no earlier than 2002-03-22 |  | N1 | 3080h | 3080h | IMS-CCR | 24.228 |  |  | Rel-5 | Frederic |  |
| 1921 | 81.1.4.2 | IMS stage 3 | 385d | 2000-10-02 A | 2002-03-22 A | 100% | 2000-10-02 | 2002-03-22 | 385d | finish no earlier than 2002-03-22 |  | N1 | 3080h | 3080h | IMS-CCR | 24.229 |  |  | Rel-5 | Frederic |  |
| 1922 | 81.1.4.3 | IMS Session Handling; stage 2 | 385d | 2000-10-02 A | 2002-03-22 A | 100% | 2000-10-02 | 2002-03-22 | 385d | finish no earlier than 2002-03-22 |  | N1 | 3080h | 3080h | IMS-CCR | 23.218 |  |  | Rel-5 | Frederic |  |
| 1923 | 16.5.1 | Conformance Test Aspects – IMS Call Control | 451d | 2005-03-11 A | 2006-12-01 A | 100% | 2005-03-11 | 2006-12-01 | 451d |  | 2006-06-02 | R5 | 3608h | 3608h | IMS-CCR_Test | 34.108, 34.229-1, 34.229-2, 34.229-3 | Motorola | Jacob.John@motorola.com | Rel-5 | Ingbert | Fri 11/03/05 |
| 1924 | 81.1.4.4 | **Main IETF dependencies** | 641d | 2000-01-03 A | 2002-06-14 A | 100% | 2000-01-03 | 2002-06-14 | 641d |  |  | NP | 58048h | 58048h | IMS |  |  |  | Rel-5 | Kimmo |  |
| 1925 | 81.1.4.4.1 | IETF: RFC 3261 (Session Initiation Protocol) | 346d | 2000-11-24 A | 2002-03-22 A | 100% | 2000-11-24 | 2002-03-22 | 346d | finish no earlier than 2002-03-22 |  | N1 | 2768h | 2768h | IMS |  |  |  | Rel-5 | Frederic |  |
| 1926 | 81.1.4.4.2 | IETF: RFC 3262 (Reliability of provisional responses) | 346d | 2000-11-24 A | 2002-03-22 A | 100% | 2000-11-24 | 2002-03-22 | 346d | finish no earlier than 2002-03-22 |  | N1 | 2768h | 2768h | IMS |  |  |  | Rel-5 | Frederic |  |
| 1927 | 81.1.4.4.3 | IETF: RFC 3312 (Without COMET)(Integration of resource management and SIP) | 382d | 2000-11-24 A | 2002-05-13 A | 100% | 2000-11-24 | 2002-05-13 | 382d | finish no earlier than 2002-05-13 |  | N1 | 3056h | 3056h | IMS |  |  |  | Rel-5 | Frederic |  |
| 1928 | 81.1.4.4.4 | IETF: RFC 3323 (SIP extensions for caller identity and privacy) | 382d | 2000-11-24 A | 2002-05-13 A | 100% | 2000-11-24 | 2002-05-13 | 382d | finish no earlier than 2002-05-13 |  | N1 | 3056h | 3056h | IMS |  |  |  | Rel-5 | Frederic |  |
| 1929 | 81.1.4.4.5 | IETF: RFC 3313 (SIP extensions for media authorization) | 382d | 2000-11-24 A | 2002-05-13 A | 100% | 2000-11-24 | 2002-05-13 | 382d | finish no earlier than 2002-05-13 |  | N1 | 3056h | 3056h | IMS |  |  |  | Rel-5 | Frederic |  |
| 1930 | 81.1.4.4.6 | IETF: RFC 3265 (specific event notification) | 346d | 2000-11-24 A | 2002-03-22 A | 100% | 2000-11-24 | 2002-03-22 | 346d | finish no earlier than 2002-03-22 |  | N1 | 2768h | 2768h | IMS |  |  |  | Rel-5 | Frederic |  |
| 1931 | 81.1.4.4.7 | IETF: RFC editor Queue (refer method) | 401d | 2000-11-24 A | 2002-06-07 A | 100% | 2000-11-24 | 2002-06-07 | 401d | finish no earlier than 2002-06-07 |  | N1 | 3208h | 3208h | IMS |  |  |  | Rel-5 | Frederic |  |
| 1932 | 81.1.4.4.8 | IETF: RFC editor Queue (DHCP options for SIP servers) | 382d | 2000-11-24 A | 2002-05-13 A | 100% | 2000-11-24 | 2002-05-13 | 382d | finish no earlier than 2002-05-13 |  | N1 | 3056h | 3056h | IMS |  |  |  | Rel-5 | Frederic |  |
| 1933 | 81.1.4.4.10 | IETF: RFC 3267 (AMR and AMR WB RTP and SDP) | 346d | 2000-11-24 A | 2002-03-22 A | 100% | 2000-11-24 | 2002-03-22 | 346d | finish no earlier than 2002-03-22 |  | N1 | 2768h | 2768h | IMS |  |  |  | Rel-5 | Frederic |  |
| 1934 | 81.1.4.4.11 | IETF: RFC 3266 (IPv6 support within SDP) | 581d | 2000-01-03 A | 2002-03-22 A | 100% | 2000-01-03 | 2002-03-22 | 581d | finish no earlier than 2002-03-22 |  | N1 | 4640h | 4640h | IMS |  |  |  | Rel-5 | Frederic |  |
| 1935 | 81.1.4.4.12 | IETF: RFC 3311 (The Update method) | 382d | 2000-11-24 A | 2002-05-13 A | 100% | 2000-11-24 | 2002-05-13 | 382d | finish no earlier than 2002-05-13 |  | N1 | 3056h | 3056h | IMS |  |  |  | Rel-5 | Frederic |  |
| 1936 | 81.1.4.4.13 | IETF: RFC 3324 (Network Asserted Identity) | 382d | 2000-11-24 A | 2002-05-13 A | 100% | 2000-11-24 | 2002-05-13 | 382d | finish no earlier than 2002-05-13 |  | N1 | 3056h | 3056h | IMS |  |  |  | Rel-5 | Frederic |  |
| 1937 | 81.1.4.4.14 | IETF: RFC editor Queue (Various 3GPP Private Extensions) | 382d | 2000-11-24 A | 2002-05-13 A | 100% | 2000-11-24 | 2002-05-13 | 382d | finish no earlier than 2002-05-13 |  | N1 | 3056h | 3056h | IMS |  |  |  | Rel-5 | Frederic |  |
| 1938 | 81.1.4.5 | **Addressing** | 380d | 2000-10-09 A | 2002-03-22 A | 100% | 2000-10-09 | 2002-03-22 | 380d |  |  | S2 | 7744h | 7744h | IMS |  |  |  | Rel-5 | Maurice |  |
| 1939 | 81.1.4.5.1 | Architectural issues | 235d | 2000-10-09 A | 2001-08-31 A | 100% | 2000-10-09 | 2001-08-31 | 235d | finish no earlier than 2001-03-16 |  | S2 | 1880h | 1880h | IMS |  |  |  | Rel-5 | Maurice |  |
| 1940 | 81.1.4.5.2 | Impact on HSS | 353d | 2000-11-15 A | 2002-03-22 A | 100% | 2000-11-15 | 2002-03-22 | 353d | finish no earlier than 2002-03-22 |  | N4 | 2824h | 2824h | IMS |  |  |  | Rel-5 | Kimmo |  |
| 1941 | 81.1.4.6 | **Service Examples (Work stopped)** | 304d | 2001-04-17 A | 2002-06-14 A | 100% | 2001-04-17 | 2002-06-14 | 304d |  |  | S1 | 4864h | 4864h | IMS-Sex | 22.928 | Motorola | Mark Cataldo | Rel-5 | Alain |  |
| 1942 | 81.1.4.6.1 | IMS Framework Report (work stopped) | 304d | 2001-04-17 A | 2002-06-14 A | 100% | 2001-04-17 | 2002-06-14 | 304d | finish no earlier than 2002-06-14 |  | S1 | 2432h | 2432h | IMS-FrWk | 22.941 | SBC | Randolph Wohlert (rwohlert@tri.sbc.com) | Rel-5 | Alain |  |

Notes:
- 1919: TSGN_10 approved the change:CN1 - SA2 SIP joint meeting spotted one more place for improvement: work tasks with ID 1998 and 1278 are actually subtasks under of single CN1 WT. One WI has been approved for the CN1 WT with title "SIP Call Control protocol
- 1920: 24.228
- 1921: 24.229
- 1922: 23.218
- 1923: -
- 1924: -
- 1925: -
- 1926: -
- 1927: -
- 1928: -
- 1929: -
- 1930: -
- 1931: -
- 1932: -
- 1933: -
- 1934: -
- 1935: -
- 1936: -
- 1937: -
- 1938: -
- 1939: -
- 1940: Covered by 29.228 & 29228
- 1941: -
- 1942: -

| ID | WBS | Task | Duration | Start | Finish | Complete | Baseline start | Baseline finish | Baseline duration | Constraint | Resources | Work | Actual work | Text1 | Text4 | Text5 | Text6 | Text8 | Text3 |
| --- | --- | --- | --- | --- | --- | --- | --- | --- | --- | --- | --- | --- | --- | --- | --- | --- | --- | --- | --- |
| 1943 | 81.2 | **Access Security for IMS** | 190d | 2001-10-08 A | 2002-06-28 A | 100% | 2001-10-08 | 2002-06-28 | 190d |  | S3 | 4120h | 4120h | IMS-ASEC | Ericsson | krister.boman@emw.ericsson.se | Rel-5 | Dionisio |  |
| 1944 | 81.2.2 | IMS impacts on UICC (ISIM application) | 185d | 2001-10-08 A | 2002-06-21 A | 100% | 2001-10-08 | 2002-06-21 | 185d | finish no earlier than 2002-06-21 | T3 | 1480h | 1480h |  | Vodafone | Jeremy Norris | Rel-5 | Xavier |  |
| 1945 | 81.2.3 | SIP extensions for Integrity protection | 140d | 2001-12-17 A | 2002-06-28 A | 100% | 2001-12-17 | 2002-06-28 | 140d | finish no earlier than 2002-06-28 | N1 | 1120h | 1120h |  |  |  | Rel-5 | Frederic |  |
| 1946 | 81.3 | Security Aspects of Requirement for Network Configuration Independence | 130d | 2001-07-02 A | 2001-12-28 A | 100% | 2001-07-02 | 2001-12-28 | 130d | finish no earlier than 2001-12-28 | S3 | 1040h | 1040h | SEC1-NCI | AT&T Wireless | hugh.shieh@attws.com | Rel-5 | Dionisio |  |
| 1947 | 81.4 | Lawful interception | 410d | 2000-09-04 A | 2002-03-29 A | 100% | 2000-09-04 | 2002-03-29 | 410d | finish no earlier than 2002-03-29 | S3 | 3280h | 3280h | IMS-LI | Reg TP | berthold.wilhelm@regtp.de | Rel-5 | Dionisio | 33.106, 33.107, new 33.108 |
| 1948 | 81.5 | Charging and OAM&P for IMS | 383d | 2000-12-25 A | 2002-06-12 A | 100% | 2000-12-25 | 2002-06-12 | 383d | finish no earlier than 2002-06-12 | S5 | 3064h | 3064h | IMS-OAM | VoiceStream, Motorola |  | Rel-5 | Dionisio | 32-series |
| 1949 | 81.6 | **Multimedia codecs and protocols for conversational PS services** | 568d | 2000-07-26 A | 2002-09-27 A | 100% | 2000-07-26 | 2002-09-27 | 568d |  | S4 | 15640h | 15640h | IMS-CODEC | Toshiba, Nokia | B. Aronson (Toshiba), pasi.s.ojala@nokia.com | Rel-5 | Paolo | 26.235, 26.236 |
| 1950 | 81.6.1 | Codecs | 427d | 2000-07-26 A | 2002-03-14 A | 100% | 2000-07-26 | 2002-03-14 | 427d | finish no earlier than 2001-03-21 | S4 | 3416h | 3416h |  |  |  | Rel-5 | Paolo | 26.235, 26.236 |
| 1951 | 81.6.2 | Transport protocols | 1d | 2002-03-12 A | 2002-03-12 A | 100% | 2002-03-12 | 2002-03-12 | 1d | finish no earlier than 2002-03-12 | S4 | 8h | 8h | IMS-CODEC | Nokia | P. Ojala | Rel-5 | Paolo | 26.236 |
| 1952 | 81.6.4 | recommendation for QoS parameter values for various media types | 195d | 2001-12-31 A | 2002-09-27 A | 100% | 2001-12-31 | 2002-09-27 | 195d | finish no earlier than 2002-09-27 | S4 | 1560h | 1560h |  |  |  | Rel-5 | Paolo |  |
| 1953 | 81.6.5 | IETF: RFC 3310 (HTTP Digest Authentication using AKA) | 382d | 2000-11-24 A | 2002-05-13 A | 100% | 2000-11-24 | 2002-05-13 | 382d | finish no earlier than 2002-05-13 | N1 | 3056h | 3056h |  |  |  | Rel-5 | Frederic |  |
| 1954 | 81.6.6 | IETF: RFC 3329 (Security mechanism agreement for SIP connections) | 382d | 2000-11-24 A | 2002-05-13 A | 100% | 2000-11-24 | 2002-05-13 | 382d | finish no earlier than 2002-05-13 | N1 | 3056h | 3056h |  |  |  | Rel-5 | Frederic |  |
| 1955 | 81.7 | **SIP message compression** | 185d | 2001-09-24 A | 2002-06-07 A | 100% | 2001-09-24 | 2002-06-07 | 185d |  | S2 | 3128h | 3128h |  |  |  | Rel-5 | Maurice |  |
| 1956 | 81.7.1 | Stage 2 | 25d | 2001-09-24 A | 2001-10-26 A | 100% | 2001-09-24 | 2001-10-26 | 25d | finish no earlier than 2001-10-26 | S2 | 200h | 200h |  |  |  | Rel-5 | Maurice |  |
| 1957 | 81.7.2 | Compression signalling | 181d | 2001-09-28 A | 2002-06-07 A | 100% | 2001-09-28 | 2002-06-07 | 181d | finish no earlier than 2002-06-07 | N1 | 1448h | 1448h |  |  |  | Rel-5 | Frederic |  |
| 1958 | 81.8 | **Stage 3 description of IMS interfaces** | 383d | 2001-03-14 A | 2002-08-30 A | 100% | 2001-03-14 | 2002-08-30 | 383d |  | NP | 29531.6h | 29531.6h |  |  |  | Rel-5 | Kimmo |  |
| 1959 | 81.8.1 | Cx interface (HSS to CSCF) | 135.95d | 2001-03-14 A | 2002-06-07 A | 100% | 2001-03-14 | 2002-06-07 | 135.95d | finish no earlier than 2002-06-07 | N4 | 1087.58h | 1087.58h |  |  |  | Rel-5 | Kimmo |  |
| 1960 | 81.8.2 | Mp interface (MRFC - MRFP) enhancements | 258d | 2001-03-14 A | 2002-03-08 A | 100% | 2001-03-14 | 2002-03-08 | 258d | finish no earlier than 2002-06-07 | N4 | 2064h | 2064h |  |  |  | Rel-5 | Kimmo |  |
| 1961 | 81.8.3 | Mw interface (CSCF to P-CSCF) | 323d | 2001-03-14 A | 2002-06-07 A | 100% | 2001-03-14 | 2002-06-07 | 323d | finish no earlier than 2002-06-07 | N1 | 2584h | 2584h |  |  |  | Rel-5 | Frederic |  |
| 1962 | 81.8.4 | Mr interface (CSCF to MRF) | 273d | 2001-03-14 A | 2002-03-29 A | 100% | 2001-03-14 | 2002-03-29 | 273d | finish no earlier than 2002-03-29 | N1 | 2184h | 2184h |  |  |  | Rel-5 | Frederic |  |
| 1963 | 81.8.5 | Dx interface (I-CSCF to SLF) | 323d | 2001-03-14 A | 2002-06-07 A | 100% | 2001-03-14 | 2002-06-07 | 323d | finish no earlier than 2002-06-07 | N4 | 2584h | 2584h |  |  |  | Rel-5 | Kimmo |  |
| 1964 | 81.8.6 | Go interface (GGSN to PCF) | 323d | 2001-03-14 A | 2002-06-07 A | 100% | 2001-03-14 | 2002-06-07 | 323d | finish no earlier than 2002-06-07 | N3 | 2584h | 2584h |  |  |  | Rel-5 | Gwiho |  |
| 1965 | 81.8.7 | ISC (IMS Service Control) Interface | 323d | 2001-03-14 A | 2002-06-07 A | 100% | 2001-03-14 | 2002-06-07 | 323d | finish no earlier than 2002-06-07 | N1 | 2584h | 2584h |  |  |  | Rel-5 | Frederic |  |
| 1966 | 81.8.8 | Sh interface (HSS to AS) | 82d | 2002-02-14 A | 2002-06-07 A | 100% | 2002-02-14 | 2002-06-07 | 82d | finish no earlier than 2002-06-07 | N4 | 656h | 656h |  |  |  | Rel-5 | Kimmo |  |
| 1967 | 81.8.9 | Si interface (HSS to IM-SSF) | 162.5d | 2002-01-16 A | 2002-08-30 A | 100% | 2002-01-16 | 2002-08-30 | 162.5d | finish no earlier than 2002-06-07 | N4 | 1300h | 1300h |  |  |  | Rel-5 | Kimmo |  |
| 1968 | 81.8.10 | Gm interface (UE to CSCF) | 323d | 2001-03-14 A | 2002-06-07 A | 100% | 2001-03-14 | 2002-06-07 | 323d | finish no earlier than 2002-06-07 | N1 | 2584h | 2584h |  |  |  | Rel-5 | Frederic |  |
| 1969 | 81.8.11 | Mi interface (CSCF to BGCF) | 323d | 2001-03-14 A | 2002-06-07 A | 100% | 2001-03-14 | 2002-06-07 | 323d | finish no earlier than 2002-06-07 | N1 | 2584h | 2584h |  |  |  | Rel-5 | Frederic |  |
| 1970 | 81.8.12 | Mj interface (BGCF to MGCF) | 323d | 2001-03-14 A | 2002-06-07 A | 100% | 2001-03-14 | 2002-06-07 | 323d | finish no earlier than 2002-06-07 | N1 | 2584h | 2584h |  |  |  | Rel-5 | Frederic |  |
| 1971 | 81.8.13 | Mk interface (BGCF to BGCF) | 323d | 2001-03-14 A | 2002-06-07 A | 100% | 2001-03-14 | 2002-06-07 | 323d | finish no earlier than 2002-06-07 | N1 | 2584h | 2584h |  |  |  | Rel-5 | Frederic |  |
| 1972 | 81.9 | Support of VHE/OSA by entities and protocols of the IMS (e.g. CSCF) | 186d | 2001-09-21 A | 2002-06-07 A | 100% | 2001-09-21 | 2002-06-07 | 186d | finish no earlier than 2002-06-07 | N5 | 1488h | 1488h | IMS-ONOSA | Ericsson | Ard.Jan.Moerdijk@eln.ericsson.se | Rel-5 | Kimmo | 29.198, 29.998 |

Notes:
- 1943: TS33.203 will be presented for info at SP#14 and is scheduled for approval at SP#15. Dependencies on IETF exist. Approved SP#15
- 1944: -
- 1945: Per 26/2-02: CN1 is not aware of any requirements and is not doing anything on this task.
- 1946: Incorporated into IMS access security TS (33.203) which will be presented for info at SP#14 and is scheduled for approval at SP#15.Editors notes removed SP#16&17
- 1947: SA#17 completed
- 1948: -
- 1949: -
- 1950: -
- 1951: -
- 1952: -
- 1953: -
- 1954: -
- 1955: -
- 1956: -
- 1957: -
- 1958: -
- 1959: -
- 1960: [DAB 08-03-02] - No work required in CN4
- 1961: -
- 1962: -
- 1963: CN4#11 30/11/01: No inputs received in CN4 / 14/02/02 Completed(introduced in 29.228)
- 1964: [DAB - 23/05/03] - 100 % complete
- 1965: -
- 1966: CN4#11 30/11/01: No inputs received in CN4 / CN4#12bis 14/02/02: WID approved / 17th May 100% complete. 3GPP TS 29.329 will be sent for approval in CN#16
- 1967: SA16: Part of Rel5 only if completed in September 02. Marked as closed 12/2008 (was marked 72% complete)
- 1968: -
- 1969: -
- 1970: -
- 1971: -
- 1972: -

| ID | WBS | Task | Duration | Start | Finish | Predecessors | Complete | Baseline start | Baseline finish | Baseline duration | Constraint | Resources | Work | Actual work | Text1 | Text4 | Text5 | Text6 | Text8 | Text12 | Text3 |
| --- | --- | --- | --- | --- | --- | --- | --- | --- | --- | --- | --- | --- | --- | --- | --- | --- | --- | --- | --- | --- | --- |
| 1973 | 81.10 | **CAMEL control of IMS services** | 365d | 2001-04-16 A | 2002-09-06 A |  | 100% | 2001-04-16 | 2002-09-06 | 365d |  | N2 | 9952h | 9952h | IMS-CAMEL | Lucent | Angelica Remoquillo | Rel-5 | Kimmo |  |  |
| 1974 | 81.10.1 | Stage2 work 'general' | 365d | 2001-04-16 A | 2002-09-06 A |  | 100% | 2001-04-16 | 2002-09-06 | 365d | finish no earlier than 2002-09-06 | N2 | 2920h | 2920h |  |  |  | Rel-5 | Kimmo |  |  |
| 1975 | 81.10.2 | Stage3 work 'CAP' | 175d | 2002-01-07 A | 2002-09-06 A |  | 100% | 2002-01-07 | 2002-09-06 | 175d | finish no earlier than 2002-09-06 | N2 | 1400h | 1400h |  |  |  | Rel-5 | Kimmo |  |  |
| 1976 | 81.10.3 | Stage2 work 'Si interface' | 175d | 2002-01-07 A | 2002-09-06 A |  | 100% | 2002-01-07 | 2002-09-06 | 175d | finish no earlier than 2002-09-06 | N2 | 1400h | 1400h |  |  |  | Rel-5 | Kimmo |  |  |
| 1977 | 81.10.4 | Stage3 work 'Si interface' | 82d | 2002-02-14 A | 2002-06-07 A |  | 100% | 2002-02-14 | 2002-06-07 | 82d | finish no earlier than 2002-06-07 | N4 | 656h | 656h |  |  |  | Rel-5 | Kimmo |  |  |
| 1978 | 81.10.5 | Deleted - SDM issues for CAMEL control of IMS | 82d | 2002-02-14 A | 2002-06-07 A |  | 100% | 2002-02-14 | 2002-06-07 | 82d | finish no earlier than 2002-06-07 | N4 | 656h | 656h |  |  |  | Rel-5 | Kimmo | NP-17 |  |
| 1979 | 81.11 | Pre-pay/real-time charging in IMS | 196d | 2001-06-15 A | 2002-03-15 A |  | 100% | 2001-06-15 | 2002-03-15 | 196d | finish no earlier than 2002-03-15 | S1 | 1568h | 1568h |  |  |  | Rel-5 | Alain |  |  |
| 1980 | 81.12 | **Charging** | 289d | 2001-08-06 A | 2002-09-12 A |  | 100% | 2001-08-06 | 2002-09-12 | 289d |  | S2,S5 | 6632h | 6632h | OAM-CH | T-Mobile | karl-heinz.nenner@t-mobile.de | Rel-5 | Dionisio |  | 32.225 |
| 1981 | 81.12.1 | Charging Implications of IMS architecture | 75d | 2001-08-06 A | 2001-11-16 A |  | 100% | 2001-08-06 | 2001-11-16 | 75d | finish no earlier than 2001-11-16 | S2 | 600h | 600h |  |  |  | Rel-5 | Maurice |  |  |
| 1982 | 81.12.2 | Charging management for IMS (off-line & on-line) | 214d | 2001-11-19 A | 2002-09-12 A | 1981 | 100% | 2001-11-19 | 2002-09-12 | 214d | finish no earlier than 2002-09-12 | S5 | 1712h | 1712h | OAM-CH |  |  | Rel-5 | Dionisio |  | 32.225 |
| 1983 | 86.1.6.10 | Billing, accounting and call detail record aspects | 251d | 2001-09-27 A | 2002-09-12 A |  | 100% | 2001-09-27 | 2002-09-12 | 251d | finish no earlier than 2002-09-12 | S5 | 2008h | 2008h | OAM-CH | T-Mobile | Karl-Heinz.Nenner@T-MOBILE.DE | Rel-5 | Dionisio |  | 32.225 |
| 1984 | 81.13 | **Other IETF dependencies** | 401d | 2000-11-24 A | 2002-06-07 A |  | 100% | 2000-11-24 | 2002-06-07 | 401d |  | NP | 9624h | 9624h |  |  |  | Rel-5 |  |  |  |
| 1985 | 81.13.1 | IETF: draft-ietf-aaa-diameter - should be CN4 | 401d | 2000-11-24 A | 2002-06-07 A |  | 100% | 2000-11-24 | 2002-06-07 | 401d | finish no earlier than 2002-06-07 | NP | 3208h | 3208h |  |  |  | Rel-5 |  |  |  |
| 1986 | 81.13.2 | IETF: draft-johansson-aaa-diameter-mm-app - should be CN4 | 401d | 2000-11-24 A | 2002-06-07 A |  | 100% | 2000-11-24 | 2002-06-07 | 401d | finish no earlier than 2002-06-07 | NP | 3208h | 3208h |  |  |  | Rel-5 |  |  |  |
| 1987 | 81.15 | Conformance Test Aspects - Provisioning of IMS | 205d | 2002-03-18 A | 2002-12-27 A |  | 100% | 2002-03-18 | 2002-12-27 | 205d | finish no earlier than 2002-12-27 | T1 | 1640h | 1640h | IMS-TEST |  |  | Rel-5 | Ingbert |  |  |
| 1988 | 81.16 | Testing of support for IMS - prose | 270d | 2002-09-18 A | 2003-09-30 A |  | 100% | 2002-09-18 | 2003-09-30 | 270d | finish no earlier than 2003-09-30 | T1 | 2160h | 2160h |  | Anritsu | dan.fox@eu.anritsu.com | Rel-5 | Ingbert |  | 34.108, 34.123 |
| 1989 | 81.17 | Testing of support for IMS - TTCN | 381d | 2002-09-18 A | 2004-03-03 A |  | 100% | 2002-09-18 | 2004-03-03 | 381d | finish no earlier than 2004-03-03 | T1 | 3048h | 3048h |  | Anritsu | dan.fox@eu.anritsu.com | Rel-5 | Ingbert |  | 34.108, 34.123 |
| 1990 | 82 | **Extended Transparent End-to-End PS Streaming Service** | 313d? | 2002-01-03 A | 2003-03-17 A |  | 100% | 2002-01-03 | 2003-03-17 | 313d? |  | S4 | 6224h | 6224h | PSS-E | Ericsson | olle.franceschi@ericsson.com | Rel-5 | Paolo |  | 26.233, 26.234 |
| 1991 | 82.1 | **Stage 1** | 86d? | 2002-11-18 A | 2003-03-17 A |  | 100% | 2002-11-18 | 2003-03-17 | 86d? |  | S1 | 1376h | 1376h |  | Vodafone | stephen.wolak@vodafone.com | Rel-5 | Alain |  | 22.233 |
| 1992 | 566.1.1 | Interaction with other services | 86d? | 2002-11-18 A | 2003-03-17 A |  | 100% | 2002-11-18 | 2003-03-17 | 86d? | finish no earlier than 2003-03-17 | S1 | 688h | 688h |  | Vodafone | stephen.wolak@vodafone.com | Rel-5 | Alain |  | 22.233 |
| 1993 | 82.2 | Stage 2 (version Rel5 of TS 26.234) | 51d | 2002-01-03 A | 2002-03-14 A |  | 100% | 2002-01-03 | 2002-03-14 | 51d | finish no earlier than 2002-03-26 | S4 | 408h | 408h |  |  |  | Rel-5 | Paolo |  | 26.234 |
| 1994 | 82.3 | RTP usage model | 242d | 2002-01-03 A | 2002-12-06 A |  | 100% | 2002-01-03 | 2002-12-06 | 242d | finish no earlier than 2002-12-06 | S4 | 1936h | 1936h |  |  |  | Rel-5 | Paolo |  | 26.937 |
| 1995 | 83 | **Rel-5 OSA enhancements** | 955d | 1999-04-27 A | 2002-12-20 A |  | 100% | 1999-04-27 | 2002-12-20 | 955d |  | S1 | 62480h | 62480h | OSA1 | Siemens | Joerg Swetina (joerg.swetina@nw.neclab.eu) | Rel-5 | Alain |  | 22.127, 23.127, 29.198-x, 29.998-x |
| 1996 | 83.1 | General Stage 2 for Rel5 | 194d | 2001-09-11 A | 2002-06-07 A |  | 100% | 2001-09-11 | 2002-06-07 | 194d |  | S2 | 1232h | 1232h |  |  |  | Rel-5 | Maurice |  |  |

Notes:
- 1973: -
- 1974: DAB 12.12.01 split into cn4 and cn2 parts
- 1975: DAB 12.12.01 split into cn4 and cn2 parts
- 1976: DAB 12.12.01 split into cn4 and cn2 parts
- 1977: [DAB 08-03-02] - UID 12004 is MASTER of UID 14998 / 17 May need to be recearch possible impact on 23.008 & 23.016, changes to 29.002 are done.
- 1978: Marked as stopped 12/2008
- 1979: Marked as closed 12/2008 (was marked 60% complete)
- 1980: -
- 1981: -
- 1982: -
- 1983: -
- 1984: Was introduced at SP#13 by Ileana Leuca (exact position in the WP and related WG have to be defined)
- 1985: Marked as closed 12/2008 (was marked 90% complete)
- 1986: Marked as closed 12/2008 (was marked 50% complete)
- 1987: The task is a building block, individual work items are being considered but are constrained by lack of supporting companies. Marked as stopped 12/2008
- 1988: Marked as stopped 12/2008
- 1989: Marked as stopped 12/2008
- 1990: -
- 1991: 2nd resp SA4
- 1992: 2nd resp SA4. Marked as closed 12/2008 (was marked 65% complete)
- 1993: 2nd resp SA2
- 1994: Marked as closed 12/2008 (was marked 90% complete)
- 1995: -
- 1996: Marked as closed 12/2008 (was marked 47% complete)

| ID | WBS | Task | Duration | Start | Finish | Predecessors | Complete | Baseline start | Baseline finish | Baseline duration | Constraint | Resources | Work | Actual work | Text1 | Text6 | Text8 | Text3 | Text4 | Text5 |
| --- | --- | --- | --- | --- | --- | --- | --- | --- | --- | --- | --- | --- | --- | --- | --- | --- | --- | --- | --- | --- |
| 1997 | 83.2 | **OSA APIs for Multimedia Call Control** | 499d | 2000-07-11 A | 2002-06-07 A |  | 100% | 2000-07-11 | 2002-06-07 | 499d |  | S2 | 5960h | 5960h | OSA1-CSCF | Rel-5 | Maurice |  |  |  |
| 1998 | 83.2.1 | Stage 1 | 438d | 2000-07-11 A | 2002-03-14 A |  | 100% | 2000-07-11 | 2002-03-14 | 438d | finish no earlier than 2002-03-14 | S1 | 3504h | 3504h |  | Rel-5 | Alain | 22.127 | Siemens | Manfred.leitgeb@siemens.at |
| 1999 | 83.2.2 | Multimedia Call Control - Stages 2 and 3 | 194d | 2001-09-11 A | 2002-06-07 A |  | 100% | 2001-09-11 | 2002-06-07 | 194d | finish no earlier than 2002-06-07 | N5 | 1552h | 1552h |  | Rel-5 | Kimmo | 29.198-04 |  |  |
| 2000 | 83.3 | Generic user interaction - Stage 3 | 194d | 2001-09-11 A | 2002-06-07 A |  | 100% | 2001-09-11 | 2002-06-07 | 194d | finish no earlier than 2002-06-07 | N5 | 1552h | 1552h |  | Rel-5 | Kimmo | 29.198-05 |  |  |
| 2001 | 83.4 | Charging - Stage 3 | 194d | 2001-09-11 A | 2002-06-07 A |  | 100% | 2001-09-11 | 2002-06-07 | 194d | finish no earlier than 2002-06-07 | N5 | 1552h | 1552h |  | Rel-5 | Kimmo | 29.198-12 |  |  |
| 2002 | 83.5 | Call Control Service Mapping; Multiparty Call Control SIP - Stage 3 | 194d | 2001-09-11 A | 2002-06-07 A |  | 100% | 2001-09-11 | 2002-06-07 | 194d | finish no earlier than 2002-06-07 | N5 | 1552h | 1552h |  | Rel-5 | Kimmo | 29.998-04-4 |  |  |
| 2003 | 83.6 | WSDL APIs for SOAP/HTTP - Stage 3 | 455d | 2000-09-11 A | 2002-06-07 A |  | 100% | 2000-09-11 | 2002-06-07 | 455d | finish no earlier than 2002-06-07 | N5 | 3640h | 3640h |  | Rel-5 | Kimmo | 29.198, 29.998 |  |  |
| 2004 | 83.7 | **OSA security** | 639d | 2000-07-11 A | 2002-12-20 A |  | 100% | 2000-07-11 | 2002-12-20 | 639d |  | S3 | 15000h | 15000h | OSA1-SEC | Rel-5 | Dionisio |  | BT | colin.blanchard@bt.com |
| 2005 | 83.7.1 | Stage 1 | 349d | 2000-07-11 A | 2001-11-09 A |  | 100% | 2000-07-11 | 2001-11-09 | 349d | finish no earlier than 2001-11-09 | S1 | 2792h | 2792h |  | Rel-5 | Alain | 22.127 | Siemens | Manfred.leitgeb@siemens.at |
| 2006 | 83.7.2 | Stage 3 | 430d | 2000-10-23 A | 2002-06-14 A |  | 100% | 2000-10-23 | 2002-06-14 | 430d | finish no earlier than 2002-06-14 | S3 | 3440h | 3440h |  | Rel-5 | Dionisio |  |  |  |
| 2007 | 83.7.3 | security related SCF(s) definition | 186d | 2001-09-21 A | 2002-06-07 A |  | 100% | 2001-09-21 | 2002-06-07 | 186d | finish no earlier than 2002-06-07 | N5 | 1488h | 1488h |  | Rel-5 | Kimmo | 29.198, 29.998 | Ericsson | Ard.Jan.Moerdijk@eln.ericsson.se |
| 2008 | 83.7.4 | changes required from supporting platforms, e.g. gsmSCF, HLR | 69d | 2000-09-11 A | 2000-12-14 A |  | 100% | 2000-09-11 | 2000-12-14 | 69d | finish no earlier than 2000-12-14 | S3 | 552h | 552h |  | Rel-5 | Dionisio |  |  |  |
| 2009 | 567.7.5 | Security (moved from Rel-6) | 202d | 2002-03-14 A | 2002-12-20 A |  | 100% | 2002-03-14 | 2002-12-20 | 202d | finish no earlier than 2002-12-20 | S3 | 1616h | 1616h |  | Rel-5 | Dionisio |  |  |  |
| 2010 | 83.8 | **Interactions OSA - e-commerce** | 815d | 1999-04-27 A | 2002-06-07 A |  | 100% | 1999-04-27 | 2002-06-07 | 815d |  | S2 | 6152h | 6152h | OSA1-ECOM | Rel-5 | Maurice |  |  |  |
| 2011 | 83.8.1 | Stage 1 | 439d | 1999-04-27 A | 2000-12-28 A |  | 100% | 1999-04-27 | 2000-12-28 | 439d | finish no earlier than 2000-12-28 | S1 | 3504h | 3504h |  | Rel-5 | Alain | 22.127 | Siemens | Joerg Swetina (joerg.swetina@nw.neclab.eu) |
| 2012 | 83.8.2 | Stages 2 and 3 | 186d | 2001-09-21 A | 2002-06-07 A |  | 100% | 2001-09-21 | 2002-06-07 | 186d | finish no earlier than 2002-06-07 | N5 | 1488h | 1488h |  | Rel-5 | Kimmo | 29.198, 29.998 | Ericsson | Ard.Jan.Moerdijk@eln.ericsson.se |
| 2013 | 83.9 | Policy Management - Stage 3 | 194d | 2001-09-11 A | 2002-06-07 A |  | 100% | 2001-09-11 | 2002-06-07 | 194d | finish no earlier than 2002-06-07 | N5 | 1552h | 1552h |  | Rel-5 | Kimmo | 29.198-13 |  |  |
| 2014 | 83.10 | Presence and Availability Management (PAM) - Stage 3 | 194d | 2001-09-11 A | 2002-06-07 A |  | 100% | 2001-09-11 | 2002-06-07 | 194d | finish no earlier than 2002-06-07 | N5 | 1552h | 1552h |  | Rel-5 | Kimmo | 29.198-14 |  |  |
| 2015 | 83.11 | **CHECK STATUS - LCS - OSA interfaces** | 455d | 2000-09-11 A | 2002-06-07 A |  | 100% | 2000-09-11 | 2002-06-07 | 455d |  | S1 | 5656h | 5656h | OSA1-LCSI | Rel-5 | Alain |  | Siemens | Joerg Swetina (joerg.swetina@nw.neclab.eu) |
| 2016 | 83.11.1 | Stage 1 | 65d | 2000-09-11 A | 2000-12-08 A |  | 100% | 2000-09-11 | 2000-12-08 | 65d | finish no earlier than 2000-12-08 | S1 | 520h | 520h |  | Rel-5 | Alain | 22.127 | Siemens | Joerg Swetina (joerg.swetina@nw.neclab.eu) |
| 2017 | 83.11.2 | Stage 2 | 1d | 2000-12-11 A | 2000-12-11 A | 2016 | 100% | 2000-12-11 | 2000-12-11 | 1d | finish no earlier than 2000-12-11 | S2 | 8h | 8h |  | Rel-5 | Maurice | 23.127 | Ericsson | Christophe GOURRAUD |
| 2018 | 83.11.3 | Stage 3 | 186d | 2001-09-21 A | 2002-06-07 A | 2017 | 100% | 2001-09-21 | 2002-06-07 | 186d | finish no earlier than 2002-06-07 | N5 | 1488h | 1488h |  | Rel-5 | Kimmo | 29.198, 29.998 | Ericsson | Ard.Jan.Moerdijk@eln.ericsson.se |
| 2019 | 567.12 | Access to User Profile | 145d | 2001-06-01 A | 2001-12-20 A |  | 100% | 2001-06-01 | 2001-12-20 | 145d | finish no earlier than 2001-12-20 | S1 | 1160h | 1160h | OSA2-UP | Rel-5 | Alain |  |  |  |
| 2020 | 567.13 | **Retrieval of Terminal capabilities** | 634d | 2000-07-11 A | 2002-12-13 A |  | 100% | 2000-07-11 | 2002-12-13 | 634d |  | S2 | 10808h | 10808h | OSA2-TC | Rel-5 | Maurice |  |  |  |
| 2021 | 567.13.1 | Stage 1 | 132d | 2000-07-11 A | 2001-01-10 A |  | 100% | 2000-07-11 | 2001-01-10 | 132d | finish no earlier than 2001-01-10 | S1 | 1056h | 1056h |  | Rel-5 | Alain | 22.127 | Siemens | Joerg Swetina (joerg.swetina@nw.neclab.eu) |
| 2022 | 567.13.2 | Stages 2 and 3 | 321d | 2001-09-21 A | 2002-12-13 A | 2021 | 100% | 2001-09-21 | 2002-12-13 | 321d | finish no earlier than 2002-12-13 | N5 | 2568h | 2568h |  | Rel-5 | Kimmo | 29.198, 29.998 | Ericsson | Ard.Jan.Moerdijk@eln.ericsson.se |
| 2023 | 567.13.3 | Provisioning of the terminal capabilities | 445d | 2001-04-02 A | 2002-12-13 A |  | 100% | 2001-04-02 | 2002-12-13 | 445d | finish no earlier than 2002-12-13 | T2 | 3560h | 3560h |  | Rel-5 |  | 23.057 |  |  |

Notes:
- 1997: For Rel5 even if completed by March
- 1998: -
- 1999: -
- 2000: -
- 2001: -
- 2002: -
- 2003: -
- 2004: CR to correct security specifications in 29.198 scheduled for approval at CN#15
- 2005: -
- 2006: Marked as closed 12/2008 (was marked 80% complete)
- 2007: -
- 2008: -
- 2009: Contribution at S3#25
- 2010: -
- 2011: Marked as closed 12/2008 (was marked 95% complete)
- 2012: -
- 2013: -
- 2014: -
- 2015: az: CN#13 - changed to Rel5
- 2016: -
- 2017: az 24/05/01: Rel4 completion 90->100%.
- 2018: -
- 2019: -
- 2020: -
- 2021: -
- 2022: -
- 2023: According to T2 SWG1 M. Cataldo this is automatically supported by the MExE support of UAProf therefore 100% complete

| ID | WBS | Task | Duration | Start | Finish | Predecessors | Complete | Baseline start | Baseline finish | Baseline duration | Constraint | Resources | Work | Actual work | Text1 | Text4 | Text5 | Text6 | Text8 | Text3 |
| --- | --- | --- | --- | --- | --- | --- | --- | --- | --- | --- | --- | --- | --- | --- | --- | --- | --- | --- | --- | --- |
| 2024 | 84 | **CAMEL phase 4** | 625d | 2000-04-17 A | 2002-09-06 A |  | 100% | 2000-04-17 | 2002-09-06 | 625d |  | S1 | 41104h | 41104h | CAMEL4 | Nokia | keijo.palviainen@nokia.com | Rel-5 | Alain |  |
| 2025 | 84.1 | Service requirements | 565d | 2000-04-17 A | 2002-06-14 A |  | 100% | 2000-04-17 | 2002-06-14 | 565d | finish no earlier than 2002-06-14 | S1 | 4520h | 4520h |  |  |  | Rel-5 | Alain |  |
| 2026 | 84.2 | Call Party Handling | 500d | 2000-07-10 A | 2002-06-07 A |  | 100% | 2000-07-10 | 2002-06-07 | 500d | finish no earlier than 2002-06-07 | N2 | 4000h | 4000h | CAMEL4-CPH |  |  | Rel-5 | Kimmo |  |
| 2027 | 84.3 | Mid call procedure for MO and MT calls | 495d | 2000-07-17 A | 2002-06-07 A |  | 100% | 2000-07-17 | 2002-06-07 | 495d | finish no earlier than 2002-06-07 | N2 | 3960h | 3960h | CAMEL4-MCP |  |  | Rel-5 | Kimmo |  |
| 2028 | 84.4 | Interactions with Optimal Routing | 430d | 2000-07-17 A | 2002-03-08 A |  | 100% | 2000-07-17 | 2002-03-08 | 430d | finish no earlier than 2002-03-08 | N2 | 3440h | 3440h | CAMEL4-IOR |  |  | Rel-5 | Kimmo |  |
| 2029 | 84.5 | Inclusion of flexible tone injection | 430d | 2000-07-17 A | 2002-03-08 A |  | 100% | 2000-07-17 | 2002-03-08 | 430d | finish no earlier than 2002-03-08 | N2 | 3440h | 3440h | CAMEL4-IFTI |  |  | Rel-5 | Kimmo |  |
| 2030 | 84.6 | CSE control over MT SMS | 430d | 2000-07-17 A | 2002-03-08 A |  | 100% | 2000-07-17 | 2002-03-08 | 430d | finish no earlier than 2002-03-08 | N2 | 3440h | 3440h | CAMEL4-CCSMS |  |  | Rel-5 | Kimmo |  |
| 2031 | 84.7 | Notification of GPRS mobility management to CSE | 331d | 2001-03-02 A | 2002-06-07 A |  | 100% | 2001-03-02 | 2002-06-07 | 331d | finish no earlier than 2002-06-07 | N2 | 2648h | 2648h | CAMEL4-NMM |  |  | Rel-5 | Kimmo |  |
| 2032 | 84.8 | Provision of location information of called subscriber | 266d | 2001-03-02 A | 2002-03-08 A |  | 100% | 2001-03-02 | 2002-03-08 | 266d | finish no earlier than 2002-03-08 | N2 | 2128h | 2128h | CAMEL4-LOCB |  |  | Rel-5 | Kimmo |  |
| 2033 | 84.9 | Inclusion of ODB data in the CSE_HLR interface | 175d | 2001-07-09 A | 2002-03-08 A |  | 100% | 2001-07-09 | 2002-03-08 | 175d | finish no earlier than 2002-03-08 | N2 | 1400h | 1400h | CAMEL4-ODB |  |  | Rel-5 | Kimmo |  |
| 2034 | 84.10 | Location information during an ongoing call (Handover DP) | 280d | 2001-05-14 A | 2002-06-07 A |  | 100% | 2001-05-14 | 2002-06-07 | 280d | finish no earlier than 2002-06-07 | N2 | 2240h | 2240h | CAMEL4-HODP |  |  | Rel-5 | Kimmo |  |
| 2035 | 84.11 | GPRS Any Time Interrogation | 240d | 2001-07-09 A | 2002-06-07 A |  | 100% | 2001-07-09 | 2002-06-07 | 240d | finish no earlier than 2002-06-07 | N2 | 1920h | 1920h | CAMEL4-ATI |  |  | Rel-5 | Kimmo |  |
| 2036 | 84.12 | Transfer of IMEI (with SW version) to CSE | 240d | 2001-07-09 A | 2002-06-07 A |  | 100% | 2001-07-09 | 2002-06-07 | 240d | finish no earlier than 2002-06-07 | N2 | 1920h | 1920h | CAMEL4-ATI |  |  | Rel-5 | Kimmo |  |
| 2037 | 84.13 | Handling of partial implementations of CAMEL4 | 131d | 2002-03-08 A | 2002-09-06 A |  | 100% | 2002-03-08 | 2002-09-06 | 131d | finish no earlier than 2002-06-07 | N2 | 1048h | 1048h | CAMEL4-SUB |  |  | Rel-5 | Kimmo |  |
| 2038 | 85 | **Rel-5 MExE enhancements** | 250d | 2001-03-26 A | 2002-03-08 A |  | 100% | 2001-03-26 | 2002-03-08 | 250d |  | T2 | 2880h | 2880h | MEXE5 |  |  | Rel-5 | Kimmo |  |
| 2039 | 85.1 | MExE Rel-5 Improvements and Investigations | 110d | 2001-03-26 A | 2002-03-08 A |  | 100% | 2001-03-26 | 2002-03-08 | 110d | finish no earlier than 2001-12-17 | T2 | 880h | 880h | MEXE5-ENHANC | Motorola | Mark Cataldo | Rel-5 | Kimmo | 22.057, 23.057 |
| 2040 | 86 | **Wideband Telephony Service - AMR** | 1036d | 2000-01-01 A | 2003-12-19 A |  | 100% | 2000-01-01 | 2003-12-19 | 1036d |  | S4 | 81496h | 81496h | AMRWB | Siemens | Imre.Varga@mch.siemens.de | Rel-5 | Paolo |  |
| 2041 | 86.1 | **Specification** | 636d | 2000-01-01 A | 2002-06-07 A |  | 100% | 2000-01-01 | 2002-06-07 | 636d |  | S4 | 19984h | 19984h |  |  |  | Rel-5 | Paolo |  |
| 2042 | 86.1.1 | Stage 1 | 125d | 2001-10-01 A | 2002-03-22 A |  | 100% | 2001-10-01 | 2002-03-22 | 125d | finish no earlier than 2002-03-22 | S1 | 1000h | 1000h |  |  |  | Rel-5 | Alain |  |
| 2043 | 86.1.2 | **Stage 2** | 77d | 2000-01-03 A | 2000-04-17 A |  | 100% | 2000-01-03 | 2000-04-17 | 77d |  | S4 | 1232h | 1232h |  |  |  | Rel-5 | Paolo |  |
| 2044 | 86.1.2.1 | Design Constraints | 27d | 2000-01-03 A | 2000-02-07 A |  | 100% | 2000-01-03 | 2000-02-07 | 27d |  | S4 [96.3%] | 208h | 208h |  |  |  | Rel-5 | Paolo |  |
| 2045 | 86.1.2.2 | General Description | 51d | 2000-02-07 A | 2000-04-17 A | 2044 | 100% | 2000-02-07 | 2000-04-17 | 51d | start no earlier than 2000-09-25 | S4 | 408h | 408h |  |  |  | Rel-5 | Paolo |  |
| 2046 | 86.1.3 | Feasibility Study | 26d | 2000-04-28 A | 2000-06-02 A | 2045 | 100% | 2000-04-28 | 2000-06-02 | 26d | finish no earlier than 2000-06-02 | S4 | 208h | 208h |  |  |  | Rel-5 | Paolo | 26.901 |
| 2047 | 86.1.4 | N1 Aspects | 66d | 2001-09-21 A | 2001-12-21 A |  | 100% | 2001-09-21 | 2001-12-21 | 66d | finish no earlier than 2001-12-21 | N1 | 528h | 528h |  |  |  | Rel-5 | Frederic |  |
| 2048 | 86.1.5 | N4 work | 83d | 2002-02-13 A | 2002-06-07 A |  | 100% | 2002-02-13 | 2002-06-07 | 83d | finish no earlier than 2002-06-07 | N4 | 664h | 664h |  |  |  | Rel-5 | Kimmo |  |

Notes:
- 2024: -
- 2025: -
- 2026: -
- 2027: -
- 2028: -
- 2029: -
- 2030: -
- 2031: -
- 2032: -
- 2033: Added on May 29, 2001
- 2034: -
- 2035: -
- 2036: -
- 2037: stage2 and stage3 CRs for approval at CN#17
- 2038: -
- 2039: -
- 2040: -
- 2041: -
- 2042: -
- 2043: -
- 2044: -
- 2045: -
- 2046: S4,TD SP-000024: TR 26.901 v.4.0.0
- 2047: Some of N1 tasks: Indication of supported codecs by the MS, Bearer cap negociation, codec indication to MS... / One common set of codec negotiation procedures will be specified as in ID1657.
- 2048: CN4#11 30/11/01: No inputs to CN4 at this meeting / 14/02/02 work started 50% reached / 17 May work is done 100%

| ID | WBS | Task | Duration | Start | Finish | Predecessors | Complete | Baseline start | Baseline finish | Baseline duration | Constraint | Resources | Work | Actual work | Text6 | Text8 | Text1 | Text3 | Text12 | Text4 | Text5 |
| --- | --- | --- | --- | --- | --- | --- | --- | --- | --- | --- | --- | --- | --- | --- | --- | --- | --- | --- | --- | --- | --- |
| 2049 | 86.1.6 | **Codec issues** | 636d | 2000-01-03 A | 2002-06-07 A |  | 100% | 2000-01-03 | 2002-06-07 | 636d |  | S4 | 9496h | 9496h | Rel-5 | Paolo |  |  |  |  |  |
| 2050 | 86.1.6.1 | Codec qualification | 86d | 2000-02-02 A | 2000-05-31 A |  | 100% | 2000-02-02 | 2000-05-31 | 86d | finish no earlier than 2000-05-31 | S4 | 688h | 688h | Rel-5 | Paolo |  |  |  |  |  |
| 2051 | 86.1.6.2 | Codec selection tests | 102d | 2000-06-01 A | 2000-10-20 A | 2050 | 100% | 2000-06-01 | 2000-10-20 | 102d | finish no earlier than 2000-10-20 | S4 | 816h | 816h | Rel-5 | Paolo |  |  |  |  |  |
| 2052 | 86.1.6.3 | Codec selection | 5d | 2000-10-23 A | 2000-10-27 A | 2051 | 100% | 2000-10-23 | 2000-10-27 | 5d | finish no earlier than 2000-10-27 | S4 | 40h | 40h | Rel-5 | Paolo |  |  |  |  |  |
| 2053 | 86.1.6.4 | TFO AMR-WB | 63d | 2001-12-18 A | 2002-03-14 A |  | 100% | 2001-12-18 | 2002-03-14 | 63d | finish no earlier than 2002-03-14 | S4 | 504h | 504h | Rel-5 | Paolo | AMRWB-TFO |  |  |  |  |
| 2054 | 86.1.6.5 | Other codec issues (verif., characterization) | 441d | 2000-09-29 A | 2002-06-07 A |  | 100% | 2000-09-29 | 2002-06-07 | 441d | finish no earlier than 2002-06-07 | S4 | 3528h | 3528h | Rel-5 | Paolo |  | 26.976 |  |  |  |
| 2055 | 86.1.6.6 | AMR-WB and narrrowband interworking | 121d | 2001-09-27 A | 2002-03-14 A |  | 100% | 2001-09-27 | 2002-03-14 | 121d | finish no earlier than 2002-03-14 | S4 | 968h | 968h | Rel-5 | Paolo | AMRWB-IWG |  |  |  |  |
| 2056 | 86.1.6.7 | Interworking with fixed broadband networks | 121d | 2001-09-27 A | 2002-03-14 A |  | 100% | 2001-09-27 | 2002-03-14 | 121d | finish no earlier than 2002-03-14 | S4 | 968h | 968h | Rel-5 | Paolo |  |  |  |  |  |
| 2057 | 86.1.6.8 | Tones and announcements | 121d | 2001-09-27 A | 2002-03-14 A |  | 100% | 2001-09-27 | 2002-03-14 | 121d | finish no earlier than 2002-03-14 | S4 | 968h | 968h | Rel-5 | Paolo |  |  |  |  |  |
| 2058 | 86.1.6.9 | Deleted - WB Conferencing and WB Voice Group calls | 1d | 2000-01-03 A | 2000-01-03 A |  | 100% | 2000-01-03 | 2000-01-03 | 1d | finish no earlier than 2000-01-03 | S1 | 8h | 8h | Rel-5 | Alain |  |  | SP-07 |  |  |
| 2059 | 86.1.8 | **Conformance tests (CRs to 34 series)** | 74d | 2000-01-01 A | 2000-04-12 A |  | 100% | 2000-01-01 | 2000-04-12 | 74d |  | T1 | 1768h | 1768h | Rel-5 | Ingbert |  |  |  |  |  |
| 2060 | 86.1.8.1 | **Terminal Acoustic Characteristics** | 74d | 2000-01-01 A | 2000-04-12 A |  | 100% | 2000-01-01 | 2000-04-12 | 74d |  | S4 | 1176h | 1176h | Rel-5 | Paolo |  |  |  |  |  |
| 2061 | 86.1.8.1.1 | Definition | 22d | 2000-01-01 A | 2000-01-31 A |  | 100% | 2000-01-01 | 2000-01-31 | 22d | finish no earlier than 2000-01-28 | S4 | 168h | 168h | Rel-5 | Paolo |  | 26.131 |  |  |  |
| 2062 | 86.1.8.1.2 | Test specification | 52d | 2000-02-01 A | 2000-04-12 A | 2061 | 100% | 2000-02-01 | 2000-04-12 | 52d | finish no earlier than 2000-03-13 | S4 | 416h | 416h | Rel-5 | Paolo |  | 26.132 |  |  |  |
| 2063 | 86.2 | Floating-point ANSI-C code for the AMR-WB speech codec | 123d | 2001-09-25 A | 2002-03-14 A |  | 100% | 2001-09-25 | 2002-03-14 | 123d | finish no earlier than 2002-03-14 | S4 | 984h | 984h | Rel-5 | Paolo | AMRWB-FP | 26.204 |  | Nokia | janne.m.vainio@nokia.com |
| 2064 | 86.3 | **Support of AMR-WB in GERAN: GMSK and 8PSK WB FR / HR** | 651d | 2000-01-03 A | 2002-06-28 A |  | 100% | 2000-01-03 | 2002-06-28 | 651d |  | GP | 23488h | 23488h | Rel-5 | Paolo | GAMRWB |  |  |  |  |
| 2065 | 86.3.1 | Channel coding in 45.003 | 591d | 2000-01-03 A | 2002-04-05 A |  | 100% | 2000-01-03 | 2002-04-05 | 591d |  | GP | 4720h | 4720h | Rel-5 | Paolo |  |  |  |  |  |
| 2066 | 86.3.2 | Signalling for the A interface | 391d | 2000-01-03 A | 2001-06-29 A |  | 100% | 2000-01-03 | 2001-06-29 | 391d | finish no earlier than 2001-06-29 | GP | 3120h | 3120h | Rel-5 | Paolo |  |  |  |  |  |
| 2067 | 86.3.3 | Signalling for Iu | 651d | 2000-01-03 A | 2002-06-28 A |  | 100% | 2000-01-03 | 2002-06-28 | 651d | finish no earlier than 2002-06-28 | GP | 5200h | 5200h | Rel-5 | Paolo |  |  |  |  |  |
| 2068 | 86.3.4 | Receiver performance in TS 45.005 | 325d | 2001-04-02 A | 2002-06-28 A |  | 100% | 2001-04-02 | 2002-06-28 | 325d | finish no earlier than 2002-06-28 | GP | 2600h | 2600h | Rel-5 | Paolo |  |  |  |  |  |
| 2069 | 86.3.5 | Link Adaptation in 45.009 | 330d | 2001-03-26 A | 2002-06-28 A |  | 100% | 2001-03-26 | 2002-06-28 | 330d | finish no earlier than 2002-06-28 | GP | 2640h | 2640h | Rel-5 | Paolo |  |  |  |  |  |
| 2070 | 86.4 | **Deleted - GERAN MS conformance test for AMR-WB** | 1036d | 2000-01-03 A | 2003-12-19 A |  | 100% | 2000-01-03 | 2003-12-19 | 1036d |  | GP | 16568h | 16568h | Rel-5 | Paolo |  |  |  |  |  |
| 2071 | 86.4.1 | Deleted - MS test for AMR-WB | 1036d | 2000-01-03 A | 2003-12-19 A |  | 100% | 2000-01-03 | 2003-12-19 | 1036d | finish no earlier than 2003-12-19 | GP | 8280h | 8280h | Rel-5 | Paolo |  |  | GP-17 |  |  |
| 2072 | 86.5 | **GERAN BTS conformance test for AMR-WB** | 762d | 2000-01-03 A | 2002-12-02 A |  | 100% | 2000-01-03 | 2002-12-02 | 762d |  | GP | 12184h | 12184h | Rel-5 | Paolo |  |  |  |  |  |
| 2073 | 86.5.1 | BTS test | 762d | 2000-01-03 A | 2002-12-02 A |  | 100% | 2000-01-03 | 2002-12-02 | 762d | finish no earlier than 2002-12-02 | GP | 6088h | 6088h | Rel-5 | Paolo |  |  |  |  |  |

Notes:
- 2049: -
- 2050: -
- 2051: -
- 2052: -
- 2053: -
- 2054: ANSI C-Code , Test Sequences, Speech Transcoding Functions, Error Concealment of lost frames, Source Controlled Bit-Rate Operation, Voice Activity Detector, Frame Structure
- 2055: -
- 2056: -
- 2057: -
- 2058: -
- 2059: -
- 2060: -
- 2061: -
- 2062: -
- 2063: -
- 2064: -
- 2065: 50098 -> 50298
- 2066: -
- 2067: -
- 2068: -
- 2069: -
- 2070: Not started 02/2003. Marked as stopped 12/2008
- 2071: Marked as stopped 12/2008
- 2072: -
- 2073: -

| ID | WBS | Task | Duration | Start | Finish | Complete | Baseline start | Baseline finish | Baseline duration | Constraint | Resources | Work | Actual work | Text1 | Text6 | Text8 | Text3 | Text4 | Text5 |
| --- | --- | --- | --- | --- | --- | --- | --- | --- | --- | --- | --- | --- | --- | --- | --- | --- | --- | --- | --- |
| 2074 | 11 | **Terminal interfaces** | 223d | 2001-05-14 A | 2002-03-20 A | 100% | 2001-05-14 | 2002-03-20 | 223d |  | T2 | 3568h | 3568h | TI | Rel-5 | Kimmo |  |  |  |
| 2075 | 87 | Terminal local model enhancements | 223d | 2001-05-14 A | 2002-03-20 A | 100% | 2001-05-14 | 2002-03-20 | 223d | finish no earlier than 2002-03-20 | T2 | 1784h | 1784h | TLM5 | Rel-5 |  | 23.227 |  |  |
| 2076 | 88 | **Rel-5 Location Services enhancements** | 845d | 2000-04-03 A | 2003-06-27 A | 100% | 2000-04-03 | 2003-06-27 | 845d |  | S2,S5 | 86804h | 86804h | LCS1 | Rel-5 | Maurice |  | Nokia | Jan Kall |
| 2077 | 88.1 | **UE positioning** | 315d | 2001-01-15 A | 2002-03-29 A | 100% | 2001-01-15 | 2002-03-29 | 315d |  | RP | 5560h | 5560h | LCS1-UEpos | Rel-5 | Issam |  |  |  |
| 2078 | 88.1.1 | UE positioning enhancements for 1.28 Mcps TDD | 255d | 2001-04-09 A | 2002-03-29 A | 100% | 2001-04-09 | 2002-03-29 | 255d | finish no earlier than 2002-03-29 | R2 | 2040h | 2040h | LCS-128Pos | Rel-5 | Joern |  | CATT | Xiaohua Mei |
| 2079 | 88.1.2 | Open SMLC-SRNC Interface within the UTRAN to support A-GPS Positioning | 195d | 2001-01-15 A | 2001-10-12 A | 100% | 2001-01-15 | 2001-10-12 | 195d |  | R2 | 1560h | 1560h | LCS-INTF | Rel-5 | Joern |  | Qualcomm | Kirk Burroughs |
| 2080 | 88.2 | **Event based and Periodic LCS** | 535d | 2000-05-22 A | 2002-06-07 A | 100% | 2000-05-22 | 2002-06-07 | 535d |  | S1 | 6288h | 6288h | LCS1-EBP | Rel-5 | Alain |  |  |  |
| 2081 | 88.2.1 | Stage 1 | 130d | 2000-05-22 A | 2000-11-17 A | 100% | 2000-05-22 | 2000-11-17 | 130d | finish no earlier than 2000-07-21 | S1 | 1040h | 1040h |  | Rel-5 | Alain | 22.071 | Pacific Bell Wireless | Randolph Wohlert (rwohlert@tri.sbc.com) |
| 2082 | 88.2.2 | Stage 2 specification | 60d | 2000-11-06 A | 2001-01-26 A | 100% | 2000-11-06 | 2001-01-26 | 60d | finish no earlier than 2001-01-26 | S2 | 480h | 480h |  | Rel-5 | Maurice |  |  |  |
| 2083 | 88.2.3 | Impact on MAP | 61d | 2002-03-15 A | 2002-06-07 A | 100% | 2002-03-15 | 2002-06-07 | 61d | finish no earlier than 2002-06-07 | N4 | 488h | 488h |  | Rel-5 | Kimmo |  |  |  |
| 2084 | 88.3 | **Location Services for GERAN in A/Gb Mode** | 485d | 2000-04-03 A | 2002-02-08 A | 100% | 2000-04-03 | 2002-02-08 | 485d |  | GP | 14760h | 14760h | LCS-GERAN | Rel-5 | Paolo |  |  |  |
| 2085 | 88.3.1 | GERAN LCS Stage 2 (first release) | 485d | 2000-04-03 A | 2002-02-08 A | 100% | 2000-04-03 | 2002-02-08 | 485d | finish no earlier than 2002-02-08 | GP,S2,G1,G2 | 3880h | 3880h |  | Rel-5 | Paolo |  |  |  |
| 2086 | 88.3.2 | Gb interface support for LCS | 370d | 2000-04-03 A | 2001-08-31 A | 100% | 2000-04-03 | 2001-08-31 | 370d | finish no earlier than 2001-08-31 | GP | 2960h | 2960h |  | Rel-5 | Paolo |  |  |  |
| 2087 | 88.3.3 | L3 protocol support for LCS | 305d | 2000-04-03 A | 2001-06-01 A | 100% | 2000-04-03 | 2001-06-01 | 305d | finish no earlier than 2001-06-01 | GP | 2440h | 2440h |  | Rel-5 | Paolo |  |  |  |
| 2088 | 88.3.4 | Stage 3 specifications | 305d | 2000-04-03 A | 2001-06-01 A | 100% | 2000-04-03 | 2001-06-01 | 305d | finish no earlier than 2001-06-01 | GP | 2440h | 2440h |  | Rel-5 | Paolo |  |  |  |
| 2089 | 88.4 | **Location Services for GERAN in Iu Mode** | 585d | 2000-04-03 A | 2002-06-28 A | 100% | 2000-04-03 | 2002-06-28 | 585d |  | S2,G1,G2,R2,R3 | 20996h | 20996h |  | Rel-5 | Paolo |  |  |  |
| 2090 | 88.4.1 | GERAN LCS Stage 2 | 585d | 2000-04-03 A | 2002-06-28 A | 100% | 2000-04-03 | 2002-06-28 | 585d | finish no earlier than 2002-06-28 | S2,G1,G2 | 4680h | 4680h |  | Rel-5 | Paolo |  |  |  |
| 2091 | 88.4.2 | Iu-ps interface support for LCS | 585d | 2000-04-03 A | 2002-06-28 A | 100% | 2000-04-03 | 2002-06-28 | 585d | finish no earlier than 2002-06-28 | R2,R3 | 4680h | 4680h |  | Rel-5 | Paolo |  |  |  |
| 2092 | 88.4.3 | Iu-cs interface support for LCS | 585d | 2000-04-03 A | 2002-06-28 A | 100% | 2000-04-03 | 2002-06-28 | 585d | finish no earlier than 2002-06-28 | R2,R3 | 4680h | 4680h |  | Rel-5 | Paolo |  |  |  |
| 2093 | 88.4.4 | Iur-g interface support for LCS | 62.5d | 2002-01-23 A | 2002-04-19 A | 100% | 2002-01-23 | 2002-04-19 | 62.5d | finish no earlier than 2002-04-19 | G1,G2 | 500h | 500h |  | Rel-5 | Paolo |  |  |  |
| 2094 | 88.4.5 | RRC protocol support for LCS | 75d | 2001-08-20 A | 2001-11-30 A | 100% | 2001-08-20 | 2001-11-30 | 75d | finish no earlier than 2001-11-30 | G1,G2,R2,R3 | 600h | 600h |  | Rel-5 | Paolo |  |  |  |
| 2095 | 88.4.6 | Additional impacts on Broadcast of LCS data on packet channels | 77.5d | 2001-08-20 A | 2001-12-05 A | 100% | 2001-08-20 | 2001-12-05 | 77.5d | finish no earlier than 2001-12-05 | G1,G2,R2,R3 | 620h | 620h |  | Rel-5 | Paolo |  |  |  |
| 2096 | 88.4.7 | Stage 3 specifications | 69.5d | 2002-03-25 A | 2002-06-28 A | 100% | 2002-03-25 | 2002-06-28 | 69.5d | finish no earlier than 2002-06-28 | G1,G2,R2,R3 | 556h | 556h |  | Rel-5 | Paolo |  |  |  |
| 2097 | 88.5 | **GERAN MS Conformance test for LCS** | 280d | 2002-06-03 A | 2003-06-27 A | 100% | 2002-06-03 | 2003-06-27 | 280d |  | GP | 6720h | 6720h | LCS-GERAN-MSconf | Rel-5 | Paolo |  |  |  |
| 2098 | 88.5.1 | Develop LCS MS test case work plan (Release 98/99/4) | 280d | 2002-06-03 A | 2003-06-27 A | 100% | 2002-06-03 | 2003-06-27 | 280d | finish no earlier than 2003-06-27 | G4,G5 | 2240h | 2240h |  | Rel-5 | Paolo |  |  |  |
| 2099 | 88.5.2 | Develop LCS MS test cases | 280d | 2002-06-03 A | 2003-06-27 A | 100% | 2002-06-03 | 2003-06-27 | 280d | finish no earlier than 2003-06-27 | G4,G5 | 2240h | 2240h |  | Rel-5 | Paolo |  |  |  |

Notes:
- 2074: -
- 2075: -
- 2076: -
- 2077: -
- 2078: -
- 2079: Finished at RP#13
- 2080: -
- 2081: Evaluate Event based and Periodic LCS to be included in R00, corresponding Stage 1 description
- 2082: Marked as closed 12/2008 (was marked 51% complete)
- 2083: Possible impact on UTRAN of LCS quality level request / 17 May No stage 2 for event-based & periodic LCS. Work 100% completefor current stage 2
- 2084: -
- 2085: -
- 2086: -
- 2087: -
- 2088: -
- 2089: -
- 2090: -
- 2091: -
- 2092: -
- 2093: FFS
- 2094: -
- 2095: -
- 2096: -
- 2097: -
- 2098: Marked as closed 12/2008 (was marked 60% complete)
- 2099: Marked as closed 12/2008 (was marked 60% complete)

| ID | WBS | Task | Duration | Start | Finish | Predecessors | Complete | Baseline start | Baseline finish | Baseline duration | Constraint | Resources | Work | Actual work | Text1 | Text6 | Text8 | Text12 | Text3 | Text4 | Text5 |
| --- | --- | --- | --- | --- | --- | --- | --- | --- | --- | --- | --- | --- | --- | --- | --- | --- | --- | --- | --- | --- | --- |
| 2100 | 88.6 | **Deleted - GERAN BTS Conformance test for LCS** | 280d | 2002-06-03 A | 2003-06-27 A |  | 100% | 2002-06-03 | 2003-06-27 | 280d |  | GP | 6720h | 6720h | LCS-GERAN-BTSconf | Rel-5 | Paolo | GP-15 |  |  |  |
| 2101 | 88.6.1 | Deleted - Develop LCS BTS test case work plan (Release 98/99/4) | 280d | 2002-06-03 A | 2003-06-27 A |  | 100% | 2002-06-03 | 2003-06-27 | 280d | finish no earlier than 2003-06-27 | G4,G5 | 2240h | 2240h |  | Rel-5 | Paolo | GP-15 |  |  |  |
| 2102 | 88.6.2 | Deleted - Develop LCS BTS test cases | 280d | 2002-06-03 A | 2003-06-27 A |  | 100% | 2002-06-03 | 2003-06-27 | 280d | finish no earlier than 2003-06-27 | G4,G5 | 2240h | 2240h |  | Rel-5 | Paolo | GP-15 |  |  |  |
| 2103 | 88.7 | LCS interoperation stage 2 aspects | 480d | 2000-08-28 A | 2002-06-28 A |  | 100% | 2000-08-28 | 2002-06-28 | 480d |  | S2 | 3840h | 3840h |  | Rel-5 | Maurice |  |  |  |  |
| 2104 | 88.8 | **LCS interoperability aspects to GERAN** | 480d | 2000-08-28 A | 2002-06-28 A |  | 100% | 2000-08-28 | 2002-06-28 | 480d |  | GP,S5 | 7680h | 7680h | LCS-GERAN | Rel-5 | Paolo |  |  |  |  |
| 2105 | 88.8.1 | Co-ordinated development of GSM LCS Phase 2 and UMTS LCS, S2 and GERAN | 480d | 2000-08-28 A | 2002-06-28 A |  | 100% | 2000-08-28 | 2002-06-28 | 480d | finish no earlier than 2002-06-28 | GP,S2,S5,R2,R3,G2,G1 | 3840h | 3840h | LCS-GERAN | Rel-5 | Paolo |  |  |  |  |
| 2106 | 88.9 | FS on LCS support in the IMS | 90d | 2001-02-12 A | 2002-01-18 A |  | 100% | 2001-02-12 | 2002-01-18 | 90d | start no earlier than 2001-02-12 | S1 | 720h | 720h |  | Rel-5 | Alain |  |  |  |  |
| 2107 | 88.10 | Charging and OAM&P for LCS enhancements | 201d | 2001-09-21 A | 2002-06-28 A |  | 100% | 2001-09-21 | 2002-06-28 | 201d | finish no earlier than 2002-06-28 | S5 | 1608h | 1608h | LCS1-OAM | Rel-5 | Dionisio |  | 32-series | VoiceStream, Motorola |  |
| 2108 | 88.11 | New security aspects of LCS (not identified) | 446d | 2000-04-14 A | 2001-12-28 A |  | 100% | 2000-04-14 | 2001-12-28 | 446d | finish no earlier than 2001-12-28 | S3 | 3568h | 3568h | LCS1-SEC | Rel-5 | Dionisio |  |  | Nokia | valtteri.niemi@nokia.com |
| 2109 | 88.12 | Specification for the Le Interface | 45d | 2002-01-14 A | 2002-03-15 A |  | 100% | 2002-01-14 | 2002-03-15 | 45d | start no earlier than 2002-01-14 | S2 | 360h | 360h | LCS1-Le | Rel-5 | Maurice |  |  |  |  |
| 2110 | 88.13 | Deleted - CHECK STATUS - Inter-GMLC interface | 153d | 2002-05-30 A | 2002-12-30 A |  | 100% | 2002-05-30 | 2002-12-30 | 153d | finish no earlier than 2002-12-30 | S2 | 1224h | 1224h |  | Rel-5 | Maurice | SP-10 |  |  |  |
| 2111 | 89 | **Rel-5 Security enhancements** | 615d | 2000-02-21 A | 2002-06-28 A |  | 100% | 2000-02-21 | 2002-06-28 | 615d |  | S3 | 29974.9h | 29974.9h |  | Rel-5 | Dionisio |  |  | Vodafone | Peter.Howard@vodafone.com |
| 2112 | 89.1 | **Network domain security** | 615d | 2000-02-21 A | 2002-06-28 A |  | 100% | 2000-02-21 | 2002-06-28 | 615d |  | S3 | 25054.9h | 25054.9h | SEC1-NDS | Rel-5 | Dionisio |  |  | Telenor | Geir-myrdahl.koien@telenor.com |
| 2113 | 89.1.1 | **Deleted -Control plane protection in core network (e.g., GTP, CAP, MAP/IP, provided by IPsec)** | 541d | 2000-05-12 A | 2002-06-07 A |  | 100% | 2000-05-12 | 2002-06-07 | 541d |  | S3 | 7118.9h | 7118.9h |  | Rel-5 | Dionisio | SP-16 |  |  |  |
| 2114 | 89.1.1.1 | Deleted - Main aspects | 290d | 2000-05-12 A | 2001-06-21 A |  | 100% | 2000-05-12 | 2001-06-21 | 290d | finish no earlier than 2001-06-21 | S3 | 2320h | 2320h |  | Rel-5 | Dionisio | SP-12 |  |  |  |
| 2115 | 89.1.1.2 | Deleted -Integration of GTP signalling security architecture | 191d | 2001-09-14 A | 2002-06-07 A |  | 100% | 2001-09-14 | 2002-06-07 | 191d | finish no earlier than 2002-06-07 | N4 | 1528h | 1528h |  | Rel-5 | Kimmo | NP-16 |  |  |  |
| 2116 | 89.1.2 | **Deleted -User plane protection in core network (e.g., provided by IPsec)** | 615d | 2000-02-21 A | 2002-06-28 A |  | 100% | 2000-02-21 | 2002-06-28 | 615d |  | S3 | 9360h | 9360h |  | Rel-5 | Dionisio | SP-16 |  |  |  |
| 2117 | 89.1.2.1 | Deleted -Main aspects | 349d | 2000-02-21 A | 2001-06-21 A |  | 100% | 2000-02-21 | 2001-06-21 | 349d | finish no earlier than 2001-06-21 | S3 | 2792h | 2792h |  | Rel-5 | Dionisio | SP-12 |  |  |  |
| 2118 | 89.1.2.2 | Deleted -Integration of GTP signalling security architecture | 206d | 2001-09-14 A | 2002-06-28 A |  | 100% | 2001-09-14 | 2002-06-28 | 206d | finish no earlier than 2002-06-28 | N4 | 1648h | 1648h |  | Rel-5 | Kimmo | NP-16 |  |  |  |
| 2119 | 89.1.3 | IP network layer security (NDS/IP) | 457d | 2000-06-15 A | 2002-03-15 A |  | 100% | 2000-06-15 | 2002-03-15 | 457d | finish no earlier than 2002-03-15 | S3 | 3656h | 3656h | SEC1-NDS-IP | Rel-5 | Dionisio |  | 33.210 | Telenor | Geir-myrdahl.koien@telenor.com |
| 2120 | 90 | **Intra Domain Connection of RAN Nodes to Multiple CN Nodes** | 455d | 2000-10-02 A | 2002-06-28 A |  | 100% | 2000-10-02 | 2002-06-28 | 455d |  | S2 | 15136h | 15136h | IUFLEX | Rel-5 | Alain |  | 23.236 | Ericsson | stephen.terrill@ericsson.com |
| 2121 | 90.1 | Overall System Architecture | 188d | 2001-01-03 A | 2001-09-21 A |  | 100% | 2001-01-03 | 2001-09-21 | 188d | finish no earlier than 2001-06-01 | S2 | 1504h | 1504h |  | Rel-5 | Maurice |  |  |  |  |
| 2122 | 90.2 | Stage 3: RAN node selecting CN node | 130d | 2001-09-24 A | 2002-03-22 A | 2121 | 100% | 2001-09-24 | 2002-03-22 | 130d | finish no earlier than 2002-03-22 | R3 | 1040h | 1040h |  | Rel-5 | Juha |  |  | Vodafone | Brendan.McWilliams@gb.vodafone.co.uk |
| 2123 | 90.3 | N1 work | 205d | 2001-09-17 A | 2002-06-28 A |  | 100% | 2001-09-17 | 2002-06-28 | 205d | start no earlier than 2001-09-17 | N1 | 1640h | 1640h |  | Rel-5 | Frederic |  | 24.008 and check 29.018 |  |  |
| 2124 | 90.4 | N4 work | 375d | 2000-10-02 A | 2002-03-08 A |  | 100% | 2000-10-02 | 2002-03-08 | 375d | finish no earlier than 2002-03-15 | N4 | 3000h | 3000h |  | Rel-5 | Kimmo |  |  |  |  |

Notes:
- 2100: Not started 02/3003. Marked as stopped 12/2008
- 2101: Marked as stopped 12/2008
- 2102: Marked as stopped 12/2008
- 2103: Marked as closed 12/2008 (was marked 17% complete)
- 2104: -
- 2105: -
- 2106: Marked as closed 12/2008 (was marked 75% complete)
- 2107: -
- 2108: 14/09/00: WI may need to be split to improve on this date. S3#17 15% complete. No progress since S3#17
- 2109: -
- 2110: Marked as stopped 12/2008
- 2111: Added BB UE authentication and rapporteur added. TO BE DELETED
- 2112: S3#17: All due in Rel5. (WI Update at S3#18). Replaced by NDS-IP and NDS-MAP. TO BE DELETED OR MOVED TO HISTORY FILE
- 2113: Marked as stopped 12/2008
- 2114: TO BE DELETED. Marked as stopped 12/2008
- 2115: Waiting for input from SA3!.... Marked as stopped 12/2008
- 2116: TO BE DELETED. Marked as stopped 12/2008
- 2117: -
- 2118: 14/02/2002 requirements are not clear/not received...Marked as closed 12/2008 (was marked 95 complete)
- 2119: 2002/12: All IPsec RFCs are stable STD Track RFCs. WID updated SP#17
- 2120: No clear indication on the end date. Put to Rel5 by AS.
- 2121: -
- 2122: Not identified
- 2123: -
- 2124: DAB 12.12.01 - % complete to 66% / 14/02/02 Work completed

| ID | WBS | Task | Duration | Start | Finish | Complete | Baseline start | Baseline finish | Baseline duration | Constraint | Resources | Work | Actual work | Text1 | Text4 | Text5 | Text6 | Text8 | Text12 | Text3 |
| --- | --- | --- | --- | --- | --- | --- | --- | --- | --- | --- | --- | --- | --- | --- | --- | --- | --- | --- | --- | --- |
| 2125 | 90.5 | **GERAN work for Intra Domain Connection of RAN Nodes to Multiple CN Nodes** | 101d | 2002-02-08 A | 2002-06-28 A | 100% | 2002-02-08 | 2002-06-28 | 101d |  | GP | 4848h | 4848h | IDCRAN-GERAN | Ericsson | ingemar.backlund@era.ericsson.se | Rel-5 | Paolo |  |  |
| 2126 | 90.5.1 | Stage 2 (changes to ) | 101d | 2002-02-08 A | 2002-06-28 A | 100% | 2002-02-08 | 2002-06-28 | 101d | finish no earlier than 2002-06-28 | G1 | 808h | 808h |  |  |  | Rel-5 | Paolo |  |  |
| 2127 | 90.5.2 | 43.051 Introduction of support for IDNNS in GERAN Iu mode | 101d | 2002-02-08 A | 2002-06-28 A | 100% | 2002-02-08 | 2002-06-28 | 101d | finish no earlier than 2002-06-28 | G1 | 808h | 808h |  |  |  | Rel-5 | Paolo |  |  |
| 2128 | 90.5.3 | Stage 3 (changes to ) | 101d | 2002-02-08 A | 2002-06-28 A | 100% | 2002-02-08 | 2002-06-28 | 101d | finish no earlier than 2002-06-28 | G2 | 808h | 808h |  |  |  | Rel-5 | Gert |  |  |
| 2129 | 90.5.4 | 48.016 Use of Gb interface concepts when a network applies IDNNS | 101d | 2002-02-08 A | 2002-06-28 A | 100% | 2002-02-08 | 2002-06-28 | 101d | finish no earlier than 2002-06-28 | G2 | 808h | 808h |  |  |  | Rel-5 | Gert |  |  |
| 2130 | 90.5.5 | 48.018 Include MSC/VLR identity in CS IMSI paging | 101d | 2002-02-08 A | 2002-06-28 A | 100% | 2002-02-08 | 2002-06-28 | 101d | finish no earlier than 2002-06-28 | G2 | 808h | 808h |  |  |  | Rel-5 | Gert |  |  |
| 2131 | 91 | **Deleted - GERAN improvements 3 (new transport layer on interface A)** | 446d | 2001-04-06 A | 2002-12-20 A | 100% | 2001-04-06 | 2002-12-20 | 446d |  | GP | 14272h | 14272h | GEIMP3 |  |  | Rel-5 | Paolo |  |  |
| 2132 | 91.1 | **Deleted - Evolution of the transport for A** | 446d | 2001-04-06 A | 2002-12-20 A | 100% | 2001-04-06 | 2002-12-20 | 446d |  | GP | 10704h | 10704h | GEIMP3-EtA |  |  | Rel-5 | Paolo | GP-12 |  |
| 2133 | 91.1.1 | Deleted - Definition of a new A/Ater interface Transport Layer option based on the Iu Interface Transport Layer | 446d | 2001-04-06 A | 2002-12-20 A | 100% | 2001-04-06 | 2002-12-20 | 446d | finish no earlier than 2002-12-20 | GP | 3568h | 3568h |  |  |  | Rel-5 | Paolo | GP-12 |  |
| 2134 | 91.1.2 | Deleted - Adaptation of the Layer 3 BSSMAP procedures as required | 446d | 2001-04-06 A | 2002-12-20 A | 100% | 2001-04-06 | 2002-12-20 | 446d | finish no earlier than 2002-12-20 | GP | 3568h | 3568h |  |  |  | Rel-5 | Paolo | GP-12 |  |
| 2135 | 92 | **Rel-5 Charging and OAM&P** | 264d | 2001-09-10 A | 2002-09-12 A | 100% | 2001-09-10 | 2002-09-12 | 264d |  | S5 | 9976h | 9976h | OAM | VoiceStream, Motorola |  | Rel-5 | Dionisio |  |  |
| 2136 | 92.1 | Rel5 Principles, high level Requirements and Architecture | 205d | 2001-09-17 A | 2002-06-28 A | 100% | 2001-09-17 | 2002-06-28 | 205d | finish no earlier than 2002-06-28 | S5 | 1640h | 1640h | OAM-AR/PR | Motorola |  | Rel-5 | Dionisio |  | 32.101, 32.102 |
| 2137 | 92.2 | Rel5 Performance Management | 259d | 2001-09-17 A | 2002-09-12 A | 100% | 2001-09-17 | 2002-09-12 | 259d | finish no earlier than 2002-09-12 | S5 | 2072h | 2072h | OAM-PM | Nortel |  | Rel-5 | Dionisio |  | 32.4xy, 52.402 |
| 2138 | 92.3 | Rel5 Charging Management | 264d | 2001-09-10 A | 2002-09-12 A | 100% | 2001-09-10 | 2002-09-12 | 264d | finish no earlier than 2002-09-12 | S5 | 2112h | 2112h | OAM-CH | T-Mobile | Karl-Heinz.Nenner@T-MOBILE.DE | Rel-5 | Dionisio |  | 32.200, 32.205, 32.215, 32.225, 32.235 |
| 2139 | 92.4 | Rel5 Network Infrastructure Management | 255d | 2001-09-21 A | 2002-09-12 A | 100% | 2001-09-21 | 2002-09-12 | 255d | finish no earlier than 2002-09-12 | S5 | 2040h | 2040h | OAM-NIM | Ericsson | thomas.tovinger@ericsson.com | Rel-5 | Dionisio |  | 32.6xy, 32.3xy |
| 2140 | 93 | **GERAN enhancements for streaming services 1 (RLC enhancements)** | 430d | 2000-11-06 A | 2002-06-28 A | 100% | 2000-11-06 | 2002-06-28 | 430d |  | GP | 8944h | 8944h |  |  |  | Rel-5 | Paolo |  |  |
| 2141 | 93.1 | Concept | 258d | 2000-11-06 A | 2001-10-31 A | 100% | 2000-11-06 | 2001-10-31 | 258d | finish no earlier than 2001-10-31 | GP | 2064h | 2064h |  |  |  | Rel-5 | Paolo |  |  |
| 2142 | 93.2 | RLC protocol enhancement (SDU Discard) | 430d | 2000-11-06 A | 2002-06-28 A | 100% | 2000-11-06 | 2002-06-28 | 430d | finish no earlier than 2002-06-28 | GP | 3440h | 3440h |  |  |  | Rel-5 | Paolo |  |  |
| 2143 | 94 | **GERAN enhancements for streaming services 2 (usage of ECSD)** | 430d | 2000-11-06 A | 2002-06-28 A | 100% | 2000-11-06 | 2002-06-28 | 430d |  | GP | 19840h | 19840h |  | Ericsson | Frank Muller | Rel-5 | Paolo |  |  |
| 2144 | 94.1 | Usage of ECSD Concept | 380d | 2000-11-06 A | 2002-04-19 A | 100% | 2000-11-06 | 2002-04-19 | 380d | finish no earlier than 2002-04-19 | GP | 3040h | 3040h |  |  |  | Rel-5 | Paolo |  |  |
| 2145 | 94.2 | Stage 2 | 380d | 2000-11-06 A | 2002-04-19 A | 100% | 2000-11-06 | 2002-04-19 | 380d | finish no earlier than 2002-04-19 | GP | 3040h | 3040h |  |  |  | Rel-5 | Paolo |  |  |
| 2146 | 94.3 | Stage 3 | 430d | 2000-11-06 A | 2002-06-28 A | 100% | 2000-11-06 | 2002-06-28 | 430d | finish no earlier than 2002-06-28 | GP | 3440h | 3440h |  |  |  | Rel-5 | Paolo |  |  |
| 2147 | 94.4 | RLC PDU formats | 430d | 2000-11-06 A | 2002-06-28 A | 100% | 2000-11-06 | 2002-06-28 | 430d | finish no earlier than 2002-06-28 | GP | 3440h | 3440h |  |  |  | Rel-5 | Paolo |  |  |
| 2148 | 94.5 | MAC header | 430d | 2000-11-06 A | 2002-06-28 A | 100% | 2000-11-06 | 2002-06-28 | 430d | finish no earlier than 2002-06-28 | GP | 3440h | 3440h |  |  |  | Rel-5 | Paolo |  |  |

Notes:
- 2125: Accept changes Gb over IP
- 2126: -
- 2127: -
- 2128: -
- 2129: Closed, accept changes for Gb over IP
- 2130: -
- 2131: Terminated - not standardized. Marked as stopped 12/2008
- 2132: TERMINATED - NOT STANDARDIZED. Marked as stopped 12/2008
- 2133: TERMINATED - NOT STANDARDIZED. Marked as stopped 12/2008
- 2134: TERMINATED - NOT STANDARDIZED. Marked as stopped 12/2008
- 2135: -
- 2136: -
- 2137: -
- 2138: -
- 2139: -
- 2140: -
- 2141: -
- 2142: -
- 2143: AWS, Nokia, Ericsson, Nortel, Siemens, Motorola, Vodafone
- 2144: -
- 2145: -
- 2146: -
- 2147: -
- 2148: -

| ID | WBS | Task | Duration | Start | Finish | Predecessors | Complete | Baseline start | Baseline finish | Baseline duration | Constraint | Resources | Work | Actual work | Text1 | Text4 | Text5 | Text6 | Text8 |
| --- | --- | --- | --- | --- | --- | --- | --- | --- | --- | --- | --- | --- | --- | --- | --- | --- | --- | --- | --- |
| 2149 | 95 | **GERAN/UTRAN interface evolution 1 (evolution of Iu PS)** | 476d | 2000-09-01 A | 2002-06-28 A |  | 100% | 2000-09-01 | 2002-06-28 | 476d |  | GP,R3 | 10688h | 10688h | GERUEV1 | SBC | Marc Grant | Rel-5 | Paolo |
| 2150 | 95.1 | **Evolution of Iu ps** | 476d | 2000-09-01 A | 2002-06-28 A |  | 100% | 2000-09-01 | 2002-06-28 | 476d |  | GP,R3 | 7248h | 7248h | GERUEV1-IuPS |  |  | Rel-5 | Paolo |
| 2151 | 95.1.1 | Identification of GERAN requirements on Iu ps | 326d | 2000-09-01 A | 2001-11-30 A |  | 100% | 2000-09-01 | 2001-11-30 | 326d | finish no earlier than 2001-11-30 | GP,R3 | 2608h | 2608h |  |  |  | Rel-5 | Paolo |
| 2152 | 95.1.2 | Update of specifications | 150d | 2001-12-03 A | 2002-06-28 A | 2151 | 100% | 2001-12-03 | 2002-06-28 | 150d | finish no earlier than 2002-06-28 | GP,R3 | 1200h | 1200h |  |  |  | Rel-5 | Paolo |
| 2153 | 96 | **GERAN/UTRAN interface evolution 2 (evolution of Iu CS)** | 476d | 2000-09-01 A | 2002-06-28 A |  | 100% | 2000-09-01 | 2002-06-28 | 476d |  | GP,R3 | 12816h | 12816h | GERUEV2 |  |  | Rel-5 | Paolo |
| 2154 | 96.1 | **Evolution of Iu cs** | 476d | 2000-09-01 A | 2002-06-28 A |  | 100% | 2000-09-01 | 2002-06-28 | 476d |  | GP,R3 | 10016h | 10016h | GERUEV2-IuCS | Lucent | Krishna Balachandran | Rel-5 | Paolo |
| 2155 | 96.1.1 | Identification of GERAN requirements on Iu cs | 426d | 2000-09-01 A | 2002-06-24 A |  | 100% | 2000-09-01 | 2002-06-24 | 426d | finish no earlier than 2002-04-19 | GP,R3 | 3408h | 3408h |  |  |  | Rel-5 | Paolo |
| 2156 | 96.1.2 | Update of specifications | 476d | 2000-09-01 A | 2002-06-28 A |  | 100% | 2000-09-01 | 2002-06-28 | 476d | finish no earlier than 2002-06-28 | GP,R3 | 3808h | 3808h |  |  |  | Rel-5 | Paolo |
| 2157 | 97 | **End to End QoS for PS Domain including IMS** | 480d | 2000-08-28 A | 2002-06-28 A |  | 100% | 2000-08-28 | 2002-06-28 | 480d |  | S2 | 9856h | 9856h | E2EQoS | Ericsson | Johnson.oyama@era.ericcson.se | Rel-5 | Maurice |
| 2158 | 97.1 | E2E QoSConcept and Architecture | 178d | 2001-01-03 A | 2001-09-07 A |  | 100% | 2001-01-03 | 2001-09-07 | 178d | finish no earlier than 2001-09-07 | S2 | 1424h | 1424h |  |  |  | Rel-5 | Maurice |
| 2159 | 97.2 | E2E QoS interworking | 465d | 2000-08-28 A | 2002-06-07 A |  | 100% | 2000-08-28 | 2002-06-07 | 465d | finish no earlier than 2002-06-07 | N3 | 3720h | 3720h | E2EQoS-IW | Lucent | Daisuke Yokota (yokota@lucent.com) | Rel-5 | Gwiho |
| 2160 | 97.3 | QoS Management (Provisioning and Monitoring) | 201d | 2001-09-21 A | 2002-06-28 A |  | 100% | 2001-09-21 | 2002-06-28 | 201d | finish no earlier than 2002-06-28 | S5 | 1608h | 1608h | E2EQoS-OAM | VoiceStream, Motorola |  | Rel-5 | Dionisio |
| 2161 | 98 | **Messaging enhancements Rel-5** | 467d | 2001-06-15 A | 2003-03-31 A |  | 100% | 2001-06-15 | 2003-03-31 | 467d |  | T2 | 19000h | 19000h | MESS5 |  |  | Rel-5 | Kimmo |
| 2162 | 98.1 | **Multimedia Messaging (MMS) enhancements** | 467d | 2001-06-15 A | 2003-03-31 A |  | 100% | 2001-06-15 | 2003-03-31 | 467d |  | T2 | 11688h | 11688h | MESS5-MMS | Siemens | Josef.Laumen@SAL.SIEMENS.DE | Rel-5 | Alain |
| 2163 | 98.1.1 | Definition of service requirements | 196d | 2001-06-15 A | 2002-03-15 A |  | 100% | 2001-06-15 | 2002-03-15 | 196d | finish no earlier than 2002-03-15 | S1 | 1568h | 1568h | MESS5-SR | Siemens | Josef.Laumen@SAL.SIEMENS.DE | Rel-5 | Alain |
| 2164 | 98.1.2 | Technical realization | 256d | 2001-06-15 A | 2002-06-07 A |  | 100% | 2001-06-15 | 2002-06-07 | 256d | finish no earlier than 2002-06-07 | T2 | 2048h | 2048h |  | Siemens | Josef.Laumen@SAL.SIEMENS.DE | Rel-5 |  |
| 2165 | 98.1.3 | WAP Forum dependency: MM1 stage 3 | 467d | 2001-06-15 A | 2003-03-31 A |  | 100% | 2001-06-15 | 2003-03-31 | 467d | finish no earlier than 2003-03-31 | T2 | 3736h | 3736h |  |  |  | Rel-5 |  |
| 2166 | 98.1.4 | MMS formats and codecs | 75d | 2001-12-03 A | 2002-03-15 A |  | 100% | 2001-12-03 | 2002-03-15 | 75d | finish no earlier than 2002-03-15 | S4 | 600h | 600h |  |  |  | Rel-5 | Paolo |
| 2167 | 98.2 | **Enhanced Messaging Service (EMS) enhancements** | 191d | 2001-06-15 A | 2002-03-08 A |  | 100% | 2001-06-15 | 2002-03-08 | 191d |  | T2 | 3584h | 3584h | MESS5-EMS | Ericsson | Alan.Baldwin@EML.ERICSSON.SE | Rel-5 | Kimmo |
| 2168 | 98.2.1 | Definition of service requirements | 66d | 2001-06-15 A | 2001-09-14 A |  | 100% | 2001-06-15 | 2001-09-14 | 66d | finish no earlier than 2001-09-14 | S1 | 528h | 528h |  | Ericsson | Alan.Baldwin@EML.ERICSSON.SE | Rel-5 | Alain |
| 2169 | 98.2.2 | Technical realization | 191d | 2001-06-15 A | 2002-03-08 A |  | 100% | 2001-06-15 | 2002-03-08 | 191d | finish no earlier than 2002-03-08 | T2 | 1528h | 1528h |  | Ericsson | Alan.Baldwin@EML.ERICSSON.SE | Rel-5 | Kimmo |
| 2170 | 99 | **GERAN Inter BSC NACC improvements over the Gb Interface** | 215d | 2001-09-03 A | 2002-06-28 A |  | 100% | 2001-09-03 | 2002-06-28 | 215d |  | GP | 8200h | 8200h | GERNACC |  |  | Rel-5 | Paolo |
| 2171 | 99.1 | **Modification of core network protocols for GERAN Inter BSC NACC over Gb Interface** | 165d | 2001-09-03 A | 2002-04-19 A |  | 100% | 2001-09-03 | 2002-04-19 | 165d |  | N4,S2 | 4064h | 4064h | GERNACC-Cnmod |  |  | Rel-5 | Kimmo |
| 2172 | 99.1.1 | Stage 2 - Concept | 43d | 2001-09-03 A | 2001-10-31 A |  | 100% | 2001-09-03 | 2001-10-31 | 43d | finish no earlier than 2001-10-31 | N4,S2 | 344h | 344h |  |  |  | Rel-5 | Kimmo |
| 2173 | 99.1.2 | Stage 2 - 23.060 change - Definition of Inter BSC NACC | 165d | 2001-09-03 A | 2002-04-19 A |  | 100% | 2001-09-03 | 2002-04-19 | 165d | finish no earlier than 2002-04-19 | N4,S2 | 1320h | 1320h |  |  |  | Rel-5 | Kimmo |
| 2174 | 99.1.3 | Stage 3 (changes to TS 29.060) | 135d | 2001-09-03 A | 2002-03-08 A |  | 100% | 2001-09-03 | 2002-03-08 | 135d | finish no earlier than 2002-03-08 | N4 | 1080h | 1080h |  |  |  | Rel-5 | Kimmo |

Notes:
- 2149: SBC, Motorola, Nokia, Ericsson, Nortel
- 2150: -
- 2151: -
- 2152: -
- 2153: -
- 2154: Lucent, Ericsson, AWS, Nortel
- 2155: -
- 2156: -
- 2157: -
- 2158: - / Text3: 23.207
- 2159: [DAB - 30/07/02] - % complete to 95% (if we exclude Diffserv). Marked as closed 12/2008 (was marked 95% complete) / Text3: 29.208, 29.207, 27.060, 29.061, 24.008, 24.228, , 24.229, 29.060, 29.163
- 2160: - / Text3: 32-series
- 2161: support of UAProf, so this in my opinion is 100% complete
- 2162: -
- 2163: - / Text3: 22.140
- 2164: stage 3 MM7 is missing / Text3: 23.140
- 2165: Marked as closed 12/2008 (was marked 80% complete)
- 2166: - / Text3: 26.140
- 2167: - / Text3: 23.040
- 2168: -
- 2169: - / Text3: 23.040
- 2170: -
- 2171: -
- 2172: -
- 2173: -
- 2174: IP 30/11/01: Input awaited from GERAN2 to CN4 / 17 May Work complete 100%

| ID | WBS | Task | Duration | Start | Finish | Complete | Baseline start | Baseline finish | Baseline duration | Constraint | Resources | Work | Actual work | Text1 | Text6 | Text8 | Text12 | Text3 | Text4 | Text5 |
| --- | --- | --- | --- | --- | --- | --- | --- | --- | --- | --- | --- | --- | --- | --- | --- | --- | --- | --- | --- | --- |
| 2175 | 99.2 | **Modification of Gb protocols for GERAN Inter BSC NACC over Gb Interface** | 151d | 2001-11-30 A | 2002-06-28 A | 100% | 2001-11-30 | 2002-06-28 | 151d |  | GP | 2416h | 2416h | GERNACC-Gbmod | Rel-5 | Paolo |  |  |  |  |
| 2176 | 99.2.1 | Stage 3 (changes to TS 48.018) | 151d | 2001-11-30 A | 2002-06-28 A | 100% | 2001-11-30 | 2002-06-28 | 151d | finish no earlier than 2002-06-28 | GP | 1208h | 1208h |  | Rel-5 | Paolo |  |  |  |  |
| 2177 | 100 | **Enhanced Power Control** | 540d | 2001-11-26 A | 2003-12-19 A | 100% | 2001-11-26 | 2003-12-19 | 540d |  | GP | 12840h | 12840h | EPC | Rel-5 | Paolo |  |  |  |  |
| 2178 | 100.1 | Realization of Enhanced power control and signalling support | 5d | 2001-11-26 A | 2001-11-30 A | 100% | 2001-11-26 | 2001-11-30 | 5d | finish no earlier than 2001-11-30 | GP | 40h | 40h |  | Rel-5 | Paolo |  |  |  |  |
| 2179 | 100.2 | Deleted - GERAN MS Conformance test for Enhanced Power Control | 530d | 2001-12-10 A | 2003-12-19 A | 100% | 2001-12-10 | 2003-12-19 | 530d | finish no earlier than 2003-12-19 | GP | 4240h | 4240h |  | Rel-5 | Paolo | GP-17 |  |  |  |
| 2180 | 100.3 | Deleted - GERAN BTS Conformance test for Enhanced Power Control | 530d | 2001-12-10 A | 2003-12-19 A | 100% | 2001-12-10 | 2003-12-19 | 530d | finish no earlier than 2003-12-19 | GP | 4240h | 4240h |  | Rel-5 | Paolo | GP-17 |  |  |  |
| 2181 | 101 | **8PSK AMR HR** | 530d | 2001-12-10 A | 2003-12-19 A | 100% | 2001-12-10 | 2003-12-19 | 530d |  | GP | 21080h | 21080h | 8PSK-AH | Rel-5 | Paolo |  |  |  |  |
| 2182 | 101.1 | **Definition of channel coding, performance requirements and signalling support** | 145d | 2001-12-10 A | 2002-06-28 A | 100% | 2001-12-10 | 2002-06-28 | 145d |  | GP | 10440h | 10440h |  | Rel-5 | Paolo |  |  |  |  |
| 2183 | 101.1.1 | Concept | 145d | 2001-12-10 A | 2002-06-28 A | 100% | 2001-12-10 | 2002-06-28 | 145d | finish no earlier than 2002-06-28 | GP | 1160h | 1160h |  | Rel-5 | Paolo |  |  |  |  |
| 2184 | 101.1.2 | Changes to 44.018 | 145d | 2001-12-10 A | 2002-06-28 A | 100% | 2001-12-10 | 2002-06-28 | 145d | finish no earlier than 2002-06-28 | G2 | 1160h | 1160h |  | Rel-5 | Gert |  |  |  |  |
| 2185 | 101.1.3 | Changes to 45.001 | 145d | 2001-12-10 A | 2002-06-28 A | 100% | 2001-12-10 | 2002-06-28 | 145d | finish no earlier than 2002-06-28 | G1 | 1160h | 1160h |  | Rel-5 | Paolo |  |  |  |  |
| 2186 | 101.1.4 | Changes to 45.002 | 145d | 2001-12-10 A | 2002-06-28 A | 100% | 2001-12-10 | 2002-06-28 | 145d | finish no earlier than 2002-06-28 | G1 | 1160h | 1160h |  | Rel-5 | Paolo |  |  |  |  |
| 2187 | 101.1.5 | Changes to 45.003 | 145d | 2001-12-10 A | 2002-06-28 A | 100% | 2001-12-10 | 2002-06-28 | 145d | finish no earlier than 2002-06-28 | G1 | 1160h | 1160h |  | Rel-5 | Paolo |  |  |  |  |
| 2188 | 101.1.6 | Changes to 45.005 | 145d | 2001-12-10 A | 2002-06-28 A | 100% | 2001-12-10 | 2002-06-28 | 145d | finish no earlier than 2002-06-28 | G1 | 1160h | 1160h |  | Rel-5 | Paolo |  |  |  |  |
| 2189 | 101.1.7 | Changes to 24.008 | 145d | 2001-12-10 A | 2002-06-28 A | 100% | 2001-12-10 | 2002-06-28 | 145d | finish no earlier than 2002-06-28 | G2 | 1160h | 1160h |  | Rel-5 | Gert |  |  |  |  |
| 2190 | 101.1.8 | Changes to 48.058 | 145d | 2001-12-10 A | 2002-06-28 A | 100% | 2001-12-10 | 2002-06-28 | 145d | finish no earlier than 2002-06-28 | G2 | 1160h | 1160h |  | Rel-5 | Gert |  |  |  |  |
| 2191 | 101.2 | Deleted - GERAN MS Conformance test for 8PSK HR | 530d | 2001-12-10 A | 2003-12-19 A | 100% | 2001-12-10 | 2003-12-19 | 530d | finish no earlier than 2003-12-19 | GP | 4240h | 4240h |  | Rel-5 | Paolo | GP-17 |  |  |  |
| 2192 | 101.3 | GERAN BTS Conformance test for 8PSK HR | 270d | 2001-12-10 A | 2002-12-20 A | 100% | 2001-12-10 | 2002-12-20 | 270d | finish no earlier than 2002-12-20 | GP | 2160h | 2160h |  | Rel-5 | Paolo |  |  |  |  |
| 2193 | 102 | Service Change and UDI Fallback | 175d | 2001-10-08 A | 2002-06-07 A | 100% | 2001-10-08 | 2002-06-07 | 175d | finish no earlier than 2002-06-07 | N3 | 1400h | 1400h | SCUDIF | Rel-5 | Gwiho |  | 29.007, 27.001, 24.008 | Ericsson | Rune.Werner.Wiik@ericsson.no |
| 2194 | 103 | **Rel-5 USIM toolkit enhancements** | 865d | 2000-06-05 A | 2003-09-26 A | 100% | 2000-06-05 | 2003-09-26 | 865d |  | T3 | 24352h | 24352h | USAT1-Interpr | Rel-5 | Xavier |  |  | G & D | Michael Meyer |
| 2195 | 103.1 | Deleted - Test specification for USIM toolkit security mechanisms | 349d | 2002-05-28 A | 2003-09-26 A | 100% | 2002-05-28 | 2003-09-26 | 349d | finish no earlier than 2003-09-26 | T3 | 2792h | 2792h |  | Rel-5 | Xavier | TP-21 |  | Gemplus | Sophie Viallet |
| 2196 | 103.2 | **Protocol Standardisation of a SIM Toolkit Interpreter** | 688d | 2000-06-05 A | 2003-01-22 A | 100% | 2000-06-05 | 2003-01-22 | 688d |  | T3 | 12512h | 12512h | USAT1-Interpr | Rel-5 | Xavier |  | 27.103 | G & D | Michael Meyer |
| 2197 | 103.2.1 | Stage 1 | 205d | 2000-06-05 A | 2001-03-16 A | 100% | 2000-06-05 | 2001-03-16 | 205d | finish no earlier than 2001-03-16 | T3 | 1640h | 1640h | USAT1-Interpr | Rel-5 | Xavier |  |  |  |  |
| 2198 | 103.2.2 | Stage 2 and 3 | 308d | 2001-01-03 A | 2002-03-08 A | 100% | 2001-01-03 | 2002-03-08 | 308d | finish no earlier than 2002-03-08 | T3 | 2464h | 2464h | USAT1-Interpr | Rel-5 | Xavier |  |  |  |  |
| 2199 | 103.2.3 | Test specification | 363d | 2001-09-03 A | 2003-01-22 A | 100% | 2001-09-03 | 2003-01-22 | 363d | finish no earlier than 2003-01-22 | T3 | 2904h | 2904h | USAT1-Interpr | Rel-5 | Xavier |  |  | Gemplus | Gérald MAUNIER |

Notes:
- 2175: -
- 2176: -
- 2177: -
- 2178: Completed 11/2001
- 2179: Not started. Marked as stopped 12/2008
- 2180: Not started. Marked as stopped 12/2008
- 2181: Completed for Rel-5
- 2182: -
- 2183: -
- 2184: -
- 2185: -
- 2186: -
- 2187: -
- 2188: -
- 2189: -
- 2190: -
- 2191: Marked as stopped 12/2008
- 2192: -
- 2193: -
- 2194: -
- 2195: Marked as stopped 12/2008
- 2196: 28/5/2001: T3-19 proposed that since the stage 2 and 3 will not be presented to TP-12 for approval as expected, the WI will be moved to rel-5, with completion expected at TP-13.
- 2197: 5/10/2001: Stage one comepeted at TP-12.
- 2198: 5/10/2001: TS 31.112 and 31.113 approved at TP-13. TS 31.114 to be presented to TP-14.
- 2199: 5/10/2001: Work started on test specification. Marked as closed 12/2008 (was marked 12% complete)

| ID | WBS | Task | Duration | Start | Finish | Complete | Baseline start | Baseline finish | Baseline duration | Constraint | Resources | Work | Actual work | Text1 | Text4 | Text5 | Text6 | Text8 | Text12 |
| --- | --- | --- | --- | --- | --- | --- | --- | --- | --- | --- | --- | --- | --- | --- | --- | --- | --- | --- | --- |
| 2200 | 103.4 | **(U)SIM API** | 133d | 2002-03-20 A | 2002-09-20 A | 100% | 2002-03-20 | 2002-09-20 | 133d |  | T3 | 2128h | 2128h | USAT1-API | Microelectrónica Española | Mario Pérez | Rel-5 | Xavier |  |
| 2201 | 103.4.1 | Java API Test specification | 133d | 2002-03-20 A | 2002-09-20 A | 100% | 2002-03-20 | 2002-09-20 | 133d | finish no earlier than 2002-09-20 | T3 | 1064h | 1064h | USAT1-API | Microelectrónica Española | Mario Pérez | Rel-5 | Xavier |  |
| 2202 | 104 | (Small) Technical Enhancements and Improvements for Rel-5 | 2349d? | 2000-01-03 A | 2008-12-31 A | 100% | 2000-01-03 | 2008-12-31 | 2349d? |  | All |  |  | TEI5 |  |  | Rel-5 | all |  |
| 2203 | 589 | Test - (Small) Technical Enhancements and Improvements for Rel-5 | 2349d? | 2000-01-03 A | 2008-12-31 A | 100% | 2000-01-03 | 2008-12-31 | 2349d? | finish no earlier than 2008-12-31 | R5,T1 | 18792h | 18792h | TEI5_Test |  |  | Rel-5 | Ingbert |  |
| 2204 | 105 | Technical Report on UE Functionality Split | 87d | 2000-01-03 A | 2000-05-01 A | 100% | 2000-01-03 | 2000-05-01 | 87d |  | S1 | 688h | 688h | UESPLIT | Motorola | jian.j.wu@motorola.com | Rel-5 | Alain |  |
| 2205 | 106 | **User Equipment Management** | 267d | 2001-06-21 A | 2002-06-28 A | 100% | 2001-06-21 | 2002-06-28 | 267d |  | S5 | 3752h | 3752h | UEM | Vodafone | john.mudge@vf.vodafone.co.uk | Rel-5 | Dionisio |  |
| 2206 | 106.1 | FS on User Equipment (UE) Management | 267d | 2001-06-21 A | 2002-06-28 A | 100% | 2001-06-21 | 2002-06-28 | 267d | finish no earlier than 2002-06-28 | S5 | 2136h | 2136h | OAM-UEM | Vodafone | john.mudge@vf.vodafone.co.uk | Rel-5 | Dionisio |  |
| 2207 | 107 | **Flow control supporting an MS with multiple data flows with different QoS over the Gb interface** | 50d | 2002-06-24 A | 2002-08-30 A | 100% | 2002-06-24 | 2002-08-30 | 50d |  | GP | 1288h | 1288h | FlowCon | Ericsson | ingemar.backlund@era.ericsson.se | Rel-5 | Paolo |  |
| 2208 | 107.1 | **Update of stage 2 specifications** | 50d | 2002-06-24 A | 2002-08-30 A | 100% | 2002-06-24 | 2002-08-30 | 50d |  | GP | 808h | 808h |  |  |  | Rel-5 | Paolo |  |
| 2209 | 107.1.1 | Concept document 23.060 (changes to) | 46d | 2002-06-28 A | 2002-08-30 A | 100% | 2002-06-28 | 2002-08-30 | 46d | finish no earlier than 2002-08-30 | S2 | 368h | 368h |  |  |  | Rel-5 | Maurice |  |
| 2210 | 107.1.2 | Flow Control | 5d | 2002-06-24 A | 2002-06-28 A | 100% | 2002-06-24 | 2002-06-28 | 5d | finish no earlier than 2002-06-28 | GP | 40h | 40h |  |  |  | Rel-5 | Paolo |  |
| 2211 | 107.2 | **Modification of BSSGP protocol** | 5d | 2002-06-24 A | 2002-06-28 A | 100% | 2002-06-24 | 2002-06-28 | 5d |  | GP | 80h | 80h |  | Ericsson | ingemar.backlund@era.ericsson.se | Rel-5 | Paolo |  |
| 2212 | 107.2.1 | Stage 3 (changes to 48.018) | 5d | 2002-06-24 A | 2002-06-28 A | 100% | 2002-06-24 | 2002-06-28 | 5d | finish no earlier than 2002-06-28 | G2 | 40h | 40h |  |  |  | Rel-5 | Gert |  |
| 2213 | 108 | **Deleted - Multiple TBF in A/Gb mode - Phase 1** | 421d | 2002-04-19 A | 2003-11-28 A | 100% | 2002-04-19 | 2003-11-28 | 421d |  | GP | 17480h | 17480h | MULTBF | Ericsson | gunnar.mildh@era.ericsson.se | Rel-5 | Paolo | GP-17 |
| 2214 | 108.1 | **Deleted - Multiple TBF in A/Gb mode - Phase 1** | 351d | 2002-04-19 A | 2003-08-22 A | 100% | 2002-04-19 | 2003-08-22 | 351d |  | GP | 8112h | 8112h | MULTBF-Agbmode |  |  | Rel-5 | Paolo | GP-17 |
| 2215 | 108.1.1 | Deleted - Multiple TBF Concept paper | 351d | 2002-04-19 A | 2003-08-22 A | 100% | 2002-04-19 | 2003-08-22 | 351d | finish no earlier than 2003-08-22 | GP | 2808h | 2808h | MULTBF-Agbmode |  |  | Rel-5 | Paolo | GP-17 |
| 2216 | 108.1.2 | Deleted - Multiple TBF Stage 2 (43.064) CRs | 156d | 2002-04-19 A | 2002-11-22 A | 100% | 2002-04-19 | 2002-11-22 | 156d | finish no earlier than 2002-11-22 | G1 | 1248h | 1248h | MULTBF-Agbmode |  |  | Rel-5 | Paolo | GP-12 |
| 2217 | 108.1.3 | Deleted - Multiple TBF Stage 3 (44.060) CRs | 156d | 2002-04-19 A | 2002-11-22 A | 100% | 2002-04-19 | 2002-11-22 | 156d | finish no earlier than 2002-11-22 | G2 | 1248h | 1248h | MULTBF-Agbmode |  |  | Rel-5 | Gert | GP-12 |
| 2218 | 108.2 | **Deleted - Multiple TBF in A/Gb mode – MS testing** | 375d | 2002-06-24 A | 2003-11-28 A | 100% | 2002-06-24 | 2003-11-28 | 375d |  | GP | 6000h | 6000h |  | Ericsson | ingemar.backlund@era.ericsson.se | Rel-5 | Paolo | GP-17 |
| 2219 | 108.2.1 | Deleted - MS conformance tests | 375d | 2002-06-24 A | 2003-11-28 A | 100% | 2002-06-24 | 2003-11-28 | 375d | finish no earlier than 2003-11-28 | G4 | 3000h | 3000h |  |  |  | Rel-5 | Paolo | GP-17 |
| 2220 | 109 | **Alignment of 3G functional split and Iu** | 922d | 2000-06-08 A | 2003-12-19 A | 100% | 2000-06-08 | 2003-12-19 | 922d |  | GP | 126664h | 126664h | GER3GAL | Ericsson | Frank Muller | Rel-5 | Paolo |  |
| 2221 | 109.1 | **GERAN user / control plane** | 540d | 2000-08-07 A | 2002-08-30 A | 100% | 2000-08-07 | 2002-08-30 | 540d |  | GP | 36232h | 36232h | GER3GAL-GUCOPL | Ericsson | Frank Muller | Rel-5 | Paolo |  |
| 2222 | 109.1.1 | **Alignment with UMTS bearer concept** | 540d | 2000-08-07 A | 2002-08-30 A | 100% | 2000-08-07 | 2002-08-30 | 540d |  | GP | 24952h | 24952h |  |  |  | Rel-5 | Paolo |  |
| 2223 | 109.1.1.1 | Enhanced power control | 1d | 2001-08-31 A | 2001-08-31 A | 100% | 2001-08-31 | 2001-08-31 | 1d | finish no earlier than 2001-08-31 | GP | 8h | 8h |  |  |  | Rel-5 | Paolo |  |
| 2224 | 109.1.1.2 | Stage 2 | 235d | 2000-08-07 A | 2001-06-29 A | 100% | 2000-08-07 | 2001-06-29 | 235d | finish no earlier than 2001-06-29 | GP | 1880h | 1880h |  |  |  | Rel-5 | Paolo |  |
| 2225 | 109.1.1.3 | Adoption of the UTRAN PDCP | 295d | 2000-11-06 A | 2001-12-21 A | 100% | 2000-11-06 | 2001-12-21 | 295d | finish no earlier than 2001-12-21 | GP | 2360h | 2360h |  |  |  | Rel-5 | Paolo |  |
| 2226 | 109.1.1.4 | Development of RLC / MAC | 261d | 2001-08-31 A | 2002-08-30 A | 100% | 2001-08-31 | 2002-08-30 | 261d | finish no earlier than 2002-08-30 | GP | 2088h | 2088h |  |  |  | Rel-5 | Paolo |  |
| 2227 | 109.1.1.5 | Development of GERAN RRC | 266d | 2001-06-22 A | 2002-06-28 A | 100% | 2001-06-22 | 2002-06-28 | 266d | finish no earlier than 2002-06-28 | GP | 2128h | 2128h |  |  |  | Rel-5 | Paolo |  |
| 2228 | 109.1.1.6 | Ciphering and integrity protection concept paper | 166d | 2001-08-31 A | 2002-04-19 A | 100% | 2001-08-31 | 2002-04-19 | 166d | finish no earlier than 2002-04-19 | GP | 1328h | 1328h |  |  |  | Rel-5 | Paolo |  |
| 2229 | 109.1.1.7 | Multiple TBF or equivalent Concept paper | 116d | 2001-08-31 A | 2002-02-08 A | 100% | 2001-08-31 | 2002-02-08 | 116d | finish no earlier than 2002-02-08 | GP | 928h | 928h |  |  |  | Rel-5 | Paolo |  |
| 2230 | 109.1.1.8 | Paging concept | 166d | 2001-08-31 A | 2002-04-19 A | 100% | 2001-08-31 | 2002-04-19 | 166d | finish no earlier than 2002-04-19 | GP | 1328h | 1328h |  |  |  | Rel-5 | Paolo |  |
| 2231 | 109.1.1.9 | Dedicated Physical subchannels, includes traffic and control channels | 66d | 2001-08-31 A | 2001-11-30 A | 100% | 2001-08-31 | 2001-11-30 | 66d | finish no earlier than 2001-11-30 | GP | 528h | 528h |  |  |  | Rel-5 | Paolo |  |
| 2232 | 109.1.1.10 | Iu support and broadcast concept | 166d | 2001-08-31 A | 2002-04-19 A | 100% | 2001-08-31 | 2002-04-19 | 166d | finish no earlier than 2002-04-19 | GP | 1328h | 1328h |  |  |  | Rel-5 | Paolo |  |
| 2233 | 109.1.1.11 | Impact of using RLC instead of LAPDm concept | 116d | 2001-08-31 A | 2002-02-08 A | 100% | 2001-08-31 | 2002-02-08 | 116d | finish no earlier than 2002-02-08 | GP | 928h | 928h |  |  |  | Rel-5 | Paolo |  |
| 2234 | 109.1.1.12 | Contention resolution, mobile station identity, and access concept | 66d | 2001-08-31 A | 2001-11-30 A | 100% | 2001-08-31 | 2001-11-30 | 66d | finish no earlier than 2001-11-30 | GP | 528h | 528h |  |  |  | Rel-5 | Paolo |  |
| 2235 | 109.1.1.13 | PDCP concept | 166d | 2001-08-31 A | 2002-04-19 A | 100% | 2001-08-31 | 2002-04-19 | 166d | finish no earlier than 2002-04-19 | GP | 1328h | 1328h |  |  |  | Rel-5 | Paolo |  |
| 2236 | 109.1.1.14 | Downlink delayed TBF release | 261d | 2001-08-31 A | 2002-08-30 A | 100% | 2001-08-31 | 2002-08-30 | 261d | finish no earlier than 2002-08-30 | GP | 2088h | 2088h |  |  |  | Rel-5 | Paolo |  |
| 2237 | 109.1.1.15 | Add transparent RLC Concept | 116d | 2001-08-31 A | 2002-02-08 A | 100% | 2001-08-31 | 2002-02-08 | 116d | finish no earlier than 2002-02-08 | GP | 928h | 928h |  |  |  | Rel-5 | Paolo |  |
| 2238 | 109.1.1.16 | Handover concept | 116d | 2001-08-31 A | 2002-02-08 A | 100% | 2001-08-31 | 2002-02-08 | 116d | finish no earlier than 2002-02-08 | GP | 928h | 928h |  |  |  | Rel-5 | Paolo |  |

Notes:
- 2200: 8/3/2001: test spec is based on R99 core spec, so deleted from Workplan
- 2201: -
- 2202: "Joker" WI, to be used for a Rel 5 CR not related to any feature and with very limited impact on the system
- 2203: "Joker" WI, to be used for small modifications applicable to Rel 5 conformance testing. Moved in from Stoyan/testing WP. / Text3: 34.108, 34.109, 34.121-1, 34.121-2, 34.122, 34.123-1, 34.123-2, 34.123-3, 34.171, 34.229-1, 34.229-2, 34.229-3
- 2204: - / Text3: new TR 22.944
- 2205: - / Text3: 32.802
- 2206: - / Text3: 32.802
- 2207: 50101 -> 50201
- 2208: 50102 -> 50202
- 2209: -
- 2210: 50103 -> 50203
- 2211: -
- 2212: -
- 2213: GP#17 Nov 2003 Moved to Rel-6 as UID_50600 MULTBF (Only Multiple TBF Concept paper produced in Rel-5)
- 2214: Marked as closed 12/2008 (was marked 26% complete)
- 2215: Marked as closed 12/2008 (was marked 50% complete)
- 2216: Marked as stopped 12/2008
- 2217: Marked as stopped 12/2008
- 2218: 08/08: duplicate UID_50106=-> 50206. Marked as stopped 12/2008
- 2219: Not started. Marked as stopped 12/2008
- 2220: AWS, Nokia, Ericsson, Nortel, Siemens, Vodafone
- 2221: AWS, Nokia, Ericsson, Nortel, Siemens, Vodafone
- 2222: -
- 2223: -
- 2224: -
- 2225: Responsible is GERAN; RAN WG2 help may be needed.
- 2226: -
- 2227: -
- 2228: -
- 2229: -
- 2230: -
- 2231: -
- 2232: -
- 2233: -
- 2234: -
- 2235: -
- 2236: -
- 2237: -
- 2238: -

| ID | WBS | Task | Duration | Start | Finish | Complete | Baseline start | Baseline finish | Baseline duration | Constraint | Resources | Work | Actual work | Text6 | Text8 | Text1 | Text4 | Text5 |
| --- | --- | --- | --- | --- | --- | --- | --- | --- | --- | --- | --- | --- | --- | --- | --- | --- | --- | --- |
| 2239 | 109.1.2 | **Physical layer alignment with UMTS bearer concept** | 280d | 2000-11-06 A | 2001-11-30 A | 100% | 2000-11-06 | 2001-11-30 | 280d |  | GP | 6960h | 6960h | Rel-5 | Paolo |  |  |  |
| 2240 | 109.1.2.1 | PDTCH/TCH in 45.003 | 155d | 2000-11-06 A | 2001-06-08 A | 100% | 2000-11-06 | 2001-06-08 | 155d | finish no earlier than 2001-06-08 | GP | 1240h | 1240h | Rel-5 | Paolo |  |  |  |
| 2241 | 109.1.2.2 | Control channels in 45.003 | 155d | 2000-11-06 A | 2001-06-08 A | 100% | 2000-11-06 | 2001-06-08 | 155d | finish no earlier than 2001-06-08 | GP | 1240h | 1240h | Rel-5 | Paolo |  |  |  |
| 2242 | 109.1.2.3 | Receiver performance in 45.005 for PDTCH/TCH and control channels | 280d | 2000-11-06 A | 2001-11-30 A | 100% | 2000-11-06 | 2001-11-30 | 280d | finish no earlier than 2001-11-30 | GP | 2240h | 2240h | Rel-5 | Paolo |  |  |  |
| 2243 | 109.2 | **Iu rg interface** | 430d | 2000-11-06 A | 2002-06-28 A | 100% | 2000-11-06 | 2002-06-28 | 430d |  | GP,RP | 39560h | 39560h | Rel-5 | Paolo | GER3GAL-Iurg | Ericsson | Frank Muller |
| 2244 | 109.2.1 | **Inter BSS interface** | 430d | 2000-11-06 A | 2002-06-28 A | 100% | 2000-11-06 | 2002-06-28 | 430d |  | GP,RP | 20640h | 20640h | Rel-5 | Paolo |  |  |  |
| 2245 | 109.2.1.1 | Identification of requirements | 430d | 2000-11-06 A | 2002-06-28 A | 100% | 2000-11-06 | 2002-06-28 | 430d | finish no earlier than 2002-06-28 | GP | 3440h | 3440h | Rel-5 | Paolo |  |  |  |
| 2246 | 109.2.1.2 | Stage 2 | 430d | 2000-11-06 A | 2002-06-28 A | 100% | 2000-11-06 | 2002-06-28 | 430d | finish no earlier than 2002-06-28 | GP | 3440h | 3440h | Rel-5 | Paolo |  |  |  |
| 2247 | 109.2.1.3 | Adoption of relevant parts from Iur | 430d | 2000-11-06 A | 2002-06-28 A | 100% | 2000-11-06 | 2002-06-28 | 430d | finish no earlier than 2002-06-28 | GP | 3440h | 3440h | Rel-5 | Paolo |  |  |  |
| 2248 | 109.2.1.4 | Complementation with GERAN specifics | 430d | 2000-11-06 A | 2002-06-28 A | 100% | 2000-11-06 | 2002-06-28 | 430d | finish no earlier than 2002-06-28 | GP | 3440h | 3440h | Rel-5 | Paolo |  |  |  |
| 2249 | 109.2.1.5 | Stage 3 | 430d | 2000-11-06 A | 2002-06-28 A | 100% | 2000-11-06 | 2002-06-28 | 430d | finish no earlier than 2002-06-28 | GP | 3440h | 3440h | Rel-5 | Paolo |  |  |  |
| 2250 | 109.2.2 | **Inter BSS-RNS interface** | 430d | 2000-11-06 A | 2002-06-28 A | 100% | 2000-11-06 | 2002-06-28 | 430d |  | GP,RP | 15480h | 15480h | Rel-5 | Paolo |  |  |  |
| 2251 | 109.2.2.1 | Identification of requirements | 430d | 2000-11-06 A | 2002-06-28 A | 100% | 2000-11-06 | 2002-06-28 | 430d | start no earlier than 2000-11-06 | GP,R3 | 3440h | 3440h | Rel-5 | Paolo |  |  |  |
| 2252 | 109.2.2.2 | Stage 2 | 430d | 2000-11-06 A | 2002-06-28 A | 100% | 2000-11-06 | 2002-06-28 | 430d | finish no earlier than 2002-06-28 | GP,R3 | 3440h | 3440h | Rel-5 | Paolo |  |  |  |
| 2253 | 109.2.2.3 | Adoption of relevant parts from Iur | 430d | 2000-11-06 A | 2002-06-28 A | 100% | 2000-11-06 | 2002-06-28 | 430d | finish no earlier than 2002-06-28 | GP,R3 | 3440h | 3440h | Rel-5 | Paolo |  |  |  |
| 2254 | 109.2.2.4 | Complementation with GERAN specifics | 107.5d | 2002-01-30 A | 2002-06-28 A | 100% | 2002-01-30 | 2002-06-28 | 107.5d | finish no earlier than 2002-06-28 | GP,R3 | 860h | 860h | Rel-5 | Paolo |  |  |  |
| 2255 | 109.2.2.5 | Stage 3 | 107.5d | 2002-01-30 A | 2002-06-28 A | 100% | 2002-01-30 | 2002-06-28 | 107.5d | finish no earlier than 2002-06-28 | GP,R3 | 860h | 860h | Rel-5 | Paolo |  |  |  |
| 2256 | 109.3 | **Voice over GERAN PS and CS concept** | 430d | 2000-11-06 A | 2002-06-28 A | 100% | 2000-11-06 | 2002-06-28 | 430d |  | GP,R3 | 18520h | 18520h | Rel-5 | Paolo |  |  |  |
| 2257 | 109.3.1 | Architecture for A, Iu cs and Iu ps | 430d | 2000-11-06 A | 2002-06-28 A | 100% | 2000-11-06 | 2002-06-28 | 430d | finish no earlier than 2002-06-28 | GP,R3 | 3440h | 3440h | Rel-5 | Paolo |  |  |  |
| 2258 | 109.3.2 | Transcoder position/operation | 115d | 2000-11-06 A | 2001-04-13 A | 100% | 2000-11-06 | 2001-04-13 | 115d | finish no earlier than 2001-04-13 | GP | 920h | 920h | Rel-5 | Paolo |  |  |  |
| 2259 | 109.3.3 | Handover | 430d | 2000-11-06 A | 2002-06-28 A | 100% | 2000-11-06 | 2002-06-28 | 430d | finish no earlier than 2002-06-28 | GP,R3 | 3440h | 3440h | Rel-5 | Paolo |  |  |  |
| 2260 | 109.3.4 | RTP payload | 430d | 2000-11-06 A | 2002-06-28 A | 100% | 2000-11-06 | 2002-06-28 | 430d | finish no earlier than 2002-06-28 | GP,R3 | 3440h | 3440h | Rel-5 | Paolo |  |  |  |
| 2261 | 109.3.5 | Codec renegotiation concept | 365d | 2000-11-06 A | 2002-03-29 A | 100% | 2000-11-06 | 2002-03-29 | 365d | finish no earlier than 2002-03-29 | GP,R3 | 2920h | 2920h | Rel-5 | Paolo |  |  |  |
| 2262 | 109.3.6 | LA | 115d | 2000-11-06 A | 2001-04-13 A | 100% | 2000-11-06 | 2001-04-13 | 115d | finish no earlier than 2001-04-13 | GP | 920h | 920h | Rel-5 | Paolo |  |  |  |

Notes:
- 2239: -
- 2240: -
- 2241: -
- 2242: -
- 2243: AWS, Nokia, Ericsson, Nortel, Siemens, Vodafone
- 2244: -
- 2245: -
- 2246: -
- 2247: -
- 2248: -
- 2249: -
- 2250: -
- 2251: -
- 2252: -
- 2253: -
- 2254: -
- 2255: -
- 2256: -
- 2257: -
- 2258: -
- 2259: -
- 2260: -
- 2261: -
- 2262: -

| ID | WBS | Task | Duration | Start | Finish | Complete | Baseline start | Baseline finish | Baseline duration | Constraint | Resources | Work | Actual work | Text6 | Text8 | Text12 | Text1 | Text4 | Text5 |
| --- | --- | --- | --- | --- | --- | --- | --- | --- | --- | --- | --- | --- | --- | --- | --- | --- | --- | --- | --- |
| 2263 | 109.4 | **Deleted - GERAN MS Conformance test for GERAN interface evolution** | 660d | 2001-06-11 A | 2003-12-19 A | 100% | 2001-06-11 | 2003-12-19 | 660d |  | GP | 10560h | 10560h | Rel-5 | Paolo | GP-17 |  |  |  |
| 2264 | 109.4.1 | Deleted - MS test | 660d | 2001-06-11 A | 2003-12-19 A | 100% | 2001-06-11 | 2003-12-19 | 660d | finish no earlier than 2003-12-19 | GP | 5280h | 5280h | Rel-5 | Paolo | GP-17 |  |  |  |
| 2265 | 109.5 | **GERAN BSS Conformance test for GERAN interface evolution** | 922d | 2000-06-08 A | 2003-12-19 A | 100% | 2000-06-08 | 2003-12-19 | 922d |  | GP | 14752h | 14752h | Rel-5 | Paolo |  |  |  |  |
| 2266 | 109.5.1 | Deleted - BSS test | 922d | 2000-06-08 A | 2003-12-19 A | 100% | 2000-06-08 | 2003-12-19 | 922d | finish no earlier than 2003-12-19 | GP | 7376h | 7376h | Rel-5 | Paolo | GP-17 |  |  |  |
| 2267 | 110 | **GERAN support for IMS** | 690d | 2000-05-01 A | 2002-12-20 A | 100% | 2000-05-01 | 2002-12-20 | 690d |  | GP | 39198.4h | 39198.4h | Rel-5 | Paolo |  | GERIMS | Nokia | Shkumbin Hamiti |
| 2268 | 110.1 | **GERAN Header adaptation** | 690d | 2000-05-01 A | 2002-12-20 A | 100% | 2000-05-01 | 2002-12-20 | 690d |  | GP,S2,RP | 12302.8h | 12302.8h | Rel-5 | Paolo |  | GERIMS-HEADAPT | Nokia | Shkumbin Hamiti |
| 2269 | 110.1.1 | Definition of compression and removal modes for PDCP protocol | 15.05d | 2000-05-01 A | 2000-06-09 A | 100% | 2000-05-01 | 2000-06-09 | 15.05d | finish no earlier than 2000-09-01 | GP,S2,RP | 120.4h | 120.4h | Rel-5 | Paolo |  |  |  |  |
| 2270 | 110.1.2 | Conceptual description in stage 2 | 393d | 2000-05-01 A | 2001-10-31 A | 100% | 2000-05-01 | 2001-10-31 | 393d | finish no earlier than 2001-10-31 | GP,S2,RP | 3144h | 3144h | Rel-5 | Paolo |  |  |  |  |
| 2271 | 110.1.3 | Necessary changes on stage 3 regarding header removal | 439.8d | 2000-11-06 A | 2002-12-20 A | 100% | 2000-11-06 | 2002-12-20 | 439.8d | finish no earlier than 2002-12-20 | GP,S2,RP | 3518.4h | 3518.4h | Rel-5 | Paolo |  |  |  |  |
| 2272 | 110.2 | **Deleted - GERAN Radio access bearer design for IMS** | 430d | 2000-11-06 A | 2002-06-28 A | 100% | 2000-11-06 | 2002-06-28 | 430d |  | GP,S2,RP | 9287.6h | 9287.6h | Rel-5 | Paolo | GP-10 | GERIMS-RABDES | Nokia | Shkumbin Hamiti |
| 2273 | 110.2.1 | **Deleted - MuM control signalling for conversational multimedia services** | 430d | 2000-11-06 A | 2002-06-28 A | 100% | 2000-11-06 | 2002-06-28 | 430d |  | GP,S2,RP | 5847.6h | 5847.6h | Rel-5 | Paolo | GP-10 |  |  |  |
| 2274 | 110.2.1.1 | Deleted - Identification of requirements | 330d | 2000-11-06 A | 2002-02-08 A | 100% | 2000-11-06 | 2002-02-08 | 330d | finish no earlier than 2002-02-08 | GP,S2,RP | 2640h | 2640h | Rel-5 | Paolo | GP-08 |  |  |  |
| 2275 | 110.2.1.2 | Deleted - Necessary modifications due to SIP | 40d | 2002-05-06 A | 2002-06-28 A | 100% | 2002-05-06 | 2002-06-28 | 40d | finish no earlier than 2002-06-28 | GP,S2,RP | 320h | 320h | Rel-5 | Paolo | GP-10 |  |  |  |
| 2276 | 110.3 | **Deleted - GERAN MS Conformance test for support of IMS** | 400d | 2001-06-11 A | 2002-12-20 A | 100% | 2001-06-11 | 2002-12-20 | 400d |  | GP | 6400h | 6400h | Rel-5 | Paolo | GP-12 | GERIMS-MSconf | Nokia | Shkumbin Hamiti |
| 2277 | 110.3.1 | Deleted - MS test | 400d | 2001-06-11 A | 2002-12-20 A | 100% | 2001-06-11 | 2002-12-20 | 400d | finish no earlier than 2002-12-20 | G4 | 3200h | 3200h | Rel-5 | Paolo | GP-12 |  |  |  |
| 2278 | 110.4 | **Deleted - GERAN BTS Conformance test for support of IMS** | 400d | 2001-06-11 A | 2002-12-20 A | 100% | 2001-06-11 | 2002-12-20 | 400d |  | GP | 6400h | 6400h | Rel-5 | Paolo | GP-12 | GERIMS-BTSconf | Nokia | Shkumbin Hamiti |
| 2279 | 110.4.1 | Deleted - BTS test | 400d | 2001-06-11 A | 2002-12-20 A | 100% | 2001-06-11 | 2002-12-20 | 400d | finish no earlier than 2002-12-20 | G3new | 3200h | 3200h | Rel-5 | Ingbert | GP-12 |  |  |  |
| 2280 | 596 | MS Conformance Testing of Dual Transfer Mode | 65d? | 2002-11-11 A | 2003-02-07 A | 100% | 2002-11-11 | 2003-02-07 | 65d? | finish no earlier than 2003-02-07 | G4,G5 | 520h | 520h | Rel-5 | Paolo |  | MSCTDTM | Vodafone | Dave Fox |
| 2281 | 597 | **Handling of early UEs** | 911d? | 2000-01-03 A | 2003-06-27 A | 100% | 2000-01-03 | 2003-06-27 | 911d? |  | S2 | 4488h | 4488h | Rel-5 | Maurice |  | LATE_UE |  |  |
| 2282 | 597.1 | Feasibility Study | 50d? | 2002-10-07 A | 2002-12-13 A | 100% | 2002-10-07 | 2002-12-13 | 50d? | finish no earlier than 2002-12-13 | S2 | 400h | 400h | Rel-5 | Maurice |  |  |  |  |
| 2283 | 597.2 | Stage 2 | 125d? | 2003-01-06 A | 2003-06-27 A | 100% | 2003-01-06 | 2003-06-27 | 125d? | start no earlier than 2003-01-06 | S2 | 1000h | 1000h | Rel-5 | Maurice |  |  |  |  |
| 2284 | 597.3 | FS for the Early Mobile Handling in UTRAN | 195d | 2002-09-09 A | 2003-06-06 A | 100% | 2002-09-09 | 2003-06-06 | 195d | finish no earlier than 2003-06-06 | R2 | 1560h | 1560h | Rel-5 | Joern |  | FSEarlyUE | Vodafone | Alan Law |
| 2285 | 597.4 | Note: Stage 3 RAN part not shown | 1d | 2000-01-03 A | 2000-01-03 A | 100% | 2000-01-03 | 2000-01-03 | 1d |  | RP | 8h | 8h | Rel-5 |  |  |  |  |  |
| 2286 | 598 | Release 4 Features | 326d? | 2000-01-03 A | 2001-03-30 A | 100% | 2000-01-03 | 2001-03-30 | 326d? |  | NP,GP, RP,SP,TP | 2608h | 2608h | Rel-4 | All |  |  |  |  |

Notes:
- 2263: Not started. Marked as stopped 12/2008
- 2264: Not started. Marked as stopped 12/2008
- 2265: Not started. Marked as stopped 12/2008
- 2266: Not started. Marked as stopped 12/2008
- 2267: AWS, Nokia, Ericsson, Nortel, Siemens, Motorola
- 2268: AWS, Nokia, Ericsson, Nortel, Siemens, Motorola
- 2269: -
- 2270: -
- 2271: -
- 2272: TERMINATED - NOT STANDARDIZED. Marked as stopped 12/2008
- 2273: TERMINATED - NOT STANDARDIZED. Marked as stopped 12/2008
- 2274: TERMINATED - NOT STANDARDIZED
- 2275: TERMINATED - NOT STANDARDIZED
- 2276: TERMINATED - NOT STANDARDIZED. Marked as stopped 12/2008
- 2277: TERMINATED - NOT STANDARDIZED. Marked as stopped 12/2008
- 2278: TERMINATED - NOT STANDARDIZED. Marked as stopped 12/2008
- 2279: TERMINATED - NOT STANDARDIZED. Marked as stopped 12/2008
- 2280: Needed to complete DTM (R99)
- 2281: -
- 2282: -
- 2283: -
- 2284: -
- 2285: -
- 2286: -

| ID | WBS | Task | Duration | Start | Finish | Predecessors | Complete | Baseline start | Baseline finish | Baseline duration | Constraint | Resources | Work | Actual work | Text1 | Text6 | Text8 | Text3 | Text12 | Text4 | Text5 |
| --- | --- | --- | --- | --- | --- | --- | --- | --- | --- | --- | --- | --- | --- | --- | --- | --- | --- | --- | --- | --- | --- |
| 2287 | 15 | **Miscellaneous UE Conformance Testing Activities** | 958d | 2001-04-02 A | 2004-12-01 A |  | 100% | 2001-04-02 | 2004-12-01 | 958d |  | T1 | 36360h | 36360h | MISTST1 | Rel-4 | Ingbert |  |  |  |  |
| 2288 | 15.1 | Optimization of Test Time, RF Aspects (FDD) | 508d | 2001-09-24 A | 2003-09-03 A |  | 100% | 2001-09-24 | 2003-09-03 | 508d | finish no earlier than 2003-09-03 | T1 | 4064h | 4064h | MISTST1-OpFDD | Rel-4 | Ingbert | 34.121 |  |  |  |
| 2289 | 15.2 | Optimization of Test Time, RF Aspects (TDD) | 508d | 2001-09-24 A | 2003-09-03 A |  | 100% | 2001-09-24 | 2003-09-03 | 508d | finish no earlier than 2003-09-03 | T1 | 4064h | 4064h | MISTST1-OpTDD | Rel-4 | Ingbert | 34.122 |  |  |  |
| 2290 | 15.3 | Extensions to R99 Test cases | 139.4w | 2001-04-02 A | 2003-12-02 A |  | 100% | 2001-04-02 | 2003-12-02 | 139.4w | finish no earlier than 2003-12-02 | T1 | 5576h | 5576h | MISTST1-Ext | Rel-4 | Ingbert | 34.123 p 1,2 |  |  |  |
| 2291 | 15.4 | Extension to R99 Test cases - TTCN | 439d | 2002-06-28 A | 2004-03-03 A |  | 100% | 2002-06-28 | 2004-03-03 | 439d | finish no earlier than 2004-03-03 | T1 | 3512h | 3512h |  | Rel-4 | Ingbert |  |  |  |  |
| 2292 | 15.5 | Creation of R99 TCs for TDD - prose | 719d | 2001-10-01 A | 2004-07-01 A |  | 100% | 2001-10-01 | 2004-07-01 | 719d | finish no earlier than 2004-07-01 | T1 | 5752h | 5752h | MISTST1-TDD | Rel-4 | Ingbert | 34.123-1 |  |  |  |
| 2293 | 15.6 | Deleted - Creation of R99 TCs for TDD - TTCN | 587d | 2002-09-03 A | 2004-12-01 A |  | 100% | 2002-09-03 | 2004-12-01 | 587d | finish no earlier than 2004-12-01 | T1 | 4696h | 4696h |  | Rel-4 | Ingbert |  | TP-26 |  |  |
| 2294 | 15.7 | Deleted - Review all other work items for impact on new or exiting 34 series specs. | 25.8w | 2002-07-02 A | 2002-12-27 A |  | 100% | 2002-07-02 | 2002-12-27 | 25.8w | finish no earlier than 2002-12-27 | T1 | 1032h | 1032h | MISTST1 | Rel-4 | Ingbert | 34.121,122,123,125 | TP-18 |  |  |
| 2295 | 46 | **Facsimile** | 89d | 2000-02-22 A | 2000-06-23 A |  | 100% | 2000-02-22 | 2000-06-23 | 89d |  | S1 | 4376h | 4376h | FAX | Rel-4 | Alain |  |  |  |  |
| 2296 | 46.1 | **Real Time Fax** | 89d | 2000-02-22 A | 2000-06-23 A |  | 100% | 2000-02-22 | 2000-06-23 | 89d |  | S2 | 3664h | 3664h | FAX-RT | Rel-4 | Maurice |  |  |  |  |
| 2297 | 46.1.1 | Terminal capabilities, AT commands | 89d | 2000-02-22 A | 2000-06-23 A |  | 100% | 2000-02-22 | 2000-06-23 | 89d | finish no earlier than 2000-06-23 | T2 | 712h | 712h |  | Rel-4 |  | 21.904, 27.007 |  |  |  |
| 2298 | 46.1.2 | Signalling aspects (e.g. ICM) | 89d | 2000-02-22 A | 2000-06-23 A |  | 100% | 2000-02-22 | 2000-06-23 | 89d | start no earlier than 2000-02-22 | N1 | 712h | 712h |  | Rel-4 | Frederic |  |  |  |  |
| 2299 | 46.1.3 | Service provision | 89d | 2000-02-22 A | 2000-06-23 A |  | 100% | 2000-02-22 | 2000-06-23 | 89d | finish no earlier than 2000-06-23 | N3 | 712h | 712h |  | Rel-4 | Gwiho | 23.146 |  |  |  |
| 2300 | 46.1.4 | Review whether service/stage 1 aspects need to be aligned | 51d | 2000-04-14 A | 2000-06-23 A |  | 100% | 2000-04-14 | 2000-06-23 | 51d | finish no earlier than 2000-12-14 | S1 | 408h | 408h |  | Rel-4 | Alain |  |  |  |  |
| 2301 | 46.1.5 | Review whether architecture/stage 2 aspects need to be aligned | 51d | 2000-04-14 A | 2000-06-23 A |  | 100% | 2000-04-14 | 2000-06-23 | 51d | finish no earlier than 2000-12-14 | S2 | 408h | 408h |  | Rel-4 | Maurice |  |  |  |  |
| 2302 | 47 | Transparent End-to-End PS mobile streaming application | 253d | 2000-04-03 A | 2001-03-21 A |  | 100% | 2000-04-03 | 2001-03-21 | 253d | finish no earlier than 2000-12-29 | S4 | 2024h | 2024h | PSTREAM | Rel-4 | Paolo | 26.233, 26.234 |  |  |  |
| 2303 | 48 | **Multimedia Messaging** | 277d | 2000-02-22 A | 2001-03-14 A |  | 100% | 2000-02-22 | 2001-03-14 | 277d |  | T2,S1 | 9992h | 9992h | MMS | Rel-4 | Kimmo | 22.140, 23.140 |  | Siemens | Josef.Laumen@SAL.SIEMENS.DE |
| 2304 | 48.1 | Definition of service requirements | 72d | 2000-02-22 A | 2000-05-31 A |  | 100% | 2000-02-22 | 2000-05-31 | 72d | start no earlier than 2000-02-22 | S1 | 576h | 576h | MMS | Rel-4 | Alain |  |  |  |  |
| 2305 | 48.2 | Review of definition of service requirements | 205d | 2000-06-01 A | 2001-03-14 A | 2304 | 100% | 2000-06-01 | 2001-03-14 | 205d | finish no earlier than 2000-09-08 | T2 | 1640h | 1640h | MMS | Rel-4 | Kimmo | 22.140, 23.140 |  | Siemens |  |
| 2306 | 48.3 | **Technical Realisation** | 243d | 2000-04-10 A | 2001-03-14 A |  | 100% | 2000-04-10 | 2001-03-14 | 243d |  | T2 | 7776h | 7776h | MMS | Rel-4 | Kimmo | 22.140, 23.140 |  | Siemens | Josef.Laumen@SAL.SIEMENS.DE |
| 2307 | 48.3.1 | Review of definition of reference Achitecture model | 243d | 2000-04-10 A | 2001-03-14 A |  | 100% | 2000-04-10 | 2001-03-14 | 243d | finish no earlier than 2001-03-14 | T2 | 1944h | 1944h | MMS | Rel-4 | Kimmo | 22.140, 23.140 |  | Siemens | Josef.Laumen@SAL.SIEMENS.DE |
| 2308 | 48.3.2 | Fulfill Requirements of Stage 1 | 243d | 2000-04-10 A | 2001-03-14 A |  | 100% | 2000-04-10 | 2001-03-14 | 243d | finish no earlier than 2001-03-14 | T2 | 1944h | 1944h | MMS | Rel-4 | Kimmo | 22.140, 23.140 |  | Siemens | Josef.Laumen@SAL.SIEMENS.DE |
| 2309 | 48.3.3 | Definition of MMS primitives in Stage 2 | 243d | 2000-04-10 A | 2001-03-14 A |  | 100% | 2000-04-10 | 2001-03-14 | 243d | finish no earlier than 2001-03-14 | T2 | 1944h | 1944h | MMS | Rel-4 | Kimmo | 22.140, 23.140 |  | Siemens | Josef.Laumen@SAL.SIEMENS.DE |
| 2310 | 49 | **Transcoder-Free Operation** | 326d | 2000-01-03 A | 2001-03-30 A |  | 100% | 2000-01-03 | 2001-03-30 | 326d |  | N4,S2,N1 | 10448h | 10448h | TrFO | Rel-4 | Kimmo |  |  |  |  |
| 2311 | 49.1 | **Out-of-Band Transcoder Control solution** | 326d | 2000-01-03 A | 2001-03-30 A |  | 100% | 2000-01-03 | 2001-03-30 | 326d |  | N4 | 8448h | 8448h | TrFO-OoBTC | Rel-4 | Kimmo |  |  | NEC | Toshiyuki Tamura (tamurato@aj.jp.nec.com) |
| 2312 | 49.1.1 | implementation in UTRAN | 145d | 2000-09-11 A | 2001-03-30 A |  | 100% | 2000-09-11 | 2001-03-30 | 145d | finish no earlier than 2001-03-30 | R3 | 1160h | 1160h | TrFO-OoBTC-UTRAN | Rel-4 | Juha | 25.401, 25.410, 25.413, 25.415, 23.153 |  | Siemens | Alexander Vesely |
| 2313 | 49.1.2 | Impact on architecture, Principles and Terminology | 211d | 2000-01-03 A | 2000-10-20 A |  | 100% | 2000-01-03 | 2000-10-20 | 211d | finish no earlier than 2000-10-20 | S2 | 1680h | 1680h | TrFO-OoBTC | Rel-4 | Maurice |  |  |  |  |
| 2314 | 49.1.3 | Codec Negotiation between UE and MSC | 125d | 2000-08-14 A | 2001-02-02 A |  | 100% | 2000-08-14 | 2001-02-02 | 125d | finish no earlier than 2001-02-02 | N1 | 1000h | 1000h | TrFO-OoBTC | Rel-4 | Frederic | 24.008, 23.009, 23.108, (29.002) |  | Motorola | Andrew Howell |
| 2315 | 49.1.4 | Codec Negotiation inter MSC | 125d | 2000-07-03 A | 2000-12-22 A |  | 100% | 2000-07-03 | 2000-12-22 | 125d | finish no earlier than 2000-12-22 | N4 | 1000h | 1000h | TrFO-OoBTC | Rel-4 | Kimmo |  |  |  |  |
| 2316 | 49.1.5 | Bearer establishment inter MSC | 125d | 2000-07-03 A | 2000-12-22 A |  | 100% | 2000-07-03 | 2000-12-22 | 125d | finish no earlier than 2000-12-22 | N4 | 1000h | 1000h | TrFO-OoBTC | Rel-4 | Kimmo | 23.153 |  |  |  |

Notes:
- 2287: -
- 2288: It is believed that the current R99 test spec. can be optimised for faster overall test times. Marked as stopped 12/2008 (was 70% complete)
- 2289: It is believed that the current R99 test spec. can be optimised for faster overall test times
- 2290: Further test coverage of the R99 specification to cover supplementry services. Marked as stopped 12/2008 (was 70% complete)
- 2291: Marked as closed 12/2008 (was marked 50% complete)
- 2292: Marked as closed 12/2008 (was marked 50% complete)
- 2293: Marked as stopped 12/2008
- 2294: Marked as stopped 12/2008
- 2295: -
- 2296: postponed from R99 to R00, SP-000169
- 2297: -
- 2298: -
- 2299: -
- 2300: -
- 2301: -
- 2302: -
- 2303: -
- 2304: -
- 2305: -
- 2306: -
- 2307: -
- 2308: e.g. minimum set of media formats, media format conversion, personalization of MMS.
- 2309: -
- 2310: Lead given to CN4 from CN / [DAB 28/11/00]
- 2311: -
- 2312: moved according to NP-000575
- 2313: e.g. study cascading TrFO/TFO/TrFO
- 2314: the link to NP-000085has been deleted because refering to a R99 status sheet / One common set of codec negotiation procedures will be specified as in ID1656.
- 2315: Bearer establishment inter MSC. TS 23.153 R99 part complete. capabilities moved to annex + list of open issues
- 2316: Bearer establishment inter MSC. TS 23.153 R99 part complete. capabilities moved to annex. / See NP-000127 / Open issues: / Handling of Conference Calls; / Handling of Multi Party Supplementary Services; / Handling of Handover UMTS to GSM; / Handling of Sending a ...

| ID | WBS | Task | Duration | Start | Finish | Complete | Baseline start | Baseline finish | Baseline duration | Constraint | Resources | Work | Actual work | Text1 | Text6 | Text8 | Text4 | Text5 |
| --- | --- | --- | --- | --- | --- | --- | --- | --- | --- | --- | --- | --- | --- | --- | --- | --- | --- | --- |
| 2317 | 49.2 | **Speech Transcoder: Location and Control at the UMTS Core Network Border** | 125d | 2000-04-10 A | 2000-09-29 A | 100% | 2000-04-10 | 2000-09-29 | 125d |  | S2 | 2000h | 2000h | TrFO-STLC | Rel-4 | Maurice |  |  |
| 2318 | 49.2.1 | Transcoder at Edge | 125d | 2000-04-10 A | 2000-09-29 A | 100% | 2000-04-10 | 2000-09-29 | 125d | finish no earlier than 2000-09-29 | NP | 1000h | 1000h | TrFO-STLC | Rel-4 | Kimmo |  |  |
| 2319 | 50 | **GERAN improvements 1 (Gb over IP)** | 225d | 2000-05-09 A | 2001-03-19 A | 100% | 2000-05-09 | 2001-03-19 | 225d |  | GP | 6472h | 6472h | GEIMP1 | Rel-4 | Paolo |  |  |
| 2320 | 50.1 | **Gb over IP (Ip-fication of Gb)** | 225d | 2000-05-09 A | 2001-03-19 A | 100% | 2000-05-09 | 2001-03-19 | 225d |  | GP | 4672h | 4672h | GbIP | Rel-4 | Paolo |  |  |
| 2321 | 50.1.1 | Concept of Gb over IP (Ip-fication of Gb) | 134d | 2000-05-09 A | 2000-11-10 A | 100% | 2000-05-09 | 2000-11-10 | 134d |  | GP | 1072h | 1072h |  | Rel-4 | Paolo |  |  |
| 2322 | 50.1.2 | Changes to 08.16, 08.18 | 225d | 2000-05-09 A | 2001-03-19 A | 100% | 2000-05-09 | 2001-03-19 | 225d |  | GP | 1800h | 1800h |  | Rel-4 | Paolo |  |  |
| 2323 | 51 | **GERAN improvements 2 (NACC)** | 677d | 2000-11-06 A | 2003-06-10 A | 100% | 2000-11-06 | 2003-06-10 | 677d |  | GP | 19224h | 19224h | GEIMP2 | Rel-4 | Paolo |  |  |
| 2324 | 51.1 | **Gb enhancements** | 155d | 2000-11-06 A | 2001-06-08 A | 100% | 2000-11-06 | 2001-06-08 | 155d |  | GP | 7440h | 7440h | Gben | Rel-4 | Paolo |  |  |
| 2325 | 51.1.1 | **Intra BSC NACC (Network Assisted Cell Change)** | 155d | 2000-11-06 A | 2001-06-08 A | 100% | 2000-11-06 | 2001-06-08 | 155d |  | GP | 6200h | 6200h |  | Rel-4 | Paolo |  |  |
| 2326 | 51.1.1.1 | Concept | 155d | 2000-11-06 A | 2001-06-08 A | 100% | 2000-11-06 | 2001-06-08 | 155d | finish no earlier than 2001-06-08 | GP | 1240h | 1240h |  | Rel-4 | Paolo |  |  |
| 2327 | 51.1.1.2 | Changes in 03.64 | 155d | 2000-11-06 A | 2001-06-08 A | 100% | 2000-11-06 | 2001-06-08 | 155d | finish no earlier than 2001-06-08 | GP | 1240h | 1240h |  | Rel-4 | Paolo |  |  |
| 2328 | 51.1.1.3 | Changes in 04.60 | 155d | 2000-11-06 A | 2001-06-08 A | 100% | 2000-11-06 | 2001-06-08 | 155d | finish no earlier than 2001-06-08 | GP | 1240h | 1240h |  | Rel-4 | Paolo |  |  |
| 2329 | 51.1.1.4 | Changes in 44.008 | 155d | 2000-11-06 A | 2001-06-08 A | 100% | 2000-11-06 | 2001-06-08 | 155d | finish no earlier than 2001-06-08 | GP | 1240h | 1240h |  | Rel-4 | Paolo |  |  |
| 2330 | 51.3 | **MS conformance test for Intra BSC NACC** | 398d | 2001-11-30 A | 2003-06-10 A | 100% | 2001-11-30 | 2003-06-10 | 398d |  | GP | 6368h | 6368h | GEIMP2-Msconf | Rel-4 | Paolo |  |  |
| 2331 | 51.3.1 | Changes in 51.010 | 398d | 2001-11-30 A | 2003-06-10 A | 100% | 2001-11-30 | 2003-06-10 | 398d | finish no earlier than 2003-12-19 | G5,G4 | 3184h | 3184h |  | Rel-4 | Paolo |  |  |
| 2332 | 52 | **GERAN improvements 4 (Delayed TBF)** | 105d | 2001-01-15 A | 2001-06-08 A | 100% | 2001-01-15 | 2001-06-08 | 105d |  | GP | 3960h | 3960h | GEIMP4 | Rel-4 | Paolo |  |  |
| 2333 | 52.1 | **Gb enhancements 2** | 105d | 2001-01-15 A | 2001-06-08 A | 100% | 2001-01-15 | 2001-06-08 | 105d |  | GP | 3120h | 3120h | GEIMP4-Gben2 | Rel-4 | Paolo |  |  |
| 2334 | 52.1.1 | stage 2 | 105d | 2001-01-15 A | 2001-06-08 A | 100% | 2001-01-15 | 2001-06-08 | 105d | finish no earlier than 2001-06-08 | GP | 840h | 840h |  | Rel-4 | Paolo |  |  |
| 2335 | 52.1.2 | **Stage 3 (changes in 44.060)** | 60d | 2001-01-15 A | 2001-04-06 A | 100% | 2001-01-15 | 2001-04-06 | 60d |  | G2 | 1440h | 1440h |  | Rel-4 | Gert |  |  |
| 2336 | 52.1.2.1 | Definition of enhanced countdown procedure | 60d | 2001-01-15 A | 2001-04-06 A | 100% | 2001-01-15 | 2001-04-06 | 60d | finish no earlier than 2001-04-06 | G2 | 480h | 480h |  | Rel-4 | Gert |  |  |
| 2337 | 52.1.2.2 | Definition of enhanced TBF release procedure | 60d | 2001-01-15 A | 2001-04-06 A | 100% | 2001-01-15 | 2001-04-06 | 60d | finish no earlier than 2001-04-06 | G2 | 480h | 480h |  | Rel-4 | Gert |  |  |
| 2338 | 52.1.2.3 | Definition of USF=FREE type polling mechanism on PDCH | 60d | 2001-01-15 A | 2001-04-06 A | 100% | 2001-01-15 | 2001-04-06 | 60d | finish no earlier than 2001-04-06 | G2 | 480h | 480h |  | Rel-4 | Gert |  |  |
| 2339 | 53 | **Low Chip Rate TDD option** | 880d | 2000-07-19 A | 2003-12-02 A | 100% | 2000-07-19 | 2003-12-02 | 880d |  | R1 | 27488h | 27488h | LCRTDD | Rel-4 | Patrick | CWTS | G. Yang |
| 2340 | 53.1 | Physical layer | 183d | 2000-07-19 A | 2001-03-30 A | 100% | 2000-07-19 | 2001-03-30 | 183d | finish no earlier than 2001-03-30 | R1 | 1464h | 1464h | LCRTDD-Phys | Rel-4 | Patrick | CWTS | G. Yang |
| 2341 | 53.2 | Layer 2 and layer 3 protocol aspects | 183d | 2000-07-19 A | 2001-03-30 A | 100% | 2000-07-19 | 2001-03-30 | 183d | finish no earlier than 2001-03-30 | R2 | 1464h | 1464h | LCRTDD-L23 | Rel-4 | Joern | CWTS | Y. Liu |
| 2342 | 53.3 | RF radio transmission/reception, system performance requirements and conformance testing | 165d | 2000-08-14 A | 2001-03-30 A | 100% | 2000-08-14 | 2001-03-30 | 165d | finish no earlier than 2001-03-30 | R4 | 1320h | 1320h | LCRTDD-RF | Rel-4 | Issam | CWTS | D. Zhang |
| 2343 | 53.4 | UE radio access capability | 165d | 2000-08-14 A | 2001-03-30 A | 100% | 2000-08-14 | 2001-03-30 | 165d | finish no earlier than 2001-03-30 | R2 | 1320h | 1320h | LCRTDD-UErac | Rel-4 | Joern | CWTS | Y. Liu |
| 2344 | 53.5 | Iub/Iur protocol aspects | 165d | 2000-08-14 A | 2001-03-30 A | 100% | 2000-08-14 | 2001-03-30 | 165d | finish no earlier than 2001-03-30 | R3 | 1320h | 1320h | LCRTDD-IubIur | Rel-4 | Juha | CWTS | Y. Liu |

Notes:
- 2317: WI description and Tdoc S2-99352 / Speech Transcoder: Location and Control at the UMTS Core Network Border
- 2318: WI description and Tdoc S2-99352...
- 2319: -
- 2320: -
- 2321: -
- 2322: -
- 2323: -
- 2324: -
- 2325: -
- 2326: -
- 2327: -
- 2328: -
- 2329: -
- 2330: -
- 2331: az 05/08: duplicated UID_50099 => 50299. Marked as closed 12/2008 (was marked 50% complete)
- 2332: -
- 2333: -
- 2334: -
- 2335: -
- 2336: -
- 2337: -
- 2338: -
- 2339: -
- 2340: -
- 2341: -
- 2342: -
- 2343: -
- 2344: -

| ID | WBS | Task | Duration | Start | Finish | Predecessors | Complete | Baseline start | Baseline finish | Baseline duration | Constraint | Resources | Work | Actual work | Text6 | Text8 | Text3 | Text12 | Text1 | Text4 | Text5 |
| --- | --- | --- | --- | --- | --- | --- | --- | --- | --- | --- | --- | --- | --- | --- | --- | --- | --- | --- | --- | --- | --- |
| 2345 | 53.6 | **Low chiprate TDD interworking with GERAN** | 101d | 2000-09-01 A | 2001-01-19 A | 2344 | 100% | 2000-09-01 | 2001-01-19 | 101d |  | GP | 1616h | 1616h | Rel-4 | Paolo |  |  |  |  |  |
| 2346 | 53.6.1 | Handover and Cell Selection / Reselection to UTRA 1.28 Mcps TDD | 101d | 2000-09-01 A | 2001-01-19 A |  | 100% | 2000-09-01 | 2001-01-19 | 101d | finish no earlier than 2001-01-19 | GP | 808h | 808h | Rel-4 | Paolo |  |  |  |  |  |
| 2347 | 53.8 | **Conformance Test Aspects - Low Chip Rate TDD** | 577d | 2001-09-17 A | 2003-12-02 A | 2345 | 100% | 2001-09-17 | 2003-12-02 | 577d |  | T1 | 12088h | 12088h | Rel-4 | Ingbert |  |  |  |  |  |
| 2348 | 53.8.1 | Testing Layer 2 and layer 3 protocol aspects | 468d | 2001-09-17 A | 2003-07-02 A |  | 100% | 2001-09-17 | 2003-07-02 | 468d | finish no earlier than 2003-07-02 | T1 | 3744h | 3744h | Rel-4 | Ingbert | 34.123-1, 34.123-2 |  |  |  |  |
| 2349 | 53.8.2 | Deleted - Testing Layer 2 and layer 3 protocol aspects - TTCN | 261d | 2002-12-03 A | 2003-12-02 A |  | 100% | 2002-12-03 | 2003-12-02 | 261d | finish no earlier than 2003-12-02 | T1 | 2088h | 2088h | Rel-4 | Ingbert | 34.123-3 | TP-22 |  |  |  |
| 2350 | 53.8.3 | Testing RF Radio Transmission and Reception | 205d | 2001-09-17 A | 2002-06-28 A |  | 100% | 2001-09-17 | 2002-06-28 | 205d | finish no earlier than 2002-06-28 | T1 | 1640h | 1640h | Rel-4 | Ingbert |  |  |  |  |  |
| 2351 | 54 | **Enable bearer independent CS architecture** | 566d | 2000-01-03 A | 2002-03-01 A |  | 100% | 2000-01-03 | 2002-03-01 | 566d |  | S2 | 20192h | 20192h | Rel-4 | Maurice |  |  | CSSPLIT | Siemens | Alexander Milinski |
| 2352 | 54.1 | **Enable bearer-independent call control** | 425d | 2000-01-03 A | 2001-08-16 A |  | 100% | 2000-01-03 | 2001-08-16 | 425d |  | N4 | 12344h | 12344h | Rel-4 | Kimmo |  |  |  | Ericsson | Heinz-Peter.Keutmann@eed.ericsson.se |
| 2353 | 54.1.1 | Architecture and Stage 2 description | 181d | 2000-01-03 A | 2000-09-08 A |  | 100% | 2000-01-03 | 2000-09-08 | 181d | finish no earlier than 2000-09-08 | S2 | 1440h | 1440h | Rel-4 | Maurice | 23.002 |  |  |  |  |
| 2354 | 54.1.2 | Standardisation of protocols (control & user planes) over Nb interface | 64d | 2001-01-02 A | 2001-03-30 A |  | 100% | 2001-01-02 | 2001-03-30 | 64d | finish no earlier than 2001-03-30 | N3 | 512h | 512h | Rel-4 | Gwiho |  |  |  |  |  |
| 2355 | 54.1.3 | Standardisation of protocols over reference points between MSC server and Gateway MSC server | 130d | 2000-09-25 A | 2001-03-23 A |  | 100% | 2000-09-25 | 2001-03-23 | 130d | finish no earlier than 2001-03-23 | N4 | 1040h | 1040h | Rel-4 | Kimmo |  |  |  |  |  |
| 2356 | 54.1.4 | Standardisation of detailed stage 2 description | 180d | 2000-07-17 A | 2001-03-23 A |  | 100% | 2000-07-17 | 2001-03-23 | 180d | finish no earlier than 2001-03-23 | N4 | 1440h | 1440h | Rel-4 | Kimmo |  |  |  |  |  |
| 2357 | 54.1.5 | **Bearer control between MSC server and MGW** | 250d | 2000-09-01 A | 2001-08-16 A |  | 100% | 2000-09-01 | 2001-08-16 | 250d |  | N4 | 4512h | 4512h | Rel-4 | Kimmo |  |  |  |  |  |
| 2358 | 54.1.5.1 | stage 3 - protocol issues | 250d | 2000-09-01 A | 2001-08-16 A |  | 100% | 2000-09-01 | 2001-08-16 | 250d | finish no earlier than 2001-08-16 | N4 | 2000h | 2000h | Rel-4 | Kimmo |  |  |  |  |  |
| 2359 | 54.1.5.2 | stage 3 - parameter value issues | 64d | 2001-01-02 A | 2001-03-30 A |  | 100% | 2001-01-02 | 2001-03-30 | 64d | finish no earlier than 2001-03-30 | N3 | 512h | 512h | Rel-4 | Gwiho |  |  |  |  |  |
| 2360 | 54.2 | Lawful interception | 155d | 2000-08-21 A | 2001-03-23 A |  | 100% | 2000-08-21 | 2001-03-23 | 155d | finish no earlier than 2001-03-23 | S3 | 1240h | 1240h | Rel-4 | Dionisio |  |  |  |  |  |
| 2361 | 54.4 | Deleted - Conformance Test Aspects - Enable bearer independent CS architecture | 260d | 2001-03-05 A | 2002-03-01 A |  | 100% | 2001-03-05 | 2002-03-01 | 260d |  | T1 | 2080h | 2080h | Rel-4 | Ingbert |  | TP-15 | CSSPLIT-TEST |  |  |
| 2362 | 55 | **MExE enhancements Rel-4** | 511d | 2000-01-03 A | 2001-12-14 A |  | 100% | 2000-01-03 | 2001-12-14 | 511d |  | T2 | 19032h | 19032h | Rel-4 | Kimmo |  |  | MEXE |  |  |
| 2363 | 55.1 | **MExE Security Analysis Activity** | 474d | 2000-02-22 A | 2001-12-14 A |  | 100% | 2000-02-22 | 2001-12-14 | 474d |  | S3 | 8464h | 8464h | Rel-4 | Dionisio |  |  | MEXE-SEC | BT | colin.blanchard@bt.com |
| 2364 | 55.1.1 | Stage 3 | 370d | 2000-07-17 A | 2001-12-14 A |  | 100% | 2000-07-17 | 2001-12-14 | 370d | finish no earlier than 2001-12-14 | S3 | 2960h | 2960h | Rel-4 | Dionisio |  |  | MEXE1-SEC |  |  |
| 2365 | 55.1.2 | Terminal aspects | 214d | 2000-02-22 A | 2000-12-15 A |  | 100% | 2000-02-22 | 2000-12-15 | 214d | finish no earlier than 2000-12-15 | T2 | 1712h | 1712h | Rel-4 |  |  |  |  |  |  |
| 2366 | 55.2 | **MExE Rel4 Improvements and Investigations** | 251d | 2000-01-03 A | 2000-12-15 A |  | 100% | 2000-01-03 | 2000-12-15 | 251d |  | T2 | 6480h | 6480h | Rel-4 | Kimmo | 22.057, 23.057 |  | MEXE-ENHANC | Motorola | Mark Cataldo |
| 2367 | 55.2.1 | 3rd MExE classmark | 251d | 2000-01-03 A | 2000-12-15 A |  | 100% | 2000-01-03 | 2000-12-15 | 251d | finish no earlier than 2000-12-15 | T2 | 2000h | 2000h | Rel-4 | Kimmo | 22.057, 23.057 |  |  | Motorola | Mark Cataldo |
| 2368 | 55.2.2 | FS on Secure download mechanism and capabilities to support SDR concepts | 225d | 2000-02-07 A | 2000-12-15 A |  | 100% | 2000-02-07 | 2000-12-15 | 225d | finish no earlier than 2000-12-15 | T2 | 1800h | 1800h | Rel-4 | Kimmo | 22.057, 23.057 |  |  | Motorola | Mark Cataldo |
| 2369 | 55.2.3 | FS on Support of MP3/MPEG4 content | 225d | 2000-02-07 A | 2000-12-15 A |  | 100% | 2000-02-07 | 2000-12-15 | 225d | finish no earlier than 2000-12-15 | T2 | 1800h | 1800h | Rel-4 | Kimmo | 22.057, 23.057 |  |  | Motorola | Mark Cataldo |

Notes:
- 2345: -
- 2346: -
- 2347: -
- 2348: Marked as closed 12/2008 (was marked 60% complete)
- 2349: Marked as stopped 12/2008
- 2350: duration set to 6 months (was 0), finish date set
- 2351: -
- 2352: DAB 12.12.01 should be 100% hence closed
- 2353: R00 stage 2 at least 80 % complete in TSGS #8 21.-23.6.2000
- 2354: -
- 2355: -
- 2356: -
- 2357: -
- 2358: -
- 2359: -
- 2360: Requirements capture: S3#14 (Aug 00), Feature specification: S3#15 (Sep 00), Definition of architecture. Should be included in general LI work mentioned above.
- 2361: Marked as stopped 12/2008
- 2362: -
- 2363: Presentation to S3 of threats and countermeasures analysis: S3#15, Feature specification: S3#16. S3#18: WID updated
- 2364: Analysis undertaken by T2. No additional analysis needed for Rel-4
- 2365: -
- 2366: -
- 2367: Additional features for MExE R2000
- 2368: -
- 2369: -

| ID | WBS | Task | Duration | Start | Finish | Complete | Baseline start | Baseline finish | Baseline duration | Constraint | Resources | Work | Actual work | Text1 | Text6 | Text8 | Text3 | Text4 | Text5 |
| --- | --- | --- | --- | --- | --- | --- | --- | --- | --- | --- | --- | --- | --- | --- | --- | --- | --- | --- | --- |
| 2370 | 56 | **Tandem Free aspects for 3G and between 2G and 3G systems** | 344d | 2000-02-22 A | 2001-06-15 A | 100% | 2000-02-22 | 2001-06-15 | 344d |  | S4 | 9696h | 9696h | TFO | Rel-4 | Paolo |  |  |  |
| 2371 | 56.1 | **Tandem Free AMR** | 344d | 2000-02-22 A | 2001-06-15 A | 100% | 2000-02-22 | 2001-06-15 | 344d |  | S4 | 6944h | 6944h | TFO-AMR | Rel-4 | Paolo |  |  |  |
| 2372 | 56.1.1 | Specification | 284d | 2000-02-22 A | 2001-03-23 A | 100% | 2000-02-22 | 2001-03-23 | 284d | start no earlier than 2000-02-22 | S4 | 2272h | 2272h |  | Rel-4 | Paolo | 28.062 |  |  |
| 2373 | 56.1.2 | **Impact on:** | 115d | 2001-01-08 A | 2001-06-15 A | 100% | 2001-01-08 | 2001-06-15 | 115d |  | NP | 1920h | 1920h |  | Rel-4 | Kimmo |  |  |  |
| 2374 | 56.1.2.1 | CN | 60d | 2001-03-26 A | 2001-06-15 A | 100% | 2001-03-26 | 2001-06-15 | 60d | finish no earlier than 2001-06-15 | NP | 480h | 480h |  | Rel-4 | Kimmo |  |  |  |
| 2375 | 56.1.2.2 | GERAN | 65d | 2001-01-08 A | 2001-04-06 A | 100% | 2001-01-08 | 2001-04-06 | 65d | finish no earlier than 2001-04-06 | GP | 520h | 520h |  | Rel-4 | Paolo |  |  |  |
| 2376 | 57 | **Advanced Speech Call Items enhancements_REL-4** | 334d | 2000-12-03 A | 2002-03-14 A | 100% | 2000-12-03 | 2002-03-14 | 334d |  | N1 | 5925.6h | 5925.6h | ASCI | Rel-4 | Frederic |  | Nortel | sonia.garapaty@nortelnetworks.com |
| 2377 | 57.1 | Stage 2 | 326.7d | 2000-12-03 A | 2002-03-14 A | 100% | 2000-12-03 | 2002-03-14 | 326.7d | finish no earlier than 2002-03-14 | N4 | 2613.6h | 2613.6h |  | Rel-4 | Kimmo | 23.067, 24.067 | Sagem | Vivien Perlic |
| 2378 | 57.2 | Stages 2 and 3 on A interface | 80d | 2000-12-03 A | 2001-03-23 A | 100% | 2000-12-03 | 2001-03-23 | 80d | finish no earlier than 2001-03-23 | N1 | 640h | 640h |  | Rel-4 | Frederic | 44.068, 44.069, 24.008 | Nortel | sonia.garapaty@nortelnetworks.com |
| 2379 | 58 | **700 MHz spectrum support** | 776d | 2000-01-03 A | 2002-12-20 A | 100% | 2000-01-03 | 2002-12-20 | 776d |  | GP | 25016h | 25016h | 700SS | Rel-4 | Paolo |  |  |  |
| 2380 | 58.1 | **GERAN support for the 700 MHz band** | 276d | 2000-01-03 A | 2001-01-19 A | 100% | 2000-01-03 | 2001-01-19 | 276d |  | GP | 8808h | 8808h |  | Rel-4 | Paolo |  |  |  |
| 2381 | 58.1.1 | Signalling support | 276d | 2000-01-03 A | 2001-01-19 A | 100% | 2000-01-03 | 2001-01-19 | 276d | finish no earlier than 2001-01-19 | GP | 2200h | 2200h |  | Rel-4 | Paolo |  |  |  |
| 2382 | 58.1.2 | Physical layer definitions | 276d | 2000-01-03 A | 2001-01-19 A | 100% | 2000-01-03 | 2001-01-19 | 276d | finish no earlier than 2001-01-19 | GP | 2200h | 2200h |  | Rel-4 | Paolo |  |  |  |
| 2383 | 58.1.3 | Receiver performance and RF budget | 276d | 2000-01-03 A | 2001-01-19 A | 100% | 2000-01-03 | 2001-01-19 | 276d | finish no earlier than 2001-01-19 | GP | 2200h | 2200h |  | Rel-4 | Paolo |  |  |  |
| 2384 | 58.2 | **GERAN MS Conformance test for 700 MHz band** | 175d | 2001-04-02 A | 2001-11-30 A | 100% | 2001-04-02 | 2001-11-30 | 175d |  | GP | 2800h | 2800h |  | Rel-4 | Paolo |  |  |  |
| 2385 | 58.2.1 | MS test | 175d | 2001-04-02 A | 2001-11-30 A | 100% | 2001-04-02 | 2001-11-30 | 175d | finish no earlier than 2001-11-30 | GP | 1400h | 1400h |  | Rel-4 | Paolo |  |  |  |
| 2386 | 58.3 | **GERAN BTS Conformance test for 700 MHz band** | 450d | 2001-04-02 A | 2002-12-20 A | 100% | 2001-04-02 | 2002-12-20 | 450d |  | GP | 7200h | 7200h |  | Rel-4 | Paolo |  |  |  |
| 2387 | 58.3.1 | BTS test | 450d | 2001-04-02 A | 2002-12-20 A | 100% | 2001-04-02 | 2002-12-20 | 450d | finish no earlier than 2002-12-20 | GP | 3600h | 3600h |  | Rel-4 | Paolo |  |  |  |
| 2388 | 59 | Operator Determined Barring for Packet Oriented Services | 208d | 2000-06-01 A | 2001-03-19 A | 100% | 2000-06-01 | 2001-03-19 | 208d | finish no earlier than 2001-03-19 | NP | 1664h | 1664h | ODB | Rel-4 | Kimmo |  | NEC | Toshiyuki Tamura (tamurato@aj.jp.nec.com) |
| 2389 | 60 | **UMTS QoS Architecture for PS Domain** | 759d | 2000-01-03 A | 2002-11-27 A | 100% | 2000-01-03 | 2002-11-27 | 759d |  | S2 | 41312h | 41312h | QoSPS | Rel-4 | Maurice |  | Ericsson | Ina.widegren@era.ericsson.se |
| 2390 | 60.1 | Architecture | 153d | 2000-06-05 A | 2001-01-03 A | 100% | 2000-06-05 | 2001-01-03 | 153d | finish no earlier than 2001-01-03 | S2 | 1224h | 1224h |  | Rel-4 | Maurice | 23.107 |  |  |
| 2391 | 60.2 | Charging and OAM&P for QoS Management | 201d | 2001-09-21 A | 2002-06-28 A | 100% | 2001-09-21 | 2002-06-28 | 201d | finish no earlier than 2002-06-28 | S5 | 1608h | 1608h | QoSPS-OAM | Rel-4 | Dionisio | 32-series | VoiceStream, Motorola |  |
| 2392 | 60.3 | **RAB Quality of Service (re)Negotiation over Iu** | 155d | 2000-08-21 A | 2001-03-23 A | 100% | 2000-08-21 | 2001-03-23 | 155d |  | R3 | 3648h | 3648h | QoSPS-MAPEND-RABQoS | Rel-4 | Juha | 25.413 | Ericsson | A. Molander |
| 2393 | 60.3.1 | RAB Quality of Service Negotiation over Iu | 155d | 2000-08-21 A | 2001-03-23 A | 100% | 2000-08-21 | 2001-03-23 | 155d | finish no earlier than 2001-03-23 | R3 | 1240h | 1240h | QoSPS-MAPEND-RABQoS-Negot | Rel-4 | Juha |  | Ericsson | A. Molander |
| 2394 | 60.3.2 | RAB Quality of Service Negotiation over Iu during relocation | 16d | 2001-03-02 A | 2001-03-23 A | 100% | 2001-03-02 | 2001-03-23 | 16d | start no earlier than 2001-03-02 | R3 | 128h | 128h | QoSPS-MAPEND-RABQoS-NegotReloc | Rel-4 | Juha |  |  |  |
| 2395 | 60.3.3 | RAB Quality of Service Re-Negotiation over Iu | 130d | 2000-09-25 A | 2001-03-23 A | 100% | 2000-09-25 | 2001-03-23 | 130d | finish no earlier than 2001-03-23 | R3 | 1040h | 1040h | QoSPS-MAPEND-RABQoS-ReNegot | Rel-4 | Juha |  | Motorola | S. Irwin |

Notes:
- 2370: RAN and CN to verify no problems for GSM terminals roaming in 3G R99
- 2371: RAN and CN to verify UMTS_AMR_2 support
- 2372: -
- 2373: "Implementation" changed to "Impact on:" by A. Sultan (for better wording)
- 2374: RAN and CN to verify UMTS_AMR_2 support
- 2375: End date Modified from June to March to have it in Rel4
- 2376: Approved at CN#10
- 2377: CN4#11 30/11/02: no inputs received in CN4
- 2378: -
- 2379: -
- 2380: -
- 2381: -
- 2382: -
- 2383: -
- 2384: -
- 2385: -
- 2386: -
- 2387: -
- 2388: Completed WI missing from the P-plan Added for tracking
- 2389: -
- 2390: -
- 2391: -
- 2392: -
- 2393: -
- 2394: -
- 2395: -

| ID | WBS | Task | Duration | Start | Finish | Complete | Baseline start | Baseline finish | Baseline duration | Constraint | Resources | Work | Actual work | Text1 | Text6 | Text8 | Text12 | Text4 | Text5 | Text3 |
| --- | --- | --- | --- | --- | --- | --- | --- | --- | --- | --- | --- | --- | --- | --- | --- | --- | --- | --- | --- | --- |
| 2396 | 60.4 | **GERAN QoS Aspects - Handovers: maintenance of real-time QoS while moving between cells in the PLMN including inter-SGSN and SRNS relocation or possibly other mechanisms** | 501d | 2000-01-03 A | 2001-11-30 A | 100% | 2000-01-03 | 2001-11-30 | 501d |  | GP | 14456h | 14456h | GERQoS | Rel-4 | Paolo |  |  |  |  |
| 2397 | 60.4.1 | **Handover Concept for the PS domain** | 501d | 2000-01-03 A | 2001-11-30 A | 100% | 2000-01-03 | 2001-11-30 | 501d |  | GP | 10448h | 10448h |  | Rel-4 | Paolo |  |  |  |  |
| 2398 | 60.4.1.1 | Stable RT handover report 25.936 including header removal | 14d | 2000-01-03 A | 2000-01-19 A | 100% | 2000-01-03 | 2000-01-19 | 14d | start no earlier than 2000-01-03 | GP [92.9%] | 104h | 104h |  | Rel-4 | Paolo |  |  |  |  |
| 2399 | 60.4.1.2 | Update of stage 2 | 293d | 2000-01-03 A | 2001-02-13 A | 100% | 2000-01-03 | 2001-02-13 | 293d | finish no earlier than 2001-02-13 | GP | 2336h | 2336h |  | Rel-4 | Paolo |  |  |  |  |
| 2400 | 60.4.1.3 | Update of relevant stage 3 specs -> RRC | 501d | 2000-01-03 A | 2001-11-30 A | 100% | 2000-01-03 | 2001-11-30 | 501d | finish no earlier than 2001-11-30 | G2 | 4000h | 4000h |  | Rel-4 | Gert |  |  |  |  |
| 2401 | 60.5 | **Deleted - GERAN MS Conformance test for inter-system and intra-system Packet data real-time Handover** | 324d | 2001-08-31 A | 2002-11-27 A | 100% | 2001-08-31 | 2002-11-27 | 324d |  | G4,R3 | 12960h | 12960h | GERQoS-Mstest | Rel-4 | Paolo | GP-12 |  |  |  |
| 2402 | 60.5.1 | **Deleted - Handover for the PS domain** | 324d | 2001-08-31 A | 2002-11-27 A | 100% | 2001-08-31 | 2002-11-27 | 324d |  | G4,R3 | 10368h | 10368h |  | Rel-4 | Paolo | GP-12 |  |  |  |
| 2403 | 60.5.1.1 | Deleted - Stable RT handover report 25.936 including header removal | 324d | 2001-08-31 A | 2002-11-27 A | 100% | 2001-08-31 | 2002-11-27 | 324d | finish no earlier than 2002-11-27 | G4,R3 | 2592h | 2592h |  | Rel-4 | Paolo | GP-12 |  |  |  |
| 2404 | 60.5.1.2 | Deleted - Update of stage 2 | 324d | 2001-08-31 A | 2002-11-27 A | 100% | 2001-08-31 | 2002-11-27 | 324d | finish no earlier than 2002-11-27 | G4,R3 | 2592h | 2592h |  | Rel-4 | Paolo | GP-12 |  |  |  |
| 2405 | 60.5.1.3 | Deleted - Update of relevant stage 3 specs | 324d | 2001-08-31 A | 2002-11-27 A | 100% | 2001-08-31 | 2002-11-27 | 324d | finish no earlier than 2002-11-27 | G4,R3 | 2592h | 2592h |  | Rel-4 | Paolo | GP-12 |  |  |  |
| 2406 | 60.6 | PS-domain handover for real-time services | 155d | 2000-08-28 A | 2001-03-30 A | 100% | 2000-08-28 | 2001-03-30 | 155d | finish no earlier than 2001-03-30 | R3 | 1240h | 1240h | QoSPS-PSdoRTS | Rel-4 | Juha |  | Nokia | A. Lansisalmi |  |
| 2407 | 60.7 | Deleted - RAB QoS Renegotiation at Relocation | 58d | 2001-01-03 A | 2001-03-23 A | 100% | 2001-01-03 | 2001-03-23 | 58d | finish no earlier than 2001-03-23 | R3 | 464h | 464h |  | Rel-4 | Juha | RP-11 |  |  | 25.851, 25.946 |
| 2408 | 61 | (Small) Technical Enhancements and Improvements for Rel-4 | 326d? | 2000-01-03 A | 2001-03-30 A | 100% | 2000-01-03 | 2001-03-30 | 326d? |  | All | 2608h | 2608h | TEI4 | Rel-4 | all |  |  |  |  |
| 2409 | 616 | Test - (Small) Technical Enhancements and Improvements for Rel-4 | 326d? | 2000-01-03 A | 2001-03-30 A | 100% | 2000-01-03 | 2001-03-30 | 326d? | finish no earlier than 2008-12-31 | R5,T1 | 2608h | 2608h | TEI4_Test | Rel-4 | Ingbert |  |  |  |  |
| 2410 | 62 | **Rel-4 Evolutions of the transport in the UTRAN** | 525d | 2000-08-21 A | 2002-08-23 A | 100% | 2000-08-21 | 2002-08-23 | 525d |  | RP | 8600h | 8600h | ETRAN | Rel-4 | Issam |  | Alcatel | Francois Courau |  |
| 2411 | 62.1 | QoS optimization for AAL2 connections over Iub and Iur interfaces | 160d | 2000-08-21 A | 2001-03-30 A | 100% | 2000-08-21 | 2001-03-30 | 160d | finish no earlier than 2001-03-30 | R3 | 1280h | 1280h | ETRAN-QoSAAL2 | Rel-4 | Juha |  | Japan Telecom | T. Yoshimura |  |
| 2412 | 62.2 | Transport bearer modification procedure on Iub, Iur, and Iu | 130d | 2000-10-02 A | 2001-03-30 A | 100% | 2000-10-02 | 2001-03-30 | 130d | finish no earlier than 2001-03-30 | R3 | 1040h | 1040h | ETRAN-MigrMod | Rel-4 | Juha |  | Japan Telecom | T. Yoshimura |  |
| 2413 | 62.3 | **Deleted - Conformance Test Aspects of Rel-4 evolutions of the transport in UTRAN** | 130d | 2002-02-25 A | 2002-08-23 A | 100% | 2002-02-25 | 2002-08-23 | 130d |  | T1 | 2080h | 2080h |  | Rel-4 | Ingbert | TP-17 |  |  |  |
| 2414 | 62.3.1 | Deleted - Testing RAB support enhancements | 130d | 2002-02-25 A | 2002-08-23 A | 100% | 2002-02-25 | 2002-08-23 | 130d | finish no earlier than 2002-08-23 | T1 | 1040h | 1040h | CT-RABS? | Rel-4 | Ingbert | TP-17 |  |  | 34.108, 34. 121, 34.122, 34.123 p 1,2, 34.123 pt 3 |
| 2415 | 63 | **Rel-4 Evolutions of the transport in the CN** | 215d | 2000-05-29 A | 2001-03-23 A | 100% | 2000-05-29 | 2001-03-23 | 215d |  | N4,N1,N2,S2 | 7968h | 7968h | CNTRSP | Rel-4 | Kimmo |  |  |  |  |
| 2416 | 63.1 | **IP Transport of CN protocols (e.g., CAP, MAP)** | 77d | 2000-12-07 A | 2001-03-23 A | 100% | 2000-12-07 | 2001-03-23 | 77d |  | N4 | 2808h | 2808h | SS7IP | Rel-4 | Kimmo |  |  |  |  |
| 2417 | 63.1.1 | **Stage 3** | 77d | 2000-12-07 A | 2001-03-23 A | 100% | 2000-12-07 | 2001-03-23 | 77d |  | N4 | 2192h | 2192h |  | Rel-4 | Kimmo |  |  |  |  |
| 2418 | 63.1.1.1 | CAP | 77d | 2000-12-07 A | 2001-03-23 A | 100% | 2000-12-07 | 2001-03-23 | 77d | finish no earlier than 2001-03-23 | N2 | 616h | 616h |  | Rel-4 | Kimmo |  |  |  |  |
| 2419 | 63.1.1.2 | MAP | 77d | 2000-12-07 A | 2001-03-23 A | 100% | 2000-12-07 | 2001-03-23 | 77d | finish no earlier than 2001-03-23 | N4 | 616h | 616h |  | Rel-4 | Kimmo |  |  |  |  |
| 2420 | 63.1.1.3 | BSSAP+ | 43d | 2001-01-15 A | 2001-03-14 A | 100% | 2001-01-15 | 2001-03-14 | 43d | finish no earlier than 2001-03-14 | N1 | 344h | 344h | SS7IP-BSSAP+ | Rel-4 | Frederic |  |  |  |  |

Notes:
- 2396: -
- 2397: -
- 2398: -
- 2399: -
- 2400: -
- 2401: Still exist? To be clarified by GERAN4/5. Marked as stopped 12/2008
- 2402: Marked as stopped 12/2008
- 2403: Marked as stopped 12/2008
- 2404: Marked as stopped 12/2008
- 2405: Marked as stopped 12/2008
- 2406: -
- 2407: Marked as stopped 12/2008
- 2408: "Joker" WI, to be used for a Rel 4 CR not related to any feature and with very limited impact on the system
- 2409: "Joker" WI, to be used for small modifications applicable to Rel 4 conformance testing. Moved in from the Stoyan/Testing WP
- 2410: -
- 2411: -
- 2412: -
- 2413: Marked as stopped 12/2008
- 2414: Marked as stopped 12/2008
- 2415: -
- 2416: -
- 2417: -
- 2418: -
- 2419: -
- 2420: -

| ID | WBS | Task | Duration | Start | Finish | Complete | Baseline start | Baseline finish | Baseline duration | Constraint | Resources | Work | Actual work | Text4 | Text5 | Text6 | Text8 | Text1 | Text3 | Text12 |
| --- | --- | --- | --- | --- | --- | --- | --- | --- | --- | --- | --- | --- | --- | --- | --- | --- | --- | --- | --- | --- |
| 2421 | 63.2 | **FS on Transport and control separation in the PS CN domain** | 215d | 2000-05-29 A | 2001-03-23 A | 100% | 2000-05-29 | 2001-03-23 | 215d |  | S2 | 3440h | 3440h | Ericsson | Juan-Antonio.Ibanez@eed.ericsson.se | Rel-4 | Maurice |  |  |  |
| 2422 | 63.2.1 | Architectural impacts | 215d | 2000-05-29 A | 2001-03-23 A | 100% | 2000-05-29 | 2001-03-23 | 215d | finish no earlier than 2001-03-23 | S2 | 1720h | 1720h |  |  | Rel-4 | Maurice |  |  |  |
| 2423 | 64 | **Rel-4 Improvements of Radio Interface** | 700d | 2000-07-10 A | 2003-03-14 A | 100% | 2000-07-10 | 2003-03-14 | 700d |  | RP | 28624h | 28624h |  |  | Rel-4 |  | RInImp |  |  |
| 2424 | 64.1 | UTRA repeater specification (master) | 183d | 2000-07-10 A | 2001-03-21 A | 100% | 2000-07-10 | 2001-03-21 | 183d | finish no earlier than 2001-03-21 | R4 | 1464h | 1464h | Mikom, Allgon | T. Kummetz, Mikom; Alf Ahlström, Allgon | Rel-4 | Issam | RInImp-REP |  |  |
| 2425 | 64.2 | DSCH power control improvement in soft handover | 140d | 2000-09-11 A | 2001-03-23 A | 100% | 2000-09-11 | 2001-03-23 | 140d | finish no earlier than 2001-03-23 | R1 | 1120h | 1120h | Nokia | antti.toskala@nokia.com | Rel-4 | Patrick | RInImp-DSCHsho |  |  |
| 2426 | 64.3 | UMTS 1800 | 320d | 2000-09-25 A | 2001-12-14 A | 100% | 2000-09-25 | 2001-12-14 | 320d | finish no earlier than 2001-12-14 | R4 | 2560h | 2560h | Motorola | Howard Benn | Rel-4 | Issam | RInImp-UMTS18 |  |  |
| 2427 | 64.4 | UMTS 1900 | 195d | 2001-03-19 A | 2001-12-14 A | 100% | 2001-03-19 | 2001-12-14 | 195d | finish no earlier than 2001-12-14 | R4 | 1560h | 1560h | Motorola | Howard Benn | Rel-4 | Issam | RInImp-UMTS19 | 25.101 |  |
| 2428 | 64.5 | FS on High Speed downlink packet access | 155d | 2000-08-21 A | 2001-03-23 A | 100% | 2000-08-21 | 2001-03-23 | 155d | finish no earlier than 2001-03-23 | R2 | 1240h | 1240h | Motorola | A. Ghosh | Rel-4 | Joern | RInImp-HSDPA |  |  |
| 2429 | 64.6 | Deleted - FS on improved common DL channel for Cell-FACH state | 340d | 2000-09-11 A | 2001-12-28 A | 100% | 2000-09-11 | 2001-12-28 | 340d | finish no earlier than 2001-12-28 | R2 | 2720h | 2720h | GBT | J. Kwak | Rel-4 | Joern | RInImp-DLCFACH |  | RP-14 |
| 2430 | 64.7 | **Conformance Test Spec. Rel-4 improvements in Radio Interface** | 375d | 2001-10-08 A | 2003-03-14 A | 100% | 2001-10-08 | 2003-03-14 | 375d |  | T1 | 12360h | 12360h |  |  | Rel-4 | Ingbert |  |  |  |
| 2431 | 64.7.1 | Deleted - Testing Improved usage of downlink resource in FDD for CCTrCHs of dedicated type | 140d | 2002-02-18 A | 2002-08-30 A | 100% | 2002-02-18 | 2002-08-30 | 140d | finish no earlier than 2002-08-30 | T1 | 1120h | 1120h |  |  | Rel-4 | Ingbert |  |  | TP-17 |
| 2432 | 64.7.2 | Deleted - Testing Terminal Power saving features | 140d | 2002-02-18 A | 2002-08-30 A | 100% | 2002-02-18 | 2002-08-30 | 140d | finish no earlier than 2002-08-30 | T1 | 1120h | 1120h |  |  | Rel-4 | Ingbert |  |  | TP-17 |
| 2433 | 64.7.3 | Deleted - Testing DSCH power control improvement in soft handover | 140d | 2002-02-18 A | 2002-08-30 A | 100% | 2002-02-18 | 2002-08-30 | 140d | finish no earlier than 2002-08-30 | T1 | 1120h | 1120h |  |  | Rel-4 | Ingbert |  |  | TP-17 |
| 2434 | 64.7.4 | Testing UMTS 1800 | 180d | 2001-10-08 A | 2002-06-14 A | 100% | 2001-10-08 | 2002-06-14 | 180d | finish no earlier than 2002-06-14 | T1 | 1440h | 1440h |  |  | Rel-4 | Ingbert |  | 34.108, 34,121, 34.122, 34.123-1 |  |
| 2435 | 64.7.5 | Testing UMTS 1900 | 180d | 2001-10-08 A | 2002-06-14 A | 100% | 2001-10-08 | 2002-06-14 | 180d | finish no earlier than 2002-06-14 | T1 | 1440h | 1440h |  |  | Rel-4 | Ingbert |  | 34.108, 34,121, 34.122, 34.123-1 |  |
| 2436 | 64.7.6 | Testing UMTS 1800 - TTCN | 195d | 2002-06-17 A | 2003-03-14 A | 100% | 2002-06-17 | 2003-03-14 | 195d | finish no earlier than 2003-03-14 | T1 | 1560h | 1560h |  |  | Rel-4 | Ingbert |  | 34.123-3 |  |
| 2437 | 64.7.7 | Testing UMTS 1900 - TTCN | 195d | 2002-06-17 A | 2003-03-14 A | 100% | 2002-06-17 | 2003-03-14 | 195d | finish no earlier than 2003-03-14 | T1 | 1560h | 1560h |  |  | Rel-4 | Ingbert |  | 34.123-3 |  |
| 2438 | 65 | **Rel-4 RAN improvements** | 938d? | 2000-08-14 A | 2004-03-17 A | 100% | 2000-08-14 | 2004-03-17 | 938d? |  | RP | 29336h | 29336h |  |  | Rel-4 |  | RANimp |  |  |
| 2439 | 65.1 | Node B synchronization for TDD | 160d | 2000-08-14 A | 2001-03-23 A | 100% | 2000-08-14 | 2001-03-23 | 160d | finish no earlier than 2001-03-23 | R1 | 1280h | 1280h | Siemens | S. Oestreich | Rel-4 | Patrick | RANimp-NBsync |  |  |
| 2440 | 65.2 | RAB support enhancement for Rel-4 | 155d | 2000-08-21 A | 2001-03-23 A | 100% | 2000-08-21 | 2001-03-23 | 155d | finish no earlier than 2001-03-23 | R2 | 1240h | 1240h | Ericsson | M. Israelsson, A. Krishnarajah | Rel-4 | Joern | RANimp-RABSE |  |  |
| 2441 | 65.4 | **Deleted - Conformance Test Aspects - Rel-4 RAN Improvements** | 577d? | 2002-01-01 A | 2004-03-17 A | 100% | 2002-01-01 | 2004-03-17 | 577d? |  | T1 | 19312h | 19312h |  |  | Rel-4 | Ingbert |  |  | TP-23 |
| 2442 | 65.4.1 | Deleted - Testing Radio access bearer support enhancments | 175d | 2002-01-01 A | 2002-09-02 A | 100% | 2002-01-01 | 2002-09-02 | 175d | finish no earlier than 2002-09-02 | T1 | 1400h | 1400h |  |  | Rel-4 | Ingbert |  |  | TP-17 |
| 2443 | 65.4.2 | Deleted - Testing RAB support enhancements-Robust Header Compression | 332d | 2002-05-28 A | 2003-09-03 A | 100% | 2002-05-28 | 2003-09-03 | 332d | finish no earlier than 2003-09-03 | T1 | 2656h | 2656h |  |  | Rel-4 | Ingbert | RABimp-RoCH | 34.123-1, -2 | TP-21 |
| 2444 | 65.4.3 | Deleted - Testing RAB support enhancements-Robust Header Compression - TTCN | 472d | 2002-05-28 A | 2004-03-17 A | 100% | 2002-05-28 | 2004-03-17 | 472d | finish no earlier than 2004-03-17 | T1 | 3776h | 3776h |  |  | Rel-4 | Ingbert |  | 34.123-3 | TP-23 |
| 2445 | 65.4.4 | Testing of Extended Robut Header Compression | 270d | 2002-09-18 A | 2003-09-30 A | 100% | 2002-09-18 | 2003-09-30 | 270d | finish no earlier than 2003-09-30 | T1 | 2160h | 2160h |  |  | Rel-4 | Ingbert | Ext-RoHC | 34.123-1, -2 |  |
| 2446 | 65.4.5 | Deleted - Testing of Extended Robut Header Compression - TTCN | 325d | 2002-09-18 A | 2003-12-16 A | 100% | 2002-09-18 | 2003-12-16 | 325d | finish no earlier than 2003-12-16 | T1 | 2600h | 2600h |  |  | Rel-4 | Ingbert |  | 34.123-3 | TP-22 |
| 2447 | 620.3.6 | Deleted - General changes to TS34.121 corresponding to release 4 | 263d? | 2003-03-03 A | 2004-03-03 A | 100% | 2003-03-03 | 2004-03-03 | 263d? | finish no earlier than 2004-03-03 | T1 | 2104h | 2104h |  |  | Rel-4 | Ingbert | RANimp-test | 34.108, 34.121 | TP-23 |

Notes:
- 2421: -
- 2422: -
- 2423: -
- 2424: -
- 2425: -
- 2426: -
- 2427: -
- 2428: -
- 2429: Stopped at RP#14
- 2430: -
- 2431: Marked as stopped 12/2008
- 2432: Marked as stopped 12/2008
- 2433: Marked as stopped 12/2008
- 2434: -
- 2435: -
- 2436: -
- 2437: -
- 2438: -
- 2439: -
- 2440: 29 Nov 2000: split into ROHC and non-ROHC part; 5 Mar 2001: splitting off of ROHC for Rel-4 agreed by R2
- 2441: Marked as stopped 12/2008
- 2442: Marked as stopped 12/2008
- 2443: UID changed. Marked as stopped 12/2008
- 2444: UID changed. Marked as stopped 12/2008
- 2445: Marked as closed 12/2008 (was marked 15% complete)
- 2446: Marked as stopped 12/2008
- 2447: Marked as stopped 12/2008

| ID | WBS | Task | Duration | Start | Finish | Complete | Baseline start | Baseline finish | Baseline duration | Constraint | Resources | Work | Actual work | Text1 | Text4 | Text6 | Text8 | Text12 | Text3 | Text5 |
| --- | --- | --- | --- | --- | --- | --- | --- | --- | --- | --- | --- | --- | --- | --- | --- | --- | --- | --- | --- | --- |
| 2448 | 66 | **Rel-4 Emergency call enhancements** | 628d | 2000-01-03 A | 2002-05-28 A | 100% | 2000-01-03 | 2002-05-28 | 628d |  | N1,S1,T1 | 3600h | 3600h | EMC1 | Ericsson | Rel-4 | Frederic |  |  |  |
| 2449 | 66.1 | **For CS based calls** | 628d | 2000-01-03 A | 2002-05-28 A | 100% | 2000-01-03 | 2002-05-28 | 628d |  | N1 | 3600h | 3600h | EMC1-CS | Ericsson | Rel-4 | Frederic |  |  |  |
| 2450 | 66.1.1 | Distinction in CS domain of emergency call types to different emergency services | 40d | 2000-05-01 A | 2000-06-23 A | 100% | 2000-05-01 | 2000-06-23 | 40d | finish no earlier than 2000-06-23 | S1 | 320h | 320h | EMC1-CS |  | Rel-4 | Alain |  |  |  |
| 2451 | 66.1.2 | Distinction in CS domain of emergency calls to different emergency types | 22d | 2000-08-24 A | 2000-09-22 A | 100% | 2000-08-24 | 2000-09-22 | 22d | finish no earlier than 2000-09-22 | N1 | 176h | 176h | EMC1-CS |  | Rel-4 | Frederic |  |  |  |
| 2452 | 66.1.3 | Deleted - Conformance Test Aspects - Emergency call enhancements | 151d | 2000-01-03 A | 2000-07-28 A | 100% | 2000-01-03 | 2000-07-28 | 151d |  | T1 | 1200h | 1200h | EMC1-CS |  | Rel-4 | Ingbert | TP-08 |  |  |
| 2453 | 66.1.4 | Testing CS based emergency calls | 67d | 2002-02-25 A | 2002-05-28 A | 100% | 2002-02-25 | 2002-05-28 | 67d | finish no earlier than 2002-05-28 | T1 | 536h | 536h | EMC1-CS |  | Rel-4 | Ingbert |  | 34.123-1 |  |
| 2454 | 66.1.5 | Testing CS based emergency calls - TTCN | 134d | 2001-11-22 A | 2002-05-28 A | 100% | 2001-11-22 | 2002-05-28 | 134d | finish no earlier than 2002-05-28 | T1 | 1072h | 1072h | EMC1-CS |  | Rel-4 | Ingbert |  | 34.123-3 |  |
| 2455 | 67 | **Rel-4 Terminal interfaces** | 315d | 2000-01-03 A | 2001-03-15 A | 100% | 2000-01-03 | 2001-03-15 | 315d |  | T2 | 14296h | 14296h | TI |  | Rel-4 | Kimmo |  |  |  |
| 2456 | 67.1 | **AT commands enhancements** | 314d | 2000-01-03 A | 2001-03-14 A | 100% | 2000-01-03 | 2001-03-14 | 314d |  | T2 | 5016h | 5016h | TI-ATC |  | Rel-4 | Kimmo |  | 27.007 |  |
| 2457 | 67.1.1 | Specification of AT commands for new services | 314d | 2000-01-03 A | 2001-03-14 A | 100% | 2000-01-03 | 2001-03-14 | 314d | finish no earlier than 2001-03-14 | T2 | 2504h | 2504h |  |  | Rel-4 | Kimmo |  | 27.007 |  |
| 2458 | 67.2 | **Wide Area Data Synchronization** | 314d | 2000-01-03 A | 2001-03-14 A | 100% | 2000-01-03 | 2001-03-14 | 314d |  | T2 | 5016h | 5016h | TI-WADS |  | Rel-4 | Kimmo |  |  |  |
| 2459 | 67.2.1 | Continues evolution of Synchronization protocol | 314d | 2000-01-03 A | 2001-03-14 A | 100% | 2000-01-03 | 2001-03-14 | 314d | finish no earlier than 2001-03-14 | T2 | 2504h | 2504h | TI-SYNC-EVOL |  | Rel-4 | Kimmo |  | 27.903, 27.103 |  |
| 2460 | 67.3 | Terminal local model | 218d | 2000-05-16 A | 2001-03-15 A | 100% | 2000-05-16 | 2001-03-15 | 218d | finish no earlier than 2001-03-15 | T2 | 1744h | 1744h | TLM | Ericsson | Rel-4 | Kimmo |  | 23.227 | Olga.Tome@ECS.ERICSSON.SE |
| 2461 | 68 | **Rel-4 Location Services enhancements** | 455d | 2000-04-03 A | 2001-12-28 A | 100% | 2000-04-03 | 2001-12-28 | 455d |  | S2 | 26799.2h | 26799.2h | LCS1 | Nokia | Rel-4 | Maurice |  |  | Jan Kall |
| 2462 | 68.1 | CBS interactions | 455d | 2000-04-03 A | 2001-12-28 A | 100% | 2000-04-03 | 2001-12-28 | 455d | finish no earlier than 2001-12-28 | T2 | 3640h | 3640h | LCS1-CBS |  | Rel-4 |  |  | 23.041 |  |
| 2463 | 68.2 | LCS support in the CS domain | 180d | 2000-05-15 A | 2001-01-19 A | 100% | 2000-05-15 | 2001-01-19 | 180d | finish no earlier than 2001-01-19 | S2 | 1440h | 1440h | LCS1-CS |  | Rel-4 | Maurice |  |  |  |
| 2464 | 68.3 | **LCS support in the PS domain** | 435d | 2000-05-01 A | 2001-12-28 A | 100% | 2000-05-01 | 2001-12-28 | 435d |  | S2 | 13560h | 13560h | LCS1-PS |  | Rel-4 | Maurice |  |  |  |
| 2465 | 68.3.1 | Stage 1 | 40d | 2000-07-03 A | 2000-08-25 A | 100% | 2000-07-03 | 2000-08-25 | 40d | start no earlier than 2000-07-03 | S1 | 320h | 320h |  | Pacific Bell Wireless | Rel-4 | Alain |  | 22.071 | Randolph Wohlert (rwohlert@tri.sbc.com) |
| 2466 | 68.3.2 | Stage 2 | 190d | 2000-05-01 A | 2001-01-19 A | 100% | 2000-05-01 | 2001-01-19 | 190d | finish no earlier than 2001-01-19 | S2 | 1520h | 1520h |  |  | Rel-4 | Maurice |  | 23.271 |  |
| 2467 | 68.3.3 | **Stage 3** | 355d | 2000-08-21 A | 2001-12-28 A | 100% | 2000-08-21 | 2001-12-28 | 355d |  | N1 | 8240h | 8240h |  |  | Rel-4 | Frederic |  |  |  |
| 2468 | 68.3.3.1 | Layer 3 LCS signalling UE (MS) -SGSN (UMTS PS and and GSM-GPRS) | 355d | 2000-08-21 A | 2001-12-28 A | 100% | 2000-08-21 | 2001-12-28 | 355d | finish no earlier than 2001-12-28 | N1 | 2840h | 2840h |  | Nokia | Rel-4 | Frederic |  |  | Janne Muhonen |
| 2469 | 68.3.3.2 | MAP impacts of LCS | 160d | 2000-08-21 A | 2001-03-30 A | 100% | 2000-08-21 | 2001-03-30 | 160d | finish no earlier than 2001-03-30 | N4 | 1280h | 1280h |  |  | Rel-4 | Kimmo |  |  |  |
| 2470 | 68.3.3.3 | GTP signalling for LCS | 160d | 2000-08-21 A | 2001-03-30 A | 100% | 2000-08-21 | 2001-03-30 | 160d | finish no earlier than 2001-03-30 | N4 | 1280h | 1280h |  |  | Rel-4 | Kimmo |  |  |  |
| 2471 | 68.4 | **UE positioning Rel-4** | 260d | 2000-04-03 A | 2001-03-30 A | 100% | 2000-04-03 | 2001-03-30 | 260d |  | RP | 4591.2h | 4591.2h | LCS1-UEpos |  | Rel-4 | Issam |  |  |  |
| 2472 | 68.4.1 | Iub/Iur interfaces for methods Rel 99 | 233.9d | 2000-04-03 A | 2001-03-30 A | 100% | 2000-04-03 | 2001-03-30 | 233.9d | finish no earlier than 2001-03-30 | R3 | 1871.2h | 1871.2h | LCS1-UEpos-IubIur | Ericsson | Rel-4 | Juha |  |  | Yun-Chao Hu |
| 2473 | 68.4.2 | UE positioning enhancements - IPDL for TDD | 150d | 2000-08-28 A | 2001-03-23 A | 100% | 2000-08-28 | 2001-03-23 | 150d | finish no earlier than 2001-03-23 | R2 | 1200h | 1200h | LCS1-UEpos-enh | Siemens | Rel-4 | Joern |  |  | M. Beckmann |

Notes:
- 2448: -
- 2449: WI approved in TSG_10
- 2450: -
- 2451: Calls to different emergency services such as ambulance, fire brigade, police, etc. can be routed to respective different emergency centres. / NP-000447 is the stage 3 changes for CS call control protocol.
- 2452: UID changed. Marked as stopped 12/2008
- 2453: -
- 2454: -
- 2455: -
- 2456: -
- 2457: goal not completely achieved because of missing input
- 2458: AS: Rel5 changed to Rel4 according to SP#10 decision, milestone on testing added
- 2459: -
- 2460: -
- 2461: -
- 2462: -
- 2463: Only MAP impact foreseen so far. To be further split if needed.
- 2464: -
- 2465: To be also considered: External LCS client identity, and Privacy options when PDP-context and when no PDP-context is established
- 2466: AS: 23.271 completed at SP#10
- 2467: -
- 2468: -
- 2469: Missing work task
- 2470: -
- 2471: UID changed
- 2472: 27/11: WG corrected; rapporteur corrected
- 2473: 5 Mar 2001: splitting off of IPDL for TDD for Rel-4 agreed by R2

| ID | WBS | Task | Duration | Start | Finish | Complete | Baseline start | Baseline finish | Baseline duration | Constraint | Resources | Work | Actual work | Text1 | Text6 | Text8 | Text3 | Text4 | Text5 | Text12 |
| --- | --- | --- | --- | --- | --- | --- | --- | --- | --- | --- | --- | --- | --- | --- | --- | --- | --- | --- | --- | --- |
| 2474 | 69 | **Rel-4 UICC/(U)SIM enhancements and interworking** | 175d | 2000-07-24 A | 2001-03-23 A | 100% | 2000-07-24 | 2001-03-23 | 175d |  | T3 | 2800h | 2800h | UICC1 | Rel-4 | Xavier |  |  |  |  |
| 2475 | 69.1 | Common PCN Handset Specification (CPHS) | 175d | 2000-07-24 A | 2001-03-23 A | 100% | 2000-07-24 | 2001-03-23 | 175d | finish no earlier than 2001-03-23 | T3 | 1400h | 1400h | UICC1-CPHS | Rel-4 | Xavier | 27.103 | One2One |  |  |
| 2476 | 70 | **Rel-4 (U)SIM toolkit enhancements** | 210d | 2000-06-05 A | 2001-03-23 A | 100% | 2000-06-05 | 2001-03-23 | 210d |  | T3 | 3360h | 3360h | USAT1-LocLnk | Rel-4 | Xavier |  | Gemplus | Jean-Francois Rubon |  |
| 2477 | 70.1 | USAT local link | 210d | 2000-06-05 A | 2001-03-23 A | 100% | 2000-06-05 | 2001-03-23 | 210d | finish no earlier than 2001-03-23 | T3 | 1680h | 1680h | USAT1-LocLnk | Rel-4 | Xavier |  | Gemplus | Jean-Francois Rubon |  |
| 2478 | 71 | **Rel-4 Security enhancements** | 576d | 2000-01-03 A | 2002-03-15 A | 100% | 2000-01-03 | 2002-03-15 | 576d |  | S3 | 24152h | 24152h |  | Rel-4 | Dionisio |  | Vodafone | Peter.Howard@vodafone.com |  |
| 2479 | 71.1 | Evolution of GSM CS algorithms (e.g. A5/3 development and deployment) | 272d | 2000-01-03 A | 2001-01-15 A | 100% | 2000-01-03 | 2001-01-15 | 272d | finish no earlier than 2001-01-15 | S3 | 2168h | 2168h | SEC1-CSALGO1 | Rel-4 | Dionisio |  |  |  |  |
| 2480 | 71.2 | **Evolution of GSM PS algorithms (e.g. GEA 2 deployment)** | 219d | 2000-02-22 A | 2000-12-22 A | 100% | 2000-02-22 | 2000-12-22 | 219d |  | S3 | 6024h | 6024h | SEC1-PSALGO1 | Rel-4 | Dionisio |  |  |  |  |
| 2481 | 71.2.1 | Main aspects | 199d | 2000-02-22 A | 2000-11-24 A | 100% | 2000-02-22 | 2000-11-24 | 199d | finish no earlier than 2000-11-24 | S3 | 1592h | 1592h | SEC1-PSALGO1 | Rel-4 | Dionisio |  |  |  |  |
| 2482 | 71.2.2 | Impact on GTP | 200d | 2000-03-20 A | 2000-12-22 A | 100% | 2000-03-20 | 2000-12-22 | 200d | finish no earlier than 2000-12-22 | N4 | 1600h | 1600h | SEC1-PSALGO1 | Rel-4 | Kimmo |  |  |  |  |
| 2483 | 71.2.3 | GEA capability indication in MS CM | 135d | 2000-06-19 A | 2000-12-22 A | 100% | 2000-06-19 | 2000-12-22 | 135d | finish no earlier than 2000-12-22 | N1 | 1080h | 1080h | SEC1-PSALGO1-GEACAP | Rel-4 | Frederic |  | Vodafone Airtouch | Duncan Mills |  |
| 2484 | 71.3 | **Deleted - MAP application layer security** | 576d | 2000-01-03 A | 2002-03-15 A | 100% | 2000-01-03 | 2002-03-15 | 576d |  | S3 | 11352h | 11352h | SEC1-MAPAL | Rel-4 | Dionisio |  |  |  | SP-15 |
| 2485 | 71.3.1 | Deleted - Main aspects | 199d | 2000-02-21 A | 2001-03-29 A | 100% | 2000-02-21 | 2001-03-29 | 199d | start no earlier than 2000-02-21 | S3 | 1592h | 1592h |  | Rel-4 | Dionisio |  |  |  | SP-11 |
| 2486 | 71.3.2 | Deleted - Other stage 3 aspects | 199d | 2000-02-22 A | 2000-11-24 A | 100% | 2000-02-22 | 2000-11-24 | 199d | finish no earlier than 2000-11-24 | N4 | 1592h | 1592h |  | Rel-4 | Kimmo |  |  |  | CP-10 |
| 2487 | 71.3.3 | Deleted - Visibility and Configurability of security | 576d | 2000-01-03 A | 2002-03-15 A | 100% | 2000-01-03 | 2002-03-15 | 576d | finish no earlier than 2002-03-15 | S3 | 4600h | 4600h | SEC1-VCS | Rel-4 | Dionisio |  | France Telecom | Sebastien.nguyenngoc@rd.francetelecom.com | SP-15 |
| 2488 | 72 | **Rel-4 Charging and OAM&P** | 221d | 2000-12-01 A | 2001-10-05 A | 100% | 2000-12-01 | 2001-10-05 | 221d |  | S5 | 10472h | 10472h | OAM | Rel-4 | Dionisio |  | VoiceStream, Motorola |  |  |
| 2489 | 72.1 | Rel4 Principles, high level Requirements and Architecture | 145d | 2000-12-01 A | 2001-06-21 A | 100% | 2000-12-01 | 2001-06-21 | 145d | finish no earlier than 2001-06-21 | S5 | 1160h | 1160h | OAM-AR/PR | Rel-4 | Dionisio | 32.101, 32.102 | Motorola, Telia | Michael.Truss@motorola.com, Tommy.R.Berggren@TELIA.SE |  |
| 2490 | 72.2 | Rel4 Performance Management | 216d | 2000-12-01 A | 2001-09-28 A | 100% | 2000-12-01 | 2001-09-28 | 216d | finish no earlier than 2001-06-21 | S5 | 1728h | 1728h |  | Rel-4 | Dionisio | 32.4xy, 52.402 | T-Mobile | karl-heinz.nenner@t-mobile.de |  |
| 2491 | 72.3 | Fault Management | 221d | 2000-12-01 A | 2001-10-05 A | 100% | 2000-12-01 | 2001-10-05 | 221d | finish no earlier than 2001-06-21 | S5 | 1768h | 1768h |  | Rel-4 | Dionisio | 32.111-1/4 | Lucent |  |  |
| 2492 | 72.4 | Configuration Management | 145d | 2000-12-01 A | 2001-06-21 A | 100% | 2000-12-01 | 2001-06-21 | 145d | finish no earlier than 2001-06-21 | S5 | 1160h | 1160h | OAM-CM | Rel-4 | Dionisio | 32.106-1/8 | Ericsson | thomas.tovinger@ericsson.com |  |
| 2493 | 72.5 | Rel4 Charging Management | 216d | 2000-12-01 A | 2001-09-28 A | 100% | 2000-12-01 | 2001-09-28 | 216d | finish no earlier than 2001-06-21 | S5 | 1728h | 1728h | OAM-CH | Rel-4 | Dionisio | 32.200, 32.205, 32.215, 32.235 | T-Mobile | karl-heinz.nenner@t-mobile.de |  |
| 2494 | 72.6 | UTRAN Operations and Maintenance procedures | 145d | 2000-12-01 A | 2001-06-21 A | 100% | 2000-12-01 | 2001-06-21 | 145d | finish no earlier than 2001-06-21 | S5 | 1160h | 1160h | UOAM | Rel-4 | Dionisio | 32.800 | Mannesmann Mobilfunk | bert.boden@d2mannesmann.de |  |
| 2495 | 73 | **Global Text Telephony** | 2537d? | 2000-01-03 A | 2009-09-18 A | 100% | 2000-01-03 | 2009-09-18 | 2537d? |  | S1,S2,S4,T1,R5 | 44928h | 44928h | GTT | Rel-4 | Maurice |  | Ericsson | gunnar.hellstrom@omnitor.se |  |
| 2496 | 73.1 | Stage 1 | 188d | 2000-04-05 A | 2000-12-22 A | 100% | 2000-04-05 | 2000-12-22 | 188d | finish no earlier than 2000-12-22 | S1 | 1504h | 1504h | GTT | Rel-4 | Alain | 22.976, 22.226 |  |  |  |
| 2497 | 73.2 | Stage 2 | 206d | 2000-01-03 A | 2000-10-13 A | 100% | 2000-01-03 | 2000-10-13 | 206d |  | S2 | 1640h | 1640h | GTT | Rel-4 | Maurice | 23.226 |  |  |  |

Notes:
- 2474: -
- 2475: 28/5/2001: CRs approved at TP-11. WI complete.
- 2476: -
- 2477: 25/5/2001:CR was approved at TP-11. WI is complete
- 2478: Added BB UE authentication and rapporteur added. TO BE DELETED
- 2479: Approved SP#17
- 2480: A5/3 development will consider new GEA algorithm based on Kasumi
- 2481: Complete TSG#09 (09/2000). S3#17: Proposed for deletion. TO BE DELETED
- 2482: -
- 2483: -
- 2484: REPLACED BY NDS-MAP and NDS-IP. Completed Auto Key Management -> Rel-6. Marked as stopped 12/2008
- 2485: UID changed. Marked as stopped 12/2008
- 2486: UID changed. Marked as stopped 12/2008
- 2487: CR approved at SA3#21 awaiting comments from CN1. Marked as stopped 12/2008
- 2488: SP#13 approved WID
- 2489: -
- 2490: -
- 2491: -
- 2492: -
- 2493: -
- 2494: -
- 2495: SP#12 updated WID SP-000162=>SP-010340
- 2496: -
- 2497: -

| ID | WBS | Task | Duration | Start | Finish | Complete | Baseline start | Baseline finish | Baseline duration | Constraint | Resources | Work | Actual work | Text1 | Text6 | Text8 | Text9 | Text12 |
| --- | --- | --- | --- | --- | --- | --- | --- | --- | --- | --- | --- | --- | --- | --- | --- | --- | --- | --- |
| 2498 | 73.3 | **Specification of Cellular Text telephone Modem** | 136d | 2000-09-11 A | 2001-03-19 A | 100% | 2000-09-11 | 2001-03-19 | 136d |  | S4 | 2704h | 2704h | GTT-CTM | Rel-4 | Paolo |  |  |
| 2499 | 73.3.1 | General description and C-code | 66d | 2000-09-11 A | 2000-12-11 A | 100% | 2000-09-11 | 2000-12-11 | 66d | finish no earlier than 2000-12-11 | S4 | 528h | 528h | GTT-CTM | Rel-4 | Paolo |  |  |
| 2500 | 73.3.2 | Minimum Performance requirements | 136d | 2000-09-11 A | 2001-03-19 A | 100% | 2000-09-11 | 2001-03-19 | 136d | finish no earlier than 2001-03-19 | S4 | 1088h | 1088h | GTT-CTM | Rel-4 | Paolo |  |  |
| 2501 | 73.5 | Deleted - Conformance Test Aspects - Global Text Telephony | 2348d? | 2000-09-21 A | 2009-09-18 A | 100% | 2000-09-21 | 2009-09-18 | 2348d? | finish no earlier than 2009-09-18 | R5,T1 | 18784h | 18784h | GTT_Test | Rel-4 | Ingbert | PCG-23 | RP-45 |
| 2502 | 629 | Release 1999 Features | 261d? | 1999-01-01 A | 1999-12-31 A | 100% | 1999-01-01 | 1999-12-31 | 261d? |  | NP,SP,TP,SMG | 2088h | 2088h |  | R99 | All |  |  |
| 2503 | 630 | **UMTS Features** | 261d? | 1999-01-01 A | 1999-12-31 A | 100% | 1999-01-01 | 1999-12-31 | 261d? |  | S1,S2,S4,SMG,N3,N4,RP | 25056h | 25056h |  | R99 | Alain |  |  |
| 2504 | 630.1 | UMTS_SERVICES | 261d? | 1999-01-01 A | 1999-12-31 A | 100% | 1999-01-01 | 1999-12-31 | 261d? | start no earlier than 1999-01-01 | S1 | 2088h | 2088h | UMTS_SERVICES | R99 | Alain |  |  |
| 2505 | 630.2 | UMTS phase 1 | 261d? | 1999-01-01 A | 1999-12-31 A | 100% | 1999-01-01 | 1999-12-31 | 261d? | start no earlier than 1999-01-01 | S1 | 2088h | 2088h | UMTS1 | R99 | Alain |  |  |
| 2506 | 630.3 | UMTS Capabilities | 261d? | 1999-01-01 A | 1999-12-31 A | 100% | 1999-01-01 | 1999-12-31 | 261d? | start no earlier than 1999-01-01 | S1 | 2088h | 2088h | UMTS_Capabil | R99 | Alain |  |  |
| 2507 | 630.4 | Architecture of the GSM-UMTS platform | 261d? | 1999-01-01 A | 1999-12-31 A | 100% | 1999-01-01 | 1999-12-31 | 261d? | start no earlier than 1999-01-01 | S2,N4 | 2088h | 2088h |  | R99 | Maurice |  |  |
| 2508 | 630.5 | UMTS Terrestrial Radio Access Network | 261d? | 1999-01-01 A | 1999-12-31 A | 100% | 1999-01-01 | 1999-12-31 | 261d? | start no earlier than 1999-01-01 | RP | 2088h | 2088h | UTRAN | R99 | Joern |  |  |
| 2509 | 630.6 | UMTS 1800, UMTS 1900 | 261d? | 1999-01-01 A | 1999-12-31 A | 100% | 1999-01-01 | 1999-12-31 | 261d? | start no earlier than 1999-01-01 | R2 | 2088h | 2088h | Rlnlmp19, Rlnlmp18 | R99 | Joern |  |  |
| 2510 | 630.7 | Mandatory speech codec for narrowband telephony service | 261d? | 1999-01-01 A | 1999-12-31 A | 100% | 1999-01-01 | 1999-12-31 | 261d? | start no earlier than 1999-01-01 | S4 | 2088h | 2088h | Mandatory_Speech_Codec, AMR-NB, AMR | R99 | Paolo |  |  |
| 2511 | 630.8 | Codec for low bitrate multimedia telephony service | 261d? | 1999-01-01 A | 1999-12-31 A | 100% | 1999-01-01 | 1999-12-31 | 261d? | start no earlier than 1999-01-01 | S4 | 2088h | 2088h | Low_bit_rate_codec_for_MM_Tel., H.324M | R99 | Paolo |  |  |
| 2512 | 630.9 | 3G Audio-Visual Terminal characteristics | 261d? | 1999-01-01 A | 1999-12-31 A | 100% | 1999-01-01 | 1999-12-31 | 261d? | start no earlier than 1999-01-01 | S4 | 2088h | 2088h | WI5TAC, 3G-AVT, Terminal_Acoustic_Characteristics | R99 | Paolo |  |  |
| 2513 | 630.10 | Updates_for_UMTS | 261d? | 1999-01-01 A | 1999-12-31 A | 100% | 1999-01-01 | 1999-12-31 | 261d? | start no earlier than 1999-01-01 | N3 | 2088h | 2088h | Updates_for_UMTS | R99 | Gwiho |  |  |
| 2514 | 630.11 | UMTS | 261d? | 1999-01-01 A | 1999-12-31 A | 100% | 1999-01-01 | 1999-12-31 | 261d? | start no earlier than 1999-01-01 | N3 | 2088h | 2088h | UMTS | R99 | Gwiho |  |  |
| 2515 | 631 | **UMTS and GSM Features** | 261d? | 1999-01-01 A | 1999-12-31 A | 100% | 1999-01-01 | 1999-12-31 | 261d? |  | S1,S2,SMG,T2,N1,N2,N3,N4,R2,R3 | 114840h | 114840h |  | R99 | Alain |  |  |
| 2516 | 631.1 | Multimedia Messaging Service | 261d? | 1999-01-01 A | 1999-12-31 A | 100% | 1999-01-01 | 1999-12-31 | 261d? | start no earlier than 1999-01-01 | T2 | 2088h | 2088h | MMS | R99 |  |  |  |
| 2517 | 631.2 | Location Services | 261d? | 1999-01-01 A | 1999-12-31 A | 100% | 1999-01-01 | 1999-12-31 | 261d? | start no earlier than 1999-01-01 | S1,S2,S3,SMG1,SMG2,SMG12,N1,N2,N4,R2,R3 | 2088h | 2088h | LCS | R99 | Alain |  |  |
| 2518 | 631.3 | **Customised Application for Mobile network Enhanced Logic Phase 3** | 261d? | 1999-01-01 A | 1999-12-31 A | 100% | 1999-01-01 | 1999-12-31 | 261d? |  | S1,S2,N2,N4 | 6264h | 6264h | CAMEL3 | R99 | Alain |  |  |
| 2519 | 631.3.1 | Global view | 261d? | 1999-01-01 A | 1999-12-31 A | 100% | 1999-01-01 | 1999-12-31 | 261d? | start no earlier than 1999-01-01 | S1,S2,N2,N4 | 2088h | 2088h | CAMEL3 | R99 | Alain |  |  |
| 2520 | 631.3.2 | Multiple Subscriber Profile (MSP) based on CAMEL phase 3 | 261d? | 1999-01-01 A | 1999-12-31 A | 100% | 1999-01-01 | 1999-12-31 | 261d? | start no earlier than 1999-01-01 | S1 | 2088h | 2088h | CAMEL3 | R99 | Alain |  |  |
| 2521 | 631.4 | Short Message Service enhancements / Enhanced Messaging Service (EMS) | 261d? | 1999-01-01 A | 1999-12-31 A | 100% | 1999-01-01 | 1999-12-31 | 261d? | start no earlier than 1999-01-01 | T2 | 2088h | 2088h | EMS | R99 |  |  |  |
| 2522 | 631.5 | Mobile Station Execution Environment | 261d? | 1999-01-01 A | 1999-12-31 A | 100% | 1999-01-01 | 1999-12-31 | 261d? | start no earlier than 1999-01-01 | S1,SMG1,T2 | 2088h | 2088h | MExE | R99 | Alain |  |  |
| 2523 | 631.6 | MS_Classmark | 261d? | 1999-01-01 A | 1999-12-31 A | 100% | 1999-01-01 | 1999-12-31 | 261d? | start no earlier than 1999-01-01 | N1 | 2088h | 2088h | MS_Classmark | R99 | Frederic |  |  |

Notes:
- 2498: -
- 2499: - / Text3: 26.226, 26.230
- 2500: - / Text3: 26.231
- 2501: RP#45 work item abandoned/closed (it was never really started)
- 2502: -
- 2503: -
- 2504: - / Text3: 22.101
- 2505: - / Text3: 22.100
- 2506: Requirement for high quality speech in UMTS Phase 1 but not in R99 / Text3: 22.105
- 2507: wid Architecture overview of the GSM-UMTS System, Architecture the GSM-UMTS Platform and New Access Network to Core Network (BSS-NSS) interface / Text3: 23.002, 23.008, 23.060, 23.101, 23.110
- 2508: - / Text3: 22.011, 22.038, 22.060, 22.078, 22.100, 22.101, 22.105, 22.115, 22.129, 23.002, 23.060, 24.007, 24.008, 25.101, 25.102, 25.104, 25.105, 25.113, 25.123, 25.133, 25.141, 25.142, 25.201, 25.211, 25.212, 25.213, 25.214, 25.215, 25.221, 25.222, 25.223, 25.224,
- 2509: - / Text3: 25.307 CR#0002, 0003 Inclusion of release independent RF related information
- 2510: Define the default speech codec for UMTS (both for FDD and TDD). Definition limited to selection of one codec among several existing ones/proposed codecs: GSM AMR, IS127 EVRC, ITU G.729 and MPEG-4 speech codec. / Text3: 04.08, 05.01, 05.02, 05.03, 05.05, 05.08, 05.09, 05.09, 05.50, 08.60, 08.61, 11.21, 26.071, 26.073, 26.074, 26.090, 26.091, 26.092, 26.093, 26.094, 26.101, 26.102, 26.103, 26.104, 26.975
- 2511: - / Text3: 26.104, 26.110, 26.111, 26.911, 26.912, 26.915
- 2512: - / Text3: 26.131, 26.132
- 2513: - / Text3: 24.022, 27.001, 29.007
- 2514: - / Text3: 27.060, 29.061
- 2515: -
- 2516: MMS allows users to send/receive messages e.g. almost unlimited text length, images, audio and video clips and new content types. R99 only includes the concept. MMS stage 3 is not included in 23.140. Rel-4 adds detailed architecture and protocols. / Text3: 22.140, 23.040, 23.140
- 2517: LCS provide ability to localize a terminal. Location data is used to provide services to end-user (e.g. local map indicating closest restaurants), for emergency services or for a UMTS network entity (RNC to direct beam when space diversity is used) / Text3: 02.07, 03.71, 04.31, 04.35, 04.71, 05.05, 08.08, 08.31, 08.71, 09.31, 22.071, 23.002, 23.003, 23.007, 23.008, 23.016, 23.018, 23.032, 23.171, 24.007, 24.008, 24.030, 24.080, 25.305, 25.306, 25.331, 25.413, 25.423, 29.002, 29.010
- 2518: CAMEL is a network feature providing mechanisms to support services of operators which are not covered by standardised services, even when roaming outside the HPLMN. / Text3: 22.101, 23.008, 23.012, 23.016, 23.018, 23.060, 23.072, 23.078, 23.079, 23.082, 23.093, 29.002, 29.078
- 2519: - / Text3: 22.078, 23.078, 29.078
- 2520: MSP is an optional service enabling mobile subscribers to have several profiles associated with a single IMSI, with each profile being a subscription option. Each profile may be used for mobile originated and mobile terminated calls. / Text3: 22.097 (Advanced Addressing)
- 2521: SMS for 3G terminals compatible with GSM SMS. Added Enhanced Messaging Service (EMS) allowing small pictures, sounds, animations to be transferred via SMS. / Text3: 23.038, 23.039, 23.040, 23.042
- 2522: MExE provides a standardized MS execution environment and ability to negotiate its supported capabilities with a MExE SP. R99 enhances SIM MExE certificate management, security clarifications, QoS and defines two MExE classmarks WAP/Personal-Java based. / Text3: 02.57, 22.057, 22.101, 23.057
- 2523: MExE classmark identifies a category of MExE UE supporting MExE functionality with a minimum level of processing, memory, display, and interactive capabilities. Several MExE classmarks may be defined. / Text3: 24.008

| ID | WBS | Task | Duration | Start | Finish | Complete | Baseline start | Baseline finish | Baseline duration | Constraint | Resources | Work | Actual work | Text1 | Text6 | Text8 | Text12 |
| --- | --- | --- | --- | --- | --- | --- | --- | --- | --- | --- | --- | --- | --- | --- | --- | --- | --- |
| 2524 | 631.7 | **MultiCall** | 261d? | 1999-01-01 A | 1999-12-31 A | 100% | 1999-01-01 | 1999-12-31 | 261d? |  | S1,N1,N2,N4 | 4176h | 4176h | Multicall | R99 | Alain |  |
| 2525 | 631.7.1 | Multicall | 261d? | 1999-01-01 A | 1999-12-31 A | 100% | 1999-01-01 | 1999-12-31 | 261d? | start no earlier than 1999-01-01 | S1 | 2088h | 2088h | Multicall | R99 | Alain |  |
| 2526 | 631.8 | Virtual Home Environment | 261d? | 1999-01-01 A | 1999-12-31 A | 100% | 1999-01-01 | 1999-12-31 | 261d? | start no earlier than 1999-01-01 | S1,SMG1,S2 | 2088h | 2088h | VHE | R99 | Alain |  |
| 2527 | 631.9 | Open Service Access | 261d? | 1999-01-01 A | 1999-12-31 A | 100% | 1999-01-01 | 1999-12-31 | 261d? | start no earlier than 1999-01-01 | S1,S2,N5 | 2088h | 2088h | OSA | R99 | Alain |  |
| 2528 | 631.10 | Super Charger mechanism for signalling traffic associated with mobility | 261d? | 1999-01-01 A | 1999-12-31 A | 100% | 1999-01-01 | 1999-12-31 | 261d? | start no earlier than 1999-01-01 | N2,N4 | 2088h | 2088h | Super_Charger | R99 | Kimmo |  |
| 2529 | 631.11 | Follow_Me service | 261d? | 1999-01-01 A | 1999-12-31 A | 100% | 1999-01-01 | 1999-12-31 | 261d? | start no earlier than 1999-01-01 | S1,N2,N4 | 2088h | 2088h | Follow_Me | R99 | Alain |  |
| 2530 | 631.12 | Wide area network Synchronization and object exchange | 261d? | 1999-01-01 A | 1999-12-31 A | 100% | 1999-01-01 | 1999-12-31 | 261d? | start no earlier than 1999-01-01 | T2 | 2088h | 2088h | SYNC | R99 |  |  |
| 2531 | 631.13 | **Terminal Interfaces** | 261d? | 1999-01-01 A | 1999-12-31 A | 100% | 1999-01-01 | 1999-12-31 | 261d? |  | T2 | 8352h | 8352h |  | R99 |  |  |
| 2532 | 631.13.1 | AT commands for 3GPP | 261d? | 1999-01-01 A | 1999-12-31 A | 100% | 1999-01-01 | 1999-12-31 | 261d? | start no earlier than 1999-01-01 | T2 | 2088h | 2088h |  | R99 |  |  |
| 2533 | 631.13.2 | Physical interfaces | 261d? | 1999-01-01 A | 1999-12-31 A | 100% | 1999-01-01 | 1999-12-31 | 261d? | start no earlier than 1999-01-01 | T2 | 2088h | 2088h |  | R99 |  |  |
| 2534 | 631.13.3 | Multiplexer | 261d? | 1999-01-01 A | 1999-12-31 A | 100% | 1999-01-01 | 1999-12-31 | 261d? | start no earlier than 1999-01-01 | T2 | 2088h | 2088h | MUX MS-TE | R99 |  |  |
| 2535 | 631.14 | **Bearer Services** | 261d? | 1999-01-01 A | 1999-12-31 A | 100% | 1999-01-01 | 1999-12-31 | 261d? |  | S1,T2,N1,N3 | 27144h | 27144h |  | R99 | Alain |  |
| 2536 | 631.14.1 | **Circuit Switched Bearer Services** | 261d? | 1999-01-01 A | 1999-12-31 A | 100% | 1999-01-01 | 1999-12-31 | 261d? |  | S1,N3 | 14616h | 14616h | Circuit_switched_Bearer_Services | R99 | Alain |  |
| 2537 | 631.14.1.1 | Circuit Switched Bearer Services | 261d? | 1999-01-01 A | 1999-12-31 A | 100% | 1999-01-01 | 1999-12-31 | 261d? | start no earlier than 1999-01-01 | S1,N3 | 2088h | 2088h | CS_Bearerss_in_UMTS | R99 | Alain |  |
| 2538 | 631.14.1.2 | CS_Bearers | 261d? | 1999-01-01 A | 1999-12-31 A | 100% | 1999-01-01 | 1999-12-31 | 261d? | start no earlier than 1999-01-01 | N3 | 2088h | 2088h | CS_Bearers | R99 | Gwiho |  |
| 2539 | 631.14.1.3 | CS_Bearerss | 261d? | 1999-01-01 A | 1999-12-31 A | 100% | 1999-01-01 | 1999-12-31 | 261d? | start no earlier than 1999-01-01 | N3 | 2088h | 2088h | CS_Bearerss | R99 | Gwiho |  |
| 2540 | 631.14.1.4 | CS_Data | 261d? | 1999-01-01 A | 1999-12-31 A | 100% | 1999-01-01 | 1999-12-31 | 261d? | start no earlier than 1999-01-01 | N3 | 2088h | 2088h | CS_Data | R99 | Gwiho |  |
| 2541 | 631.14.1.5 | CS_Data_Bearers | 261d? | 1999-01-01 A | 1999-12-31 A | 100% | 1999-01-01 | 1999-12-31 | 261d? | start no earlier than 1999-01-01 | N3 | 2088h | 2088h | CS_Data_Bearers | R99 | Gwiho |  |
| 2542 | 631.14.1.6 | Deleted - Circuit Switched Bearer Services | 261d? | 1999-01-01 A | 1999-12-31 A | 100% | 1999-01-01 | 1999-12-31 | 261d? | start no earlier than 1999-01-01 | N3 | 2088h | 2088h | CSBS | R99 | Gwiho | NP-06 |
| 2543 | 631.14.2 | Frame Tunnelling Mode | 261d? | 1999-01-01 A | 1999-12-31 A | 100% | 1999-01-01 | 1999-12-31 | 261d? | start no earlier than 1999-01-01 | T2,N1,N3 | 2088h | 2088h | FTM | R99 | Gwiho |  |
| 2544 | 631.14.3 | Access to ISPs and Intranets – Wireless/Remote access to LANs | 261d? | 1999-01-01 A | 1999-12-31 A | 100% | 1999-01-01 | 1999-12-31 | 261d? | start no earlier than 1999-01-01 | N3 | 2088h | 2088h | Interworking with PDN (DHCP) | R99 | Gwiho |  |
| 2545 | 631.14.4 | **PHS Internet Access Forum Specification** | 261d? | 1999-01-01 A | 1999-12-31 A | 100% | 1999-01-01 | 1999-12-31 | 261d? |  | S1,N3 | 6264h | 6264h | PIAFS | R99 | Alain |  |
| 2546 | 631.14.4.1 | Personal Handyphone System Internet Access Forum Standard (PIAFS) | 261d? | 1999-01-01 A | 1999-12-31 A | 100% | 1999-01-01 | 1999-12-31 | 261d? | start no earlier than 1999-01-01 | S1 | 2088h | 2088h | PIAFS | R99 | Alain |  |
| 2547 | 631.14.4.2 | Support_of_PIAFS_in_UMTS | 261d? | 1999-01-01 A | 1999-12-31 A | 100% | 1999-01-01 | 1999-12-31 | 261d? | start no earlier than 1999-01-01 | N3 | 2088h | 2088h | Support_of_PIAFS_in_UMTS | R99 | Gwiho |  |

Notes:
- 2524: Multicall allows several simultaneous CS calls with dedicated bearers of independent traffic and performance characteristics. R99 Multicall was defined as a supplementary service limited to one CS bearer to be used for speech at any time. / Text3: 22.030, 22.083, 22.087, 23.008, 23.009, 23.016, 23.018, 23.108, 23.135, 24.008, 24.080, 24.135, 29.002, 29.010
- 2525: - / Text3: 22.030, 22.083, 22.087
- 2526: Information exists in SP#5-8 reports & in SP-99416,SP-000095,SP 000155. OSA allows service development by operators and 3rd parties by making use of network functionality through open, standardised, secure, extensible and scalable interfaces. / Text3: 02.01, 22.105, 22.121,23.127
- 2527: Open Service Architecture became in later Releases Open Service Access. Produced by Parlay, ETSI SPAN (TISPAN), 3GPP SA1 (Stage 1), SA2 (Stage 2) and CN5 (Stage 3), resulting in a single set of standard OSA APIs for the whole development community. / Text3: 22.121, 23.127, 29.198, 29.998
- 2528: Super Charger reduces mobility management cost by reducing the volume of location update signalling. It changes subscriber data management associated with inter-VLR and SGSN location updates. It also applies to packet services (SGSN replaces VLR and … / Text3: 21.905, 23.007, 23.008, 23.012, 23.016, 23.018, 23.040, 23.060, 23.116, 23.912, 29.002
- 2529: Follow Me enables a mobile subscriber A to manipulate the Follow Me data of a party B in such a way that - under certain conditions - subsequent calls directed to party B will be forwarded to subscriber A. It is PLMN-specific and control based on USSD / Text3: 21.905, 22.004, 22.030, 22.082, 22.090, 22.094, 23.090, 24.090, 22.094, 23.011, 23.015, 23.082, 29.002
- 2530: Allows data stored in ME/USIM to be synchronized with the outside world. TS 27.103 defines protocols based upon IrMC level 4 and will evaluate new technologies (XML) for inclusion. From Rel-4 IrMC was replaced by SyncML in 27.103. / Text3: 27.103, 27.903
- 2531: -
- 2532: AT commands to control a 3G ME via an external Terminal Equipment (TE), fully compatible with GSM AT commands. R99 adds new AT commands e.g. to control Advanced Speech Call Items (ASCI) services. / Text3: 27.005, 27.007
- 2533: Conclusion: 3GPP should not produce any technical specification for terminal interfaces other than radio interface and USIM interface. SDOs could develop own optional physical connector specification based on market requirements / Text3: 27.901
- 2534: Multiplexing protocol allowing a number of simultaneous sessions between a MS and a terminal; used to send any data (voice, SMS, USSD, fax etc.). 27.010 describes the protocol, but not the commands or data transported with it. / Text3: 27.010
- 2535: -
- 2536: CS and real-time data services provided for interworking with PSTN/ISDN so that user is unaware of access network used (UMTS, GSM or handover between ANs). Transparent(constant delay) & non-transparent(zero error with flow control) services are supported / Text3: 22.002, 23.910, 27.001, 29.007
- 2537: CS and real-time data services provided for interworking with PSTN/ISDN so that user is unaware of access network used (UMTS, GSM or handover between ANs). Transparent(constant delay) & non-transparent(zero error with flow control) services are supported / Text3: 22.002, 23.910, 27.001, 29.007
- 2538: - / Text3: 29.007
- 2539: - / Text3: 04.21, 23.910, 27.001, 29.007
- 2540: - / Text3: 27.001, 27.002, 27.003, 29.007
- 2541: - / Text3: 23.910, 27.001, 29.007
- 2542: No CR or new TS/TR approved under this WI / Text3: 29.007
- 2543: FTM is a type of async non-transparent CS bearer service (22.002). Generic term for HDLC and HDLC-related transmission protocols. Converts async non-transp data stream towards mobile side & sync data stream using X.31 flag stuffing on fixed network side. / Text3: 22.002, 27.001, 27.007, 29.007
- 2544: Access to an Intranet or ISP by running DHCP between the TE and a server in the Intranet/ISP domain. / Text3: 29.061
- 2545: PIAFS is one type of CS bearer data service (22.002). It refers to async CS tx protocol over ISDN 64 kbit/s unrestricted digital line. Facilitates interworking between PHS-MS and UMTS-UE & UMTS-UE and existing PIAFS TA (Terminal Adapter). / Text3: 22.002, 27.001, 27.007, 29.007
- 2546: PIAFS was originally standardised by the PHS Internet Access Forum in Japan. More information can be found at: http://www.infopro.or.jp/piaf / Text3: 22.002
- 2547: - / Text3: 27.001, 27.007, 29.007

| ID | WBS | Task | Duration | Start | Finish | Complete | Baseline start | Baseline finish | Baseline duration | Constraint | Resources | Work | Actual work | Text1 | Text6 | Text8 | Text12 |
| --- | --- | --- | --- | --- | --- | --- | --- | --- | --- | --- | --- | --- | --- | --- | --- | --- | --- |
| 2548 | 631.15 | **Universal Integrated Circuit Card (UICC) and Universal Subscriber Identity Module (USIM)** | 261d? | 1999-01-01 A | 1999-12-31 A | 100% | 1999-01-01 | 1999-12-31 | 261d? |  | T3 | 27144h | 27144h | UICC, USIM | R99 | Xavier |  |
| 2549 | 631.15.1 | UICC / Terminal interface; Physical and logical characteristics | 261d? | 1999-01-01 A | 1999-12-31 A | 100% | 1999-01-01 | 1999-12-31 | 261d? | start no earlier than 1999-01-01 | T3 | 2088h | 2088h | UICC | R99 | Xavier |  |
| 2550 | 631.15.2 | UICC/(U)SIM enhancements and interworking | 261d? | 1999-01-01 A | 1999-12-31 A | 100% | 1999-01-01 | 1999-12-31 | 261d? | start no earlier than 1999-01-01 | T3 | 2088h | 2088h | UICC1 | R99 | Xavier |  |
| 2551 | 631.15.3 | Characteristics of the USIM application | 261d? | 1999-01-01 A | 1999-12-31 A | 100% | 1999-01-01 | 1999-12-31 | 261d? | start no earlier than 1999-01-01 | T3 | 2088h | 2088h | USIM | R99 | Xavier |  |
| 2552 | 631.15.4 | UICC Application Identifiers | 261d? | 1999-01-01 A | 1999-12-31 A | 100% | 1999-01-01 | 1999-12-31 | 261d? | start no earlier than 1999-01-01 | T3 | 2088h | 2088h | AID, Application_Identifiers | R99 | Xavier |  |
| 2553 | 631.15.5 | SIM Application Toolkit | 261d? | 1999-01-01 A | 1999-12-31 A | 100% | 1999-01-01 | 1999-12-31 | 261d? | start no earlier than 1999-01-01 | S1,T3 | 2088h | 2088h | SAT | R99 | Alain |  |
| 2554 | 631.15.6 | USIM Application Toolkit | 261d? | 1999-01-01 A | 1999-12-31 A | 100% | 1999-01-01 | 1999-12-31 | 261d? | start no earlier than 1999-01-01 | T3 | 2088h | 2088h | USAT | R99 | Xavier |  |
| 2555 | 631.15.7 | Bearer Independent Protocol for SAT applications to exchange data over the GSM network | 261d? | 1999-01-01 A | 1999-12-31 A | 100% | 1999-01-01 | 1999-12-31 | 261d? | start no earlier than 1999-01-01 | T3 | 2088h | 2088h | BIP | R99 | Xavier |  |
| 2556 | 631.15.8 | Administrative commands and functions for IC cards | 261d? | 1999-01-01 A | 1999-12-31 A | 100% | 1999-01-01 | 1999-12-31 | 261d? | start no earlier than 1999-01-01 | T3 | 2088h | 2088h |  | R99 | Xavier |  |
| 2557 | 631.15.9 | USIM and UICC requirements | 261d? | 1999-01-01 A | 1999-12-31 A | 100% | 1999-01-01 | 1999-12-31 | 261d? | start no earlier than 1999-01-01 | T3 | 2088h | 2088h |  | R99 | Xavier |  |
| 2558 | 631.15.10 | SIM_API | 261d? | 1999-01-01 A | 1999-12-31 A | 100% | 1999-01-01 | 1999-12-31 | 261d? | start no earlier than 1999-01-01 | T3 | 2088h | 2088h | SIM_API | R99 | Xavier |  |
| 2559 | 631.15.11 | SIM_toolkit_API | 261d? | 1999-01-01 A | 1999-12-31 A | 100% | 1999-01-01 | 1999-12-31 | 261d? | start no earlier than 1999-01-01 | SMG9,T3 | 2088h | 2088h | SIM_toolkit | R99 | Xavier |  |
| 2560 | 631.15.12 | Deleted - 1.8 Volt SIM ME interface | 261d? | 1999-01-01 A | 1999-12-31 A | 100% | 1999-01-01 | 1999-12-31 | 261d? | start no earlier than 1999-01-01 | SMG9 | 2088h | 2088h | SMIME_1.8V | R99 | Xavier | TP-06 |
| 2561 | 631.16 | **USIM/UICC Testing** | 261d? | 1999-01-01 A | 1999-12-31 A | 100% | 1999-01-01 | 1999-12-31 | 261d? |  | T3 | 10440h | 10440h |  | R99 | Xavier |  |
| 2562 | 631.16.1 | Terminal tests for the UICC Interface | 261d? | 1999-01-01 A | 1999-12-31 A | 100% | 1999-01-01 | 1999-12-31 | 261d? | start no earlier than 1999-01-01 | T3 | 2088h | 2088h |  | R99 | Xavier |  |
| 2563 | 631.16.2 | USIM application test specification | 261d? | 1999-01-01 A | 1999-12-31 A | 100% | 1999-01-01 | 1999-12-31 | 261d? | start no earlier than 1999-01-01 | T3 | 2088h | 2088h |  | R99 | Xavier |  |
| 2564 | 631.16.3 | USIM conformance test specification | 261d? | 1999-01-01 A | 1999-12-31 A | 100% | 1999-01-01 | 1999-12-31 | 261d? | start no earlier than 1999-01-01 | T3 | 2088h | 2088h |  | R99 | Xavier |  |
| 2565 | 631.16.4 | SIM toolkit test specification | 261d? | 1999-01-01 A | 1999-12-31 A | 100% | 1999-01-01 | 1999-12-31 | 261d? | start no earlier than 1999-01-01 | T3 | 2088h | 2088h |  | R99 | Xavier |  |
| 2566 | 631.17 | **Security** | 261d? | 1999-01-01 A | 1999-12-31 A | 100% | 1999-01-01 | 1999-12-31 | 261d? |  | S3,N2,N4 | 8352h | 8352h | Security | R99 | Dionisio |  |
| 2567 | 631.17.1 | Fraud Information Gathering Service (for connection-orientated services) | 261d? | 1999-01-01 A | 1999-12-31 A | 100% | 1999-01-01 | 1999-12-31 | 261d? | start no earlier than 1999-01-01 | S3 | 2088h | 2088h | FIGS | R99 | Dionisio |  |
| 2568 | 631.17.2 | Immediate Service Termination / SECurity Immediate Service Termination | 261d? | 1999-01-01 A | 1999-12-31 A | 100% | 1999-01-01 | 1999-12-31 | 261d? | start no earlier than 1999-01-01 | S3,N2,N4 | 2088h | 2088h | IST, SECIST | R99 | Dionisio |  |
| 2569 | 631.17.3 | Core_Network_Security | 261d? | 1999-01-01 A | 1999-12-31 A | 100% | 1999-01-01 | 1999-12-31 | 261d? | start no earlier than 1999-01-01 | N4 | 2088h | 2088h | Core_Network_Security | R99 | Kimmo |  |
| 2570 | 632 | **GSM Features** | 261d? | 1999-01-01 A | 1999-12-31 A | 100% | 1999-01-01 | 1999-12-31 | 261d? |  | S1,S2,SMG,T2,N1,N2,N3,N4 | 50112h | 50112h |  | R99 | Alain |  |
| 2571 | 632.1 | **Dual Transfer Mode within GSM and GPRS** | 261d? | 1999-01-01 A | 1999-12-31 A | 100% | 1999-01-01 | 1999-12-31 | 261d? |  | SMG,N1 | 6264h | 6264h | DTM | R99 | Frederic |  |
| 2572 | 632.1.1 | Class A Dual Transfer Mode | 261d? | 1999-01-01 A | 1999-12-31 A | 100% | 1999-01-01 | 1999-12-31 | 261d? | start no earlier than 1999-01-01 | SMG | 2088h | 2088h | Class_A_Dual_Transfer_Mode_(DTM) | R99 | Frederic |  |
| 2573 | 632.1.2 | Dual Transfer Mode | 261d? | 1999-01-01 A | 1999-12-31 A | 100% | 1999-01-01 | 1999-12-31 | 261d? | start no earlier than 1999-01-01 | SMG,N1 | 2088h | 2088h | DTM | R99 | Frederic |  |

Notes:
- 2548: For 3G, GSM 11.11 was divided into two parts: a platform comprised of basic physical, electrical and logical specification (31.101) and an application specification (31.102)
- 2549: Defines a generic Terminal/Integrated Circuit Card (ICC) interface. Is independent of 3G USIM application => platform for any IC card application. Ensures interoperability between ICC and terminal independently of manufacturer, card issuer or operator. / Text3: 31.101 (Since 10/2000, ETSI EP SCP is responsible for the generic Terminal/Integrated Circuit Card (ICC) interface TS 102 221)
- 2550: - / Text3: 31.102, 31.900
- 2551: Defines Universal Subscriber Identity Module (USIM) application for 3G telecom network operation & resides on UICC, an IC card specified in 31.101. UICC can be used as a multi-application card: several USIMs and/or other applications can co-exist / Text3: 31.102
- 2552: Defines and administers Application IDentifiers (AID) for UICC. AID is used to address an application in the card. Consists of Registered application provider ID (RID) & Proprietary application ID exception (PIX - according to ISO/IEC 7816-5). / Text3: 21.111, 31.110
- 2553: - / Text3: 11.14, 22.030, 22.100, 22.101
- 2554: Defines UICC - ME interface, and mandatory ME procedures for USAT. Based on GSM 11.14 (SIM Application Toolkit). Commands and procedures defined in USIM and 3G Terminal for using USAT. Service and security requirements defined in 22.100 and 22.101. / Text3: 31.111
- 2555: Defines at SIM-ME interface a basic protocol allowing SIM Toolkit applications to determine available bearers and to exchange data by selecting using the most appropriate bearer available (CS data, GPRS, SMS, Unstructured Supplementary Service Data (USSD) / Text3: 03.48, 11.10, 11.14
- 2556: Defines function and syntax of administrative commands for telecommunication IC Card used during installation, activation and de-activation of applications. Compliant to ISO/IEC 7816 series. Handed over to ETSI Project Smart Card Platform (SCP) in 2000. / Text3: ETSI TS 102 222
- 2557: High level requirements for 3GPP IC card and its interface to 3GPP terminal (USIM&UICC reqs). Service&security reqs in 322.01,22.00. USIM is a 3GPP application on an IC card. Inter-operates with 3GPP terminals and provides access to 3GPP services / Text3: 21.111
- 2558: - / Text3: 03.19
- 2559: - / Text3: 03.48, 11.11, 11.14
- 2560: No CR or new TS/TR approved under this WI / Text3: 11.18
- 2561: -
- 2562: Test spec for the interface between UICC and terminal (originally based GSM 11.10-1 clause 27). Ensures UICC - terminal interoperability independently of manufacturer, card issuer or operator. Tests for applications residing on UICC are in 31.121 / Text3: 31.120
- 2563: Application test spec originally based on GSM 11.17. Aspects related to UICC administrative management phase are not defined. Any internal technical realisation of either UICC or terminal is only specified where these are reflected over the interface. / Text3: 31.121
- 2564: Conformance Test specification for UICC defined in 31.101 with USIM defined in 31.102. / Text3: 31.122
- 2565: SIM Application Toolkit (SAT) has major impact on ME design and enhances SIM/ME interface. Contains tests for SIM/ME interface optional features (no network related signalling issues involved). Doesn't form basis for any type approval or regulatory tests. / Text3: 11.10-4
- 2566: - / Text3: 02.09, 03.20, 21.133, 22.022, 23.003, 23.007, 23.008, 23.012, 23.018, 24.007, 24.008, 24.010, 24.011, 29.002, 29.060, 33.102, 33.103, 33.105, 33.107, 35.201
- 2567: HPLMN can monitor its subscribers in VPLMN, which collects info on a defined set of monitored subscribers activities & sends it to HPLMN, which can perform service limitation control eg Operator Determined Barring (ODB) and IST to limit financial exposure / Text3: 22.031, 23.031
- 2568: HPLMN can terminate all activities of its subscriber in VPLMN, if decides (based on info via eg FIGS) that a roaming subscriber is behaving in fraudulent/suspicious way. HPLMN can terminate all subscriber activities including calls in progress. / Text3: 03.35, 22.032, 23.008, 23.016, 23.035, 29.002
- 2569: - / Text3: 29.002
- 2570: -
- 2571: WID on BSS co-ordination of Radio Resource allocation for class A GPRS services - GSM Radio Access (R99) / Text3: 03.55, 03.64, 04.18, 04.60, 05.01, 05.02, 05.08, 08.08, 23.060, 24.007, 24.008
- 2572: - / Text3: 05.10
- 2573: - / Text3: 03.55, 03.64, 04.18, 05.01, 05.02, 05.08, 24.008

| ID | WBS | Task | Duration | Start | Finish | Complete | Baseline start | Baseline finish | Baseline duration | Constraint | Resources | Work | Actual work | Text1 | Text6 | Text12 | Text4 | Text5 |
| --- | --- | --- | --- | --- | --- | --- | --- | --- | --- | --- | --- | --- | --- | --- | --- | --- | --- | --- |
| 2574 | 632.2 | **General Packet Radio Service enahancements** | 261d? | 1999-01-01 A | 1999-12-31 A | 100% | 1999-01-01 | 1999-12-31 | 261d? |  | S1,S2,SMG1,SMG2,SMG7,N1,N2,N3,N4,T2 | 8352h | 8352h | GPRS enhancements | R99 |  |  |  |
| 2575 | 632.2.1 | General Packet Radio Service | 261d? | 1999-01-01 A | 1999-12-31 A | 100% | 1999-01-01 | 1999-12-31 | 261d? | start no earlier than 1999-01-01 | S1,S2,SMG1,SMG2,SMG7,N1,N2,N3,N4,T2 | 2088h | 2088h | GPRS | R99 |  |  |  |
| 2576 | 632.2.2 | GPRS2 | 261d? | 1999-01-01 A | 1999-12-31 A | 100% | 1999-01-01 | 1999-12-31 | 261d? | start no earlier than 1999-01-01 | SMG1,N2 | 2088h | 2088h | GPRS2 | R99 |  |  |  |
| 2577 | 632.2.3 | GPRS Tunnelling Protocol enhancement | 261d? | 1999-01-01 A | 1999-12-31 A | 100% | 1999-01-01 | 1999-12-31 | 261d? | start no earlier than 1999-01-01 | N4,N2 | 2088h | 2088h | GTP_enhancement | R99 |  |  |  |
| 2578 | 632.3 | **Enhanced Data rates for GSM Evolution - Phase 1** | 261d? | 1999-01-01 A | 1999-12-31 A | 100% | 1999-01-01 | 1999-12-31 | 261d? |  | SMG2,SMG1,SMG3,SMG4,SMG7,SMG9,SMG10,N1,N3,T2 | 25056h | 25056h | EDGE - Phase 1 | R99 |  |  |  |
| 2579 | 632.3.1 | Enhanced Data rates for GSM Evolution | 261d? | 1999-01-01 A | 1999-12-31 A | 100% | 1999-01-01 | 1999-12-31 | 261d? | start no earlier than 1999-01-01 | SMG2,SMG1,SMG3,SMG4,SMG7,SMG9,SMG10,N1,N3,T2 | 2088h | 2088h | EDGE | R99 |  |  |  |
| 2580 | 632.3.2 | EDGE-Layer1 | 261d? | 1999-01-01 A | 1999-12-31 A | 100% | 1999-01-01 | 1999-12-31 | 261d? | start no earlier than 1999-01-01 | SMG2 | 2088h | 2088h | EDGE-Layer1 | R99 |  |  |  |
| 2581 | 632.3.3 | High Speed Circuit Switched Data | 261d? | 1999-01-01 A | 1999-12-31 A | 100% | 1999-01-01 | 1999-12-31 | 261d? | start no earlier than 1999-01-01 | SMG1,SMG2,SMG7 | 2088h | 2088h | HSCSD | R99 |  |  |  |
| 2582 | 632.3.4 | Enhanced Circuit Switched Data - Phase 1 | 261d? | 1999-01-01 A | 1999-12-31 A | 100% | 1999-01-01 | 1999-12-31 | 261d? | start no earlier than 1999-01-01 | S1,SMG | 2088h | 2088h | ECSD | R99 |  |  |  |
| 2583 | 632.3.5 | EDGE-Enhanced Circuit Switched Data | 261d? | 1999-01-01 A | 1999-12-31 A | 100% | 1999-01-01 | 1999-12-31 | 261d? | start no earlier than 1999-01-01 | SMG2 | 2088h | 2088h | EDGE-ECSD | R99 |  |  |  |
| 2584 | 632.3.6 | Enhanced GPRS - Phase 1 | 261d? | 1999-01-01 A | 1999-12-31 A | 100% | 1999-01-01 | 1999-12-31 | 261d? | start no earlier than 1999-01-01 | SMG,N1 | 2088h | 2088h | EGPRS | R99 |  |  |  |
| 2585 | 632.3.7 | EDGE-EGPRS | 261d? | 1999-01-01 A | 1999-12-31 A | 100% | 1999-01-01 | 1999-12-31 | 261d? | start no earlier than 1999-01-01 | SMG2 | 2088h | 2088h | EDGE-EGPRS | R99 |  |  |  |
| 2586 | 632.3.8 | Packet Flow Context (PFC) | 261d? | 1999-01-01 A | 1999-12-31 A | 100% | 1999-01-01 | 1999-12-31 | 261d? | start no earlier than 1999-01-01 | SMG2 | 2088h | 2088h | PFC | R99 |  |  |  |
| 2587 | 632.3.9 | Support for EGPRS in ANSI-136 networks and EDGE COMPACT | 261d? | 1999-01-01 A | 1999-12-31 A | 100% | 1999-01-01 | 1999-12-31 | 261d? | start no earlier than 1999-01-01 | SMG | 2088h | 2088h | EDGE-Compact | R99 |  |  |  |
| 2588 | 632.3.10 | EGPRS COMPACT | 261d? | 1999-01-01 A | 1999-12-31 A | 100% | 1999-01-01 | 1999-12-31 | 261d? | start no earlier than 1999-01-01 | SMG | 2088h | 2088h | EGPRS-Compact | R99 |  |  |  |
| 2589 | 632.3.11 | COMPACT | 261d? | 1999-01-01 A | 1999-12-31 A | 100% | 1999-01-01 | 1999-12-31 | 261d? | start no earlier than 1999-01-01 | SMG,N1 | 2088h | 2088h | COMPACT | R99 |  |  |  |
| 2590 | 632.4 | GSM_400 | 261d? | 1999-01-01 A | 1999-12-31 A | 100% | 1999-01-01 | 1999-12-31 | 261d? | start no earlier than 1999-01-01 | SMG2,SMG7,T2 | 2088h | 2088h | GSM_400 | R99 |  |  |  |
| 2591 | 632.5 | GSM_450 | 261d? | 1999-01-01 A | 1999-12-31 A | 100% | 1999-01-01 | 1999-12-31 | 261d? | start no earlier than 1999-01-01 | SMG2 | 2088h | 2088h | GSM_450 | R99 |  |  |  |
| 2592 | 632.6 | GSM_700 | 261d? | 1999-01-01 A | 1999-12-31 A | 100% | 1999-01-01 | 1999-12-31 | 261d? | start no earlier than 1999-01-01 | SMG2 | 2088h | 2088h | GSM_700 | R99 |  |  |  |
| 2593 | 632.7 | Deleted - GERAN | 261d? | 1999-01-01 A | 1999-12-31 A | 100% | 1999-01-01 | 1999-12-31 | 261d? | start no earlier than 1999-01-01 | SMG2,S2 | 2088h | 2088h | GERAN | R99 | SP-06 |  |  |
| 2594 | 633 | **GSM Features transposed to UMTS** | 261d? | 1999-01-01 A | 1999-12-31 A | 100% | 1999-01-01 | 1999-12-31 | 261d? |  | S1,S3,T2,N2,N4 | 16704h | 16704h |  | R99 |  |  |  |
| 2595 | 633.1 | Cell Broadcast Service | 261d? | 1999-01-01 A | 1999-12-31 A | 100% | 1999-01-01 | 1999-12-31 | 261d? | start no earlier than 1999-01-01 | T2 | 2088h | 2088h | CBS | R99 |  |  |  |
| 2596 | 633.2 | **GSM mobile number portability euro MNP / North American MNP** | 261d? | 1999-01-01 A | 1999-12-31 A | 100% | 1999-01-01 | 1999-12-31 | 261d? |  | S1,N2,N4 | 4176h | 4176h | MNP | R99 |  |  |  |
| 2597 | 633.2.1 | Mobile Number Portability | 261d? | 1999-01-01 A | 1999-12-31 A | 100% | 1999-01-01 | 1999-12-31 | 261d? | start no earlier than 1999-01-01 | N2,N4 | 2088h | 2088h | MNP | R99 |  |  |  |
| 2598 | 633.3 | Automatic establishment of roaming relations | 261d? | 1999-01-01 A | 1999-12-31 A | 100% | 1999-01-01 | 1999-12-31 | 261d? | start no earlier than 1999-01-01 | S1 | 2088h | 2088h |  | R99 |  | Telecom Italia | enrico.scarrone@telecomitalia.it |
| 2599 | 633.4 | Advanced addressing | 261d? | 1999-01-01 A | 1999-12-31 A | 100% | 1999-01-01 | 1999-12-31 | 261d? | start no earlier than 1999-01-01 | S1 | 2088h | 2088h |  | R99 |  |  |  |
| 2600 | 633.5 | UMTS numbering, addressing and identities | 261d? | 1999-01-01 A | 1999-12-31 A | 100% | 1999-01-01 | 1999-12-31 | 261d? | start no earlier than 1999-01-01 | S1 | 2088h | 2088h |  | R99 |  |  |  |
| 2601 | 633.6 | Lawful Interception | 261d? | 1999-01-01 A | 1999-12-31 A | 100% | 1999-01-01 | 1999-12-31 | 261d? | start no earlier than 1999-01-01 | S3 | 2088h | 2088h | LI | R99 |  |  |  |

Notes:
- 2574: GPRS was introduced in Release 97. Release 99 brings a number of essential corrections e.g. on Downlink Power Control, Timing Advance procedure, Cell reselection delay time, PBCCH scheduling, PTCCH mapping, etc. / Text3: 05.02, 05.05, 05.08, 05.10, 05.50, 11.21, 23.064, 24.008, 24.060 / Text8: Alain
- 2575: - / Text3: 02.60, 03.22, 03.64, 04.18, 04.60, 04.64, 04.65, 05.01, 05.02, 05.05, 05.08, 05.10, 08.08, 08.18, 11.10-1, 11.21, 22.041, 22.060, 23.003, 23.007, 23.060, 23.107, 23.122, 24.007, 24.008, 27.007, 27.060, 29.002, 29.016, 29.018, 29.060, 29.061 / Text8: Alain
- 2576: Introduction of EGPRS (S1) + Introduction of Reserved Service Labels in the APN (N2) / Text3: 02.60, 23.003
- 2577: - / Text3: 23.003, 23.008, 29.060 / Text8: Kimmo
- 2578: EDGE is independent of the frequency bands, so it can be deployed e.g. in 900 and 1900 MHz bands. The new physical layer based on 8-PSK modulation is introduced and EGPRS and ECSD facilitate the new modulation in single and multi slot constellation. / Text3: 10.59, 02.34, 02.60, 03.30, 05.10, 05.50, 11.26 / Text8: Maurice
- 2579: - / Text3: 02.34, 03.10, 03.20, 03.64, 04.03, 04.04, 04.06, 04.08, 04.18, 04.21, 04.22, 04.60, 04.64, 05.01, 05.02, 05.03, 05.04, 05.05, 05.08, 05.10, 05.50, 07.01, 07.02, 07.03, 08.08, 08.20, 08.58, 08.60, 09.07, 09.18, 11.10-1, 11.11, 11.21, 11.26, 23.034, 24.008, / Text8: Maurice
- 2580: - / Text3: 05.05, 05.10, 05.50
- 2581: No additional features for R99. / Text3: 02.34, 04.18, 11.10-1
- 2582: ECSD supports both transparent and non-transparent services, up to 64 kbit/s and 57.6 kbit/s respectively. See Tdoc SMG2 670/99 ECSD Concept Evaluation for more info / Text3: 05.02, 08.58, 22.034 / Text8: Alain
- 2583: - / Text3: 05.03
- 2584: - / Text3: 02.07, 03.64, 04.14, 04.18, 04.60, 05.05, 05.08, 24.008
- 2585: - / Text3: 05.03, 05.05, 05.08
- 2586: - / Text3: 04.18
- 2587: Support for EGPRS in ANSI-136 networks and EDGE Compact (for ANSI-136 networks only). COMPACT = Deployment of services in spectrum below 1 MHz / Text3: 03.22, 03.30, 03.64, 05.01, 05.02, 05.03, 05.05, 05.08, 05.10
- 2588: COMPACT = Deployment of services in spectrum below 1 MHz / Text3: 04.18, 05.02
- 2589: COMPACT = Deployment of services in spectrum below 1 MHz / Text3: 03.22, 04.18, 04.60, 05.08, 23.122, 24.008
- 2590: - / Text3: 02.17, 03.22, 03.30, 04.04, 04.18, 04.60, 05.01, 05.02, 05.05, 05.08, 05.10, 05.50, 08.18, 08.58, 11.21, 24.008, 27.007 / Text8: GSM in the 400 MHz bands allows to deploy GSM within frequency bands in the range 450 to 500 MHz, previously used for analogue cellular systems. See Tdoc SMG2 190/99 and 595/99 for further info.
- 2591: - / Text3: 03.22, 03.30, 05.01, 05.05, 05.08
- 2592: - / Text3: 05.05
- 2593: No CR or new TS/TR approved under this WI / Text3: G2: 04.18 CR#A248 , 04.60 CR#B090 / Text8: Maurice
- 2594: - / Text8: Alain
- 2595: Moved to CT1 at TSG-T closure. Applicability of the Cell Broadcast Service (as defined for GSM network) to 3G networks / Text3: 23.041
- 2596: R98 MNP: mobile subscriber ability to change PLMN operator within the same country whilst retaining its original MS ISDN number (MSISDN). IMSI is changed, only MSISDN is kept. R99 adds requirements for North American Service Provider Number Portability. / Text3: 22.066 / Text8: Alain
- 2597: - / Text3: 23.018, 23.066, 29.002 / Text8: Kimmo
- 2598: framework for commercial and technical interworking between UMTS Home Environments and Serving Networks who have no direct prior commercial agreements with each other. / Text3: 22.101, 22.971 / Text8: Alain
- 2599: - / Text3: 22.101, 22.75U, 22.975 / Text8: Alain
- 2600: Also new requirements for Single and Multiple Numbering scheme was added (CR#20 and 21). Deleted the term International Mobile User Identifier (IMUI) and changed IMSI (International Mobile Station Identifier=>International Mobile Subscriber Identity. / Text3: 22.101 / Text8: Alain
- 2601: Defines an interception system in UMTS that supports a number of regional interception regulations. Regional interception requirements shall be met in using specific (regional) mediation functions allowing only required information to be transported. / Text3: 33.106, 33.107 / Text8: Dionisio

| ID | WBS | Task | Duration | Start | Finish | Complete | Baseline start | Baseline finish | Baseline duration | Constraint | Resources | Work | Actual work | Text1 | Text6 | Text8 |
| --- | --- | --- | --- | --- | --- | --- | --- | --- | --- | --- | --- | --- | --- | --- | --- | --- |
| 2602 | 634 | **Charging** | 261d? | 1999-01-01 A | 1999-12-31 A | 100% | 1999-01-01 | 1999-12-31 | 261d? |  | S1,S5 | 6264h | 6264h | CH | R99 | Alain |
| 2603 | 634.1 | Charging | 261d? | 1999-01-01 A | 1999-12-31 A | 100% | 1999-01-01 | 1999-12-31 | 261d? | start no earlier than 1999-01-01 | S1 | 2088h | 2088h | Charging | R99 | Alain |
| 2604 | 634.2 | OAM Charging Management | 261d? | 1999-01-01 A | 1999-12-31 A | 100% | 1999-01-01 | 1999-12-31 | 261d? | start no earlier than 1999-01-01 | S5 | 2088h | 2088h | OAMCH, CH | R99 | Dionisio |
| 2605 | 635 | **Operations, Administration, Maintenance and Provisioning (OAM&P)** | 261d? | 1999-01-01 A | 1999-12-31 A | 100% | 1999-01-01 | 1999-12-31 | 261d? |  | S5 | 12528h | 12528h | OAM | R99 | Dionisio |
| 2606 | 635.1 | OAM Principles and High-level Requirements | 261d? | 1999-01-01 A | 1999-12-31 A | 100% | 1999-01-01 | 1999-12-31 | 261d? | start no earlier than 1999-01-01 | S5 | 2088h | 2088h | PR, Princs_&_Reqs_(PR) | R99 | Dionisio |
| 2607 | 635.2 | OAM Architecture | 261d? | 1999-01-01 A | 1999-12-31 A | 100% | 1999-01-01 | 1999-12-31 | 261d? | start no earlier than 1999-01-01 | S5 | 2088h | 2088h | OAMAR, AR, Telecom_Management_Arch_(AR) | R99 | Dionisio |
| 2608 | 635.3 | OAM Configuration Management | 261d? | 1999-01-01 A | 1999-12-31 A | 100% | 1999-01-01 | 1999-12-31 | 261d? | start no earlier than 1999-01-01 | S5 | 2088h | 2088h | OAMCM, CM | R99 | Dionisio |
| 2609 | 635.4 | OAM Fault Management | 261d? | 1999-01-01 A | 1999-12-31 A | 100% | 1999-01-01 | 1999-12-31 | 261d? | start no earlier than 1999-01-01 | S5 | 2088h | 2088h | OAMFM | R99 | Dionisio |
| 2610 | 635.5 | OAM Performance Management | 261d? | 1999-01-01 A | 1999-12-31 A | 100% | 1999-01-01 | 1999-12-31 | 261d? | start no earlier than 1999-01-01 | S5 | 2088h | 2088h | OAMPM, PM | R99 | Dionisio |
| 2611 | 636 | Vocabulary | 261d? | 1999-01-01 A | 1999-12-31 A | 100% | 1999-01-01 | 1999-12-31 | 261d? | start no earlier than 1999-01-01 | S1 | 2088h | 2088h | Vocabulary | R99 | Alain |
| 2612 | 637 | Emergency | 261d? | 1999-01-01 A | 1999-12-31 A | 100% | 1999-01-01 | 1999-12-31 | 261d? | start no earlier than 1999-01-01 | S1 | 2088h | 2088h | Emergency | R99 | Alain |
| 2613 | 638 | GSM General Bearer Services (GBS) and interworking scenarios support in UMTS | 261d? | 1999-01-01 A | 1999-12-31 A | 100% | 1999-01-01 | 1999-12-31 | 261d? | start no earlier than 1999-01-01 | S1 | 2088h | 2088h | GSM_to_UMTS_Evol | R99 | Alain |
| 2614 | 639 | GPRS_Mobile_IP_interworking | 261d? | 1999-01-01 A | 1999-12-31 A | 100% | 1999-01-01 | 1999-12-31 | 261d? | start no earlier than 1999-01-01 | N3 | 2088h | 2088h | GPRS_Mobile_IP_interworking | R99 |  |
| 2615 | 640 | GSM/UMTS interworking | 261d? | 1999-01-01 A | 1999-12-31 A | 100% | 1999-01-01 | 1999-12-31 | 261d? | start no earlier than 1999-01-01 | N1,N2,N4,R3,S1,SMG | 2088h | 2088h | 2G3Ginterworking | R99 | Frederic |
| 2616 | 641 | Handover | 261d? | 1999-01-01 A | 1999-12-31 A | 100% | 1999-01-01 | 1999-12-31 | 261d? | start no earlier than 1999-01-01 | S1,SMG2,N1,N2,N4 | 2088h | 2088h | Handover | R99 | Alain |
| 2617 | 642 | 2G3Ghandover | 261d? | 1999-01-01 A | 1999-12-31 A | 100% | 1999-01-01 | 1999-12-31 | 261d? | start no earlier than 1999-01-01 | SMG2 | 2088h | 2088h | 2G3Ghandover | R99 |  |
| 2618 | 643 | Service Provider Name Indication | 261d? | 1999-01-01 A | 1999-12-31 A | 100% | 1999-01-01 | 1999-12-31 | 261d? | start no earlier than 1999-01-01 | S1 | 2088h | 2088h | SPANME | R99 | Alain |
| 2619 | 644 | Data & Data_CleanUp | 261d? | 1999-01-01 A | 1999-12-31 A | 100% | 1999-01-01 | 1999-12-31 | 261d? | start no earlier than 1999-01-01 | SMG1 | 2088h | 2088h | Data, Data_CleanUp | R99 |  |
| 2620 | 645 | Unstructured Supplementary Service Data | 261d? | 1999-01-01 A | 1999-12-31 A | 100% | 1999-01-01 | 1999-12-31 | 261d? | start no earlier than 1999-01-01 | SMG1,N4 | 2088h | 2088h | USSD | R99 | Kimmo |
| 2621 | 646 | Man-Machine Interface (MMI) of the User Equipment (UE) | 261d? | 1999-01-01 A | 1999-12-31 A | 100% | 1999-01-01 | 1999-12-31 | 261d? | start no earlier than 1999-01-01 | S1 | 2088h | 2088h | MMI | R99 | Alain |
| 2622 | 647 | Network Identity and Timezone (NITZ) | 261d? | 1999-01-01 A | 1999-12-31 A | 100% | 1999-01-01 | 1999-12-31 | 261d? | start no earlier than 1999-01-01 | SMG1,SMG3 | 2088h | 2088h | NITZ | R99 | Alain |
| 2623 | 648 | Operator Determined Barring for Packet Oriented Services | 261d? | 1999-01-01 A | 1999-12-31 A | 100% | 1999-01-01 | 1999-12-31 | 261d? | start no earlier than 1999-01-01 | S1 | 2088h | 2088h | ODB_Enh. | R99 | Alain |
| 2624 | 649 | Packet Flow Management | 261d? | 1999-01-01 A | 1999-12-31 A | 100% | 1999-01-01 | 1999-12-31 | 261d? | start no earlier than 1999-01-01 | SMG2 | 2088h | 2088h | Packet_Flow_Management | R99 |  |
| 2625 | 650 | GPRS_Point-To-Multipoint Group call | 261d? | 1999-01-01 A | 1999-12-31 A | 100% | 1999-01-01 | 1999-12-31 | 261d? | start no earlier than 1999-01-01 | SMG1 | 2088h | 2088h | GPRS_PTMG | R99 |  |

Notes:
- 2602: -
- 2603: WID SP-99271 Charging and accounting / Text3: 22.115, 23.121
- 2604: WID SP-99581 SA5 Year 2000 Work plan / Text3: 32.005, 32.015
- 2605: WID SP-99581 SA5 Year 2000 Work plan
- 2606: WID SP-99581 SA5 Year 2000 Work plan / Text3: 32.101
- 2607: WID SP-99581 SA5 Year 2000 Work plan / Text3: 32.101, 32.102
- 2608: WID SP-99273 Configuration management / Text3: 32.106, 32.106-1, 32.106-2, 32.106-3, 32.106-4, 32.106-5, 32.106-6, 32.106-7, 32.106-8
- 2609: WID SP-99272 Fault management / Text3: 32.111, 32.111-1, 32.111-2, 32.111-3, 32.111-4
- 2610: WID SP-99274 Performance management / Text3: 12.04, 32.104
- 2611: - / Text3: 21.905
- 2612: - / Text3: 22.101
- 2613: UMTS shall support GSM General Bearer Services (GBS) and interworking scenarios as specified in 02.02 / Text3: 22.105
- 2614: - / Text3: 29.061
- 2615: - / Text3: 03.22, 04.18, 04.60, 05.02, 05.08, 05.10, 08.08, 08.18, 08.58, 09.08, 22.011, 23.003, 23.009, 23.014, 23.034, 23.122, 24.007, 24.008, 24.011, 24.080, 29.108
- 2616: - / Text3: 04.18, 08.08, 08.58, 22.129, 23.009, 29.002, 29.010
- 2617: - / Text3: 04.18, 04.60, 05.02, 05.08, 05.10, 08.08, 29.010
- 2618: Service Provider Name Indication included in R98 (02.07) was not carried into R99 (22.101), but is in the SIM/USIM specification for R99 / Text3: 22.101
- 2619: - / Text3: 02.01, 02.02, 02.04, 02.34
- 2620: No additional features for R99. / Text3: 02.04, 02.90, 23.090, 29.002
- 2621: Data services streamlining + Support for Anonymous Call Rejection / Text3: 22.030
- 2622: - / Text3: 02.42, 04.08
- 2623: Remove ODB for Packet Oriented Services from R99 / Text3: 22.041
- 2624: - / Text3: 08.18
- 2625: - / Text3: 02.60

| ID | WBS | Task | Duration | Start | Finish | Complete | Baseline start | Baseline finish | Baseline duration | Constraint | Resources | Work | Actual work | Text6 | Text8 |
| --- | --- | --- | --- | --- | --- | --- | --- | --- | --- | --- | --- | --- | --- | --- | --- |
| 2626 | 651 | **Call Forwarding** | 261d? | 1999-01-01 A | 1999-12-31 A | 100% | 1999-01-01 | 1999-12-31 | 261d? |  | SMG1,N2,N4 | 8352h | 8352h | R99 | Kimmo |
| 2627 | 651.1 | Call Forwarding enhancements | 261d? | 1999-01-01 A | 1999-12-31 A | 100% | 1999-01-01 | 1999-12-31 | 261d? | start no earlier than 1999-01-01 | N4,N2 | 2088h | 2088h | R99 | Kimmo |
| 2628 | 651.2 | Call_Forwarding | 261d? | 1999-01-01 A | 1999-12-31 A | 100% | 1999-01-01 | 1999-12-31 | 261d? | start no earlier than 1999-01-01 | SMG1,N2 | 2088h | 2088h | R99 | Kimmo |
| 2629 | 651.3 | Call_Forwarding_Enhancements | 261d? | 1999-01-01 A | 1999-12-31 A | 100% | 1999-01-01 | 1999-12-31 | 261d? | start no earlier than 1999-01-01 | N4 | 2088h | 2088h | R99 | Kimmo |
| 2630 | 652 | **Quality of Service** | 261d? | 1999-01-01 A | 1999-12-31 A | 100% | 1999-01-01 | 1999-12-31 | 261d? |  | S2,T2,N1,N2,N4 | 10440h | 10440h | R99 | Maurice |
| 2631 | 652.1 | End-to-end UMTS Quality of Service management | 261d? | 1999-01-01 A | 1999-12-31 A | 100% | 1999-01-01 | 1999-12-31 | 261d? | start no earlier than 1999-01-01 | S2,T2,N1,N2,N4 | 2088h | 2088h | R99 | Maurice |
| 2632 | 652.2 | End-to-end QoS for PS Domain including IMS | 261d? | 1999-01-01 A | 1999-12-31 A | 100% | 1999-01-01 | 1999-12-31 | 261d? | start no earlier than 1999-01-01 | S2 | 2088h | 2088h | R99 | Maurice |
| 2633 | 652.3 | GPRS-enhanced_QoS | 261d? | 1999-01-01 A | 1999-12-31 A | 100% | 1999-01-01 | 1999-12-31 | 261d? | start no earlier than 1999-01-01 | T2 | 2088h | 2088h | R99 |  |
| 2634 | 652.4 | QoS_enhancements | 261d? | 1999-01-01 A | 1999-12-31 A | 100% | 1999-01-01 | 1999-12-31 | 261d? | start no earlier than 1999-01-01 | N2,N1,N4 | 2088h | 2088h | R99 | Kimmo |
| 2635 | 653 | Support of Localised Service Area | 261d? | 1999-01-01 A | 1999-12-31 A | 100% | 1999-01-01 | 1999-12-31 | 261d? | start no earlier than 1999-01-01 | SMG2,SMG3,SMG7,N2 | 2088h | 2088h | R99 | Maurice |
| 2636 | 654 | Transcoder_location | 261d? | 1999-01-01 A | 1999-12-31 A | 100% | 1999-01-01 | 1999-12-31 | 261d? | start no earlier than 1999-01-01 | S2 | 2088h | 2088h | R99 | Maurice |
| 2637 | 655 | Antenna_test_methods | 261d? | 1999-01-01 A | 1999-12-31 A | 100% | 1999-01-01 | 1999-12-31 | 261d? | start no earlier than 1999-01-01 | SMG2 | 2088h | 2088h | R99 |  |
| 2638 | 656 | WBAMR / high quality speech in UMTS Phase 1 but not in R99 | 261d? | 1999-01-01 A | 1999-12-31 A | 100% | 1999-01-01 | 1999-12-31 | 261d? | start no earlier than 1999-01-01 | S1 | 2088h | 2088h | R99 | Alain |
| 2639 | 657 | **Codec** | 261d? | 1999-01-01 A | 1999-12-31 A | 100% | 1999-01-01 | 1999-12-31 | 261d? |  | S4 | 14616h | 14616h | R99 | Paolo |
| 2640 | 657.1 | Codec(s)_for_Multimedia_Telephony_Service | 261d? | 1999-01-01 A | 1999-12-31 A | 100% | 1999-01-01 | 1999-12-31 | 261d? | start no earlier than 1999-01-01 | S4 | 2088h | 2088h | R99 | Paolo |
| 2641 | 657.2 | QoS for Speech and Multimedia Codec | 261d? | 1999-01-01 A | 1999-12-31 A | 100% | 1999-01-01 | 1999-12-31 | 261d? | start no earlier than 1999-01-01 | S4 | 2088h | 2088h | R99 | Paolo |
| 2642 | 657.3 | Tandem Free Operation - Adaptive Multi-Rate codec types | 261d? | 1999-01-01 A | 1999-12-31 A | 100% | 1999-01-01 | 1999-12-31 | 261d? | start no earlier than 1999-01-01 | S4 | 2088h | 2088h | R99 | Paolo |
| 2643 | 657.4 | Noise Suppression for AMR | 261d? | 1999-01-01 A | 1999-12-31 A | 100% | 1999-01-01 | 1999-12-31 | 261d? | start no earlier than 1999-01-01 | S4 | 2088h | 2088h | R99 | Paolo |
| 2644 | 657.5 | Out-of-Band Transcoder | 261d? | 1999-01-01 A | 1999-12-31 A | 100% | 1999-01-01 | 1999-12-31 | 261d? | start no earlier than 1999-01-01 | N1 | 2088h | 2088h | R99 | Frederic |
| 2645 | 657.6 | Out-of-Band Transcoder Control | 261d? | 1999-01-01 A | 1999-12-31 A | 100% | 1999-01-01 | 1999-12-31 | 261d? | start no earlier than 1999-01-01 | N1 | 2088h | 2088h | R99 | Frederic |
| 2646 | 658 | Advanced Speech Call Items enhancements | 261d? | 1999-01-01 A | 1999-12-31 A | 100% | 1999-01-01 | 1999-12-31 | 261d? | start no earlier than 1999-01-01 | SMG1,SMG2,SMG3,SMG7,SMG9,N1,C1,N4,S1,T2 | 2088h | 2088h | R99 | Alain |
| 2647 | 659 | Call Control improvements | 261d? | 1999-01-01 A | 1999-12-31 A | 100% | 1999-01-01 | 1999-12-31 | 261d? | start no earlier than 1999-01-01 | N1 | 2088h | 2088h | R99 | Frederic |
| 2648 | 660 | Multimedia | 261d? | 1999-01-01 A | 1999-12-31 A | 100% | 1999-01-01 | 1999-12-31 | 261d? | start no earlier than 1999-01-01 | N1,N3 | 2088h | 2088h | R99 | Frederic |
| 2649 | 661 | Sub-System Number allocation for RANAP, RNSAP | 261d? | 1999-01-01 A | 1999-12-31 A | 100% | 1999-01-01 | 1999-12-31 | 261d? | start no earlier than 1999-01-01 | N2 | 2088h | 2088h | R99 | Frederic |
| 2650 | 662 | Intranet / ISP access with DHCP end-to-end | 261d? | 1999-01-01 A | 1999-12-31 A | 100% | 1999-01-01 | 1999-12-31 | 261d? | start no earlier than 1999-01-01 | N3 | 2088h | 2088h | R99 | Gwiho |
| 2651 | 663 | Point_to_Multipoint_Services | 261d? | 1999-01-01 A | 1999-12-31 A | 100% | 1999-01-01 | 1999-12-31 | 261d? | start no earlier than 1999-01-01 | N3 | 2088h | 2088h | R99 | Gwiho |
| 2652 | 664 | Facsimile | 261d? | 1999-01-01 A | 1999-12-31 A | 100% | 1999-01-01 | 1999-12-31 | 261d? | start no earlier than 1999-01-01 | S1 | 2088h | 2088h | R99 | Alain |
| 2653 | 665 | Realtime_NT_FAX_in_UMTS | 261d? | 1999-01-01 A | 1999-12-31 A | 100% | 1999-01-01 | 1999-12-31 | 261d? | start no earlier than 1999-01-01 | N3 | 2088h | 2088h | R99 | Gwiho |
| 2654 | 666 | Gateway Location Register (GLR) - Mobile Application Part (MAP) specification | 261d? | 1999-01-01 A | 1999-12-31 A | 100% | 1999-01-01 | 1999-12-31 | 261d? | start no earlier than 1999-01-01 | N4 | 2088h | 2088h | R99 | Kimmo |
| 2655 | 667 | Multiple Subscriber Profile phase 2 | 261d? | 1999-01-01 A | 1999-12-31 A | 100% | 1999-01-01 | 1999-12-31 | 261d? | start no earlier than 1999-01-01 | S1,N4 | 2088h | 2088h | R99 | Alain |
| 2656 | 668 | Prepaging | 261d? | 1999-01-01 A | 1999-12-31 A | 100% | 1999-01-01 | 1999-12-31 | 261d? | start no earlier than 1999-01-01 | N2,N4 | 2088h | 2088h | R99 | Kimmo |
| 2657 | 669 | Downlink Advanced Receiver Performance | 261d? | 1999-01-01 A | 1999-12-31 A | 100% | 1999-01-01 | 1999-12-31 | 261d? | start no earlier than 1999-01-01 | SMG | 2088h | 2088h | R99 |  |
| 2658 | 670 | Harmonized Standard | 261d? | 1999-01-01 A | 1999-12-31 A | 100% | 1999-01-01 | 1999-12-31 | 261d? | start no earlier than 1999-01-01 | SMG2 | 2088h | 2088h | R99 |  |
| 2659 | 671 | Streamlining of specifications | 261d? | 1999-01-01 A | 1999-12-31 A | 100% | 1999-01-01 | 1999-12-31 | 261d? | start no earlier than 1999-01-01 | N3 | 2088h | 2088h | R99 | Gwiho |
| 2660 | 672 | R99_Service_Clean_up | 261d? | 1999-01-01 A | 1999-12-31 A | 100% | 1999-01-01 | 1999-12-31 | 261d? | start no earlier than 1999-01-01 | N3 | 2088h | 2088h | R99 | Gwiho |

Notes:
- 2626: -
- 2627: No additional features for R99. / Text1: CF_enhancements / Text3: 23.078, 23.079, 23.082, 29.002, 29.078
- 2628: - / Text1: Call_Forwarding / Text3: 02.82, 29.002
- 2629: - / Text1: Call_Forwarding_Enhancements / Text3: 23.082
- 2630: WID SMG 98-0781 End To End UMTS QoS Management
- 2631: WID SMG 98-0781 End To End UMTS QoS Management / Text1: QoS / Text3: 23.107, 23.907, 24.008
- 2632: - / Text1: E2EQoS / Text3: 23.060, 23.170
- 2633: AT-commands for Enhanced QoS Support management / Text1: GPRS-enhanced_QoS / Text3: 27.007
- 2634: - / Text1: QoS_enhancements / Text3: 23.008, 23.016, 24.008, 29.002, 29.060
- 2635: Mechanism which can be used as a platform for providing special tariffs and/or special set of service features for certain subscribers within a regionally restricted area or areas. No additional features for R99. / Text1: SoLSA / Text3: 04.08, 04.18, 08.08, 11.10-1, 29.002
- 2636: UE location identification: background information and associated primitives 2. Transcoder location at the core network and source depending coding belonging to the non-access stratum. / Text1: Transcoder_location / Text3: 23.110
- 2637: - / Text1: Antenna_test_methods / Text3: 03.30
- 2638: Add requirement for high quality speech in UMTS Phase 1 but not in R99 / Text1: WBAMR / Text3: 22.105
- 2639: -
- 2640: - / Text1: Multimedia_Codec, CSM, WI2MMC, Codec(s)_for_CS_MM_Tel._Serv, Codec(s)_for_MM_Tel_Service, Codec_for_Multimedia_Telephony / Text3: 26.911, 26.104, 26.111
- 2641: - / Text1: QoS_for_Speech_&_MM_Codecs_/_AMR / Text3: 26.102, 26.912
- 2642: UMTS_AMR2 is default Codec Type in R99 dual_mode terminals / Text1: TFOAMR / Text3: 26.103
- 2643: Combination of the AMR speech codec and the Noise Suppression function. TS 06.77 and TR 06.78 only apply to GSM. They apply to UMTS from Rel-4 onwards, when they were converted to TS 26.077 and TR 26.078. / Text1: AMRNS / Text3: 06.77, 06.78
- 2644: Transcoder handling in the CN at inter-system handover and relocation + Introduction of UMTS AMR / Text1: OoBT / Text3: 23.009, 24.008
- 2645: 24.008 CR#0572 in NP-020220 was approved under this WI / Text1: OoBTC / Text3: 24.008 CR#0572 in NP-020220
- 2646: - / Text1: ASCI / Text3: 02.30, 02.68, 03.68, 03.69, 04.18, 08.08, 11.10-1, 11.11, 23.067, 23.094, 24.008, 24.067, 27.007, 29.002
- 2647: Minor improvements to 24.007 and 24.008 to increase the number of simultaneous calls/sessions from the present 7: the TI value is increased (NP-99441). / Text1: CC_Related_items / Text3: 24.007, 24.008
- 2648: - / Text1: Multimedia / Text3: 24.008, 27.001, 29.007
- 2649: Sub-System Number allocation for Radio Access Network Application Part, Radio Network Subsystem Application Part / Text1: SSN_allocation / Text3: 23.003
- 2650: Access to an Intranet/ISP with DHCP end to end / Text1: ISPaccess / Text3: 29.061
- 2651: Support for the IP-Multicast protocol / Text1: Point_to_Multipoint_Services / Text3: 29.061
- 2652: - / Text1: FAX / Text3: 22.003, 22.100
- 2653: Asynchronous Interface for real-time NT Fax + Introduction of Asynchronous interface for Real-time non-transparent FAX / Text1: Realtime_NT_FAX_in_UMTS / Text3: 27.001, 27.003
- 2654: - / Text1: GLR / Text3: 29.120
- 2655: - / Text1: MSP2 / Text3: 22.097, 23.072, 23.083, 23.084, 23.091, 23.093, 23.097
- 2656: - / Text1: Prepaging / Text3: 23.018, 23.082, 29.002
- 2657: Re-definition of channel quality measure used for AMR link adaptation for DARP MS / Text3: 05.09
- 2658: - / Text1: HS / Text3: 13.21
- 2659: - / Text1: Streamlining / Text3: 27.060, 29.061
- 2660: - / Text1: R99_Service_Clean_up / Text3: 03.10, 27.001, 27.002, 27.003, 27.060, 29.007, 29.061

| ID | WBS | Task | Type | Duration | Start | Finish | Complete | Baseline start | Baseline finish | Baseline duration | Constraint | Resources | Work | Actual work | Text1 | Text6 | Text8 | Text3 | Text12 | Text4 | Text5 |
| --- | --- | --- | --- | --- | --- | --- | --- | --- | --- | --- | --- | --- | --- | --- | --- | --- | --- | --- | --- | --- | --- |
| 2661 | 673 | **(Small) Technical Enhancements and Improvements for R99** |  | 261d? | 1999-01-01 A | 1999-12-31 A | 100% | 1999-01-01 | 1999-12-31 | 261d? |  | N3 | 6264h | 6264h | TEI | R99 | Gwiho |  |  |  |  |
| 2662 | 673.1 | TEI_[CS_Data] |  | 261d? | 1999-01-01 A | 1999-12-31 A | 100% | 1999-01-01 | 1999-12-31 | 261d? | start no earlier than 1999-01-01 | N3 | 2088h | 2088h | TEI_[CS_Data] | R99 | Gwiho |  |  |  |  |
| 2663 | 673.2 | TEI_[GPRS] |  | 261d? | 1999-01-01 A | 1999-12-31 A | 100% | 1999-01-01 | 1999-12-31 | 261d? | start no earlier than 1999-01-01 | N3 | 2088h | 2088h | TEI_[GPRS] | R99 | Gwiho |  |  |  |  |
| 2664 | 674 | **R99 UE Conformance Testing** |  | 261d? | 1999-01-01 A | 1999-12-31 A | 100% | 1999-01-01 | 1999-12-31 | 261d? |  | R5,T1 | 4176h | 4176h | TEI_Test | R99 | Ingbert | 34.108, 34.121, 34.122, 34.123-1, 34.123-2, 34.123-3 |  |  |  |
| 2665 | 674.1 | Deleted - RTEI |  | 261d? | 1999-01-01 A | 1999-12-31 A | 100% | 1999-01-01 | 1999-12-31 | 261d? | start no earlier than 1999-01-01 | T1 | 2088h | 2088h | RTEI | R99 | Ingbert | 34.123-1 CR#0650, 0651, 34.123-3 CR#0148, 0149, 0150 | TP-06 |  |  |
| 2666 | 674.2 | Common test environments for User Equipment (UE); Conformance testing | milestone | 0d? | 1999-01-01 A | 1999-01-01 A | 100% | 1999-01-01 | 1999-01-01 | 0d? | start no earlier than 1999-01-01 | R5,T1 |  |  | TEI_Test | R99 | Ingbert | 34.108 |  |  |  |
| 2667 | 674.3 | Terminal conformance specification, Radio transmission and reception (FDD) | milestone | 0d? | 1999-01-01 A | 1999-01-01 A | 100% | 1999-01-01 | 1999-01-01 | 0d? | start no earlier than 1999-01-01 | R5,T1 |  |  | TEI_Test | R99 | Ingbert | 34.121 |  |  |  |
| 2668 | 674.4 | Terminal conformance specification, Radio transmission and reception (TDD) | milestone | 0d? | 1999-01-01 A | 1999-01-01 A | 100% | 1999-01-01 | 1999-01-01 | 0d? | start no earlier than 1999-01-01 | R5,T1 |  |  | TEI_Test | R99 | Ingbert | 34.122 |  |  |  |
| 2669 | 674.5 | UE conformance specification; Part 1: Protocol conformance specification | milestone | 0d? | 1999-01-01 A | 1999-01-01 A | 100% | 1999-01-01 | 1999-01-01 | 0d? | start no earlier than 1999-01-01 | R5,T1 |  |  | TEI_Test | R99 | Ingbert | 34.123-1 |  |  |  |
| 2670 | 674.6 | UE conformance specification; Part 2: Implementation Conformance Statement (ICS) specification | milestone | 0d? | 1999-01-01 A | 1999-01-01 A | 100% | 1999-01-01 | 1999-01-01 | 0d? | start no earlier than 1999-01-01 | R5,T1 |  |  | TEI_Test | R99 | Ingbert | 34.123-2 |  |  |  |
| 2671 | 674.7 | UE conformance specification; Part 3: Abstract test suites (ATSs) | milestone | 0d? | 1999-01-01 A | 1999-01-01 A | 100% | 1999-01-01 | 1999-01-01 | 0d? | start no earlier than 1999-01-01 | R5,T1 |  |  | TEI_Test | R99 | Ingbert | 34.123-3 |  |  |  |
| 2672 | 675 | Deleted - Dual Tone Multi-Frequency signalling : Support in the whole 3GPP system |  | 261d? | 1999-01-01 A | 1999-12-31 A | 100% | 1999-01-01 | 1999-12-31 | 261d? | start no earlier than 1999-01-01 | N1 | 2088h | 2088h | DTMF | R99 | Frederic | 23.014 CR#0004 | NP-06 |  |  |
| 2673 | 676 | Deleted - Intersystem_Change |  | 261d? | 1999-01-01 A | 1999-12-31 A | 100% | 1999-01-01 | 1999-12-31 | 261d? | start no earlier than 1999-01-01 | SMG | 2088h | 2088h | Intersystem_Change | R99 |  | 04.18 CR#A243 | SMG |  |  |
| 2674 | 677 | Deleted - Long_Forwardedto_Numbers |  | 261d? | 1999-01-01 A | 1999-12-31 A | 100% | 1999-01-01 | 1999-12-31 | 261d? | start no earlier than 1999-01-01 | N2 | 2088h | 2088h | Long_Forwardedto_Numbers | R99 | Kimmo | 29.002 | NP-06 |  |  |
| 2675 | 678 | Deleted - RANimp-FSEarlyUE |  | 261d? | 1999-01-01 A | 1999-12-31 A | 100% | 1999-01-01 | 1999-12-31 | 261d? | start no earlier than 1999-01-01 | R3 | 2088h | 2088h | RANimp-FSEarlyUE | R99 | Juha | 25.413 CR#0520, 0538, 0565, 0563, 0541, 0540, 0539, 0547 | RP-06 |  |  |
| 2676 | 679 | Release 1999 Studies |  | 261d? | 1999-01-01 A | 1999-12-31 A | 100% | 1999-01-01 | 1999-12-31 | 261d? |  | S1,T2 | 2088h | 2088h |  | R99 | Alain |  |  |  |  |
| 2677 | 680 | Advanced Addressing/Numbering |  | 261d? | 1999-01-01 A | 1999-12-31 A | 100% | 1999-01-01 | 1999-12-31 | 261d? | start no earlier than 1999-01-01 | S1 | 2088h | 2088h | Numbering | R99 | Alain | 22.975 |  | Vodafone | mona.mustapha@vodafone.com |
| 2678 | 681 | Combined GSM and Mobile IP mobility handling in UMTS IP CN |  | 261d? | 1999-01-01 A | 1999-12-31 A | 100% | 1999-01-01 | 1999-12-31 | 261d? | start no earlier than 1999-01-01 | S2 | 2088h | 2088h |  | R99 | Maurice | 23.923 |  |  |  |
| 2679 | 682 | UE Capabilities Requirements |  | 261d? | 1999-01-01 A | 1999-12-31 A | 100% | 1999-01-01 | 1999-12-31 | 261d? | start no earlier than 1999-01-01 | T2 | 2088h | 2088h | UCR | R99 |  | 21.904 |  |  |  |
| 2680 | 683 | Electrical safety requirements and regulations |  | 261d? | 1999-01-01 A | 1999-12-31 A | 100% | 1999-01-01 | 1999-12-31 | 261d? | start no earlier than 1999-01-01 | T2 | 2088h | 2088h |  | R99 |  | 34.907 |  |  |  |
| 2681 | 684 | Specific Absorbtion Rate (SAR) requirements and regulations in different regions |  | 261d? | 1999-01-01 A | 1999-12-31 A | 100% | 1999-01-01 | 1999-12-31 | 261d? | start no earlier than 1999-01-01 | T2 | 2088h | 2088h |  | R99 |  | 34.925 |  |  |  |
| 2682 | 685 | Multi-mode UE issues |  | 261d? | 1999-01-01 A | 1999-12-31 A | 100% | 1999-01-01 | 1999-12-31 | 261d? | start no earlier than 1999-01-01 | T2 | 2088h | 2088h |  | R99 |  | 21.810, 21.910 |  |  |  |
| 2683 | 686 | Provision of fax service in GSM and UMTS |  | 261d? | 1999-01-01 A | 1999-12-31 A | 100% | 1999-01-01 | 1999-12-31 | 261d? | start no earlier than 1999-01-01 | T2 | 2088h | 2088h |  | R99 |  | 22.945 |  | Ericsson | peter.bleckert@ericsson.com |
| 2684 | 687 | Separating Radio Resources and Mobility Management specific parts of the MS Classmark |  | 650d | 2003-09-19 A | 2006-03-16 A | 100% | 2003-09-19 | 2006-03-16 | 650d |  | T2 | 5200h | 5200h |  | R99 |  | 23.814 |  |  |  |

Notes:
- 2661: -
- 2662: -
- 2663: -
- 2664: Specifies Conformance Tests for a 3G UE to be recognised as 3GPP-standard compliant. A 3GPP-external body, GCF (Global Certification Forum), delivers certificates to prove that a UE has correctly passed tests and is then conform to the 3GPP standard.
- 2665: No CR or new TS/TR approved under this WI
- 2666: -
- 2667: measurement procedures for the conformance test of the UE that contain transmitting characteristics, receiving characteristics and performance requirements in addition to requirements for support of RRM (Radio Resource Management) in FDD mode.
- 2668: measurement procedures for the conformance test of the UE that contain transmitting characteristics, receiving characteristics and performance requirements in addition to requirements for support of RRM (Radio Resource Management) in TDD mode.
- 2669: TS 34.123, composed of three parts, actually specifies the protocol conformance testing for the 3G UE. Part 1 describes the overall test structure.
- 2670: Part 2 contains the applicability of each test case defined as the Implementation Conformance Statement (ICS) proforma, in compliance with the relevant requirements, and in accordance with the relevant guidance given in ISO/IEC 9646-7 and ETS 300 406.
- 2671: Part 3 specifies the protocol conformance testing in TTCN for the 3G UE at the Uu interface. It defines the TTCN test specification and design considerations in Abstract Test Suites based on the test cases specified in prose in part 1.
- 2672: No CR or new TS/TR approved under this WI
- 2673: No CR or new TS/TR approved under this WI
- 2674: -
- 2675: No CR or new TS/TR approved under this WI
- 2676: -
- 2677: Study on requirements for numbering and addressing for UMTS
- 2678: -
- 2679: Moved to CT1 at TSG-T closure
- 2680: Moved to RAN4 at TSG-T closure. TR summarizes differences between international and national standards relevant to IEC60950 and refers to regulations for conformity assessment due to different regulatory environments in different countries / regions.
- 2681: Moved to RAN4 at TSG-T closure.
- 2682: Moved to CT1 at TSG-T closure. Consequences on roaming capabilities and service availability (e.g. handover) of multi-mode UEs while roaming in various regions with various network configurations. Case studies for each of the possible scenarios in specs
- 2683: CP#27: Moved to C1 on closure of T2; see TP-050062. CP#28: C1->C3
- 2684: CP#27: change of WG as a result of closure of CN and T.
